# Outline ELEXON Plan_kc

Schedule from MS Project, 2022-10-31 to 2027-12-23, status date 2024-10-21, A marks actual dates.

## Calendars

- Standard: Mon-Fri 08:00-12:00, 13:00-17:00; Sat-Sun off.

## Resources

| Resource |
| --- |
| PMO |
| SI |
| PPC |
| Lead Workstream |
| CPT |
| PP |
| SI Design |
| SI Design |
| SI Design |
| Design |
| SI DevOps |
| SI Test |
| PSG |
| DAG |
| TMAG |
| CCAG |
| Code drafters (SRO Design Team |
| Code Bodies) |
| CCAG PM |
| Programme Participants |
| Code drafters |
| CDWG |
| SRO Design Team |
| Code Bodies |
| Ofgem |
| Elexon resources TBC |
| LDP Programme Manager |
| SRO Client Programme Director |
| IPA |
| LDP |
| SRO |
| )) |
| ? |
| TBC |
| OOC |
| MHHSP |
| Adrian Page |
| Amy Clayton |
| Anand Kaveripatna |
| Berlinda Kugara |
| Cesar Lopes |
| Charlie Blanks |
| Chetan Ubale |
| Daniel Callender |
| Daniel Gee |
| David Hollinshead |
| Dean Bailey |
| Dominic Mooney |
| Elayaraja Jeyaraman |
| Georgi Rabotov |
| Giles Clayden |
| Helen Richardson |
| Ishti Bhatti |
| Jafer Shah |
| Jason Brogden |
| John Edmonds Bell |
| John Wiggins |
| Karthikeyan Ganesan |
| Kasimali Hajiyani |
| Kate Goodman |
| Keegan Moodley |
| Keith Clark |
| Keith Lawlor |
| kevin Davis |
| Kishore Konduru |
| Kyle Abraham |
| Mahjabeen Newaz |
| Martin Freeman |
| Matt Hall |
| Matthew Breen |
| Michael Inije |
| Michael Walton |
| Ming Li |
| Nathalia Revlien |
| Nick Sewell |
| Nigel Hunt |
| Oskar Cahill |
| Paul Pettitt |
| Rakhee Shah |
| Rebecca Farooq |
| Renu Rathor |
| Robert Short |
| Robert Topley |
| Saadia Sajjad |
| Sean Tuffy |
| Shaid Hussain |
| Sharmeen Shaikh |
| Simon Berry |
| Steve Bradford |
| Steve Weston |
| Taaran Suri |
| Waseem Mohammed |
| Zak Hussain |
| berli |
| SI Migration |
| v |
| Andrew Margan |
| Lee Cox |
| DIP SP |
| DIPS SP |
| DIPSP |
| Ian Smith |
| N/A |
| SIT Component Integration Testing 2 Preparation Complete (incl. approval of SI SIT Component Integration Test Readiness Report) |
| Nich |
| Nicola Farley |
| Warren Fulton |
| Richard Puddephatt |
| Matthew Bray |
| Programme |
| LDSOs |
| Ben Wickins |
| paul |
| LDSO |
| Simon chidwick |
| Stuart Scott |
| MHHS Programme |
| Claire Silk |
| Laura Kennedy |
| Rowan B |
| FD |
| MB |
| AM |
| Roger Robar |
| Laura Kennedy. |

## Schedule

| ID | WBS | Task | Type | Duration | Start | Finish | Complete | Remaining | Baseline start | Baseline finish | Baseline duration | Baseline 1 start | Baseline 1 finish | Total slack | Constraint | Baseline cost | Responsible | Involved | Update Version | MHHS Resource Name | Sched Status | RAG | Text9 | Task Status | Future RAG |
| --- | --- | --- | --- | --- | --- | --- | --- | --- | --- | --- | --- | --- | --- | --- | --- | --- | --- | --- | --- | --- | --- | --- | --- | --- | --- |
| 1 | 1 | **PROGRAMME PLAN.** |  | 1344d? | 2022-10-31 A | 2027-12-23 | 56% | 586.52d? | 2022-10-31 | 2027-12-23 | 1195d |  |  |  |  | -0 | N/A | N/A | 5.0 | N/A |  |  |  |  |  |
| 2 | 1.1 | MHHS Programme Start | milestone | 0d | 2022-10-31 A | 2022-10-31 A | 100% |  | 2022-10-31 | 2022-10-31 | 0d |  |  |  |  |  | N/A | N/A | 5.7 | N/A | Complete | COMPLETE |  |  |  |
| 3 | 1.2 | **PROGRAMME MANAGEMENT** |  | 1089d | 2022-10-31 A | 2026-12-31 | 44% | 609.27d | 2022-10-31 | 2026-12-31 | 1089d | 2022-10-31 | 2026-12-31 | 255d |  |  | N/A | N/A | 5.0 | N/A |  |  |  |  |  |
| 4 | 1.2.1 | **Programme Management** |  | 1089d | 2022-10-31 A | 2026-12-31 | 43% | 616d | 2022-10-31 | 2026-12-31 | 1089d | 2022-10-31 | 2026-12-31 | 255d |  |  | N/A | N/A | 5.0 | N/A |  |  | Programme Management | M10 |  |
| 5 | 1.2.1.1 | Sprint-based prioritisation planning and execution |  | 1089d | 2022-10-31 A | 2026-12-31 | 43% | 616d | 2022-10-31 | 2026-12-31 | 1089d | 2022-10-31 | 2026-12-31 | 255d | finish no earlier than 2026-12-31 |  | PMO | CPT | 5.0 | N/A | Green | GREEN | Programme Management |  |  |
| 6 | 1.2.1.2 | Programme governance secretariat |  | 1089d | 2022-10-31 A | 2026-12-31 | 43% | 616d | 2022-10-31 | 2026-12-31 | 1089d | 2022-10-31 | 2026-12-31 | 255d |  |  | PMO | CPT | 5.0 | N/A | Green | GREEN | Programme Management |  |  |
| 7 | 1.2.1.3 | RAID management and reporting |  | 1089d | 2022-10-31 A | 2026-12-31 | 43% | 616d | 2022-10-31 | 2026-12-31 | 1089d | 2022-10-31 | 2026-12-31 | 255d |  |  | PMO | CPT | 5.0 | N/A | Green | GREEN | Programme Management |  |  |
| 8 | 1.2.1.4 | Tracking against Programme outcomes and KPIs |  | 1089d | 2022-10-31 A | 2026-12-31 | 43% | 616d | 2022-10-31 | 2026-12-31 | 1089d | 2022-10-31 | 2026-12-31 | 255d |  |  | PMO | CPT | 5.0 | N/A | Green | GREEN | Programme Management |  |  |
| 9 | 1.2.1.5 | Change control and reporting |  | 1089d | 2022-10-31 A | 2026-12-31 | 43% | 616d | 2022-10-31 | 2026-12-31 | 1089d | 2022-10-31 | 2026-12-31 | 255d |  |  | PMO | CPT | 5.0 | N/A | Green | GREEN | Programme Management |  |  |
| 10 | 1.2.1.6 | Ongoing identification of lessons learned relating to the PMO and implementation of improvements |  | 1089d | 2022-10-31 A | 2026-12-31 | 43% | 616d | 2022-10-31 | 2026-12-31 | 1089d | 2022-10-31 | 2026-12-31 | 255d |  |  | PMO | CPT | 5.0 | N/A | Green | GREEN | Programme Management |  |  |
| 11 | 1.2.2 | **Programme Internal Assurance Reviews** |  | 1089d | 2022-10-31 A | 2026-12-31 | 43% | 616d | 2022-10-31 | 2026-12-31 | 1089d | 2022-10-31 | 2026-12-31 | 255d |  |  | N/A | N/A | 5.0 | N/A |  |  | Programme Management | M9 | D18A - Quarterly Assurance Report |
| 12 | 1.2.2.1 | Programme Internal Assurance Reviews |  | 1089d | 2022-10-31 A | 2026-12-31 | 43% | 616d | 2022-10-31 | 2026-12-31 | 1089d | 2022-10-31 | 2026-12-31 | 255d |  |  | CPT | PMO | 5.0 | N/A | Green | GREEN | Programme Management |  | D18A - Quarterly Assurance Report |
| 13 | 1.2.3 | **Engagement with PPs** |  | 1089d | 2022-10-31 A | 2026-12-31 | 43% | 615.89d | 2022-10-31 | 2026-12-31 | 1089d | 2022-10-31 | 2026-12-31 | 255d |  |  | N/A | N/A | 5.0 | N/A |  |  | Programme Management | M5,M6 |  |
| 14 | 1.2.3.1 | Ongoing PP liaison activities |  | 1089d | 2022-10-31 A | 2026-12-31 | 43% | 616d | 2022-10-31 | 2026-12-31 | 1089d | 2022-10-31 | 2026-12-31 | 255d |  |  | PPC | CPT | 5.0 | N/A | Green | GREEN | Programme Management |  |  |
| 15 | 1.2.3.2 | Milestone and Control Point objective setting |  | 1089d | 2022-10-31 A | 2026-12-31 | 43% | 616d | 2022-10-31 | 2026-12-31 | 1089d | 2022-10-31 | 2026-12-31 | 255d |  |  | PPC | CPT | 5.0 | N/A | Green | GREEN | Programme Management |  |  |
| 16 | 1.2.3.3 | Reporting |  | 1089d | 2022-10-31 A | 2026-12-31 | 43% | 616d | 2022-10-31 | 2026-12-31 | 1089d | 2022-10-31 | 2026-12-31 | 255d |  |  | PPC |  | 5.0 | N/A | Green | GREEN | Programme Management |  |  |
| 17 | 1.2.3.4 | **PP Engagement Events** |  | 1089d | 2022-10-31 A | 2026-12-31 | 43% | 616d | 2022-10-31 | 2026-12-31 | 1089d | 2022-10-31 | 2026-12-31 | 255d |  |  | N/A | N/A | 5.0 | N/A |  |  | Programme Management |  |  |
| 18 | 1.2.3.4.1 | Bilateral meetings |  | 1089d | 2022-10-31 A | 2026-12-31 | 43% | 616d | 2022-10-31 | 2026-12-31 | 1089d | 2022-10-31 | 2026-12-31 | 255d |  |  | PPC | CPT | 5.0 | N/A | Green | GREEN | Programme Management |  |  |
| 19 | 1.2.3.4.2 | Monthly webinars |  | 1089d | 2022-10-31 A | 2026-12-31 | 43% | 616d | 2022-10-31 | 2026-12-31 | 1089d | 2022-10-31 | 2026-12-31 | 255d |  |  | PPC | CPT | 5.0 | N/A | Green | GREEN | Programme Management |  |  |
| 20 | 1.2.3.4.3 | Open days |  | 1089d | 2022-10-31 A | 2026-12-31 | 43% | 616d | 2022-10-31 | 2026-12-31 | 1089d | 2022-10-31 | 2026-12-31 | 255d |  |  | PPC | CPT | 5.0 | N/A | Green | GREEN | Programme Management |  |  |
| 21 | 1.2.3.5 | **PP Communications** |  | 1088d | 2022-10-31 A | 2026-12-30 | 43% | 615d | 2022-10-31 | 2026-12-30 | 1088d | 2022-10-31 | 2026-12-30 | 256d |  |  | N/A | N/A | 5.0 | N/A |  |  | Programme Management |  |  |
| 22 | 1.2.3.5.1 | The Clock updates (weekly) |  | 1088d | 2022-10-31 A | 2026-12-30 | 43% | 615d | 2022-10-31 | 2026-12-30 | 1088d | 2022-10-31 | 2026-12-30 | 256d |  |  | PPC |  | 5.0 | N/A | Green | GREEN | Programme Management |  |  |
| 23 | 1.2.3.5.2 | Maintain and update content on public-facing Portal (and ongoing feedback reviews to identify and implement Portal improvements) |  | 1088d | 2022-10-31 A | 2026-12-30 | 43% | 615d | 2022-10-31 | 2026-12-30 | 1088d | 2022-10-31 | 2026-12-30 | 256d |  |  | PPC |  | 5.0 | N/A | Green | GREEN | Programme Management |  |  |
| 24 | 1.2.4 | **Code Change Support / Other Programme Alignment** |  | 1089d | 2022-10-31 A | 2026-12-31 | 43% | 616d | 2022-10-31 | 2026-12-31 | 1089d | 2022-10-31 | 2026-12-31 | 255d |  |  | N/A | N/A | 5.0 | N/A |  |  | Programme Management | M6 | D17 - Code Change Report & Recommendations |
| 25 | 1.2.4.1 | Support DCC/BEIS on SEC change |  | 1089d | 2022-10-31 A | 2026-12-31 | 43% | 616d | 2022-10-31 | 2026-12-31 | 1089d | 2022-10-31 | 2026-12-31 | 255d |  |  | CPT |  | 5.0 | N/A | Green | GREEN | Programme Management |  |  |
| 26 | 1.2.4.2 | Support on Smart Meters Act changes |  | 1089d | 2022-10-31 A | 2026-12-31 | 43% | 616d | 2022-10-31 | 2026-12-31 | 1089d | 2022-10-31 | 2026-12-31 | 255d |  |  | CPT |  | 5.0 | N/A | Green | GREEN | Programme Management |  |  |
| 27 | 1.2.4.3 | Support DCC/RECCo on CSS change |  | 1089d | 2022-10-31 A | 2026-12-31 | 43% | 616d | 2022-10-31 | 2026-12-31 | 1089d | 2022-10-31 | 2026-12-31 | 255d |  |  | CPT |  | 5.0 | N/A | Green | GREEN | Programme Management |  |  |
| 28 | 1.2.4.4 | Support Elexon on BSC change |  | 1089d | 2022-10-31 A | 2026-12-31 | 43% | 616d | 2022-10-31 | 2026-12-31 | 1089d | 2022-10-31 | 2026-12-31 | 255d |  |  | CPT |  | 5.0 | N/A | Green | GREEN | Programme Management |  |  |
| 29 | 1.2.4.5 | Support code change inside & outside CCIAG |  | 1089d | 2022-10-31 A | 2026-12-31 | 43% | 616d | 2022-10-31 | 2026-12-31 | 1089d | 2022-10-31 | 2026-12-31 | 255d |  |  | CPT |  | 5.0 | N/A | Green | GREEN | Programme Management |  |  |
| 30 | 1.2.4.6 | Support code change inside & outside CCAG |  | 1089d | 2022-10-31 A | 2026-12-31 | 43% | 616d | 2022-10-31 | 2026-12-31 | 1089d | 2022-10-31 | 2026-12-31 | 255d |  |  | CPT |  | 5.0 | N/A | Green | GREEN | Programme Management |  |  |

| ID | WBS | Task | Type | Duration | Start | Finish | Predecessors | Complete | Remaining | Baseline start | Baseline finish | Baseline duration | Baseline 1 start | Baseline 1 finish | Total slack | Constraint | Baseline cost | Responsible | Involved | Text9 | Task Status | Update Version | MHHS Resource Name | Sched Status | RAG | Future RAG | MHHS Programme Phase | Text29 | Artefact ID | Milestone ID | Tier |
| --- | --- | --- | --- | --- | --- | --- | --- | --- | --- | --- | --- | --- | --- | --- | --- | --- | --- | --- | --- | --- | --- | --- | --- | --- | --- | --- | --- | --- | --- | --- | --- |
| 31 | 1.2.5 | **Programme Replan Baseline** |  | 163d | 2022-10-31 A | 2023-06-14 A |  | 100% |  | 2022-10-31 | 2023-06-14 | 163d | 2022-10-31 | 2023-06-14 |  |  |  | N/A | N/A | Programme Management | M5+ | 5.0 | N/A |  |  |  |  |  |  |  |  |
| 32 | 1.2.5.1 | Round 3 consultation preparation |  | 32d | 2022-10-31 A | 2022-12-13 A |  | 100% |  | 2022-10-31 | 2022-12-13 | 32d | 2022-10-31 | 2022-12-13 |  |  |  | PMO | CPT | Programme Management |  | 5.0 | N/A | Complete | COMPLETE |  |  |  |  |  |  |
| 33 | 1.2.5.2 | PSG decision to launch Round 3 consultation | milestone | 0d | 2022-12-07 A | 2022-12-07 A | 32FS-5d | 100% |  | 2022-12-07 | 2022-12-07 | 0d | 2022-12-07 | 2022-12-07 |  |  |  | PMO | PPC | Programme Management |  | 5.0 | N/A | Complete | COMPLETE |  |  |  |  |  |  |
| 34 | 1.2.5.3 | Round 3 consultation (incl. walkthroughs and Q&A) |  | 35d | 2022-12-14 A | 2023-01-31 A | 33FS+5d | 100% |  | 2022-12-14 | 2023-01-31 | 35d | 2022-12-14 | 2023-01-31 |  |  |  | PP | PMO, PPC,IPA | Programme Management |  | 5.0 | N/A | Complete | COMPLETE |  |  |  |  |  |  |
| 35 | 1.2.5.4 | Review and uplift of foundational testing documents to align with replan approach |  | 92d | 2022-12-14 A | 2023-04-20 A | 34SS | 100% |  | 2022-12-14 | 2023-04-20 | 92d | 2022-12-14 | 2023-04-20 |  |  |  | SI Test | CPT | Programme Management |  | 5.0 | N/A | Complete | COMPLETE |  |  |  |  |  |  |
| 36 | 1.2.5.5 | Round 3 consultation responses analysis (incl. identification of SIT volunteers) |  | 10d | 2023-02-01 A | 2023-02-14 A | 34 | 100% |  | 2023-02-01 | 2023-02-14 | 10d | 2023-02-01 | 2023-02-14 |  |  |  | PMO | CPT | Programme Management |  | 5.0 | N/A | Complete | COMPLETE |  |  |  |  |  |  |
| 37 | 1.2.5.6 | Replan re-drafting and supporting artefact updates (incl. engagement with Ofgem) |  | 26d | 2023-02-15 A | 2023-03-22 A | 36 | 100% |  | 2023-02-15 | 2023-03-22 | 26d | 2023-02-15 | 2023-03-22 |  |  |  | PMO | CPT,IPA,Ofgem | Programme Management |  | 5.0 | N/A | Complete | COMPLETE |  |  |  |  |  |  |
| 38 | 1.2.5.7 | Draft Replan Change Request |  | 31d | 2023-02-15 A | 2023-03-29 A | 36 | 100% |  | 2023-02-15 | 2023-03-29 | 31d | 2023-02-15 | 2023-03-29 |  |  |  | PMO | CPT | Programme Management |  | 5.0 | N/A | Complete | COMPLETE |  |  |  |  |  |  |
| 39 | 1.2.5.8 | PSG decision to issue CR for industry impact assessment | milestone | 0d | 2023-04-05 A | 2023-04-05 A | 38FS+5d | 100% |  | 2023-04-05 | 2023-04-05 | 0d | 2023-04-05 | 2023-04-05 |  |  |  | PMO | CPT | Programme Management |  | 5.0 | N/A | Complete | COMPLETE |  |  |  |  |  |  |
| 40 | 1.2.5.9 | Industry impact assessment |  | 10d | 2023-04-06 A | 2023-04-19 A | 39 | 100% |  | 2023-04-06 | 2023-04-19 | 10d | 2023-04-06 | 2023-04-19 |  |  |  | PP | PMO,PPC | Programme Management |  | 5.0 | N/A | Complete | COMPLETE |  |  |  |  |  |  |
| 41 | 1.2.5.10 | Replan playbacks (to assist PPs in impact assessment) |  | 5d | 2023-04-11 A | 2023-04-17 A | 40SS+3d | 100% |  | 2023-04-11 | 2023-04-17 | 5d | 2023-04-11 | 2023-04-17 |  |  |  | CPT | PPC,PP | Programme Management |  | 5.0 | N/A | Complete | COMPLETE |  |  |  |  |  |  |
| 42 | 1.2.5.11 | Industry impact assessment responses analysis |  | 5d | 2023-04-20 A | 2023-04-26 A | 40 | 100% |  | 2023-04-20 | 2023-04-26 | 5d | 2023-04-20 | 2023-04-26 |  |  |  | PMO | CPT | Programme Management |  | 5.0 | N/A | Complete | COMPLETE |  |  |  |  |  |  |
| 43 | 1.2.5.12 | Extraordinary PSG decision to agree baseline recommendation | milestone | 0d | 2023-05-03 A | 2023-05-03 A | 42FS+5d | 100% |  | 2023-05-03 | 2023-05-03 | 0d | 2023-05-03 | 2023-05-03 |  |  |  | CPT | PMO,PP | Programme Management |  | 5.0 | N/A | Complete | COMPLETE |  |  |  |  |  |  |
| 44 | 1.2.5.13 | Programme Replan playbacks and drop-in sessions |  | 5d | 2023-06-08 A | 2023-06-14 A |  | 100% |  | 2023-06-08 | 2023-06-14 | 5d | 2023-06-08 | 2023-06-14 |  |  |  | PMO | PPC, PP | Programme Management |  | 5.0 | N/A | Complete | COMPLETE |  |  |  |  |  |  |
| 45 | 1.3 | **DESIGN, BUILD & TEST (PIT)** |  | 1221d? | 2022-10-31 A | 2027-07-05 |  | 76% | 294.14d? | 2022-10-31 | 2027-07-05 | 1101d | 2022-10-31 | 2027-01-18 | 123d |  | -0 | N/A | N/A | DBT |  |  | N/A |  |  | 1 May 2022 - 31 Jul 2023 | Design, Build & Test (PIT) | DAG |  |  |  |
| 46 | 1.3.1 | **Design Baseline & Enduring PP Support** |  | 1101d | 2022-10-31 A | 2027-01-18 |  | 71% | 319.69d | 2022-10-31 | 2027-01-18 | 1101d | 2022-10-31 | 2027-01-18 | 243d |  | -0 | N/A | N/A | DBT |  | 5.0 | N/A |  |  |  | Design, Build & Test (PIT) |  |  |  |  |
| 47 | 1.3.1.1 | Physical design baselined (M5) | milestone | 0d | 2022-10-31 A | 2022-10-31 A |  | 100% |  | 2022-10-31 | 2022-10-31 | 0d | 2022-10-31 | 2022-10-31 |  |  |  | SRO Design | SI Design,PP,IPA | DBT |  | 5.0 | Paul Pettitt | Complete | COMPLETE |  | Design, Build & Test (PIT) | PSG | MHHS-ART001 | T1-DB-1000 | T1 |
| 48 | 1.3.1.2 | **M5 Design Work-Off Plan Implementation & Approval** |  | 79d | 2022-10-31 A | 2023-02-16 A |  | 100% |  | 2022-10-31 | 2023-02-16 | 79d | 2022-10-31 | 2023-02-16 |  |  |  | N/A | N/A | DBT |  | 5.0 | N/A |  |  |  | Design, Build & Test (PIT) |  |  |  |  |
| 49 | 1.3.1.2.1 | Implementation of M5 design Work-Off Plan |  | 74d | 2022-10-31 A | 2023-02-09 A | 47 | 100% |  | 2022-10-31 | 2023-02-09 | 74d | 2022-10-31 | 2023-02-09 |  |  |  | SI Design | PP | DBT |  | 5.0 | Paul Pettitt | Complete | COMPLETE |  | Design, Build & Test (PIT) |  |  |  |  |
| 50 | 1.3.1.2.2 | M5 design Work-Off Plan completion approved | milestone | 0d | 2023-02-16 A | 2023-02-16 A | 49FS+5d | 100% |  | 2023-02-16 | 2023-02-16 | 0d | 2023-02-16 | 2023-02-16 |  |  |  | SI Design | PP | DBT |  | 5.0 | Paul Pettitt | Complete | COMPLETE |  | Design, Build & Test (PIT) | DAG |  | T3-DB-0014 | T3 |
| 51 | 1.3.1.3 | **Enduring PP Design Support** |  | 1089d | 2022-10-31 A | 2026-12-31 A |  | 100% |  | 2022-10-31 | 2026-12-31 | 1089d | 2022-10-31 | 2026-12-31 |  |  |  | N/A | N/A | DBT |  | 5.0 | N/A |  |  |  | Design, Build & Test (PIT) |  |  |  |  |
| 52 | 1.3.1.3.1 | Design playbacks and drop-in sessions |  | 45d | 2022-10-31 A | 2022-12-30 A | 47 | 100% |  | 2022-10-31 | 2022-12-30 | 45d | 2022-10-31 | 2022-12-30 |  |  |  | SI Design | PMO,PPC, SRO Design | DBT |  | 5.0 | Paul Pettitt | Complete | COMPLETE |  | Design, Build & Test (PIT) |  |  |  |  |
| 53 | 1.3.1.3.2 | Support participants on E2E MHHS Design |  | 1089d | 2022-10-31 A | 2026-12-31 A | 47 | 100% |  | 2022-10-31 | 2026-12-31 | 1089d | 2022-10-31 | 2026-12-31 |  |  |  | SI Design | PP | DBT |  | 5.0 | Paul Pettitt | Complete | COMPLETE |  | Design, Build & Test (PIT) |  |  |  |  |
| 54 | 1.3.1.3.3 | DIP Onboarding Support |  | 70d | 2022-11-14 A | 2023-02-17 A |  | 100% |  | 2022-11-14 | 2023-02-17 | 70d | 2022-11-14 | 2023-02-17 |  | must start on 2022-11-14 |  | SI Design | SRO Design | DBT |  | 5.0 | Paul Pettitt | Complete | COMPLETE |  | Design, Build & Test (PIT) |  |  |  |  |
| 55 | 1.3.1.3.4 | iServer Launch | milestone | 0d | 2023-02-16 A | 2023-02-16 A | 50 | 100% |  | 2023-02-16 | 2023-02-16 | 0d | 2023-02-16 | 2023-02-16 |  |  |  | SI Design | PP | DBT |  | 5.0 | Paul Pettitt | Complete | COMPLETE |  | Design, Build & Test (PIT) |  |  |  |  |

| ID | WBS | Task | Type | Duration | Start | Finish | Predecessors | Complete | Remaining | Baseline start | Baseline finish | Baseline duration | Baseline 1 start | Baseline 1 finish | Total slack | Constraint | Baseline cost | Responsible | Involved | Text9 | Update Version | MHHS Resource Name | MHHS Programme Phase | Sched Status | RAG | Milestone ID | Text29 | Tier |
| --- | --- | --- | --- | --- | --- | --- | --- | --- | --- | --- | --- | --- | --- | --- | --- | --- | --- | --- | --- | --- | --- | --- | --- | --- | --- | --- | --- | --- |
| 56 | 1.3.1.4 | **Establish Design Change Management Processes** |  | 1101d | 2022-10-31 A | 2027-01-18 |  | 36% | 706.22d | 2022-10-31 | 2027-01-18 | 1101d | 2022-10-31 | 2027-01-18 | 243d |  |  | N/A | N/A | DBT | 5.0 | N/A | Design, Build & Test (PIT) |  |  |  |  |  |
| 57 | 1.3.1.4.1 | Internal review of internal change management processes |  | 35d | 2022-10-31 A | 2022-12-16 A |  | 100% |  | 2022-10-31 | 2022-12-16 | 35d | 2022-10-31 | 2022-12-16 |  |  |  | SRO | SI Design | DBT | 5.0 | Paul Pettitt | Design, Build & Test (PIT) | Complete | COMPLETE |  |  |  |
| 58 | 1.3.1.4.2 | SRO approval of internal change management processes | milestone | 0d | 2022-12-16 A | 2022-12-16 A | 57FF | 100% |  | 2022-12-16 | 2022-12-16 | 0d | 2022-12-16 | 2022-12-16 |  |  |  | SRO | SI Design | DBT | 5.0 | Paul Pettitt | Design, Build & Test (PIT) | Complete | COMPLETE |  |  |  |
| 59 | 1.3.1.4.3 | Change Process Webinar | milestone | 0d | 2023-01-16 A | 2023-01-16 A |  | 100% |  | 2023-01-16 | 2023-01-16 | 0d | 2023-01-16 | 2023-01-16 |  | must start on 2023-01-16 |  | SI Design | PP | DBT | 5.0 | Paul Pettitt | Design, Build & Test (PIT) | Complete | COMPLETE |  |  |  |
| 60 | 1.3.1.4.4 | Enduring change management process approved | milestone | 0d | 2023-02-16 A | 2023-02-16 A | 50FF | 100% |  | 2023-02-16 | 2023-02-16 | 0d | 2023-02-16 | 2023-02-16 |  |  |  | SI Design | PP | DBT | 5.0 | Paul Pettitt | Design, Build & Test (PIT) | Complete | COMPLETE | T3-DB-0016 | DAG | T3 |
| 61 | 1.3.1.4.5 | Maintain E2E MHHS Design (post-M5 design change management processes operational) |  | 1022d | 2023-02-17 A | 2027-01-18 | 60 | 34% | 678d | 2023-02-17 | 2027-01-18 | 1022d | 2023-02-17 | 2027-01-18 | 243d |  |  | SI Design | PP | DBT | 5.0 | Paul Pettitt | Design, Build & Test (PIT) | Green | GREEN |  |  |  |
| 62 | 1.3.1.5 | **Design Authority Mobilisation** |  | 29d | 2022-12-14 A | 2023-01-23 A |  | 100% |  | 2022-12-14 | 2023-01-23 | 29d | 2022-12-14 | 2023-01-23 |  |  |  | N/A | N/A | DBT | 5.0 | N/A | Design, Build & Test (PIT) |  |  |  |  |  |
| 63 | 1.3.1.5.1 | Design Authority ToR approved | milestone | 0d | 2022-12-14 A | 2022-12-14 A |  | 100% |  | 2022-12-14 | 2022-12-14 | 0d | 2022-12-14 | 2022-12-14 |  | must start on 2022-12-14 |  | SI Design | PP | DBT | 5.0 | Paul Pettitt | Design, Build & Test (PIT) | Complete | COMPLETE | T3-DB-0010 | DAG | T3 |
| 64 | 1.3.1.5.2 | Inaugural Design Authority | milestone | 0d | 2023-01-23 A | 2023-01-23 A | 63FS+29d | 100% |  | 2023-01-23 | 2023-01-23 | 0d | 2023-01-23 | 2023-01-23 |  |  |  | SI Design | PP | DBT | 5.0 | Paul Pettitt | Design, Build & Test (PIT) | Complete | COMPLETE |  |  |  |
| 65 | 1.3.1.6 | **Network Operation Services Adaptor Procurement** |  | 0d | 2023-05-23 A | 2023-05-23 A |  | 100% |  | 2023-05-23 | 2023-05-23 | 0d | 2023-02-01 | 2025-03-14 |  |  | -0 | N/A | N/A | DBT | 5.0 | N/A | Design, Build & Test (PIT) |  |  |  |  |  |
| 66 | 1.3.1.6.1 | All SIT LDSOs have procured their adapter providers | milestone | 0d | 2023-05-23 A | 2023-05-23 A | 615SS | 100% |  | 2023-05-23 | 2023-05-23 | 0d | 2023-05-23 | 2023-05-23 |  |  |  | SI Design | PP | DBT | 5.0 | Paul Pettitt | Design, Build & Test (PIT) | Complete | COMPLETE | T3-DB-0020 | DAG | T3 |
| 67 | 1.3.2 | **PP Mobilisation** |  | 67d | 2022-10-31 A | 2023-01-31 A |  | 100% |  | 2022-10-31 | 2023-01-31 | 67d | 2022-10-31 | 2023-01-31 |  |  |  | N/A | N/A | DBT | 5.0 | N/A | Design, Build & Test (PIT) |  |  |  |  |  |
| 68 | 1.3.2.1 | Set up governance |  | 67d | 2022-10-31 A | 2023-01-31 A |  | 100% |  | 2022-10-31 | 2023-01-31 | 67d | 2022-10-31 | 2023-01-31 |  |  |  | PP |  | DBT | 5.0 | PP | Design, Build & Test (PIT) | Complete | COMPLETE |  |  |  |
| 69 | 1.3.2.2 | Set up reporting |  | 67d | 2022-10-31 A | 2023-01-31 A |  | 100% |  | 2022-10-31 | 2023-01-31 | 67d | 2022-10-31 | 2023-01-31 |  |  |  | PP |  | DBT | 5.0 | PP | Design, Build & Test (PIT) | Complete | COMPLETE |  |  |  |
| 70 | 1.3.2.3 | Obtain funding |  | 67d | 2022-10-31 A | 2023-01-31 A |  | 100% |  | 2022-10-31 | 2023-01-31 | 67d | 2022-10-31 | 2023-01-31 |  |  |  | PP |  | DBT | 5.0 | PP | Design, Build & Test (PIT) | Complete | COMPLETE |  |  |  |
| 71 | 1.3.2.4 | Earmark resources |  | 67d | 2022-10-31 A | 2023-01-31 A |  | 100% |  | 2022-10-31 | 2023-01-31 | 67d | 2022-10-31 | 2023-01-31 |  |  |  | PP |  | DBT | 5.0 | PP | Design, Build & Test (PIT) | Complete | COMPLETE |  |  |  |
| 72 | 1.3.2.5 | Mobilise initial team |  | 67d | 2022-10-31 A | 2023-01-31 A |  | 100% |  | 2022-10-31 | 2023-01-31 | 67d | 2022-10-31 | 2023-01-31 |  |  |  | PP |  | DBT | 5.0 | PP | Design, Build & Test (PIT) | Complete | COMPLETE |  |  |  |
| 73 | 1.3.3 | **PIT Stub Specification and Delivery** |  | 435d | 2022-10-31 A | 2024-06-28 A |  | 100% |  | 2022-10-31 | 2024-06-28 | 430d | 2022-10-31 | 2023-05-31 |  |  | -0 | N/A | N/A | DBT | 5.0 | N/A | Design, Build & Test (PIT) |  |  |  |  |  |
| 74 | 1.3.3.1 | **DIP Simulator** |  | 108d | 2022-10-31 A | 2023-03-29 A |  | 100% |  | 2022-10-31 | 2023-03-29 | 108d | 2022-10-31 | 2023-03-29 |  |  |  | N/A | N/A | DBT | 5.0 | N/A | Design, Build & Test (PIT) |  |  |  |  |  |
| 75 | 1.3.3.1.1 | Build & Test |  | 95d | 2022-10-31 A | 2023-03-10 A | 47 | 100% |  | 2022-10-31 | 2023-03-10 | 95d | 2022-10-31 | 2023-03-10 |  |  |  | SI DevOps |  | DBT | 5.0 | Rebecca Farooq | Design, Build & Test (PIT) | Complete | COMPLETE |  |  |  |
| 76 | 1.3.3.1.2 | UAT |  | 85d | 2022-11-14 A | 2023-03-10 A | 75SS+10d | 100% |  | 2022-11-14 | 2023-03-10 | 85d | 2022-11-14 | 2023-03-10 |  |  |  | SI Test |  | DBT | 5.0 | Rebecca Farooq | Design, Build & Test (PIT) | Complete | COMPLETE |  |  |  |
| 77 | 1.3.3.1.3 | Beta test |  | 95d | 2022-10-31 A | 2023-03-10 A | 75SS | 100% |  | 2022-10-31 | 2023-03-10 | 95d | 2022-10-31 | 2023-03-10 |  |  |  | PP | SI Test | DBT | 5.0 | Rebecca Farooq | Design, Build & Test (PIT) | Complete | COMPLETE |  |  |  |
| 78 | 1.3.3.1.4 | Prepare for release |  | 18d | 2023-03-06 A | 2023-03-29 A | 77FS-5d | 100% |  | 2023-03-06 | 2023-03-29 | 18d | 2023-03-06 | 2023-03-29 |  |  |  | SI DevOps |  | DBT | 5.0 | Rebecca Farooq | Design, Build & Test (PIT) | Complete | COMPLETE |  |  |  |
| 79 | 1.3.3.1.5 | DIP Simulator released | milestone | 0d | 2023-03-29 A | 2023-03-29 A | 78FF | 100% |  | 2023-03-29 | 2023-03-29 | 0d | 2023-03-29 | 2023-03-29 |  | start no earlier than 2023-01-30 |  | SI DevOps |  | DBT | 5.0 | Rebecca Farooq | Design, Build & Test (PIT) | Complete | COMPLETE | T3-DB-0018 | SITAG | T3 |

| ID | WBS | Task | Type | Duration | Start | Finish | Predecessors | Complete | Baseline start | Baseline finish | Baseline duration | Baseline 1 start | Baseline 1 finish | Constraint | Baseline cost | Responsible | Involved | Text9 | Update Version | MHHS Resource Name | MHHS Programme Phase | Sched Status | RAG | Milestone ID | Text29 | Tier |
| --- | --- | --- | --- | --- | --- | --- | --- | --- | --- | --- | --- | --- | --- | --- | --- | --- | --- | --- | --- | --- | --- | --- | --- | --- | --- | --- |
| 80 | 1.3.3.2 | **DIP Simulator Uplifts** |  | 257d | 2023-07-06 A | 2024-06-28 A |  | 100% | 2023-07-06 | 2024-06-28 | 252d |  |  |  | -0 | N/A | N/A | DBT | 5.1 | N/A | Design, Build & Test (PIT) |  |  |  |  |  |
| 81 | 1.3.3.2.1 | DIP Simulator uplifted to align with design releases - design/build/test |  | 27d | 2023-07-06 A | 2023-08-11 A | 117 | 100% | 2023-07-06 | 2023-08-11 | 27d |  |  |  |  | SI DevOps |  | DBT | 5.1 | Rebecca Farooq | Design, Build & Test (PIT) | Complete | COMPLETE |  |  |  |
| 82 | 1.3.3.2.2 | DIP Simulator uplifted to align with Interim Release 2 | milestone | 0d | 2023-08-11 A | 2023-08-11 A | 81 | 100% | 2023-08-11 | 2023-08-11 | 0d |  |  |  |  | SI DevOps |  | DBT | 5.1 | Rebecca Farooq | Design, Build & Test (PIT) | Complete | COMPLETE | T3-DB-0035 | SITAG | T3 |
| 83 | 1.3.3.2.3 | DIP Simulator uplifted to align with design releases - design/build/test |  | 20d | 2023-10-09 A | 2023-11-03 A | 126FS+2d | 100% | 2023-10-09 | 2023-11-03 | 20d |  |  |  |  | SI DevOps |  | DBT | 5.3 | Rebecca Farooq | Design, Build & Test (PIT) | Complete | COMPLETE |  |  |  |
| 84 | 1.3.3.2.4 | DIP Simulator uplifted to align with Interim Release 5 | milestone | 0d | 2023-11-03 A | 2023-11-03 A | 83 | 100% | 2023-11-03 | 2023-11-03 | 0d |  |  |  |  | SI DevOps |  | DBT | 5.11 | Rebecca Farooq | Design, Build & Test (PIT) | Complete | COMPLETE | T3-DB-0039 | SITAG | T3 |
| 85 | 1.3.3.2.5 | DIP Simulator uplifted to align with design releases - design/build/test |  | 37d | 2024-02-01 A | 2024-03-22 A | 134 | 100% | 2024-02-01 | 2024-03-22 | 37d |  |  |  |  | SI DevOps | PP,SRO,Testing | DBT | 5.14 | Matthew Bray | Design, Build & Test (PIT) | Complete | COMPLETE |  |  |  |
| 86 | 1.3.3.2.6 | DIP Simulator uplifted to align with Interim Release 7 | milestone | 0d | 2024-03-22 A | 2024-03-22 A | 85 | 100% | 2024-03-22 | 2024-03-22 | 0d |  |  |  |  | SI DevOps | PP,SRO,Testing | DBT | 5.14 | Matthew Bray | Design, Build & Test (PIT) | Complete | COMPLETE | T3-DB-0182 | SITAG | T3 |
| 87 | 1.3.3.2.7 | DIP Simulator uplifted to align with design releases - design/build/test |  | 57d | 2024-04-04 A | 2024-06-21 A | 138 | 100% | 2024-04-04 | 2024-06-21 | 57d |  |  |  |  | SI DevOps | PP,SRO,Testing | DBT | 5.14 | Matthew Bray | Design, Build & Test (PIT) | Complete | COMPLETE |  |  |  |
| 88 | 1.3.3.2.8 | DIP Simulator uplifted to align with Interim Release 8 | milestone | 0d | 2024-06-28 A | 2024-06-28 A | 87FS+5d | 100% | 2024-06-28 | 2024-06-28 | 0d |  |  |  |  | SI DevOps | PP,SRO,Testing | DBT | 5.28 | Matthew Bray | Design, Build & Test (PIT) | Complete | COMPLETE | T3-DB-0183 | SITAG | T3 |
| 89 | 1.3.3.3 | **Data Generator** |  | 130d | 2022-12-01 A | 2023-05-31 A |  | 100% | 2022-12-01 | 2023-05-31 | 130d | 2022-12-01 | 2023-05-31 |  |  | N/A | N/A | DBT | 5.0 | N/A | Design, Build & Test (PIT) |  |  |  |  |  |
| 90 | 1.3.3.3.1 | Design | manual | 15d | 2022-12-01 A | 2022-12-21 A |  | 100% | 2022-12-01 | 2022-12-21 | 15d | 2022-12-01 | 2022-12-21 |  |  | SI DevOps |  | DBT | 5.0 | Rebecca Farooq | Design, Build & Test (PIT) | Complete | COMPLETE |  |  |  |
| 91 | 1.3.3.3.2 | Build & Test |  | 50d | 2023-02-16 A | 2023-04-26 A | 90FS+40d | 100% | 2023-02-16 | 2023-04-26 | 50d | 2023-02-16 | 2023-04-26 |  |  | SI DevOps |  | DBT | 5.0 | Rebecca Farooq | Design, Build & Test (PIT) | Complete | COMPLETE |  |  |  |
| 92 | 1.3.3.3.3 | UAT |  | 10d | 2023-04-27 A | 2023-05-10 A | 91 | 100% | 2023-04-27 | 2023-05-10 | 10d | 2023-04-27 | 2023-05-10 |  |  | SI Test |  | DBT | 5.0 | Rebecca Farooq | Design, Build & Test (PIT) | Complete | COMPLETE |  |  |  |
| 93 | 1.3.3.3.4 | Beta test |  | 45d | 2023-03-30 A | 2023-05-31 A | 91FS-20d, 95FF | 100% | 2023-03-30 | 2023-05-31 | 45d | 2023-03-30 | 2023-05-31 |  |  | PP | SI Test | DBT | 5.0 | Rebecca Farooq | Design, Build & Test (PIT) | Complete | COMPLETE |  |  |  |
| 94 | 1.3.3.3.5 | Prepare for release |  | 24d | 2023-04-27 A | 2023-05-30 A | 92SS | 100% | 2023-04-27 | 2023-05-30 | 24d | 2023-04-27 | 2023-05-30 |  |  | SI DevOps |  | DBT | 5.0 | Rebecca Farooq | Design, Build & Test (PIT) | Complete | COMPLETE |  |  |  |
| 95 | 1.3.3.3.6 | Data Generator released | milestone | 0d | 2023-05-31 A | 2023-05-31 A | 94FS+1d | 100% | 2023-05-31 | 2023-05-31 | 0d | 2023-05-31 | 2023-05-31 |  |  | SI DevOps |  | DBT | 5.0 | Rebecca Farooq | Design, Build & Test (PIT) | Complete | COMPLETE | T3-DB-0022 | SITAG | T3 |
| 96 | 1.3.4 | **Design Artefact Releases** |  | 503d? | 2023-02-22 A | 2025-01-24 A |  | 100% | 2023-02-22 | 2024-11-13 | 398d | 2023-02-22 | 2023-09-29 |  | -0 | N/A | N/A | DBT | 5.0 | N/A | Design, Build & Test (PIT) |  |  |  | DAG |  |
| 97 | 1.3.4.1 | **Interim release 1** |  | 79d | 2023-02-22 A | 2023-06-12 A |  | 100% | 2023-02-22 | 2023-06-12 | 79d | 2023-02-22 | 2023-06-28 |  |  | N/A | N/A | DBT | 5.0 | N/A | Design, Build & Test (PIT) |  |  |  |  |  |
| 98 | 1.3.4.1.1 | Prioritise DINs and CR |  | 1d | 2023-02-22 A | 2023-02-22 A |  | 100% | 2023-02-22 | 2023-02-22 | 1d | 2023-02-22 | 2023-02-22 | must start on 2023-02-22 |  | SI Design |  | DBT | 5.0 | Paul Pettitt | Design, Build & Test (PIT) | Complete | COMPLETE |  |  |  |
| 99 | 1.3.4.1.2 | **Industry input session** |  | 7d | 2023-02-23 A | 2023-03-03 A |  | 100% | 2023-02-23 | 2023-03-03 | 7d | 2023-02-23 | 2023-03-03 |  |  | N/A | N/A | DBT | 5.0 | N/A | Design, Build & Test (PIT) |  |  |  |  |  |
| 100 | 1.3.4.1.2.1 | Raise a CR covering prioritized assessment cluster |  | 1d | 2023-02-23 A | 2023-02-23 A | 98 | 100% | 2023-02-23 | 2023-02-23 | 1d | 2023-02-23 | 2023-02-23 |  |  | SI Design |  | DBT | 5.0 | Paul Pettitt | Design, Build & Test (PIT) | Complete | COMPLETE |  |  |  |
| 101 | 1.3.4.1.2.2 | Organize Industry Input session to go through significant items to reach consensus |  | 1d | 2023-02-23 A | 2023-02-23 A | 100SS | 100% | 2023-02-23 | 2023-02-23 | 1d | 2023-02-23 | 2023-02-23 |  |  | SI Design | PP | DBT | 5.0 | Paul Pettitt,Berlinda Kugara | Design, Build & Test (PIT) | Complete | COMPLETE |  |  |  |
| 102 | 1.3.4.1.2.3 | Conduct Meeting |  | 1d | 2023-03-03 A | 2023-03-03 A | 101FS+5d | 100% | 2023-03-03 | 2023-03-03 | 1d | 2023-03-03 | 2023-03-03 |  |  | SI Design | PP | DBT | 5.0 | Paul Pettitt,Berlinda Kugara | Design, Build & Test (PIT) | Complete | COMPLETE |  |  |  |
| 103 | 1.3.4.1.3 | Update baselined artefacts |  | 10d | 2023-03-24 A | 2023-04-06 A |  | 100% | 2023-03-24 | 2023-04-06 | 10d | 2023-03-24 | 2023-04-06 |  |  | SI Design |  | DBT | 5.0 | Paul Pettitt | Design, Build & Test (PIT) | Complete | COMPLETE |  |  |  |

Notes:
- 84: Action: 26/7/23 - forecast changed from 15/12/23 - 3/11/23 - Changed from Interim Release 6 to 5. Updated in milestone register

| ID | WBS | Task | Type | Duration | Start | Finish | Predecessors | Complete | Baseline start | Baseline finish | Baseline duration | Baseline 1 start | Baseline 1 finish | Constraint | Baseline cost | Responsible | Involved | Text9 | Update Version | MHHS Resource Name | MHHS Programme Phase | Sched Status | RAG | Milestone ID | Text29 | Tier | Action |
| --- | --- | --- | --- | --- | --- | --- | --- | --- | --- | --- | --- | --- | --- | --- | --- | --- | --- | --- | --- | --- | --- | --- | --- | --- | --- | --- | --- |
| 104 | 1.3.4.1.4 | **Participant review and impact assess changes** |  | 18d | 2023-04-14 A | 2023-05-09 A |  | 100% | 2023-04-14 | 2023-05-09 | 18d | 2023-04-14 | 2023-05-09 |  |  | N/A | N/A | DBT | 5.0 | N/A | Design, Build & Test (PIT) |  |  |  |  |  |  |
| 105 | 1.3.4.1.4.1 | Issue Redline Version of documents |  | 1d | 2023-04-14 A | 2023-04-14 A | 103FS+5d | 100% | 2023-04-14 | 2023-04-14 | 1d | 2023-04-14 | 2023-04-14 |  |  | SI Design |  | DBT | 5.0 | Paul Pettitt | Design, Build & Test (PIT) | Complete | COMPLETE |  |  |  |  |
| 106 | 1.3.4.1.4.2 | Participants provide review comments to common log |  | 17d | 2023-04-17 A | 2023-05-09 A | 105 | 100% | 2023-04-17 | 2023-05-09 | 17d | 2023-04-17 | 2023-05-09 |  |  | PP |  | DBT | 5.0 | Paul Pettitt | Design, Build & Test (PIT) | Complete | COMPLETE |  |  |  |  |
| 107 | 1.3.4.1.5 | **Assurance review** |  | 19d | 2023-05-10 A | 2023-06-05 A |  | 100% | 2023-05-10 | 2023-06-05 | 19d | 2023-05-10 | 2023-06-05 |  |  | N/A | N/A | DBT | 5.0 | N/A | Design, Build & Test (PIT) |  |  |  |  |  |  |
| 108 | 1.3.4.1.5.1 | SI Design Review and Respond to Comments |  | 5d | 2023-05-10 A | 2023-05-16 A | 106 | 100% | 2023-05-10 | 2023-05-16 | 5d | 2023-05-10 | 2023-05-16 |  |  | SI Design |  | DBT | 5.0 | Paul Pettitt | Design, Build & Test (PIT) | Complete | COMPLETE |  |  |  |  |
| 109 | 1.3.4.1.5.2 | Prep for Assurance Review Meeting |  | 7d | 2023-05-17 A | 2023-05-25 A | 108 | 100% | 2023-05-17 | 2023-05-25 | 7d | 2023-05-17 | 2023-05-25 |  |  | SI Design |  | DBT | 5.0 | Paul Pettitt | Design, Build & Test (PIT) | Complete | COMPLETE |  |  |  |  |
| 110 | 1.3.4.1.5.3 | Conduct Assurance Review Meeting |  | 1d | 2023-05-26 A | 2023-05-26 A | 109 | 100% | 2023-05-26 | 2023-05-26 | 1d | 2023-05-26 | 2023-05-26 |  |  | SI Design |  | DBT | 5.0 | Paul Pettitt | Design, Build & Test (PIT) | Complete | COMPLETE |  |  |  |  |
| 111 | 1.3.4.1.5.4 | Update Artefacts following Assurance Review |  | 6d | 2023-05-29 A | 2023-06-05 A | 110 | 100% | 2023-05-29 | 2023-06-05 | 6d | 2023-05-29 | 2023-06-05 |  |  | SI Design |  | DBT | 5.0 | Paul Pettitt | Design, Build & Test (PIT) | Complete | COMPLETE |  |  |  |  |
| 112 | 1.3.4.1.6 | PSG Approval of interim release plan |  | 1d | 2023-06-08 A | 2023-06-08 A |  | 100% | 2023-06-08 | 2023-06-08 | 1d |  |  | must start on 2023-06-08 |  | PP | SI Design | DBT | 5.1 | Paul Pettitt | Design, Build & Test (PIT) | Complete | COMPLETE |  |  |  |  |
| 113 | 1.3.4.1.7 | Publish updated baselined artefacts | milestone | 0d | 2023-06-06 A | 2023-06-12 A | 111 | 100% | 2023-06-06 | 2023-06-12 | 5d | 2023-06-15 | 2023-06-21 |  |  | SI Design |  | DBT | 5.0 | Paul Pettitt | Design, Build & Test (PIT) | Complete | COMPLETE |  |  |  |  |
| 114 | 1.3.4.1.8 | Interim release 1 Go live | milestone | 0d | 2023-06-12 A | 2023-06-12 A | 113 | 100% | 2023-06-12 | 2023-06-12 | 0d | 2023-06-28 | 2023-06-28 |  |  | SI Design |  | DBT | 5.0 | Paul Pettitt | Design, Build & Test (PIT) | Complete | COMPLETE | T3-DB-0095 | DAG | T3 |  |
| 115 | 1.3.4.2 | **Interim release 2** |  | 27d | 2023-05-30 A | 2023-07-05 A |  | 100% | 2023-05-30 | 2023-07-05 | 27d | 2023-05-24 | 2023-07-28 |  |  | N/A | N/A | DBT | 5.0 | N/A | Design, Build & Test (PIT) |  |  |  |  |  |  |
| 116 | 1.3.4.2.1 | Update baselined artefacts |  | 27d | 2023-05-30 A | 2023-07-05 A |  | 100% | 2023-05-30 | 2023-07-05 | 27d |  |  | must start on 2023-05-30 |  | SI Design | PP | DBT | 5.1 | Paul Pettitt | Design, Build & Test (PIT) | Complete | COMPLETE |  |  |  |  |
| 117 | 1.3.4.2.2 | Interim release 2 Go live | milestone | 0d | 2023-07-05 A | 2023-07-05 A | 116 | 100% | 2023-07-05 | 2023-07-05 | 0d | 2023-07-28 | 2023-07-28 |  |  | SI Design |  | DBT | 5.0 | Paul Pettitt | Design, Build & Test (PIT) | Complete | COMPLETE | T3-DB-0096 | DAG | T3 |  |
| 118 | 1.3.4.3 | **Interim release 3** |  | 35d | 2023-06-15 A | 2023-08-02 A |  | 100% | 2023-06-15 | 2023-08-02 | 35d | 2023-06-29 | 2023-09-29 |  |  | N/A | N/A | DBT | 5.0 | N/A | Design, Build & Test (PIT) |  |  |  |  |  |  |
| 119 | 1.3.4.3.1 | Update baselined artefacts |  | 35d | 2023-06-15 A | 2023-08-02 A |  | 100% | 2023-06-15 | 2023-08-02 | 35d |  |  | must start on 2023-06-15 |  | SI Design | PP | DBT | 5.1 | Paul Pettitt | Design, Build & Test (PIT) | Complete | COMPLETE |  |  |  |  |
| 120 | 1.3.4.3.2 | Interim release 3 Go live | milestone | 0d | 2023-08-02 A | 2023-08-02 A | 119 | 100% | 2023-08-02 | 2023-08-02 | 0d | 2023-09-29 | 2023-09-29 |  |  | SI Design |  | DBT | 5.0 | Paul Pettitt | Design, Build & Test (PIT) | Complete | COMPLETE | T3-DB-0097 | DAG | T3 |  |
| 121 | 1.3.4.4 | **Interim release 4** |  | 36d | 2023-07-12 A | 2023-08-30 A |  | 100% | 2023-07-12 | 2023-08-30 | 36d |  |  |  |  | N/A | N/A | DBT | 5.1 | N/A | Design, Build & Test (PIT) |  |  |  |  |  |  |
| 122 | 1.3.4.4.1 | Update baselined artefacts |  | 36d | 2023-07-12 A | 2023-08-30 A |  | 100% | 2023-07-12 | 2023-08-30 | 36d |  |  | must start on 2023-07-12 |  | SI Design | PP | DBT | 5.1 | Paul Pettitt | Design, Build & Test (PIT) | Complete | COMPLETE |  |  |  |  |
| 123 | 1.3.4.4.2 | Interim release 4 Go live | milestone | 0d | 2023-08-30 A | 2023-08-30 A | 122 | 100% | 2023-08-30 | 2023-08-30 | 0d |  |  |  |  | SI Design |  | DBT | 5.1 | Paul Pettitt | Design, Build & Test (PIT) | Complete | COMPLETE | T3-DB-0081 | DAG | T3 |  |
| 124 | 1.3.4.5 | **Interim release 5** |  | 147d | 2023-08-17 A | 2024-03-08 A |  | 100% | 2023-08-17 | 2024-03-08 | 147d |  |  |  | -0 | N/A | N/A | DBT | 5.1 | N/A | Design, Build & Test (PIT) |  |  |  |  |  |  |
| 125 | 1.3.4.5.1 | Update baselined artefacts |  | 35d | 2023-08-17 A | 2023-10-04 A |  | 100% | 2023-08-17 | 2023-10-04 | 35d |  |  | must start on 2023-08-17 |  | SI Design | PP | DBT | 5.1 | Paul Pettitt | Design, Build & Test (PIT) | Complete | COMPLETE |  |  |  |  |
| 126 | 1.3.4.5.2 | Interim release 5 Go live | milestone | 0d | 2023-10-04 A | 2023-10-04 A | 125 | 100% | 2023-10-04 | 2023-10-04 | 0d |  |  |  |  | SI Design |  | DBT | 5.1 | Paul Pettitt | Design, Build & Test (PIT) | Complete | COMPLETE | T3-DB-0083 | DAG | T3 | 11/8 - successor is SIT functional (starts in march) |
| 127 | 1.3.4.5.3 | Interim Release 5 Deployed to SIT |  | 10d | 2024-02-26 A | 2024-03-08 A | 126FS+102d | 100% | 2024-02-26 | 2024-03-08 | 10d |  |  |  |  | SI Testing | PP | DBT | 5.16 |  |  | Complete | COMPLETE |  |  |  |  |

| ID | WBS | Task | Type | Duration | Start | Finish | Predecessors | Complete | Baseline start | Baseline finish | Baseline duration | Constraint | Baseline cost | Responsible | Involved | Text9 | Update Version | MHHS Resource Name | MHHS Programme Phase | Sched Status | RAG | Milestone ID | Text29 | Tier | Action | Task Status |
| --- | --- | --- | --- | --- | --- | --- | --- | --- | --- | --- | --- | --- | --- | --- | --- | --- | --- | --- | --- | --- | --- | --- | --- | --- | --- | --- |
| 128 | 1.3.4.6 | **Interim release 6** |  | 192d | 2023-09-14 A | 2024-06-07 A |  | 100% | 2023-09-14 | 2024-06-07 | 192d |  | -0 | N/A | N/A | DBT | 5.1 | N/A | Design, Build & Test (PIT) |  |  |  |  |  |  |  |
| 129 | 1.3.4.6.1 | Update baselined artefacts |  | 35d | 2023-09-14 A | 2023-11-01 A |  | 100% | 2023-09-14 | 2023-11-01 | 32d | must start on 2023-09-14 |  | SI Design | PP | DBT | 5.1 | Paul Pettitt | Design, Build & Test (PIT) | Complete | COMPLETE |  |  |  |  |  |
| 130 | 1.3.4.6.2 | Interim release 6 Go live | milestone | 0d | 2023-11-01 A | 2023-11-01 A | 129 | 100% | 2023-11-01 | 2023-11-01 | 0d |  |  | SI Design |  | DBT | 5.11 | Paul Pettitt | Design, Build & Test (PIT) | Complete | COMPLETE | T3-DB-0085 | DAG | T3 |  |  |
| 131 | 1.3.4.6.3 | Interim Release 6 Deployed to SIT |  | 10d | 2024-05-27 A | 2024-06-07 A | 130FS+147d | 100% | 2024-05-27 | 2024-06-07 | 10d |  |  | SI Testing | PP | DBT | 5.16 |  |  | Complete | COMPLETE |  |  |  |  |  |
| 132 | 1.3.4.7 | **Interim release 7** |  | 168d | 2023-10-18 A | 2024-06-07 A |  | 100% | 2023-10-18 | 2024-06-07 | 168d |  | -0 | N/A | N/A | DBT | 5.5 | N/A | Design, Build & Test (PIT) |  |  |  |  |  |  |  |
| 133 | 1.3.4.7.1 | Update baselined artefacts |  | 76d | 2023-10-18 A | 2024-01-31 A |  | 100% | 2023-10-18 | 2024-01-31 | 76d | start no earlier than 2023-10-18 |  | SI Design | PP | DBT | 5.5 | Paul Pettitt | Design, Build & Test (PIT) | Complete | COMPLETE |  |  |  |  |  |
| 134 | 1.3.4.7.2 | Interim release 7 Go live | milestone | 0d | 2024-01-31 A | 2024-01-31 A | 133 | 100% | 2024-01-31 | 2024-01-31 | 0d |  |  | SI Design | PP | DBT | 5.14 | Paul Pettitt | Design, Build & Test (PIT) | Complete | COMPLETE | T3-DB-0098 | DAG | T3 | 4/8 - add as t3 milestones. Awaiting approval at TMAG |  |
| 135 | 1.3.4.7.3 | Interim Release 7 Deployed to SIT |  | 10d | 2024-05-27 A | 2024-06-07 A | 134FS+82d | 100% | 2024-05-27 | 2024-06-07 | 10d |  |  | SI Testing | PP | DBT | 5.16 |  |  | Complete | COMPLETE |  |  |  |  |  |
| 136 | 1.3.4.8 | **Interim release 8** |  | 248d? | 2024-02-14 A | 2025-01-24 A |  | 100% | 2024-02-14 | 2024-11-13 | 143d |  | -0 | N/A | N/A | DBT | 5.5 | N/A | Design, Build & Test (PIT) |  |  |  | DAG |  |  |  |
| 137 | 1.3.4.8.1 | Update baselined artefacts |  | 36d | 2024-02-14 A | 2024-04-03 A |  | 100% | 2024-02-14 | 2024-04-03 | 36d | start no earlier than 2024-02-14 |  | SI Design | PP | DBT | 5.5 | Paul Pettitt | Design, Build & Test (PIT) | Complete | COMPLETE |  |  |  |  |  |
| 138 | 1.3.4.8.2 | Interim release 8 Go live | milestone | 0d | 2024-04-03 A | 2024-04-03 A | 137 | 100% | 2024-04-03 | 2024-04-03 | 0d | start no earlier than 2024-01-10 |  | SI Design | PP | DBT | 5.14 | Paul Pettitt | Design, Build & Test (PIT) | Complete | COMPLETE | T3-DB-0099 | DAG | T3 | 4/8 - add as t3 milestones. Awaiting approval at TMAG |  |
| 139 | 1.3.4.8.3 | **Interim Release 8.3 - Maintenance Window** |  | 11d | 2024-10-07 A | 2024-10-21 A |  | 100% | 2024-10-07 | 2024-10-21 | 0d |  |  | Design |  | DBT | 6.0 |  |  | Overdue Start |  |  |  |  |  | -686.67 |
| 140 | 1.3.4.8.3.1 | Interim Release 8.3 'effective from date' to SIT A | milestone | 0d | 2024-10-21 A | 2024-10-21 A | 138FS+143d | 100% | 2024-10-21 | 2024-10-21 | 10d |  |  | SI Testing | PP | DBT | 5.16 | Roger Robar |  | Complete | COMPLETE |  |  |  |  |  |
| 141 | 1.3.4.8.3.2 | Interim Release 8.3 'effective from date' to SIT B | milestone | 0d | 2024-10-07 A | 2024-10-07 A | 140SS-11d | 100% | 2024-10-07 | 2024-10-07 | 0d |  |  | Design |  | DBT | 5.16 |  |  | Complete | COMPLETE |  |  |  |  |  |
| 142 | 1.3.4.8.4 | **Interim Release 8.4** |  | 49d | 2024-09-25 A | 2024-12-02 A |  | 100% | 2024-09-25 | 2024-11-13 | 0d |  |  | Design |  | DBT | 6.1 | Paul Pettitt |  | Overdue Start |  |  | DAG |  |  | -694.67 |
| 143 | 1.3.4.8.4.1 | Update baselined artefacts |  | 8d | 2024-09-25 A | 2024-10-04 A |  | 100% | 2024-09-25 | 2024-10-04 | 0d | start no earlier than 2024-09-25 |  | Design |  | DBT | 6.1 | Paul Pettitt |  | Complete | COMPLETE |  |  |  |  |  |
| 144 | 1.3.4.8.4.2 | Interim Release 8.4 Published | milestone | 0d | 2024-10-16 A | 2024-10-16 A | 143FS+8d | 100% | 2024-10-16 | 2024-10-16 | 0d | start no earlier than 2024-10-09 |  | Design |  | DBT | 6.1 | Paul Pettitt |  | Complete | COMPLETE | T3-DB-0184 | DAG | T3 |  |  |
| 145 | 1.3.4.8.4.3 | Interim Release 8.4 Deployed to SIT by Participants |  | 6d | 2024-11-25 A | 2024-12-02 A | 144FS+25d | 100% | 2024-11-13 | 2024-11-13 | 0d |  |  | Design |  | DBT | 6.12 | Paul Pettitt |  | Complete | COMPLETE |  |  |  |  |  |
| 146 | 1.3.4.8.5 | **Interim Release 8.5** |  | 71d | 2024-10-16 A | 2025-01-22 A |  | 100% | 2024-10-16 | 2024-12-04 | 0d |  |  | Design |  | DBT | 6.11 | Paul Pettitt |  | Overdue Start |  |  | DAG |  |  | -728.67 |
| 147 | 1.3.4.8.5.1 | Update baselined artefacts |  | 8d | 2024-10-16 A | 2024-10-25 A |  | 100% | 2024-10-16 | 2024-10-25 | 0d | start no earlier than 2024-10-16 |  | Design |  | DBT | 6.11 | Paul Pettitt |  | Complete | COMPLETE |  |  |  |  |  |
| 148 | 1.3.4.8.5.2 | Interim Release 8.5 Published | milestone | 0d | 2024-11-06 A | 2024-11-06 A | 147FS+8d | 100% | 2024-11-06 | 2024-11-06 | 0d |  |  | Design |  | DBT | 6.11 | Paul Pettitt |  | Complete | COMPLETE | T3-DB-0185 | DAG | T3 |  |  |
| 149 | 1.3.4.8.5.3 | Interim Release 8.5 Deployed to SIT by Participants |  | 3d | 2025-01-20 A | 2025-01-22 A | 148FS+52d | 100% | 2024-12-04 | 2024-12-04 | 0d |  |  | Design |  | DBT | 6.12 | Paul Pettitt |  | Complete | COMPLETE |  |  |  |  |  |
| 150 | 1.3.4.8.6 | **Interim Release 8.6** |  | 45d? | 2024-11-21 A | 2025-01-22 A |  | 100% | 2024-11-21 | 2025-01-22 | 0d |  |  | Design |  | DBT | 6.14 | Paul Pettitt |  | Overdue Start |  |  | DAG |  |  | -769.67 |
| 151 | 1.3.4.8.6.1 | Update baselined artefacts |  | 2d? | 2024-11-21 A | 2024-11-22 A |  | 100% | 2024-11-21 | 2024-11-22 | 0d | start no earlier than 2024-11-21 |  |  |  | DBT | 6.14 | Paul Pettitt |  | Complete | COMPLETE |  |  |  |  |  |
| 152 | 1.3.4.8.6.2 | Interim Release 8.6 Published |  | 1d? | 2024-11-25 A | 2024-11-25 A | 151 | 100% | 2024-11-25 | 2024-11-25 | 0d |  |  |  |  | DBT | 6.14 | Paul Pettitt |  | Complete | COMPLETE |  |  |  |  |  |
| 153 | 1.3.4.8.6.3 | Interim Release 8.6 Deployed to SIT by Participants |  | 3d | 2025-01-20 A | 2025-01-22 A | 152FS+39d | 100% | 2025-01-20 | 2025-01-22 | 0d |  |  | Design |  | DBT | 6.14 | Paul Pettitt |  | Complete | COMPLETE | T3-TE-0187 | DAG | T3 |  |  |

| ID | WBS | Task | Duration | Start | Finish | Predecessors | Complete | Remaining | Baseline start | Baseline finish | Baseline duration | Baseline 1 start | Baseline 1 finish | Total slack | Constraint | Baseline cost | Responsible | Text9 | Task Status | Update Version | Sched Status | MHHS Resource Name | Text29 | RAG | Milestone ID | Tier | Involved | MHHS Programme Phase | Action |
| --- | --- | --- | --- | --- | --- | --- | --- | --- | --- | --- | --- | --- | --- | --- | --- | --- | --- | --- | --- | --- | --- | --- | --- | --- | --- | --- | --- | --- | --- |
| 154 | 1.3.4.8.7 | **Interim Release 8.7** | 5d | 2025-01-20 A | 2025-01-24 A |  | 100% |  | 2025-01-20 | 2025-01-27 |  |  |  |  |  |  | Design | DBT | -769.67 | 6.16 | Overdue Start | Paul Pettitt | DAG |  |  |  |  |  |  |
| 155 | 1.3.4.8.7.1 | Update baselined artefacts | 2d | 2025-01-20 A | 2025-01-21 A |  | 100% |  | 2025-01-20 | 2025-01-21 |  |  |  |  | start no earlier than 2025-01-20 |  |  | DBT |  | 6.16 | Complete | Paul Pettitt |  | COMPLETE |  |  |  |  |  |
| 156 | 1.3.4.8.7.2 | Interim Release 8.7 Published | 1d | 2025-01-22 A | 2025-01-22 A | 155 | 100% |  | 2025-01-22 | 2025-01-22 |  |  |  |  |  |  |  | DBT |  | 6.16 | Complete | Paul Pettitt |  | COMPLETE |  |  |  |  |  |
| 157 | 1.3.4.8.7.3 | Interim Release 8.7 Deployed to SIT by Participants | 3d | 2025-01-22 A | 2025-01-24 A | 156FS-1d | 100% |  | 2025-01-23 | 2025-01-27 |  |  |  |  |  |  | Design | DBT |  | 6.16 | Complete | Paul Pettitt | DAG | COMPLETE | T3-TE-0188 | T3 |  |  |  |
| 158 | 1.3.5 | **Queries Support / Knowledgebase & Tool Roll-Out (Systems)** | 325d | 2023-01-03 A | 2024-04-01 A |  | 100% |  | 2023-01-03 | 2024-04-01 | 325d | 2023-01-03 | 2024-04-01 |  |  |  | N/A | DBT |  | 5.0 |  | N/A |  |  |  |  | N/A | Design, Build & Test (PIT) |  |
| 159 | 1.3.5.1 | **Query Management** | 325d | 2023-01-03 A | 2024-04-01 A |  | 100% |  | 2023-01-03 | 2024-04-01 | 325d | 2023-01-03 | 2024-04-01 |  |  |  | N/A | DBT |  | 5.0 |  | N/A |  |  |  |  | N/A | Design, Build & Test (PIT) |  |
| 160 | 1.3.5.1.1 | Respond to Participant Queries | 325d | 2023-01-03 A | 2024-04-01 A |  | 100% |  | 2023-01-03 | 2024-04-01 | 325d | 2023-01-03 | 2024-04-01 |  | must start on 2023-01-03 |  | SI Design | DBT |  | 5.0 | Complete | Paul Pettitt |  | COMPLETE |  |  | PP | Design, Build & Test (PIT) | 11/8 - runs out to end of the programme |
| 161 | 1.3.5.1.2 | Respond to Programme Queries | 325d | 2023-01-03 A | 2024-04-01 A | 160SS | 100% |  | 2023-01-03 | 2024-04-01 | 325d | 2023-01-03 | 2024-04-01 |  |  |  | SI Design | DBT |  | 5.0 | Complete | Paul Pettitt |  | COMPLETE |  |  | PP | Design, Build & Test (PIT) | 11/8 - runs out to end of the programme |
| 162 | 1.3.5.2 | **Query Support tooling (FreshDesk)** | 23d | 2023-06-01 A | 2023-07-03 A |  | 100% |  | 2023-06-01 | 2023-07-03 | 23d | 2023-06-01 | 2023-07-03 |  |  |  | N/A | DBT |  | 5.0 |  | N/A |  |  |  |  | N/A | Design, Build & Test (PIT) |  |
| 163 | 1.3.5.2.1 | Migrate to Standalone Freshdesk | 10d | 2023-06-01 A | 2023-06-14 A |  | 100% |  | 2023-06-01 | 2023-06-14 | 10d | 2023-06-01 | 2023-06-14 |  | must start on 2023-06-01 |  | SI Design | DBT |  | 5.0 | Complete | Paul Pettitt |  | COMPLETE |  |  |  | Design, Build & Test (PIT) |  |
| 164 | 1.3.5.2.2 | Develop reporting dashboard | 5d | 2023-06-15 A | 2023-06-21 A | 163 | 100% |  | 2023-06-15 | 2023-06-21 | 5d | 2023-06-15 | 2023-06-21 |  |  |  | SI Design | DBT |  | 5.0 | Complete | Paul Pettitt |  | COMPLETE |  |  |  | Design, Build & Test (PIT) |  |
| 165 | 1.3.5.2.3 | Issue to SRO for Review | 5d | 2023-06-22 A | 2023-06-28 A | 164 | 100% |  | 2023-06-22 | 2023-06-28 | 5d | 2023-06-22 | 2023-06-28 |  |  |  | SI Design | DBT |  | 5.0 | Complete | Paul Pettitt |  | COMPLETE |  |  |  | Design, Build & Test (PIT) |  |
| 166 | 1.3.5.2.4 | Update following review | 2d | 2023-06-29 A | 2023-06-30 A | 165 | 100% |  | 2023-06-29 | 2023-06-30 | 2d | 2023-06-29 | 2023-06-30 |  |  |  | SI Design | DBT |  | 5.0 | Complete | Paul Pettitt |  | COMPLETE |  |  |  | Design, Build & Test (PIT) |  |
| 167 | 1.3.5.2.5 | Sign off | 1d | 2023-07-03 A | 2023-07-03 A | 166 | 100% |  | 2023-07-03 | 2023-07-03 | 1d | 2023-07-03 | 2023-07-03 |  |  |  | SI Design | DBT |  | 5.0 | Complete | Paul Pettitt |  | COMPLETE |  |  |  | Design, Build & Test (PIT) |  |
| 168 | 1.3.5.3 | **KnowledgeBase Development** | 72d | 2023-06-01 A | 2023-09-08 A |  | 100% |  | 2023-06-01 | 2023-09-08 | 72d | 2023-06-01 | 2023-09-08 |  |  |  | N/A | DBT |  | 5.0 |  | N/A |  |  |  |  | N/A | Design, Build & Test (PIT) |  |
| 169 | 1.3.5.3.1 | Define Scope of KB | 1d | 2023-06-01 A | 2023-06-01 A | 163SS | 100% |  | 2023-06-01 | 2023-06-01 | 1d | 2023-06-01 | 2023-06-01 |  |  |  | SI Design | DBT |  | 5.0 | Complete | Paul Pettitt |  | COMPLETE |  |  |  | Design, Build & Test (PIT) |  |
| 170 | 1.3.5.3.2 | Capture Existing KB artefacts | 20d | 2023-06-02 A | 2023-06-29 A | 169 | 100% |  | 2023-06-02 | 2023-06-29 | 20d | 2023-06-02 | 2023-06-29 |  |  |  | SI Design | DBT |  | 5.0 | Complete | Paul Pettitt |  | COMPLETE |  |  |  | Design, Build & Test (PIT) |  |
| 171 | 1.3.5.3.3 | Tag artefacts | 5d | 2023-06-30 A | 2023-07-06 A | 170 | 100% |  | 2023-06-30 | 2023-07-06 | 5d | 2023-06-30 | 2023-07-06 |  |  |  | SI Design | DBT |  | 5.0 | Complete | Paul Pettitt |  | COMPLETE |  |  |  | Design, Build & Test (PIT) |  |
| 172 | 1.3.5.3.4 | Develop Participant Interfaces | 20d | 2023-07-07 A | 2023-08-03 A | 171 | 100% |  | 2023-07-07 | 2023-08-03 | 20d | 2023-07-07 | 2023-08-03 |  |  |  | SI Design | DBT |  | 5.0 | Complete | Paul Pettitt |  | COMPLETE |  |  |  | Design, Build & Test (PIT) |  |
| 173 | 1.3.5.3.5 | Promote to Collaboration Portal | 21d | 2023-08-04 A | 2023-09-01 A | 172 | 100% |  | 2023-08-04 | 2023-09-01 | 21d | 2023-08-04 | 2023-09-01 |  |  |  | SI Design | DBT |  | 5.0 | Complete | Paul Pettitt |  | COMPLETE |  |  |  | Design, Build & Test (PIT) |  |
| 174 | 1.3.5.3.6 | Link into FreshDesk | 5d | 2023-09-04 A | 2023-09-08 A | 173 | 100% |  | 2023-09-04 | 2023-09-08 | 5d | 2023-09-04 | 2023-09-08 |  |  |  | SI Design | DBT |  | 5.0 | Complete | Paul Pettitt |  | COMPLETE |  |  |  | Design, Build & Test (PIT) |  |
| 175 | 1.3.6 | **PP Design, Build & Test (DBT)** | 1221d? | 2022-10-31 A | 2027-07-05 |  | 71% | 352.9d? | 2022-10-31 | 2027-07-05 | 495d | 2022-10-31 | 2026-02-16 | 123d |  | -0 | N/A | DBT |  | 5.0 |  | N/A |  |  |  |  | N/A | Design, Build & Test (PIT) |  |
| 176 | 1.3.6.1 | **PP Impact Assessment, Planning & Procurement** | 110d | 2022-10-31 A | 2023-03-31 A |  | 100% |  | 2022-10-31 | 2023-03-31 | 110d | 2022-10-31 | 2023-03-31 |  |  |  | N/A | DBT |  | 5.0 |  | N/A |  |  |  |  | N/A | Design, Build & Test (PIT) |  |
| 177 | 1.3.6.1.1 | **PP Impact Assessment** | 67d | 2022-10-31 A | 2023-01-31 A |  | 100% |  | 2022-10-31 | 2023-01-31 | 67d | 2022-10-31 | 2023-01-31 |  |  |  | N/A | DBT |  | 5.0 |  | N/A |  |  |  |  | N/A | Design, Build & Test (PIT) |  |
| 178 | 1.3.6.1.1.1 | Develop heatmap for impact of MHHS | 67d | 2022-10-31 A | 2023-01-31 A | 47 | 100% |  | 2022-10-31 | 2023-01-31 | 67d | 2022-10-31 | 2023-01-31 |  |  |  | PP | DBT |  | 5.0 | Complete | PP |  | COMPLETE |  |  |  | Design, Build & Test (PIT) |  |
| 179 | 1.3.6.1.1.2 | Develop detailed impact assessment | 67d | 2022-10-31 A | 2023-01-31 A | 47 | 100% |  | 2022-10-31 | 2023-01-31 | 67d | 2022-10-31 | 2023-01-31 |  |  |  | PP | DBT |  | 5.0 | Complete | PP |  | COMPLETE |  |  |  | Design, Build & Test (PIT) |  |

| ID | WBS | Task | Duration | Start | Finish | Predecessors | Complete | Remaining | Baseline start | Baseline finish | Baseline duration | Baseline 1 start | Baseline 1 finish | Total slack | Free slack | Constraint | Responsible | Involved | Text9 | Update Version | MHHS Resource Name | MHHS Programme Phase | Sched Status | RAG | Task Status |
| --- | --- | --- | --- | --- | --- | --- | --- | --- | --- | --- | --- | --- | --- | --- | --- | --- | --- | --- | --- | --- | --- | --- | --- | --- | --- |
| 180 | 1.3.6.1.2 | **PP Planning** | 67d | 2022-10-31 A | 2023-01-31 A |  | 100% |  | 2022-10-31 | 2023-01-31 | 67d | 2022-10-31 | 2023-01-31 |  |  |  | N/A | N/A | DBT | 5.0 | N/A | Design, Build & Test (PIT) |  |  |  |
| 181 | 1.3.6.1.2.1 | Develop detailed short-term plan | 23d | 2022-10-31 A | 2022-11-30 A | 47 | 100% |  | 2022-10-31 | 2022-11-30 | 23d | 2022-10-31 | 2022-11-30 |  |  |  | PP |  | DBT | 5.0 | PP | Design, Build & Test (PIT) | Complete | COMPLETE |  |
| 182 | 1.3.6.1.2.2 | Develop overall project plan for implementation | 67d | 2022-10-31 A | 2023-01-31 A | 47 | 100% |  | 2022-10-31 | 2023-01-31 | 67d | 2022-10-31 | 2023-01-31 |  |  |  | PP |  | DBT | 5.0 | PP | Design, Build & Test (PIT) | Complete | COMPLETE |  |
| 183 | 1.3.6.1.2.3 | Develop procurement plan | 67d | 2022-10-31 A | 2023-01-31 A | 47 | 100% |  | 2022-10-31 | 2023-01-31 | 67d | 2022-10-31 | 2023-01-31 |  |  |  | PP |  | DBT | 5.0 | PP | Design, Build & Test (PIT) | Complete | COMPLETE |  |
| 184 | 1.3.6.1.3 | **PP Software/Service Procurement** | 110d | 2022-10-31 A | 2023-03-31 A |  | 100% |  | 2022-10-31 | 2023-03-31 | 110d | 2022-10-31 | 2023-03-31 |  |  |  | N/A | N/A | DBT | 5.0 | N/A | Design, Build & Test (PIT) |  |  |  |
| 185 | 1.3.6.1.3.1 | Run tender process | 67d | 2022-10-31 A | 2023-01-31 A | 47 | 100% |  | 2022-10-31 | 2023-01-31 | 67d | 2022-10-31 | 2023-01-31 |  |  |  | PP |  | DBT | 5.0 | PP | Design, Build & Test (PIT) | Complete | COMPLETE |  |
| 186 | 1.3.6.1.3.2 | Select provider & sign commercials | 43d | 2023-02-01 A | 2023-03-31 A | 185 | 100% |  | 2023-02-01 | 2023-03-31 | 43d | 2023-02-01 | 2023-03-31 |  |  |  | PP |  | DBT | 5.0 | PP | Design, Build & Test (PIT) | Complete | COMPLETE |  |
| 187 | 1.3.6.2 | **Design Handover** | 850d? | 2024-04-02 A | 2027-07-05 |  | 4% | 814.54d? | 2024-09-02 | 2027-07-05 | 0d |  |  | 123d |  |  | Design |  | DBT | 6.1 | Helix |  | Overdue Start |  | -694.67 |
| 188 | 1.3.6.2.1 | **Creation of the Configuration Management Database** | 14d | 2024-09-02 A | 2024-09-19 A |  | 100% |  | 2024-09-02 | 2024-09-19 | 0d |  |  |  |  |  | Design |  | DBT | 6.1 | Helix |  | Overdue Start |  | -701.67 |
| 189 | 1.3.6.2.1.1 | Identify all baselined design artefacts | 9d | 2024-09-02 A | 2024-09-12 A |  | 100% |  | 2024-09-02 | 2024-09-12 | 0d |  |  |  |  | start no earlier than 2024-09-02 | Design |  | DBT | 6.1 | Helix |  | Complete | COMPLETE |  |
| 190 | 1.3.6.2.1.2 | Create CMBD | 5d | 2024-09-13 A | 2024-09-19 A | 189 | 100% |  | 2024-09-13 | 2024-09-19 | 0d |  |  |  |  |  | Design |  | DBT | 6.1 | Helix |  | Complete | COMPLETE |  |
| 191 | 1.3.6.2.2 | **Knowledge Transfer** | 86d? | 2025-01-06 A | 2025-05-05 |  | 10% | 77d? | 2024-09-02 | 2024-10-28 | 0d |  |  | 688d |  |  | Design |  | DBT | 6.17 | Helix |  | Overdue Start | RED | -701.67 |
| 192 | 1.3.6.2.2.1 | Elexon to document knowledge transfer requirements | 4d | 2025-01-06 A | 2025-01-09 A |  | 100% |  | 2024-09-02 | 2024-09-12 | 0d |  |  |  |  | start no earlier than 2024-09-02 | Design |  | DBT | 6.17 | Helix |  | Complete | COMPLETE |  |
| 193 | 1.3.6.2.2.2 | Review Requirements | 5d | 2025-01-10 A | 2025-01-16 A | 192 | 100% |  | 2024-09-13 | 2024-09-19 | 0d |  |  |  |  |  | Design |  | DBT | 6.17 | Paul Pettitt |  | Complete | COMPLETE |  |
| 194 | 1.3.6.2.2.3 | Agree Success Criteria | 31d | 2025-01-17 | 2025-02-28 | 193 |  |  | 2024-09-20 | 2024-10-03 | 0d |  |  | 688d | 0d |  | Design |  | DBT | 6.17 | Helix / Paul Pettitt |  | Red | RED | -11.67 |
| 195 | 1.3.6.2.2.4 | Identify Key personel with Elexon | 3d | 2025-03-03 | 2025-03-05 | 194 |  |  | 2024-10-04 | 2024-10-08 | 0d |  |  | 688d | 0d |  | Design |  | DBT | 6.17 | Helix |  | Red | RED | 33.33 |
| 196 | 1.3.6.2.2.5 | Draft Agenda for initial meeting | 1d? | 2025-03-06 | 2025-03-06 | 195 |  |  | 2024-10-09 | 2024-10-09 | 0d |  |  | 688d | 0d |  | Design |  | DBT | 6.17 | Helix |  | Red | RED | 36.33 |
| 197 | 1.3.6.2.2.6 | Define cadence for handover sessions | 2d | 2025-03-07 | 2025-03-10 | 196 |  |  | 2024-10-10 | 2024-10-11 | 0d |  |  | 688d | 0d |  | Design |  | DBT | 6.17 | Helix |  | Red | RED | 37.33 |
| 198 | 1.3.6.2.2.7 | Share Design Information | 20d | 2025-03-11 | 2025-04-07 | 197 |  |  | 2024-09-02 | 2024-09-27 | 0d |  |  | 688d | 0d | start no earlier than 2024-09-02 | Design |  | DBT | 6.17 | Helix / Paul Pettitt |  | Red | RED | 41.33 |
| 199 | 1.3.6.2.2.8 | Conduct Initial Handover Session | 20d? | 2025-04-08 | 2025-05-05 | 198 |  |  | 2024-10-01 | 2024-10-28 | 0d |  |  | 688d |  | start no earlier than 2024-10-01 | Design |  | DBT | 6.17 | Helix |  | Red | RED | 69.33 |
| 200 | 1.3.6.2.3 | **Triage Sessions** | 391d | 2024-04-02 | 2025-09-30 |  |  |  | 2024-10-01 | 2025-04-01 | 0d |  |  | 582d |  |  | Design |  | DBT | 6.17 | Helix |  | Overdue Start | RED | -701.67 |
| 201 | 1.3.6.2.3.1 | Design Triage Sessions | 261d | 2024-10-01 | 2025-09-30 |  |  |  | 2024-10-01 | 2025-09-30 | 0d |  |  | 582d |  | start no earlier than 2024-10-01 | Design |  | DBT | 6.17 | Helix |  | Overdue Start | GREEN | -119.67 |
| 202 | 1.3.6.2.3.2 | Test Triage Sessions | 261d | 2024-04-02 | 2025-04-01 |  |  |  | 2024-10-01 | 2025-04-01 | 0d |  |  | 712d |  | finish no earlier than 2025-04-01 | Design |  | DBT | 6.17 | Helix |  | Overdue Start | GREEN | -301.67 |
| 203 | 1.3.6.2.4 | **Knowledge Base** | 9d | 2024-09-02 A | 2024-09-12 A |  | 100% |  | 2024-09-02 | 2024-09-12 | 0d |  |  |  |  |  | Design |  | DBT | 6.1 | Helix |  | Overdue Start | COMPLETE | -701.67 |
| 204 | 1.3.6.2.4.1 | Document Knowledge base update process | 4d | 2024-09-02 A | 2024-09-05 A |  | 100% |  | 2024-09-02 | 2024-09-05 | 0d |  |  |  |  | start no earlier than 2024-09-02 | Design |  | DBT | 6.1 | Helix |  | Complete | COMPLETE |  |
| 205 | 1.3.6.2.4.2 | Document Design updates to Collaboration Base | 5d | 2024-09-06 A | 2024-09-12 A |  | 100% |  | 2024-09-06 | 2024-09-12 | 0d |  |  |  |  | start no earlier than 2024-09-06 | Design |  | DBT | 6.1 | Helix |  | Complete | COMPLETE |  |

Notes:
- 193: 27/01/25 - Design Handover activities dependent on Helix completing an action before they can be progressed.
- 194: 27/01/25 - Design Handover activities dependent on Helix completing an action before they can be progressed.
- 195: 27/01/25 - Design Handover activities dependent on Helix completing an action before they can be progressed.
- 196: 27/01/25 - Design Handover activities dependent on Helix completing an action before they can be progressed.
- 197: 27/01/25 - Design Handover activities dependent on Helix completing an action before they can be progressed.
- 198: 27/01/25 - Design Handover activities dependent on Helix completing an action before they can be progressed.
- 199: 27/01/25 - Design Handover activities dependent on Helix completing an action before they can be progressed.

| ID | WBS | Task | Type | Duration | Start | Finish | Predecessors | Complete | Baseline start | Baseline finish | Baseline duration | Baseline 1 start | Baseline 1 finish | Total slack | Free slack | Constraint | Baseline cost | Responsible | Text9 | Task Status | Update Version | Sched Status | MHHS Resource Name | RAG | Involved | MHHS Programme Phase | Milestone ID | Text29 | Tier |
| --- | --- | --- | --- | --- | --- | --- | --- | --- | --- | --- | --- | --- | --- | --- | --- | --- | --- | --- | --- | --- | --- | --- | --- | --- | --- | --- | --- | --- | --- |
| 206 | 1.3.6.2.5 | **FreshDesk** |  | 26d? | 2025-08-20 | 2025-09-24 |  |  | 2025-08-20 | 2025-09-24 | 0d |  |  | 586d |  |  |  | Design | DBT | -701.67 | 6.17 | Overdue Start | Helix / Paul Pettitt | GREEN |  |  |  |  |  |
| 207 | 1.3.6.2.5.1 | Agree Indicative Handover of FreshDesk Calls to Service Now |  | 4d | 2025-08-20 | 2025-08-25 |  |  | 2025-08-20 | 2025-08-25 | 0d |  |  | 586d | 0d | start no earlier than 2025-08-20 |  | Design | DBT | 203.33 | 6.17 | Green | Helix | GREEN |  |  |  |  |  |
| 208 | 1.3.6.2.5.2 | Prepare Comms to Industry |  | 10d | 2025-08-26 | 2025-09-08 | 207 |  | 2025-08-26 | 2025-09-08 | 0d |  |  | 586d | 0d | start no earlier than 2025-02-07 |  | Design | DBT | 209.33 | 6.17 | Green | Paul Pettitt | GREEN |  |  |  |  |  |
| 209 | 1.3.6.2.5.3 | Issue Comms to Industry |  | 1d? | 2025-09-09 | 2025-09-09 | 208 |  | 2025-09-09 | 2025-09-09 | 0d |  |  | 586d | 0d | start no earlier than 2025-02-21 |  | Design | DBT | 223.33 | 6.17 | Green | Paul Pettitt | GREEN |  |  |  |  |  |
| 210 | 1.3.6.2.5.4 | Redirect Design Mailbox to Service Now |  | 1d? | 2025-09-10 | 2025-09-10 | 209 |  | 2025-09-10 | 2025-09-10 | 0d |  |  | 586d | 0d | start no earlier than 2025-03-03 |  | Design | DBT | 224.33 | 6.17 | Green | Paul Pettitt | GREEN |  |  |  |  |  |
| 211 | 1.3.6.2.5.5 | Archive Freshdesk calls |  | 5d | 2025-09-11 | 2025-09-17 | 210 |  | 2025-09-11 | 2025-09-17 | 0d |  |  | 586d | 0d | start no earlier than 2025-03-03 |  | Design | DBT | 225.33 | 6.17 | Green | Paul Pettitt | GREEN |  |  |  |  |  |
| 212 | 1.3.6.2.5.6 | Decommission FreshDesk |  | 5d | 2025-09-18 | 2025-09-24 | 211 |  | 2025-09-18 | 2025-09-24 | 0d |  |  | 586d |  | start no earlier than 2025-03-10 |  | Design | DBT | 232.33 | 6.17 | Green | Paul Pettitt | GREEN |  |  |  |  |  |
| 213 | 1.3.6.2.6 | **iServer** |  | 611d? | 2025-03-03 | 2027-07-05 |  |  | 2025-03-03 | 2027-07-05 | 0d |  |  |  |  |  |  | Design | DBT | -701.67 | 6.17 | Overdue Start | Paul Pettitt | GREEN |  |  |  |  |  |
| 214 | 1.3.6.2.6.1 | Gather Licensing information |  | 88d? | 2025-03-03 | 2025-07-02 |  |  | 2025-03-03 | 2025-07-02 | 0d |  |  | 604d | 0d | start no earlier than 2025-03-03 |  | Design | DBT | 33.33 | 6.17 | Green | Paul Pettitt | GREEN |  |  |  |  |  |
| 215 | 1.3.6.2.6.2 | Inform Orbus of iServer support termination |  | 1d? | 2025-07-03 | 2025-07-03 | 214 |  | 2026-02-05 | 2026-02-05 |  |  |  | 604d | 0d |  |  | Design | DBT | 155.33 | 6.17 | Green | Paul Pettitt | GREEN |  |  |  |  |  |
| 216 | 1.3.6.2.6.3 | Produce iServer decomissioning pack |  | 4d | 2025-07-04 | 2025-07-09 | 215 |  | 2026-02-06 | 2026-02-11 |  |  |  | 604d | 0d |  |  | Design | DBT | 156.33 | 6.17 | Green | Paul Pettitt | GREEN |  |  |  |  |  |
| 217 | 1.3.6.2.6.4 | TORWG paper day |  | 1d? | 2025-07-31 | 2025-07-31 | 216FS+15d |  | 2026-03-05 | 2026-03-05 |  |  |  | 604d | 0d |  |  | Design | DBT | 183.33 | 6.17 | Green | Paul Pettitt | GREEN |  |  |  |  |  |
| 218 | 1.3.6.2.6.5 | TORWG updated on iServer |  | 1d? | 2025-08-08 | 2025-08-08 | 217FS+5d |  | 2026-03-13 | 2026-03-13 |  |  |  | 604d | 0d |  |  | Design | DBT | 191.33 | 6.17 | Green | Paul Pettitt | GREEN |  |  |  |  |  |
| 219 | 1.3.6.2.6.6 | Clear down old information |  | 1d? | 2025-08-11 | 2025-08-11 | 218 |  | 2025-08-11 | 2025-08-11 | 0d |  |  | 604d | 0d |  |  | Design | DBT | 194.33 | 6.17 | Green | Paul Pettitt | GREEN |  |  |  |  |  |
| 220 | 1.3.6.2.6.7 | Clear down accounts |  | 2d | 2025-08-12 | 2025-08-13 | 219 |  | 2025-08-12 | 2025-08-13 | 0d |  |  | 604d | 0d | start no earlier than 2025-03-10 |  | Design | DBT | 195.33 | 6.17 | Green | Paul Pettitt | GREEN |  |  |  |  |  |
| 221 | 1.3.6.2.6.8 | Identify Collaboration Base Design Dependencies on iServer |  | 2d | 2025-08-14 | 2025-08-15 | 220 |  | 2025-08-14 | 2025-08-15 | 0d |  |  | 604d | 0d | start no earlier than 2025-04-01 |  | Design | DBT | 197.33 | 6.17 | Green | Paul Pettitt | GREEN |  |  |  |  |  |
| 222 | 1.3.6.2.6.9 | Remove Design dependencies |  | 5d | 2025-08-18 | 2025-08-22 | 221 |  | 2025-08-18 | 2025-08-22 | 0d |  |  | 604d | 0d | start no earlier than 2025-04-03 |  | Design | DBT | 201.33 | 6.17 | Green | Paul Pettitt | GREEN |  |  |  |  |  |
| 223 | 1.3.6.2.6.10 | Close down iServer |  | 5d | 2025-08-25 | 2025-08-29 | 222 |  | 2025-08-25 | 2025-08-29 | 0d |  |  | 604d |  | start no earlier than 2025-04-10 |  | Design | DBT | 208.33 | 6.17 | Green | Paul Pettitt | GREEN |  |  |  |  |  |
| 224 | 1.3.6.3 | **Central Systems DBT** |  | 325d | 2022-10-31 A | 2024-01-26 A |  | 100% | 2022-10-31 | 2024-01-26 | 345d | 2022-10-31 | 2024-05-13 |  |  |  | -0 | N/A | DBT | -316.67 | 5.0 |  | N/A |  | N/A | Design, Build & Test (PIT) |  |  |  |
| 225 | 1.3.6.3.1 | **Elexon Central Systems DBT CIT (Entering at Interval 1)** |  | 248d | 2022-10-31 A | 2023-10-11 A |  | 100% | 2022-10-31 | 2023-10-11 | 249d | 2022-10-31 | 2023-09-29 |  |  |  | -0 | N/A | DBT |  | 5.0 |  | N/A |  | N/A | Design, Build & Test (PIT) |  |  |  |
| 226 | 1.3.6.3.1.1 | **Design and Build** |  | 235d | 2022-10-31 A | 2023-09-22 A |  | 100% | 2022-10-31 | 2023-09-22 | 240d | 2022-10-31 | 2023-09-29 |  |  |  |  | N/A | DBT | -259.67 | 5.0 |  | N/A |  | N/A | Design, Build & Test (PIT) |  |  |  |
| 227 | 1.3.6.3.1.1.1 | Helix Design and Build |  | 235d | 2022-10-31 A | 2023-09-22 A | 2 | 100% | 2022-10-31 | 2023-09-22 | 240d | 2022-10-31 | 2023-09-29 |  |  |  |  | PP | DBT |  | 5.0 | Complete |  | COMPLETE | SI Test | Design, Build & Test (PIT) |  |  |  |
| 228 | 1.3.6.3.1.2 | **Test Approach & Plan** |  | 235d | 2022-10-31 A | 2023-09-22 A |  | 100% | 2022-10-31 | 2023-09-22 | 235d | 2022-10-31 | 2023-07-21 |  |  |  | -0 | N/A | DBT |  | 5.0 |  | N/A |  | N/A | Design, Build & Test (PIT) |  |  |  |
| 229 | 1.3.6.3.1.2.1 | Develop Test Approach & Plan |  | 180d | 2022-10-31 A | 2023-07-07 A |  | 100% | 2022-10-31 | 2023-07-07 | 180d | 2022-10-31 | 2023-07-07 |  |  |  |  | PP | DBT |  | 5.0 | Complete |  | COMPLETE | SI Test | Design, Build & Test (PIT) |  |  |  |
| 230 | 1.3.6.3.1.2.2 | Elexon Central Systems Test Approach & Plan (PIT) submitted to Programme for assurance | milestone | 0d | 2023-07-13 A | 2023-07-13 A | 229FF+4d | 100% | 2023-07-13 | 2023-07-13 | 0d | 2023-07-07 | 2023-07-07 |  |  |  |  | PP | DBT |  | 5.0 | Complete |  | COMPLETE | SI Test | Design, Build & Test (PIT) | T3-DB-0029 | SITAG | T3 |
| 231 | 1.3.6.3.1.2.3 | Elexon Central Systems Test Approach & Plan (PIT) V2 resubmitted to Programme for assurance | milestone, manual | 0d | 2023-07-27 A | 2023-07-27 A | 230FS+9d | 100% | 2023-07-27 | 2023-07-27 | 0d |  |  |  |  |  |  | PP | DBT |  | 5.4 | Complete |  | COMPLETE | SI Test | Design, Build & Test (PIT) |  |  |  |
| 232 | 1.3.6.3.1.2.4 | Elexon Central Systems Test Approach & Plan (PIT) V3 resubmitted to Programme for assurance | milestone | 0d | 2023-08-18 A | 2023-08-18 A | 231FS+17d | 100% | 2023-08-18 | 2023-08-18 | 0d |  |  |  |  |  |  | PP | DBT |  | 5.4 | Complete |  | COMPLETE | SI Test | Design, Build & Test (PIT) |  |  |  |
| 233 | 1.3.6.3.1.2.5 | Elexon Central Systems Test approach and plan MHHS Review Completed | milestone | 0d | 2023-09-22 A | 2023-09-22 A | 232FS+25d | 100% | 2023-09-22 | 2023-09-22 | 0d | 2023-07-10 | 2023-07-21 |  |  |  |  | SI Test | DBT |  | 5.8 | Complete |  | COMPLETE | PP | Design, Build & Test (PIT) | T3-DB-0106 | SITAG | T3 |

Notes:
- 207: 27/01/25 - Timelines updated so that the activity takes place leading into M10.
- 208: 27/01/25 - Timelines updated so that the activity takes place leading into M10.
- 209: 27/01/25 - Timelines updated so that the activity takes place leading into M10.
- 210: 27/01/25 - Timelines updated so that the activity takes place leading into M10.
- 211: 27/01/25 - Timelines updated so that the activity takes place leading into M10.
- 212: 27/01/25 - Timelines updated so that the activity takes place leading into M10.
- 217: 27/01/25 - Programme to confirm whether this needs to go to TORWG or not.
- 218: 27/01/25 - Programme to confirm whether this needs to go to TORWG or not.

| ID | WBS | Task | Type | Duration | Start | Finish | Predecessors | Complete | Baseline start | Baseline finish | Baseline duration | Baseline 1 start | Baseline 1 finish | Constraint | Baseline cost | Responsible | Involved | Text9 | Update Version | MHHS Resource Name | MHHS Programme Phase | Sched Status | RAG | Artefact ID | Milestone ID | Text29 | Tier |
| --- | --- | --- | --- | --- | --- | --- | --- | --- | --- | --- | --- | --- | --- | --- | --- | --- | --- | --- | --- | --- | --- | --- | --- | --- | --- | --- | --- |
| 234 | 1.3.6.3.1.3 | **Test Readiness Report** |  | 16d | 2023-07-28 A | 2023-08-18 A |  | 100% | 2023-07-28 | 2023-08-18 | 51d | 2023-07-21 | 2023-09-29 |  |  | N/A | N/A | DBT | 5.0 | N/A | Design, Build & Test (PIT) |  |  |  |  |  |  |
| 235 | 1.3.6.3.1.3.1 | Test readiness reporting |  | 16d | 2023-07-28 A | 2023-08-18 A | 230FS+10d | 100% | 2023-07-28 | 2023-08-18 | 51d | 2023-07-21 | 2023-09-29 |  |  | PP | 109 | DBT | 5.0 |  | Design, Build & Test (PIT) | Complete | COMPLETE |  |  |  |  |
| 236 | 1.3.6.3.1.4 | **Requirements to test Traceability Matrix (RTTM)** |  | 35d | 2023-08-04 A | 2023-09-22 A |  | 100% | 2023-08-04 | 2023-09-22 | 35d | 2022-10-31 | 2023-08-18 |  | -0 | N/A | N/A | DBT | 5.0 | N/A | Design, Build & Test (PIT) |  |  |  |  |  |  |
| 237 | 1.3.6.3.1.4.1 | Elexon Central Systems RTTM submitted to Programme for assurance | milestone | 0d | 2023-08-04 A | 2023-08-04 A | 230 | 100% | 2023-08-04 | 2023-08-04 | 0d | 2023-08-04 | 2023-08-04 | start no earlier than 2023-04-28 |  | PP | SI Test | DBT | 5.0 |  | Design, Build & Test (PIT) | Complete | COMPLETE | MHHS-ART009 | T3-DB-0030 | SITAG | T3 |
| 238 | 1.3.6.3.1.4.2 | Elexon Central Systems RTTM MHHS Review Completed | milestone | 0d | 2023-09-22 A | 2023-09-22 A | 237FS+35d | 100% | 2023-09-22 | 2023-09-22 | 0d | 2023-08-07 | 2023-08-18 |  |  | SI Test | PP | DBT | 5.8 |  | Design, Build & Test (PIT) | Complete | COMPLETE |  | T3-DB-0107 | SITAG | T3 |
| 239 | 1.3.6.3.1.5 | **Test Scenarios** |  | 35d | 2023-08-04 A | 2023-09-22 A |  | 100% | 2023-08-04 | 2023-09-22 | 35d | 2022-10-31 | 2023-08-18 |  | -0 | N/A | N/A | DBT | 5.0 | N/A | Design, Build & Test (PIT) |  |  |  |  |  |  |
| 240 | 1.3.6.3.1.5.1 | Elexon Central Systems test scenarios submitted to Programme for assurance | milestone | 0d | 2023-08-04 A | 2023-08-04 A | 230 | 100% | 2023-08-04 | 2023-08-04 | 0d | 2023-08-04 | 2023-08-04 |  |  | PP | SI Test | DBT | 5.0 |  | Design, Build & Test (PIT) | Complete | COMPLETE |  | T3-DB-0032 | SITAG | T3 |
| 241 | 1.3.6.3.1.5.2 | Elexon Central Systems Test scenarios MHHS Review Completed | milestone | 0d | 2023-09-22 A | 2023-09-22 A | 240FS+35d | 100% | 2023-09-22 | 2023-09-22 | 0d | 2023-08-07 | 2023-08-18 |  |  | SI Test | PP | DBT | 5.8 |  | Design, Build & Test (PIT) | Complete | COMPLETE |  | T3-DB-0108 | SITAG | T3 |
| 242 | 1.3.6.3.1.6 | **PIT Execution** |  | 38d | 2023-08-21 A | 2023-10-11 A |  | 100% | 2023-08-21 | 2023-10-11 | 248d | 2022-10-31 | 2023-09-29 |  | -0 | N/A | N/A | DBT | 5.0 | N/A | Design, Build & Test (PIT) |  |  |  |  |  |  |
| 243 | 1.3.6.3.1.6.1 | PIT Test Execution Progress Report |  | 18d | 2023-09-04 A | 2023-09-27 A | 235FS+10d | 100% | 2023-09-04 | 2023-09-27 | 235d | 2022-10-31 | 2023-09-22 |  |  | PP | SI Test | DBT | 5.1 |  | Design, Build & Test (PIT) | Complete | COMPLETE |  |  |  |  |
| 244 | 1.3.6.3.1.6.2 | Elexon Central Systems PIT Execution |  | 28d | 2023-08-21 A | 2023-09-27 A | 235 | 100% | 2023-08-21 | 2023-09-27 | 240d | 2022-10-31 | 2023-09-29 |  |  | PP | SI Test | DBT | 5.1 |  | Design, Build & Test (PIT) | Complete | COMPLETE |  |  |  |  |
| 245 | 1.3.6.3.1.6.3 | Elexon Central Systems PIT Completion Report submitted to Programme for assurance | milestone | 0d | 2023-09-27 A | 2023-09-27 A | 244 | 100% | 2023-09-27 | 2023-09-27 | 0d | 2024-01-05 | 2024-01-05 |  |  | PP | SI Test | DBT | 5.8 |  | Design, Build & Test (PIT) | Complete | COMPLETE |  | T3-DB-0109 | SITAG | T3 |
| 246 | 1.3.6.3.1.6.4 | Elexon Central Systems PIT Completion Report MHHS Review Completed | milestone | 0d | 2023-10-11 A | 2023-10-11 A | 238, 241, 243, 245FS+10d, 233 | 100% | 2023-10-11 | 2023-10-11 | 0d |  |  |  |  | SI Test | PP | DBT | 5.8 |  | Design, Build & Test (PIT) | Complete | COMPLETE |  | T3-DB-0110 | SITAG | T3 |
| 247 | 1.3.6.3.2 | **DIP DBT CIT (Entering at Interval 1)** |  | 221d | 2023-01-02 A | 2023-11-06 A |  | 100% | 2023-01-02 | 2023-11-06 | 266d | 2022-10-31 | 2023-09-29 |  | -0 | N/A | N/A | DBT | 5.0 | N/A | Design, Build & Test (PIT) |  |  |  |  |  |  |
| 248 | 1.3.6.3.2.1 | Design |  | 80d | 2023-01-02 A | 2023-04-21 A |  | 100% | 2023-01-02 | 2023-04-21 | 80d | 2023-01-02 | 2023-04-21 | must start on 2023-01-02 |  | PP | SI Design | DBT | 5.0 |  | Design, Build & Test (PIT) | Complete | COMPLETE |  |  |  |  |
| 249 | 1.3.6.3.2.2 | Build |  | 155d | 2023-01-09 A | 2023-08-11 A | 248SS+5d | 100% | 2023-01-09 | 2023-08-11 | 155d | 2023-01-09 | 2023-08-11 |  |  | PP |  | DBT | 5.5 |  | Design, Build & Test (PIT) | Complete | COMPLETE |  |  |  |  |
| 250 | 1.3.6.3.2.3 | **Test Approach & Plan** |  | 9d | 2023-07-07 A | 2023-07-20 A |  | 100% | 2023-07-07 | 2023-07-20 | 190d | 2022-10-31 | 2023-07-21 |  |  | N/A | N/A | DBT | 5.0 | N/A | Design, Build & Test (PIT) |  |  |  |  |  |  |
| 251 | 1.3.6.3.2.3.1 | DIP Test Approach & Plan (PIT) submitted to Programme for assurance | milestone | 0d | 2023-07-07 A | 2023-07-07 A |  | 100% | 2023-07-07 | 2023-07-07 | 0d | 2023-07-07 | 2023-07-07 |  |  | PP | SI Test | DBT | 5.0 |  | Design, Build & Test (PIT) | Complete | COMPLETE | MHHS-ART073 | T3-DB-0026 | SITAG | T3 |
| 252 | 1.3.6.3.2.3.2 | DIP Test Approach & Plan (PIT) MHHS Review Completed | milestone | 0d | 2023-07-20 A | 2023-07-20 A | 251FS+9d | 100% | 2023-07-20 | 2023-07-20 | 10d | 2023-07-10 | 2023-07-21 |  |  | SI Test | PP | DBT | 5.0 |  | Design, Build & Test (PIT) | Complete | COMPLETE |  |  |  |  |
| 253 | 1.3.6.3.2.4 | **PIT Test Readiness Report** |  | 31d | 2023-07-21 A | 2023-09-01 A |  | 100% | 2023-07-21 | 2023-09-01 | 51d | 2023-07-21 | 2023-09-29 |  |  | N/A | N/A | DBT | 5.0 | N/A | Design, Build & Test (PIT) |  |  |  |  |  |  |
| 254 | 1.3.6.3.2.4.1 | Test readiness reporting |  | 31d | 2023-07-21 A | 2023-09-01 A | 251FS+9d | 100% | 2023-07-21 | 2023-09-01 | 51d | 2023-07-21 | 2023-09-29 |  |  | SI Test | 109 | DBT | 5.0 |  | Design, Build & Test (PIT) | Complete | COMPLETE |  |  |  |  |
| 255 | 1.3.6.3.2.5 | **Requirements to test Traceability Matrix (RTTM)** |  | 18d | 2023-08-04 A | 2023-08-30 A |  | 100% | 2023-08-04 | 2023-08-30 | 210d | 2022-10-31 | 2023-08-18 |  |  | N/A | N/A | DBT | 5.0 | N/A | Design, Build & Test (PIT) |  |  |  |  |  |  |
| 256 | 1.3.6.3.2.5.1 | DIP RTTM submitted to Programme for assurance | milestone | 0d | 2023-08-04 A | 2023-08-04 A | 251FS+15d | 100% | 2023-08-04 | 2023-08-04 | 0d | 2023-08-04 | 2023-08-04 |  |  | PP | SI Test | DBT | 5.6 |  | Design, Build & Test (PIT) | Complete | COMPLETE | MHHS-ART009 | T3-DB-0034 | SITAG | T3 |
| 257 | 1.3.6.3.2.5.2 | DIP RTTM MHHS Review Completed | milestone | 0d | 2023-08-30 A | 2023-08-30 A | 256FS+18d | 100% | 2023-08-30 | 2023-08-30 | 10d | 2023-08-07 | 2023-08-18 |  |  | SI Test | PP | DBT | 5.0 |  | Design, Build & Test (PIT) | Complete | COMPLETE |  |  |  |  |

Notes:
- 254: Action: 14/8 - Query from RG - IS this an SI Test deliverable or expected to be a DIP deliverable if so be more specific

| ID | WBS | Task | Type | Duration | Start | Finish | Predecessors | Complete | Baseline start | Baseline finish | Baseline duration | Baseline 1 start | Baseline 1 finish | Constraint | Baseline cost | Responsible | Involved | Text9 | Update Version | MHHS Resource Name | MHHS Programme Phase | Sched Status | RAG | Milestone ID | Text29 | Tier |
| --- | --- | --- | --- | --- | --- | --- | --- | --- | --- | --- | --- | --- | --- | --- | --- | --- | --- | --- | --- | --- | --- | --- | --- | --- | --- | --- |
| 258 | 1.3.6.3.2.6 | **Test Scenarios** |  | 22d | 2023-07-31 A | 2023-08-30 A |  | 100% | 2023-07-31 | 2023-08-30 | 206d | 2022-10-31 | 2023-08-18 |  |  | N/A | N/A | DBT | 5.0 | N/A | Design, Build & Test (PIT) |  |  |  |  |  |
| 259 | 1.3.6.3.2.6.1 | DIP PIT test scenarios submitted to Programme for assurance | milestone | 0d | 2023-07-31 A | 2023-07-31 A | 251FS+15d | 100% | 2023-07-31 | 2023-07-31 | 0d | 2023-08-04 | 2023-08-04 |  |  | PP | SI Test | DBT | 5.0 |  | Design, Build & Test (PIT) | Complete | COMPLETE | T3-DB-0036 | SITAG | T3 |
| 260 | 1.3.6.3.2.6.2 | DIP Test scenarios MHHS Review Completed | milestone | 0d | 2023-08-30 A | 2023-08-30 A | 259FS+22d | 100% | 2023-08-30 | 2023-08-30 | 10d | 2023-08-07 | 2023-08-18 |  |  | SI Test | PP | DBT | 5.0 |  | Design, Build & Test (PIT) | Complete | COMPLETE |  |  |  |
| 261 | 1.3.6.3.2.7 | **PIT execution** |  | 50d | 2023-08-29 A | 2023-11-06 A |  | 100% | 2023-08-29 | 2023-11-06 | 47d | 2022-10-31 | 2023-09-29 |  | -0 | N/A | N/A | DBT | 5.0 | N/A | Design, Build & Test (PIT) |  |  |  |  |  |
| 262 | 1.3.6.3.2.7.1 | PIT Test Execution Progress Report |  | 37d | 2023-09-01 A | 2023-10-23 A | 263FF, 254 | 100% | 2023-09-01 | 2023-10-23 | 37d | 2022-10-31 | 2023-09-22 | start no earlier than 2023-08-29 |  | PP | SI Test | DBT | 5.6 |  | Design, Build & Test (PIT) | Complete | COMPLETE |  |  |  |
| 263 | 1.3.6.3.2.7.2 | PIT Execution (Interim Release 1) |  | 30d | 2023-08-29 A | 2023-10-09 A |  | 100% | 2023-08-29 | 2023-10-09 | 24d | 2022-10-31 | 2023-09-29 | start no earlier than 2023-08-29 |  | PP | SI Test | DBT | 5.6 |  | Design, Build & Test (PIT) | Complete | COMPLETE |  |  |  |
| 264 | 1.3.6.3.2.7.3 | PIT Execution (Interim Release 2) |  | 10d | 2023-10-10 A | 2023-10-23 A | 263 | 100% | 2023-10-10 | 2023-10-23 | 10d |  |  |  |  | PP | SI Test | DBT | 5.6 |  | Design, Build & Test (PIT) | Complete | COMPLETE |  |  |  |
| 265 | 1.3.6.3.2.7.4 | DIP PIT Completion Report (Interim Release 1) submitted to Programme for assurance | milestone | 0d | 2023-10-09 A | 2023-10-09 A | 263 | 100% | 2023-10-09 | 2023-10-09 | 0d | 2024-01-05 | 2024-01-05 |  |  | PP | SI Test | DBT | 5.8 |  | Design, Build & Test (PIT) | Complete | COMPLETE | T3-DB-0111 | SITAG | T3 |
| 266 | 1.3.6.3.2.7.5 | DIP PIT Completion Report (Interim Release 1) MHHS Review Completed | milestone | 0d | 2023-10-23 A | 2023-10-23 A | 265FS+10d | 100% | 2023-10-23 | 2023-10-23 | 0d |  |  |  |  | SI Test | SI Test | DBT | 5.10 |  | Design, Build & Test (PIT) | Complete | COMPLETE | T3-DB-0112 | SITAG | T3 |
| 267 | 1.3.6.3.2.7.6 | DIP PIT Completion Report (Interim Release 2) submitted to Programme for assurance | milestone | 0d | 2023-10-23 A | 2023-10-23 A | 264, 262 | 100% | 2023-10-23 | 2023-10-23 | 0d | 2024-01-05 | 2024-01-05 |  |  | PP | SI Test | DBT | 5.10 |  | Design, Build & Test (PIT) | Complete | COMPLETE | T3-DB-0113 | SITAG | T3 |
| 268 | 1.3.6.3.2.7.7 | DIP PIT Completion Report (Interim Release 2) MHHS Review Completed | milestone | 0d | 2023-11-06 A | 2023-11-06 A | 267FS+10d | 100% | 2023-11-06 | 2023-11-06 | 0d |  |  |  |  | SI Test | SI Test | DBT | 5.14 |  | Design, Build & Test (PIT) | Complete | COMPLETE | T3-DB-0114 | SITAG | T3 |
| 269 | 1.3.6.3.3 | **DCC (DSP) DBT SIT Functional (Entering at SIT Functional)** |  | 325d | 2022-10-31 A | 2024-01-26 A |  | 100% | 2022-10-31 | 2024-01-26 | 345d | 2022-10-31 | 2024-01-05 |  | -0 | N/A | N/A | DBT | 5.18 | N/A | Design, Build & Test (PIT) |  |  |  |  |  |
| 270 | 1.3.6.3.3.1 | Design |  | 67d | 2022-10-31 A | 2023-01-31 A |  | 100% | 2022-10-31 | 2023-01-31 | 67d | 2022-10-31 | 2023-01-31 |  |  | PP | SI Design | DBT | 5.18 |  | Design, Build & Test (PIT) | Complete | COMPLETE |  |  |  |
| 271 | 1.3.6.3.3.2 | **Test Approach & Plan** |  | 20d | 2023-11-17 A | 2023-12-15 A |  | 100% | 2023-11-17 | 2023-12-15 | 20d | 2022-10-31 | 2023-10-27 |  | -0 | N/A | N/A | DBT | 5.18 | N/A | Design, Build & Test (PIT) |  |  |  |  |  |
| 272 | 1.3.6.3.3.2.1 | DCC Test Approach & Plan (PIT) submitted to Programme for assurance | milestone | 0d | 2023-11-17 A | 2023-11-17 A | 270FS+208d | 100% | 2023-11-17 | 2023-11-17 | 0d | 2023-10-13 | 2023-10-13 |  |  | PP | SI Test | DBT | 5.18 |  | Design, Build & Test (PIT) | Complete | COMPLETE | T3-DB-0068 | SITAG | T3 |
| 273 | 1.3.6.3.3.2.2 | DCC Test Approach & Plan (PIT) MHHS Review Completed | milestone | 0d | 2023-12-15 A | 2023-12-15 A | 272FS+20d | 100% | 2023-12-15 | 2023-12-15 | 0d | 2023-10-16 | 2023-10-27 |  |  | SI Test | PP | DBT | 5.18 |  | Design, Build & Test (PIT) | Complete | COMPLETE | T3-DB-0115 | SITAG | T3 |
| 274 | 1.3.6.3.3.3 | **Test Readiness Report** |  | 22d | 2023-12-04 A | 2024-01-02 A |  | 100% | 2023-12-04 | 2024-01-02 | 51d | 2023-10-27 | 2024-01-05 |  |  | N/A | N/A | DBT | 5.18 | N/A | Design, Build & Test (PIT) |  |  |  |  |  |
| 275 | 1.3.6.3.3.3.1 | Test readiness reporting |  | 22d | 2023-12-04 A | 2024-01-02 A | 272FS+10d | 100% | 2023-12-04 | 2024-01-02 | 51d | 2023-10-27 | 2024-01-05 |  |  | PP | 109 | DBT | 5.18 |  | Design, Build & Test (PIT) | Complete | COMPLETE |  |  |  |
| 276 | 1.3.6.3.3.4 | **Requirements to test Traceability Matrix (RTTM)** |  | 30d | 2023-12-15 A | 2024-01-26 A |  | 100% | 2023-12-15 | 2024-01-26 | 30d | 2022-10-31 | 2023-11-24 |  | -0 | N/A | N/A | DBT | 5.18 | N/A | Design, Build & Test (PIT) |  |  |  |  |  |
| 277 | 1.3.6.3.3.4.1 | DCC RTTM submitted to Programme for assurance | milestone | 0d | 2023-12-15 A | 2023-12-15 A | 272FS+20d | 100% | 2023-12-15 | 2023-12-15 | 0d | 2023-11-10 | 2023-11-10 | start no earlier than 2023-04-28 |  | PP | SI Test | DBT | 5.18 |  | Design, Build & Test (PIT) | Complete | COMPLETE | T3-DB-0074 | SITAG | T3 |
| 278 | 1.3.6.3.3.4.2 | DCC RTTM MHHS Review Completed | milestone | 0d | 2024-01-26 A | 2024-01-26 A | 277FS+30d | 100% | 2024-01-26 | 2024-01-26 | 0d | 2023-11-13 | 2023-11-24 |  |  | SI Test | PP | DBT | 5.18 |  | Design, Build & Test (PIT) | Complete | COMPLETE | T3-DB-0116 | SITAG | T3 |
| 279 | 1.3.6.3.3.5 | **Test Scenarios** |  | 30d | 2023-12-15 A | 2024-01-26 A |  | 100% | 2023-12-15 | 2024-01-26 | 30d | 2022-10-31 | 2023-11-24 |  | -0 | N/A | N/A | DBT | 5.18 | N/A | Design, Build & Test (PIT) |  |  |  |  |  |
| 280 | 1.3.6.3.3.5.1 | DCC test scenarios submitted to Programme for assurance | milestone | 0d | 2023-12-15 A | 2023-12-15 A | 272FS+20d | 100% | 2023-12-15 | 2023-12-15 | 0d | 2023-11-10 | 2023-11-10 |  |  | PP | SI Test | DBT | 5.18 |  | Design, Build & Test (PIT) | Complete | COMPLETE | T3-DB-0078 | SITAG | T3 |
| 281 | 1.3.6.3.3.5.2 | DCC Test Scenarios MHHS Review Completed | milestone | 0d | 2024-01-26 A | 2024-01-26 A | 280FS+30d | 100% | 2024-01-26 | 2024-01-26 | 0d | 2023-11-13 | 2023-11-24 |  |  | SI Test | PP | DBT | 5.18 |  | Design, Build & Test (PIT) | Complete | COMPLETE | T3-DB-0117 | SITAG | T3 |

Notes:
- 268: Guidance: 6/10 - LC - Successor should be SIT Component Integration Testing 1 Preparation Complete but not linked as DIP test completion plus 10 day review breaks logic. Decision will be made to proceed without a conclusion of the report review

| ID | WBS | Task | Type | Duration | Start | Finish | Predecessors | Complete | Baseline start | Baseline finish | Baseline duration | Baseline 1 start | Baseline 1 finish | Constraint | Baseline cost | Responsible | Involved | Text9 | Update Version | MHHS Resource Name | MHHS Programme Phase | Sched Status | RAG | Milestone ID | Text29 | Tier | Artefact ID |
| --- | --- | --- | --- | --- | --- | --- | --- | --- | --- | --- | --- | --- | --- | --- | --- | --- | --- | --- | --- | --- | --- | --- | --- | --- | --- | --- | --- |
| 282 | 1.3.6.3.4 | **RECCo (EES) DBT CIT (Entering at Interval 6)** |  | 71d | 2023-10-13 A | 2024-01-19 A |  | 100% | 2023-10-13 | 2024-01-19 | 320d | 2022-10-31 | 2024-01-05 |  | -0 | N/A | N/A | DBT | 5.0 | N/A | Design, Build & Test (PIT) |  |  |  |  |  |  |
| 283 | 1.3.6.3.4.1 | **Test Approach & Plan** |  | 20d | 2023-10-13 A | 2023-11-09 A |  | 100% | 2023-10-13 | 2023-11-09 | 20d | 2022-10-31 | 2023-10-27 |  | -0 | N/A | N/A | DBT | 5.0 | N/A | Design, Build & Test (PIT) |  |  |  |  |  |  |
| 284 | 1.3.6.3.4.1.1 | EES Test Approach & Plan (PIT) submitted to Programme for assurance | milestone | 0d | 2023-10-13 A | 2023-10-13 A |  | 100% | 2023-10-13 | 2023-10-13 | 0d | 2023-10-13 | 2023-10-13 | start no earlier than 2023-10-13 |  | PP | SI Test | DBT | 5.8 |  | Design, Build & Test (PIT) | Complete | COMPLETE | T3-DB-0066 | SITAG | T3 |  |
| 285 | 1.3.6.3.4.1.2 | EES Test approach and plan (PIT) MHHS Review Completed | milestone | 0d | 2023-11-09 A | 2023-11-09 A | 284FS+20d | 100% | 2023-11-09 | 2023-11-09 | 0d | 2023-10-16 | 2023-10-27 |  |  | SI Test | PP | DBT | 5.8 |  | Design, Build & Test (PIT) | Complete | COMPLETE | T3-DB-0119 | SITAG | T3 |  |
| 286 | 1.3.6.3.4.2 | **Test Readiness Report** |  | 10d | 2023-10-27 A | 2023-11-09 A |  | 100% | 2023-10-27 | 2023-11-09 | 51d | 2023-10-27 | 2024-01-05 |  |  | N/A | N/A | DBT | 5.0 | N/A | Design, Build & Test (PIT) |  |  |  |  |  |  |
| 287 | 1.3.6.3.4.2.1 | Test readiness reporting |  | 10d | 2023-10-27 A | 2023-11-09 A | 284FS+10d | 100% | 2023-10-27 | 2023-11-09 | 51d | 2023-10-27 | 2024-01-05 |  |  | PP | 109 | DBT | 5.0 |  | Design, Build & Test (PIT) | Complete | COMPLETE |  |  |  |  |
| 288 | 1.3.6.3.4.3 | **Requirements to test Traceability Matrix (RTTM)** |  | 20d | 2023-11-02 A | 2023-11-30 A |  | 100% | 2023-11-02 | 2023-11-30 | 20d | 2022-10-31 | 2023-11-24 |  | -0 | N/A | N/A | DBT | 5.0 | N/A | Design, Build & Test (PIT) |  |  |  |  |  |  |
| 289 | 1.3.6.3.4.3.1 | EES RTTM submitted to Programme for assurance | milestone | 0d | 2023-11-02 A | 2023-11-02 A | 284FS+15d | 100% | 2023-11-02 | 2023-11-02 | 0d | 2023-11-10 | 2023-11-10 |  |  | PP | SI Test | DBT | 5.8 |  | Design, Build & Test (PIT) | Complete | COMPLETE | T3-DB-0072 | SITAG | T3 | MHHS-ART009 |
| 290 | 1.3.6.3.4.3.2 | EES RTTM MHHS Review Completed | milestone | 0d | 2023-11-30 A | 2023-11-30 A | 289FS+20d | 100% | 2023-11-30 | 2023-11-30 | 0d | 2023-11-13 | 2023-11-24 |  |  | SI Test | PP | DBT | 5.14 |  | Design, Build & Test (PIT) | Complete | COMPLETE | T3-DB-0120 | SITAG | T3 |  |
| 291 | 1.3.6.3.4.4 | **Test Scenarios** |  | 20d | 2023-11-02 A | 2023-11-30 A |  | 100% | 2023-11-02 | 2023-11-30 | 20d | 2022-10-31 | 2023-11-24 |  | -0 | N/A | N/A | DBT | 5.0 | N/A | Design, Build & Test (PIT) |  |  |  |  |  |  |
| 292 | 1.3.6.3.4.4.1 | EES test scenarios submitted to Programme for assurance | milestone | 0d | 2023-11-02 A | 2023-11-02 A | 284FS+15d | 100% | 2023-11-02 | 2023-11-02 | 0d | 2023-11-10 | 2023-11-10 |  |  | PP | SI Test | DBT | 5.8 |  | Design, Build & Test (PIT) | Complete | COMPLETE | T3-DB-0031 | SITAG | T3 |  |
| 293 | 1.3.6.3.4.4.2 | EES Test scenarios MHHS Review Completed | milestone | 0d | 2023-11-30 A | 2023-11-30 A | 292FS+20d | 100% | 2023-11-30 | 2023-11-30 | 0d | 2023-11-13 | 2023-11-24 |  |  | SI Test | PP | DBT | 5.14 |  | Design, Build & Test (PIT) | Complete | COMPLETE | T3-DB-0121 | SITAG | T3 |  |
| 294 | 1.3.6.3.4.5 | **PIT execution** |  | 51d | 2023-11-10 A | 2024-01-19 A |  | 100% | 2023-11-10 | 2024-01-19 | 320d | 2022-10-31 | 2024-01-05 |  | -0 | N/A | N/A | DBT | 5.0 | N/A | Design, Build & Test (PIT) |  |  |  |  |  |  |
| 295 | 1.3.6.3.4.5.1 | PIT Test Execution Progress Report |  | 41d | 2023-11-10 A | 2024-01-05 A | 287 | 100% | 2023-11-10 | 2024-01-05 | 41d | 2022-10-31 | 2023-12-29 |  |  | PP | SI Test | DBT | 5.0 |  | Design, Build & Test (PIT) | Complete | COMPLETE |  |  |  |  |
| 296 | 1.3.6.3.4.5.2 | PIT Execution |  | 41d | 2023-11-10 A | 2024-01-05 A | 292FS+5d | 100% | 2023-11-10 | 2024-01-05 | 310d | 2022-10-31 | 2024-01-05 |  |  | PP | SI Test | DBT | 5.0 |  | Design, Build & Test (PIT) | Complete | COMPLETE |  |  |  |  |
| 297 | 1.3.6.3.4.5.3 | EES PIT Completion Report submitted to Programme for assurance | milestone | 0d | 2024-01-05 A | 2024-01-05 A | 295, 296 | 100% | 2024-01-05 | 2024-01-05 | 0d | 2024-01-05 | 2024-01-05 |  |  | PP | SI Test | DBT | 5.14 |  | Design, Build & Test (PIT) | Complete | COMPLETE | T3-DB-0122 | SITAG | T3 |  |
| 298 | 1.3.6.3.4.5.4 | EES PIT Completion Report MHHS Review Completed | milestone | 0d | 2024-01-19 A | 2024-01-19 A | 285, 290, 293, 297FS+10d | 100% | 2024-01-19 | 2024-01-19 | 0d |  |  |  |  | SI Test | PP | DBT | 5.14 |  | Design, Build & Test (PIT) | Complete | COMPLETE | T3-DB-0123 | SITAG | T3 |  |
| 299 | 1.3.6.3.5 | **Registration Services DBT CIT (Entering at Interval 2)** |  | 70d | 2023-07-28 A | 2023-11-03 A |  | 100% | 2023-07-28 | 2023-11-03 | 70d | 2022-10-31 | 2024-02-28 |  | -0 | N/A | N/A | DBT | 5.0 | N/A | Design, Build & Test (PIT) |  |  |  |  |  |  |
| 300 | 1.3.6.3.5.1 | **Test Approach & Plan** |  | 40d | 2023-07-28 A | 2023-09-22 A |  | 100% | 2023-07-28 | 2023-09-22 | 40d | 2022-10-31 | 2023-08-11 |  | -0 | N/A | N/A | DBT | 5.0 | N/A | Design, Build & Test (PIT) |  |  |  |  |  |  |
| 301 | 1.3.6.3.5.1.1 | Registration Services Test Approach & Plan (PIT) submitted to Programme for assurance | milestone | 0d | 2023-07-28 A | 2023-07-28 A |  | 100% | 2023-07-28 | 2023-07-28 | 0d | 2023-07-28 | 2023-07-28 |  |  | PP | SI Test | DBT | 5.0 |  | Design, Build & Test (PIT) | Complete | COMPLETE | T3-DB-0028 | SITAG | T3 | MHHS-ART073 |
| 302 | 1.3.6.3.5.1.2 | Registration Services Test approach and plan MHHS Review Completed | milestone | 0d | 2023-09-22 A | 2023-09-22 A | 301FS+40d | 100% | 2023-09-22 | 2023-09-22 | 0d | 2023-07-31 | 2023-08-11 |  |  | SI Test | PP | DBT | 5.8 |  | Design, Build & Test (PIT) | Complete | COMPLETE | T3-DB-0124 | SITAG | T3 |  |
| 303 | 1.3.6.3.5.2 | **Test Readiness Report** |  | 20d | 2023-08-14 A | 2023-09-08 A |  | 100% | 2023-08-14 | 2023-09-08 | 51d | 2023-08-11 | 2023-10-20 |  |  | N/A | N/A | DBT | 5.0 | N/A | Design, Build & Test (PIT) |  |  |  |  |  |  |
| 304 | 1.3.6.3.5.2.1 | Test readiness reporting |  | 20d | 2023-08-14 A | 2023-09-08 A | 301FS+10d | 100% | 2023-08-14 | 2023-09-08 | 51d | 2023-08-11 | 2023-10-20 |  |  | PP | 109 | DBT | 5.0 |  | Design, Build & Test (PIT) | Complete | COMPLETE |  |  |  |  |
| 305 | 1.3.6.3.5.3 | **Requirements to test Traceability Matrix (RTTM)** |  | 20d | 2023-09-01 A | 2023-09-29 A |  | 100% | 2023-09-01 | 2023-09-29 | 20d | 2022-10-31 | 2023-09-15 |  | -0 | N/A | N/A | DBT | 5.0 | N/A | Design, Build & Test (PIT) |  |  |  |  |  |  |
| 306 | 1.3.6.3.5.3.1 | Registration Services RTTM submitted to Programme for assurance | milestone | 0d | 2023-09-01 A | 2023-09-01 A | 301FS+15d | 100% | 2023-09-01 | 2023-09-01 | 0d | 2023-09-01 | 2023-09-01 | start no earlier than 2023-04-28 |  | PP | SI Test | DBT | 5.6 |  | Design, Build & Test (PIT) | Complete | COMPLETE | T3-DB-0042 | SITAG | T3 | MHHS-ART009 |
| 307 | 1.3.6.3.5.3.2 | Registration Services RTTM MHHS Review Completed | milestone | 0d | 2023-09-29 A | 2023-09-29 A | 306FS+20d | 100% | 2023-09-29 | 2023-09-29 | 0d | 2023-09-04 | 2023-09-15 |  |  | SI Test | PP | DBT | 5.8 |  | Design, Build & Test (PIT) | Complete | COMPLETE | T3-DB-0125 | SITAG | T3 |  |

| ID | WBS | Task | Type | Duration | Start | Finish | Predecessors | Complete | Remaining | Baseline start | Baseline finish | Baseline duration | Baseline 1 start | Baseline 1 finish | Total slack | Constraint | Baseline cost | Responsible | Involved | Text9 | Update Version | MHHS Resource Name | MHHS Programme Phase | Sched Status | RAG | Milestone ID | Text29 | Tier |
| --- | --- | --- | --- | --- | --- | --- | --- | --- | --- | --- | --- | --- | --- | --- | --- | --- | --- | --- | --- | --- | --- | --- | --- | --- | --- | --- | --- | --- |
| 308 | 1.3.6.3.5.4 | **Test Scenarios** |  | 20d | 2023-09-01 A | 2023-09-29 A |  | 100% |  | 2023-09-01 | 2023-09-29 | 20d | 2022-10-31 | 2023-09-15 |  |  | -0 | N/A | N/A | DBT | 5.0 | N/A | Design, Build & Test (PIT) |  |  |  |  |  |
| 309 | 1.3.6.3.5.4.1 | Registration Services test scenarios submitted to Programme for assurance | milestone | 0d | 2023-09-01 A | 2023-09-01 A | 301FS+15d | 100% |  | 2023-09-01 | 2023-09-01 | 0d | 2023-09-01 | 2023-09-01 |  |  |  | PP | SI Test | DBT | 5.6 |  | Design, Build & Test (PIT) | Complete | COMPLETE | T3-DB-0044 | SITAG | T3 |
| 310 | 1.3.6.3.5.4.2 | Registration Services Test scenarios MHHS Review Completed | milestone | 0d | 2023-09-29 A | 2023-09-29 A | 309FS+20d | 100% |  | 2023-09-29 | 2023-09-29 | 0d | 2023-09-04 | 2023-09-15 |  |  |  | SI Test | PP | DBT | 5.8 |  | Design, Build & Test (PIT) | Complete | COMPLETE | T3-DB-0126 | SITAG | T3 |
| 311 | 1.3.6.3.5.5 | **PIT execution** |  | 40d | 2023-09-11 A | 2023-11-03 A |  | 100% |  | 2023-09-11 | 2023-11-03 | 40d | 2023-01-02 | 2023-10-20 |  |  | -0 | N/A | N/A | DBT | 5.0 | N/A | Design, Build & Test (PIT) |  |  |  |  |  |
| 312 | 1.3.6.3.5.5.1 | PIT Test Execution Progress Report |  | 33d | 2023-09-11 A | 2023-10-25 A | 304 | 100% |  | 2023-09-11 | 2023-10-25 | 30d | 2023-01-02 | 2023-10-13 |  |  |  | PP | SI Test | DBT | 5.0 |  | Design, Build & Test (PIT) | Complete | COMPLETE |  |  |  |
| 313 | 1.3.6.3.5.5.2 | PIT Execution |  | 30d | 2023-09-11 A | 2023-10-20 A | 309FS+5d | 100% |  | 2023-09-11 | 2023-10-20 | 30d | 2023-01-16 | 2023-10-20 |  |  |  | PP | SI Test | DBT | 5.0 |  | Design, Build & Test (PIT) | Complete | COMPLETE |  |  |  |
| 314 | 1.3.6.3.5.5.3 | Registration Services PIT (CIT interval 2) Completion Report submitted to Programme for assurance | milestone | 0d | 2023-10-25 A | 2023-10-25 A | 312, 313 | 100% |  | 2023-10-25 | 2023-10-25 | 0d | 2024-01-05 | 2024-01-05 |  |  |  | PP | SI Test | DBT | 5.10 |  | Design, Build & Test (PIT) | Complete | COMPLETE | T3-DB-0127 | SITAG | T3 |
| 315 | 1.3.6.3.5.5.4 | Registration Services PIT (CIT interval 2) Completion Report MHHS Review Completed | milestone | 0d | 2023-11-03 A | 2023-11-03 A | 302, 307, 310, 314FS+7d | 100% |  | 2023-11-03 | 2023-11-03 | 0d |  |  |  |  |  | SI Test | PP | DBT | 5.11 |  | Design, Build & Test (PIT) | Complete | COMPLETE | T3-DB-0128 | SITAG | T3 |
| 316 | 1.3.6.4 | **SIT Participants DBT** |  | 401d | 2023-08-11 A | 2025-02-21 |  | 80% | 79.2d | 2023-08-11 | 2024-12-20 | 495d | 2022-10-31 | 2025-03-14 | 739d |  | -0 | N/A | N/A | DBT | 5.0 | N/A | Design, Build & Test (PIT) |  |  |  |  |  |
| 317 | 1.3.6.4.1 | **All Data Services DBT CIT (Entering at Interval 3)** |  | 71d | 2023-08-11 A | 2023-11-17 A |  | 100% |  | 2023-08-11 | 2023-11-17 | 275d | 2022-10-31 | 2023-11-03 |  |  | -0 | N/A | N/A | DBT | 5.0 | N/A | Design, Build & Test (PIT) |  |  |  |  |  |
| 318 | 1.3.6.4.1.1 | **Test Approach & Plan** |  | 30d | 2023-08-11 A | 2023-09-21 A |  | 100% |  | 2023-08-11 | 2023-09-21 | 29d | 2022-10-31 | 2023-08-25 |  |  | -0 | N/A | N/A | DBT | 5.0 | N/A | Design, Build & Test (PIT) |  |  |  |  |  |
| 319 | 1.3.6.4.1.1.1 | All Data Services Test Approach & Plans (PIT) submitted to Programme for assurance | milestone | 0d | 2023-08-11 A | 2023-08-11 A |  | 100% |  | 2023-08-11 | 2023-08-11 | 0d | 2023-08-11 | 2023-08-11 |  | start no earlier than 2023-08-11 |  | PP | SI Test | DBT | 5.0 |  | Design, Build & Test (PIT) | Complete | COMPLETE | T3-DB-0038 | SITAG | T3 |
| 320 | 1.3.6.4.1.1.2 | All Data Services Test approach and plans MHHS Review Completed | milestone | 0d | 2023-09-21 A | 2023-09-21 A | 319FS+30d | 100% |  | 2023-09-21 | 2023-09-21 | 0d | 2023-08-14 | 2023-08-25 |  |  |  | SI Test | PP | DBT | 5.11 |  | Design, Build & Test (PIT) | Complete | COMPLETE | T3-DB-0129 | SITAG | T3 |
| 321 | 1.3.6.4.1.2 | **Test Readiness Report** |  | 11d | 2023-08-25 A | 2023-09-08 A |  | 100% |  | 2023-08-25 | 2023-09-08 | 11d | 2023-08-25 | 2023-11-03 |  |  | -0 | N/A | N/A | DBT | 5.0 | N/A | Design, Build & Test (PIT) |  |  |  |  |  |
| 322 | 1.3.6.4.1.2.1 | Test readiness reporting |  | 11d | 2023-08-25 A | 2023-09-08 A | 319FS+10d | 100% |  | 2023-08-25 | 2023-09-08 | 11d | 2023-08-25 | 2023-11-03 |  |  |  | PP | 109 | DBT | 5.0 |  | Design, Build & Test (PIT) | Complete | COMPLETE |  |  |  |
| 323 | 1.3.6.4.1.3 | **Requirements to test Traceability Matrix (RTTM)** |  | 7d | 2023-09-20 A | 2023-09-29 A |  | 100% |  | 2023-09-20 | 2023-09-29 | 5d | 2022-10-31 | 2023-10-06 |  |  | -0 | N/A | N/A | DBT | 5.0 | N/A | Design, Build & Test (PIT) |  |  |  |  |  |
| 324 | 1.3.6.4.1.3.1 | All Data Services RTTMs submitted to Programme for assurance | milestone | 0d | 2023-09-20 A | 2023-09-20 A | 319FS+29d | 100% |  | 2023-09-20 | 2023-09-20 | 0d | 2023-09-22 | 2023-09-22 |  |  |  | PP | SI Test | DBT | 5.7 |  | Design, Build & Test (PIT) | Complete | COMPLETE | T3-DB-0058 | SITAG | T3 |
| 325 | 1.3.6.4.1.3.2 | All Data Services RTTMs MHHS Review Completed | milestone | 0d | 2023-09-29 A | 2023-09-29 A | 324FS+7d | 100% |  | 2023-09-29 | 2023-09-29 | 0d | 2023-09-25 | 2023-10-06 |  |  |  | SI Test | PP | DBT | 5.8 |  | Design, Build & Test (PIT) | Complete | COMPLETE | T3-DB-0130 | SITAG | T3 |
| 326 | 1.3.6.4.1.4 | **Test Scenarios** |  | 6d | 2023-09-20 A | 2023-09-28 A |  | 100% |  | 2023-09-20 | 2023-09-28 | 4d | 2022-10-31 | 2023-10-06 |  |  | -0 | N/A | N/A | DBT | 5.0 | N/A | Design, Build & Test (PIT) |  |  |  |  |  |
| 327 | 1.3.6.4.1.4.1 | All Data Services test scenarios' submitted to Programme for assurance | milestone | 0d | 2023-09-20 A | 2023-09-20 A | 319FS+29d | 100% |  | 2023-09-20 | 2023-09-20 | 0d | 2023-09-22 | 2023-09-22 |  |  |  | PP | SI Test | DBT | 5.7 |  | Design, Build & Test (PIT) | Complete | COMPLETE | T3-DB-0056 | SITAG | T3 |
| 328 | 1.3.6.4.1.4.2 | All Data Services Test scenarios' MHHS Review Completed | milestone | 0d | 2023-09-28 A | 2023-09-28 A | 327FS+6d | 100% |  | 2023-09-28 | 2023-09-28 | 0d | 2023-09-25 | 2023-10-06 |  |  |  | SI Test | PP | DBT | 5.11 |  | Design, Build & Test (PIT) | Complete | COMPLETE | T3-DB-0131 | SITAG | T3 |
| 329 | 1.3.6.4.1.5 | **PIT execution** |  | 50d | 2023-09-11 A | 2023-11-17 A |  | 100% |  | 2023-09-11 | 2023-11-17 | 275d | 2022-10-31 | 2023-11-03 |  |  | -0 | N/A | N/A | DBT | 5.0 | N/A | Design, Build & Test (PIT) |  |  |  |  |  |
| 330 | 1.3.6.4.1.5.1 | PIT Test Execution Progress Report |  | 40d | 2023-09-11 A | 2023-11-03 A | 322 | 100% |  | 2023-09-11 | 2023-11-03 | 260d | 2022-10-31 | 2023-10-27 |  |  |  | PP | SI Test | DBT | 5.0 |  | Design, Build & Test (PIT) | Complete | COMPLETE |  |  |  |
| 331 | 1.3.6.4.1.5.2 | PIT Execution |  | 27d | 2023-09-28 A | 2023-11-03 A | 327FS+5d | 100% |  | 2023-09-28 | 2023-11-03 | 265d | 2022-10-31 | 2023-11-03 |  |  |  | PP | SI Test | DBT | 5.0 |  | Design, Build & Test (PIT) | Complete | COMPLETE |  |  |  |
| 332 | 1.3.6.4.1.5.3 | All Data Services PIT Completion Reports submitted to Programme for assurance | milestone | 0d | 2023-11-03 A | 2023-11-03 A | 330, 331 | 100% |  | 2023-11-03 | 2023-11-03 | 0d | 2024-01-05 | 2024-01-05 |  |  |  | PP | SI Test | DBT | 5.11 |  | Design, Build & Test (PIT) | Complete | COMPLETE | T3-DB-0132 | SITAG | T3 |
| 333 | 1.3.6.4.1.5.4 | All Data Services PIT Completion Reports MHHS Review Completed | milestone | 0d | 2023-11-17 A | 2023-11-17 A | 320, 325, 328, 332FS+10d | 100% |  | 2023-11-17 | 2023-11-17 | 0d |  |  |  |  |  | SI Test | PP | DBT | 5.13 |  | Design, Build & Test (PIT) | Complete | COMPLETE | T3-DB-0133 | SITAG | T3 |

| ID | WBS | Task | Type | Duration | Start | Finish | Predecessors | Complete | Remaining | Baseline start | Baseline finish | Baseline duration | Baseline 1 start | Baseline 1 finish | Total slack | Constraint | Baseline cost | Responsible | Involved | Text9 | Update Version | MHHS Resource Name | MHHS Programme Phase | Sched Status | RAG | Milestone ID | Text29 | Tier | Artefact ID |
| --- | --- | --- | --- | --- | --- | --- | --- | --- | --- | --- | --- | --- | --- | --- | --- | --- | --- | --- | --- | --- | --- | --- | --- | --- | --- | --- | --- | --- | --- |
| 334 | 1.3.6.4.2 | **All Metering Services DBT CIT (Entering at Interval 4)** |  | 70d | 2023-08-25 A | 2023-12-01 A |  | 100% |  | 2023-08-25 | 2023-12-01 | 285d | 2022-10-31 | 2023-11-17 |  |  | -0 | N/A | N/A | DBT | 5.0 | N/A | Design, Build & Test (PIT) |  |  |  |  |  |  |
| 335 | 1.3.6.4.2.1 | **Test Approach & Plan** |  | 40d | 2023-08-25 A | 2023-10-20 A |  | 100% |  | 2023-08-25 | 2023-10-20 | 40d | 2022-10-31 | 2023-09-08 |  |  | -0 | N/A | N/A | DBT | 5.0 | N/A | Design, Build & Test (PIT) |  |  |  |  |  |  |
| 336 | 1.3.6.4.2.1.1 | All Metering Services Test Approach & Plans (PIT) submitted to Programme for assurance | milestone | 0d | 2023-08-25 A | 2023-08-25 A |  | 100% |  | 2023-08-25 | 2023-08-25 | 0d | 2023-08-25 | 2023-08-25 |  |  |  | PP | SI Test | DBT | 5.6 |  | Design, Build & Test (PIT) | Complete | COMPLETE | T3-DB-0040 | SITAG | T3 |  |
| 337 | 1.3.6.4.2.1.2 | All Metering Services Test approach and plans MHHS Review Completed | milestone | 0d | 2023-10-20 A | 2023-10-20 A | 336FS+40d | 100% |  | 2023-10-20 | 2023-10-20 | 0d | 2023-08-28 | 2023-09-08 |  |  |  | SI Test | PP | DBT | 5.8 |  | Design, Build & Test (PIT) | Complete | COMPLETE | T3-DB-0134 | SITAG | T3 |  |
| 338 | 1.3.6.4.2.2 | **Test Readiness Report** |  | 11d | 2023-09-11 A | 2023-09-25 A |  | 100% |  | 2023-09-11 | 2023-09-25 | 51d | 2023-09-08 | 2023-11-17 |  |  |  | N/A | N/A | DBT | 5.0 | N/A | Design, Build & Test (PIT) |  |  |  |  |  |  |
| 339 | 1.3.6.4.2.2.1 | Test readiness reporting |  | 11d | 2023-09-11 A | 2023-09-25 A | 336FS+10d | 100% |  | 2023-09-11 | 2023-09-25 | 51d | 2023-09-08 | 2023-11-17 |  |  |  | PP | 109 | DBT | 5.0 |  | Design, Build & Test (PIT) | Complete | COMPLETE |  |  |  |  |
| 340 | 1.3.6.4.2.3 | **Requirements to test Traceability Matrix (RTTM)** |  | 30d | 2023-09-15 A | 2023-10-27 A |  | 100% |  | 2023-09-15 | 2023-10-27 | 30d | 2022-10-31 | 2023-09-29 |  |  | -0 | N/A | N/A | DBT | 5.0 | N/A | Design, Build & Test (PIT) |  |  |  |  |  |  |
| 341 | 1.3.6.4.2.3.1 | All Metering Services RTTMs submitted to Programme for assurance | milestone | 0d | 2023-09-15 A | 2023-09-15 A | 336FS+15d | 100% |  | 2023-09-15 | 2023-09-15 | 0d | 2023-09-15 | 2023-09-15 |  |  |  | PP | SI Test | DBT | 5.8 |  | Design, Build & Test (PIT) | Complete | COMPLETE | T3-DB-0048 | SITAG | T3 | MHHS-ART009 |
| 342 | 1.3.6.4.2.3.2 | All Metering Services MHHS Reviews Completed | milestone | 0d | 2023-10-27 A | 2023-10-27 A | 341FS+30d | 100% |  | 2023-10-27 | 2023-10-27 | 0d | 2023-09-18 | 2023-09-29 |  |  |  | SI Test | PP | DBT | 5.13 |  | Design, Build & Test (PIT) | Complete | COMPLETE | T3-DB-0135 | SITAG | T3 |  |
| 343 | 1.3.6.4.2.4 | **Test Scenarios** |  | 30d | 2023-09-15 A | 2023-10-27 A |  | 100% |  | 2023-09-15 | 2023-10-27 | 30d | 2022-10-31 | 2023-09-29 |  |  | -0 | N/A | N/A | DBT | 5.0 | N/A | Design, Build & Test (PIT) |  |  |  |  |  |  |
| 344 | 1.3.6.4.2.4.1 | All Metering Services test scenarios' submitted to Programme for assurance | milestone | 0d | 2023-09-15 A | 2023-09-15 A | 336FS+15d | 100% |  | 2023-09-15 | 2023-09-15 | 0d | 2023-09-15 | 2023-09-15 |  |  |  | PP | SI Test | DBT | 5.8 |  | Design, Build & Test (PIT) | Complete | COMPLETE | T3-DB-0050 | SITAG | T3 |  |
| 345 | 1.3.6.4.2.4.2 | All Metering Services Test scenarios' MHHS Review Completed | milestone | 0d | 2023-10-27 A | 2023-10-27 A | 344FS+30d | 100% |  | 2023-10-27 | 2023-10-27 | 0d | 2023-09-18 | 2023-09-29 |  |  |  | SI Test | PP | DBT | 5.13 |  | Design, Build & Test (PIT) | Complete | COMPLETE | T3-DB-0136 | SITAG | T3 |  |
| 346 | 1.3.6.4.2.5 | **PIT execution** |  | 50d | 2023-09-25 A | 2023-12-01 A |  | 100% |  | 2023-09-25 | 2023-12-01 | 285d | 2022-10-31 | 2023-11-17 |  |  | -0 | N/A | N/A | DBT | 5.0 | N/A | Design, Build & Test (PIT) |  |  |  |  |  |  |
| 347 | 1.3.6.4.2.5.1 | PIT Test Execution Progress Report |  | 39d | 2023-09-26 A | 2023-11-17 A | 339 | 100% |  | 2023-09-26 | 2023-11-17 | 39d | 2022-10-31 | 2023-11-10 |  |  |  | PP | SI Test | DBT | 5.0 |  | Design, Build & Test (PIT) | Complete | COMPLETE |  |  |  |  |
| 348 | 1.3.6.4.2.5.2 | PIT Execution |  | 40d | 2023-09-25 A | 2023-11-17 A | 344FS+5d | 100% |  | 2023-09-25 | 2023-11-17 | 275d | 2022-10-31 | 2023-11-17 |  |  |  | PP | SI Test | DBT | 5.0 |  | Design, Build & Test (PIT) | Complete | COMPLETE |  |  |  |  |
| 349 | 1.3.6.4.2.5.3 | All Metering Services PIT Completion Reports submitted to Programme for assurance | milestone | 0d | 2023-11-17 A | 2023-11-17 A | 347, 348 | 100% |  | 2023-11-17 | 2023-11-17 | 0d | 2024-01-05 | 2024-01-05 |  |  |  | PP | SI Test | DBT | 5.13 |  | Design, Build & Test (PIT) | Complete | COMPLETE | T3-DB-0137 | SITAG | T3 |  |
| 350 | 1.3.6.4.2.5.4 | All Metering Services PIT Completion Reports MHHS Review Completed | milestone | 0d | 2023-12-01 A | 2023-12-01 A | 337, 342, 345, 349FS+10d | 100% |  | 2023-12-01 | 2023-12-01 | 0d |  |  |  |  |  | SI Test | PP | DBT | 5.13 |  | Design, Build & Test (PIT) | Complete | COMPLETE | T3-DB-0138 | SITAG | T3 |  |
| 351 | 1.3.6.4.3 | **All SIT Programme Participants PIT (SIT Functional)** |  | 331d | 2023-11-17 A | 2025-02-21 |  | 62% | 126.21d | 2023-11-17 | 2024-12-20 | 451d | 2022-12-30 | 2024-02-16 | 739d |  | -0 | N/A | N/A | DBT | 5.0 | N/A | Design, Build & Test (PIT) |  |  |  |  |  |  |
| 352 | 1.3.6.4.3.1 | **Test Approach & Plans** |  | 40d | 2023-11-17 A | 2024-01-11 A |  | 100% |  | 2023-11-17 | 2024-01-11 | 40d | 2022-12-30 | 2023-11-30 |  |  | -0 | N/A | N/A | DBT | 5.2 | N/A | Design, Build & Test (PIT) |  |  |  |  |  |  |
| 353 | 1.3.6.4.3.1.1 | SIT Functional PIT Test Approach & Plan (PIT) submitted to Programme for assurance | milestone | 0d | 2023-11-17 A | 2023-11-17 A |  | 100% |  | 2023-11-17 | 2023-11-17 | 0d | 2023-11-16 | 2023-11-16 |  | start no earlier than 2023-11-17 |  | PP | SI Test | DBT | 5.16 |  | Design, Build & Test (PIT) | Complete | COMPLETE | T3-DB-0093 | SITAG | T3 |  |
| 354 | 1.3.6.4.3.1.2 | All SIT Functional Test approach and plans MHHS Reviews Completed | milestone | 0d | 2024-01-11 A | 2024-01-11 A | 353FS+40d | 100% |  | 2024-01-11 | 2024-01-11 | 0d | 2023-11-17 | 2023-11-30 |  |  |  | SI Test | PP | DBT | 5.8 |  | Design, Build & Test (PIT) | Complete | COMPLETE | T3-DB-0139 | SITAG | T3 |  |
| 355 | 1.3.6.4.3.2 | **Test Readiness Reports** |  | 11d | 2023-12-01 A | 2023-12-15 A |  | 100% |  | 2023-12-01 | 2023-12-15 | 51d | 2023-11-30 | 2024-02-08 |  |  |  | N/A | N/A | DBT | 5.2 | N/A | Design, Build & Test (PIT) |  |  |  |  |  |  |
| 356 | 1.3.6.4.3.2.1 | Test readiness reporting |  | 11d | 2023-12-01 A | 2023-12-15 A | 353FS+10d | 100% |  | 2023-12-01 | 2023-12-15 | 51d | 2023-11-30 | 2024-02-08 |  |  |  | PP | 109 | DBT | 5.2 |  | Design, Build & Test (PIT) | Complete | COMPLETE |  |  |  |  |
| 357 | 1.3.6.4.3.3 | **Requirements to test Traceability Matrices (RTTM)** |  | 30d | 2023-12-07 A | 2024-01-18 A |  | 100% |  | 2023-12-07 | 2024-01-18 | 30d | 2023-01-06 | 2024-01-05 |  |  | -0 | N/A | N/A | DBT | 5.2 | N/A | Design, Build & Test (PIT) |  |  |  |  |  |  |
| 358 | 1.3.6.4.3.3.1 | SIT Functional PIT RTTM submitted to Programme for assurance | milestone | 0d | 2023-12-07 A | 2023-12-07 A | 353FS+15d | 100% |  | 2023-12-07 | 2023-12-07 | 0d | 2023-12-14 | 2023-12-14 |  |  |  | PP | SI Test | DBT | 5.14 |  | Design, Build & Test (PIT) | Complete | COMPLETE | T3-DB-0091 | SITAG | T3 |  |
| 359 | 1.3.6.4.3.3.2 | All SIT Functional RTTMs MHHS Reviews Completed | milestone | 0d | 2024-01-18 A | 2024-01-18 A | 358FS+30d | 100% |  | 2024-01-18 | 2024-01-18 | 0d | 2023-12-15 | 2024-01-05 |  |  |  | SI Test | PP | DBT | 5.14 |  | Design, Build & Test (PIT) | Complete | COMPLETE | T3-DB-0140 | SITAG | T3 |  |

| ID | WBS | Task | Type | Duration | Start | Finish | Predecessors | Complete | Baseline start | Baseline finish | Baseline duration | Baseline 1 start | Baseline 1 finish | Constraint | Baseline cost | Responsible | Involved | Text9 | Update Version | MHHS Resource Name | MHHS Programme Phase | Sched Status | RAG | Milestone ID | Text29 | Tier |
| --- | --- | --- | --- | --- | --- | --- | --- | --- | --- | --- | --- | --- | --- | --- | --- | --- | --- | --- | --- | --- | --- | --- | --- | --- | --- | --- |
| 360 | 1.3.6.4.3.4 | **Test Scenarios** |  | 30d | 2023-12-07 A | 2024-01-18 A |  | 100% | 2023-12-07 | 2024-01-18 | 30d | 2023-01-06 | 2024-01-05 |  | -0 | N/A | N/A | DBT | 5.2 | N/A | Design, Build & Test (PIT) |  |  |  |  |  |
| 361 | 1.3.6.4.3.4.1 | SIT Functional PIT test scenarios submitted to Programme for assurance | milestone | 0d | 2023-12-07 A | 2023-12-07 A | 353FS+15d | 100% | 2023-12-07 | 2023-12-07 | 0d | 2023-12-14 | 2023-12-14 |  |  | PP | SI Test | DBT | 5.14 |  | Design, Build & Test (PIT) | Complete | COMPLETE | T3-DB-0089 | SITAG | T3 |
| 362 | 1.3.6.4.3.4.2 | All SIT Functional Test scenarios' MHHS Reviews Completed | milestone | 0d | 2024-01-18 A | 2024-01-18 A | 361FS+30d | 100% | 2024-01-18 | 2024-01-18 | 0d | 2023-12-15 | 2024-01-05 |  |  | SI Test | PP | DBT | 5.14 |  | Design, Build & Test (PIT) | Complete | COMPLETE | T3-DB-0141 | SITAG | T3 |
| 363 | 1.3.6.4.3.5 | **PIT execution** |  | 51d | 2023-12-15 A | 2024-02-23 A |  | 100% | 2023-12-15 | 2024-02-23 | 301d | 2022-12-30 | 2024-02-09 |  | -0 | N/A | N/A | DBT | 5.0 | N/A | Design, Build & Test (PIT) |  |  |  |  |  |
| 364 | 1.3.6.4.3.5.1 | PIT Test Execution Progress Reports |  | 40d | 2023-12-18 A | 2024-02-09 A | 356 | 100% | 2023-12-18 | 2024-02-09 | 40d | 2022-12-30 | 2024-02-01 |  |  | PP | SI Test | DBT | 5.0 |  | Design, Build & Test (PIT) | Complete | COMPLETE |  |  |  |
| 365 | 1.3.6.4.3.5.2 | PIT Execution |  | 41d | 2023-12-15 A | 2024-02-09 A | 361FS+5d | 100% | 2023-12-15 | 2024-02-09 | 290d | 2022-12-30 | 2024-02-09 |  |  | PP | SI Test | DBT | 5.0 |  | Design, Build & Test (PIT) | Complete | COMPLETE |  |  |  |
| 366 | 1.3.6.4.3.5.3 | All SIT Functional PIT Completion Reports submitted to Programme for Assurance | milestone | 0d | 2024-02-09 A | 2024-02-09 A | 364, 365 | 100% | 2024-02-09 | 2024-02-09 | 0d | 2024-01-05 | 2024-01-05 |  |  | PP | SI Test | DBT | 5.19 |  | Design, Build & Test (PIT) | Complete | COMPLETE | T3-DB-0087 | SITAG | T3 |
| 367 | 1.3.6.4.3.5.4 | All SIT Functional PIT Completion Reports MHHS Review Completed | milestone | 0d | 2024-02-23 A | 2024-02-23 A | 354, 359, 362, 366FS+10d | 100% | 2024-02-23 | 2024-02-23 | 0d |  |  |  |  | SI Test | PP | DBT | 5.19 |  | Design, Build & Test (PIT) | Complete | COMPLETE | T3-DB-0142 | SITAG | T3 |
| 368 | 1.3.6.4.3.6 | **All SIT Programme Participants PIT (SIT Migration)** |  | 71d | 2024-02-16 A | 2024-05-24 A |  | 100% | 2024-02-16 | 2024-05-24 | 301d |  |  |  | -0 | N/A | N/A | DBT | 5.1 | N/A | Design, Build & Test (PIT) |  |  |  |  |  |
| 369 | 1.3.6.4.3.6.1 | **Test Approach & Plans** |  | 40d | 2024-02-16 A | 2024-04-11 A |  | 100% | 2024-02-16 | 2024-04-11 | 40d |  |  |  | -0 | N/A | N/A | DBT | 5.2 | N/A | Design, Build & Test (PIT) |  |  |  |  |  |
| 370 | 1.3.6.4.3.6.1.1 | All SIT Migration PIT Test Approach & Plans submitted to Programme for assurance | milestone | 0d | 2024-02-16 A | 2024-02-16 A |  | 100% | 2024-02-16 | 2024-02-16 | 0d |  |  | start no earlier than 2024-02-16 |  | PP | SI Test | DBT | 5.8 |  | Design, Build & Test (PIT) | Complete | COMPLETE | T3-DB-0143 | SITAG | T3 |
| 371 | 1.3.6.4.3.6.1.2 | All SIT Migration PIT Test approach and plans MHHS Reviews Completed | milestone | 0d | 2024-04-11 A | 2024-04-11 A | 370FS+40d | 100% | 2024-04-11 | 2024-04-11 | 0d |  |  |  |  | SI Test | PP | DBT | 5.23 |  | Design, Build & Test (PIT) | Complete | COMPLETE | T3-DB-0144 | SITAG | T3 |
| 372 | 1.3.6.4.3.6.2 | **Test Readiness Reports** |  | 11d | 2024-03-01 A | 2024-03-15 A |  | 100% | 2024-03-01 | 2024-03-15 | 51d |  |  |  |  | N/A | N/A | DBT | 5.2 | N/A | Design, Build & Test (PIT) |  |  |  |  |  |
| 373 | 1.3.6.4.3.6.2.1 | Test readiness reporting |  | 11d | 2024-03-01 A | 2024-03-15 A | 370FS+10d | 100% | 2024-03-01 | 2024-03-15 | 51d |  |  |  |  | PP | 109 | DBT | 5.2 |  | Design, Build & Test (PIT) | Complete | COMPLETE |  |  |  |
| 374 | 1.3.6.4.3.6.3 | **Requirements to test Traceability Matrices (RTTM)** |  | 30d | 2024-03-07 A | 2024-04-18 A |  | 100% | 2024-03-07 | 2024-04-18 | 30d |  |  |  | -0 | N/A | N/A | DBT | 5.2 | N/A | Design, Build & Test (PIT) |  |  |  |  |  |
| 375 | 1.3.6.4.3.6.3.1 | All SIT Migration PIT RTTMs submitted to Programme for assurance | milestone | 0d | 2024-03-07 A | 2024-03-07 A | 370FS+15d | 100% | 2024-03-07 | 2024-03-07 | 0d |  |  |  |  | PP | SI Test | DBT | 5.23 |  | Design, Build & Test (PIT) | Complete | COMPLETE | T3-DB-0145 | SITAG | T3 |
| 376 | 1.3.6.4.3.6.3.2 | All SIT Migration RTTMs MHHS Reviews Completed | milestone | 0d | 2024-04-18 A | 2024-04-18 A | 375FS+30d | 100% | 2024-04-18 | 2024-04-18 | 0d |  |  |  |  | SI Test | PP | DBT | 5.25 |  | Design, Build & Test (PIT) | Complete | COMPLETE | T3-DB-0146 | SITAG | T3 |
| 377 | 1.3.6.4.3.6.4 | **Test Scenarios** |  | 30d | 2024-03-07 A | 2024-04-18 A |  | 100% | 2024-03-07 | 2024-04-18 | 30d |  |  |  | -0 | N/A | N/A | DBT | 5.2 | N/A | Design, Build & Test (PIT) |  |  |  |  |  |
| 378 | 1.3.6.4.3.6.4.1 | All SIT Migration PIT test scenarios submitted to Programme for assurance | milestone | 0d | 2024-03-07 A | 2024-03-07 A | 370FS+15d | 100% | 2024-03-07 | 2024-03-07 | 0d |  |  |  |  | PP | SI Test | DBT | 5.23 |  | Design, Build & Test (PIT) | Complete | COMPLETE | T3-DB-0147 | SITAG | T3 |
| 379 | 1.3.6.4.3.6.4.2 | All SIT Migration Test scenarios MHHS Reviews Completed | milestone | 0d | 2024-04-18 A | 2024-04-18 A | 378FS+30d | 100% | 2024-04-18 | 2024-04-18 | 0d |  |  |  |  | SI Test | PP | DBT | 5.25 |  | Design, Build & Test (PIT) | Complete | COMPLETE | T3-DB-0148 | SITAG | T3 |
| 380 | 1.3.6.4.3.6.5 | **PIT execution** |  | 51d | 2024-03-15 A | 2024-05-24 A |  | 100% | 2024-03-15 | 2024-05-24 | 301d |  |  |  | -0 | N/A | N/A | DBT | 5.1 | N/A | Design, Build & Test (PIT) |  |  |  |  |  |
| 381 | 1.3.6.4.3.6.5.1 | PIT Test Execution Progress Reports |  | 40d | 2024-03-18 A | 2024-05-10 A | 373 | 100% | 2024-03-18 | 2024-05-10 | 40d |  |  |  |  | PP | SI Test | DBT | 5.1 |  | Design, Build & Test (PIT) | Complete | COMPLETE |  |  |  |
| 382 | 1.3.6.4.3.6.5.2 | PIT Execution |  | 41d | 2024-03-15 A | 2024-05-10 A | 378FS+5d | 100% | 2024-03-15 | 2024-05-10 | 290d |  |  |  |  | PP | SI Test | DBT | 5.1 |  | Design, Build & Test (PIT) | Complete | COMPLETE |  |  |  |
| 383 | 1.3.6.4.3.6.5.3 | All SIT Migration PIT Completion Reports submitted to Programme for assurance | milestone | 0d | 2024-05-10 A | 2024-05-10 A | 381, 382 | 100% | 2024-05-10 | 2024-05-10 | 0d | 2024-01-05 | 2024-01-05 |  |  | PP | SI Test | DBT | 5.8 |  | Design, Build & Test (PIT) | Complete | COMPLETE | T3-DB-0149 | SITAG | T3 |
| 384 | 1.3.6.4.3.6.5.4 | All SIT Migration PIT Completion Reports MHHS Review Completed | milestone | 0d | 2024-05-24 A | 2024-05-24 A | 371, 376, 379, 383FS+10d | 100% | 2024-05-24 | 2024-05-24 | 0d |  |  |  |  | SI Test | PP | DBT | 5.8 |  | Design, Build & Test (PIT) | Complete | COMPLETE | T3-DB-0150 | SITAG | T3 |

| ID | WBS | Task | Type | Duration | Start | Finish | Predecessors | Complete | Remaining | Baseline start | Baseline finish | Baseline duration | Baseline 1 start | Baseline 1 finish | Total slack | Free slack | Constraint | Baseline cost | Responsible | Involved | Text9 | Update Version | MHHS Resource Name | MHHS Programme Phase | Sched Status | RAG | Milestone ID | Text29 | Tier | Guidance | Task Status |
| --- | --- | --- | --- | --- | --- | --- | --- | --- | --- | --- | --- | --- | --- | --- | --- | --- | --- | --- | --- | --- | --- | --- | --- | --- | --- | --- | --- | --- | --- | --- | --- |
| 385 | 1.3.6.4.3.7 | **All SIT Programme Participants PIT (SIT Non Functional)** |  | 161d | 2024-07-12 A | 2025-02-21 |  | 63% | 59.63d | 2024-07-12 | 2024-12-20 | 301d |  |  | 734d |  |  | -0 | N/A | N/A | DBT | 6.0 | N/A | Design, Build & Test (PIT) |  |  |  |  |  |  |  |
| 386 | 1.3.6.4.3.7.1 | **Test Approach & Plan** |  | 41d | 2024-09-27 A | 2024-11-22 |  |  | 41d | 2024-09-27 | 2024-11-22 | 40d |  |  | 21d |  |  | -0 | N/A | N/A | DBT | 6.0 | N/A | Design, Build & Test (PIT) |  |  |  |  |  |  |  |
| 387 | 1.3.6.4.3.7.1.1 | SIT Non-Functional PIT Test Approach & Plan (PIT) submitted to Programme for assurance | milestone | 0d | 2024-09-27 A | 2024-09-27 A |  | 100% |  | 2024-09-27 | 2024-09-27 | 0d |  |  |  |  | start no earlier than 2024-05-10 |  | PP | SI Test | DBT | 6.0 | Roger Robar | Design, Build & Test (PIT) | Complete | COMPLETE | T3-DB-0151 | SITAG | T3 |  |  |
| 388 | 1.3.6.4.3.7.1.2 | SIT Non-Functional Test approach and plan MHHS Review Completed |  | 1d | 2024-11-21 A | 2024-11-22 | 387FS+40d |  | 1d | 2024-11-21 | 2024-11-22 | 0d |  |  | 21d | 20d |  |  | SI Test | PP | DBT | 6.0 | Roger Robar | Design, Build & Test (PIT) | Green | RED | T3-DB-0152 | SITAG | T3 | 6/9/24: Approved at esitag on 26/7/24 | -68.67 |
| 389 | 1.3.6.4.3.7.2 | **Test Readiness Report** |  | 13d | 2024-10-04 A | 2024-10-22 |  | 85% | 2d | 2024-10-04 | 2024-10-22 | 51d |  |  | 0d |  |  |  | N/A | N/A | DBT | 6.0 | N/A | Design, Build & Test (PIT) |  |  |  |  |  |  |  |
| 390 | 1.3.6.4.3.7.2.1 | Test readiness reporting |  | 13d | 2024-10-04 A | 2024-10-22 | 387FS+10d | 85% | 2d | 2024-10-04 | 2024-10-22 | 51d |  |  | 0d |  |  |  | PP | 109 | DBT | 6.0 |  | Design, Build & Test (PIT) | Green | RED |  |  |  |  |  |
| 391 | 1.3.6.4.3.7.3 | **Requirements to test Traceability Matrix (RTTM)** |  | 20d | 2024-11-01 A | 2024-11-29 |  |  | 20d | 2024-11-01 | 2024-11-29 | 30d |  |  | 16d |  |  | -0 | N/A | N/A | DBT | 6.0 | N/A | Design, Build & Test (PIT) |  |  |  |  |  |  |  |
| 392 | 1.3.6.4.3.7.3.1 | SIT Non-Functional PIT RTTM submitted to Programme for assurance | milestone | 0d | 2024-11-01 A | 2024-11-01 A | 387FS+26d | 100% |  | 2024-11-01 | 2024-11-01 | 0d |  |  |  |  |  |  | PP | SI Test | DBT | 6.0 | Roger Robar | Design, Build & Test (PIT) | Complete | COMPLETE | T3-DB-0153 | SITAG | T3 |  |  |
| 393 | 1.3.6.4.3.7.3.2 | SIT Non-Functional RTTM MHHS Review Completed | milestone | 0d | 2024-11-29 | 2024-11-29 | 392FS+20d |  |  | 2024-11-29 | 2024-11-29 | 0d |  |  | 16d | 15d | start no earlier than 2024-11-29 |  | SI Test | PP | DBT | 6.0 | Roger Robar | Design, Build & Test (PIT) | Green | RED | T3-DB-0154 | SITAG | T3 |  | -60.29 |
| 394 | 1.3.6.4.3.7.4 | **Test Scenarios** |  | 20d | 2024-11-01 A | 2024-11-29 |  |  | 20d | 2024-11-01 | 2024-11-29 | 30d |  |  | 16d |  |  | -0 | N/A | N/A | DBT | 6.0 | N/A | Design, Build & Test (PIT) |  |  |  |  |  |  |  |
| 395 | 1.3.6.4.3.7.4.1 | SIT Non-Functional PIT test scenarios submitted to Programme for assurance | milestone | 0d | 2024-11-01 A | 2024-11-01 A | 387FS+26d | 100% |  | 2024-11-01 | 2024-11-01 | 0d |  |  |  |  |  |  | PP | SI Test | DBT | 6.0 | Roger Robar | Design, Build & Test (PIT) | Complete | COMPLETE | T3-DB-0155 | SITAG | T3 |  |  |
| 396 | 1.3.6.4.3.7.4.2 | SIT Non-Functional Test scenarios MHHS Review Completed | milestone | 0d | 2024-11-29 | 2024-11-29 | 395FS+20d |  |  | 2024-11-29 | 2024-11-29 | 0d |  |  | 16d | 15d |  |  | SI Test | PP | DBT | 6.0 | Roger Robar | Design, Build & Test (PIT) | Green | RED | T3-DB-0156 | SITAG | T3 |  | -60.29 |
| 397 | 1.3.6.4.3.7.5 | **PIT execution** |  | 161d | 2024-07-12 A | 2025-02-21 |  | 61% | 63.37d | 2024-07-12 | 2024-12-20 | 301d |  |  | 734d |  |  | -0 | N/A | N/A | DBT | 6.0 | N/A | Design, Build & Test (PIT) |  |  |  |  |  |  |  |
| 398 | 1.3.6.4.3.7.5.1 | PIT Test Execution Progress Report |  | 50d | 2024-07-15 A | 2024-11-21 | 390 | 56% | 22d | 2024-07-15 | 2024-11-21 | 39d |  |  | 7d | 6d | finish no earlier than 2024-11-21 |  | PP | SI Test | DBT | 6.0 | Roger Robar | Design, Build & Test (PIT) | Green | RED |  |  |  |  |  |
| 399 | 1.3.6.4.3.7.5.2 | PIT Execution |  | 44d | 2024-07-12 A | 2024-11-29 | 395FS+5d | 66% | 15d | 2024-07-12 | 2024-11-29 | 290d |  |  | 1d | 0d | finish no earlier than 2024-11-29 |  | PP | SI Test | DBT | 6.0 | Roger Robar | Design, Build & Test (PIT) | Green | RED |  |  |  |  |  |
| 400 | 1.3.6.4.3.7.5.3 | SIT Non-Functional PIT Completion Report submitted to Programme for assurance | milestone | 0d | 2024-11-29 | 2024-11-29 | 398, 399 |  |  | 2024-11-29 | 2024-11-29 | 0d | 2024-01-05 | 2024-01-05 | 1d | 0d |  |  | PP | SI Test | DBT | 6.0 | Roger Robar | Design, Build & Test (PIT) | Green | RED | T3-DB-0157 | SITAG | T3 |  | -60.29 |
| 401 | 1.3.6.4.3.7.5.4 | SIT Non-Functional PIT Completion Report Theme 1 MHHS Review Completed | milestone | 0d | 2024-12-20 A | 2024-12-20 | 388, 393, 396, 400FS+15d | 50% | 0d | 2024-12-20 | 2024-12-20 | 0d |  |  | 1d | 0d |  |  | SI Test | PP | DBT | 6.0 | Roger Robar | Design, Build & Test (PIT) | Green | RED | T3-DB-0158 | SITAG | T3 |  |  |
| 402 | 1.3.6.4.3.7.5.5 | SIT Non-Functional PIT Completion Report Theme 2 & 3 MHHS Review Completed | milestone | 0d | 2025-02-21 | 2025-02-21 | 388, 393, 396, 400FS+60d |  |  | 2025-02-21 | 2025-02-21 |  |  |  | 734d | 20d |  |  | SI Test |  | DBT | 6.13 |  |  | Green | GREEN | T3-DB-0186 | SITAG | T3 |  | 23.71 |
| 403 | 1.3.6.4.3.8 | **SIT Programme Participants PIT (SIT Operational Theme 1, 2, 3 (Batch 2))** |  | 146d | 2024-07-12 A | 2025-01-31 |  | 46% | 78.55d | 2024-07-12 | 2024-12-20 | 71d |  |  | 61d |  |  | -0 | N/A | N/A | DBT | 6.0 | N/A | Design, Build & Test (PIT) |  |  |  |  |  |  |  |
| 404 | 1.3.6.4.3.8.1 | **Test Approach & Plan** |  | 40d | 2024-09-27 A | 2024-11-21 |  |  | 40d | 2024-09-27 | 2024-11-21 | 40d |  |  | 112d |  |  | -0 | N/A | N/A | DBT | 6.0 | N/A | Design, Build & Test (PIT) |  |  |  |  |  |  |  |
| 405 | 1.3.6.4.3.8.1.1 | SIT Operational PIT Test Approach & Plan (PIT) submitted to Programme for assurance | milestone | 0d | 2024-09-27 A | 2024-09-27 A |  | 100% |  | 2024-09-27 | 2024-09-27 | 0d |  |  |  |  | start no earlier than 2024-09-27 |  | PP | SI Test | DBT | 6.0 | Roger Robar | Design, Build & Test (PIT) | Complete | COMPLETE | T3-DB-0159 | SITAG | T3 |  |  |
| 406 | 1.3.6.4.3.8.1.2 | SIT Operational Test approach and plan MHHS Review Completed | milestone | 0d | 2024-11-21 | 2024-11-21 | 405FS+40d |  |  | 2024-11-21 | 2024-11-21 | 0d |  |  | 112d | 51d |  |  | SI Test | PP | DBT | 6.0 | Roger Robar | Design, Build & Test (PIT) | Green | RED | T3-DB-0160 | SITAG | T3 |  | -68.29 |
| 407 | 1.3.6.4.3.8.2 | **Test Readiness Report** |  | 13d | 2024-10-04 A | 2024-10-22 |  | 42% | 7.5d | 2024-10-04 | 2024-10-22 | 51d |  |  | 0d |  |  |  | N/A | N/A | DBT | 6.0 | N/A | Design, Build & Test (PIT) |  |  |  |  |  |  |  |
| 408 | 1.3.6.4.3.8.2.1 | Test readiness reporting |  | 13d | 2024-10-04 A | 2024-10-22 | 405FS+10d | 42% | 7.5d | 2024-10-04 | 2024-10-22 | 51d |  |  | 0d |  |  |  | PP | 109 | DBT | 6.0 |  | Design, Build & Test (PIT) | Green | RED |  |  |  |  |  |

Notes:
- 388: 28/01/25 - 26/34 test approach reviews completed. Status is Red because some NF test approach and plans have not yet been assured. Programme continues to work with PPs to close out outstanding feedback on test approach and plans so drafting of the Overarching Readiness Report can proceed on schedule.
- 393: 28/01/25 - 24/34 RTTM reviews completed. Status is Red because some NF RTTMs have not yet been assured. Programme continues to work with PPs to close out outstanding feedback on RTTMs so drafting of the Overarching Readiness Report can proceed on schedule.
- 396: 28/01/25 - 22/34 test scenario reviews completed. Status is Red because some NF test scenarios have not yet been assured. Programme continues to work with PPs to close out outstanding feedback on scenarios so drafting of the Overarching Readiness Report can proceed on schedule.
- 400: 28/01/25 - 33/34 Non-Functional PIT Completion Reports submitted. Status is Red because there is an outstanding report due. Programme continues to work with the PP to receive the report so drafting of the Overarching Readiness Report can proceed on schedule.
- 401: 28/01/25 - 0/2 Theme 1 Completion Reports assured by the Programme. Status red as programme assurance on both reports has not yet completed. Programme continues to work with PPs to close out outstanding feedback on scenarios so drafting of the Overarching Readiness Report can proceed on schedule.
- 402: 28/01/25 - 10/34 Theme 2 & 3 Completion Reports assured by the Programme. Programme continues to work with PPs to close out outstanding feedback on scenarios so drafting of the Overarching Readiness Report can proceed on schedule. Status green because the deadline for assurance is 21/02/24, as agreed at NFTWG.
- 405: 28/01/25 - 33/34 test approach and plans have been submitted to the Programme, this however is complete because the final PP who have not submitted have a seperate approach and plan arragement agreed.
- 406: 28/01/25 - 28/34 test approach reviews completed. Status is Red because some Ops test approach and plans have not yet been assured. Programme continues to work with PPs to close out outstanding feedback on test approach and plans so drafting of the Overarching Readiness Report can proceed on schedule.

| ID | WBS | Task | Type | Duration | Start | Finish | Predecessors | Complete | Remaining | Baseline start | Baseline finish | Baseline duration | Baseline 1 start | Baseline 1 finish | Total slack | Free slack | Constraint | Baseline cost | Responsible | Involved | Text9 | Update Version | MHHS Resource Name | MHHS Programme Phase | Task Status | Sched Status | RAG | Milestone ID | Text29 | Tier |
| --- | --- | --- | --- | --- | --- | --- | --- | --- | --- | --- | --- | --- | --- | --- | --- | --- | --- | --- | --- | --- | --- | --- | --- | --- | --- | --- | --- | --- | --- | --- |
| 409 | 1.3.6.4.3.8.3 | **Requirements to test Traceability Matrix (RTTM)** |  | 20d | 2024-11-01 | 2024-11-29 |  |  |  | 2024-11-01 | 2024-11-29 | 30d |  |  | 106d |  |  | -0 | N/A | N/A | DBT | 6.0 | N/A | Design, Build & Test (PIT) |  |  |  |  |  |  |
| 410 | 1.3.6.4.3.8.3.1 | SIT Operational PIT RTTM submitted to Programme for assurance | milestone | 0d | 2024-11-01 | 2024-11-01 | 405FS+26d |  |  | 2024-11-01 | 2024-11-01 | 0d |  |  | 106d | 0d |  |  | PP | SI Test | DBT | 6.0 | Roger Robar | Design, Build & Test (PIT) | -88.29 | Green | RED | T3-DB-0161 | SITAG | T3 |
| 411 | 1.3.6.4.3.8.3.2 | SIT Operational RTTM MHHS Review Completed | milestone | 0d | 2024-11-29 | 2024-11-29 | 410FS+20d |  |  | 2024-11-29 | 2024-11-29 | 0d |  |  | 106d | 45d |  |  | SI Test | PP | DBT | 6.0 | Roger Robar | Design, Build & Test (PIT) | -60.29 | Green | RED | T3-DB-0162 | SITAG | T3 |
| 412 | 1.3.6.4.3.8.4 | **Test Scenarios** |  | 20d | 2024-11-01 | 2024-11-29 |  |  |  | 2024-11-01 | 2024-11-29 | 30d |  |  | 0d |  |  | -0 | N/A | N/A | DBT | 6.0 | N/A | Design, Build & Test (PIT) |  |  |  |  |  |  |
| 413 | 1.3.6.4.3.8.4.1 | SIT Operational PIT test scenarios submitted to Programme for assurance | milestone | 0d | 2024-11-01 | 2024-11-01 | 405FS+26d |  |  | 2024-11-01 | 2024-11-01 | 0d |  |  | 0d |  |  |  | PP | SI Test | DBT | 6.0 | Roger Robar | Design, Build & Test (PIT) | -88.29 | Green | RED | T3-DB-0163 | SITAG | T3 |
| 414 | 1.3.6.4.3.8.4.2 | SIT Operational Test scenarios MHHS Review Completed | milestone | 0d | 2024-11-29 | 2024-11-29 | 413FS+20d |  |  | 2024-11-29 | 2024-11-29 | 0d |  |  | 106d | 45d |  |  | SI Test | PP | DBT | 6.0 | Roger Robar | Design, Build & Test (PIT) | -60.29 | Green | RED | T3-DB-0164 | SITAG | T3 |
| 415 | 1.3.6.4.3.8.5 | **PIT execution** |  | 146d | 2024-07-12 A | 2025-01-31 |  | 47% | 77.62d | 2024-07-12 | 2024-12-20 | 51d |  |  | 61d |  |  | -0 | N/A | N/A | DBT | 6.0 | N/A | Design, Build & Test (PIT) |  |  |  |  |  |  |
| 416 | 1.3.6.4.3.8.5.1 | PIT Test Execution Progress Report |  | 40d | 2024-07-15 A | 2024-11-21 | 408 | 45% | 22d | 2024-07-15 | 2024-11-21 | 40d |  |  | 99d | 38d |  |  | PP | SI Test | DBT | 6.0 | Roger Robar | Design, Build & Test (PIT) |  | Green | RED |  |  |  |
| 417 | 1.3.6.4.3.8.5.2 | PIT Execution |  | 39d | 2024-07-12 A | 2024-11-29 | 413 | 49% | 20d | 2024-07-12 | 2024-11-29 | 41d |  |  | 61d | 0d |  |  | PP | SI Test | DBT | 6.0 | Roger Robar | Design, Build & Test (PIT) |  | Green | RED |  |  |  |
| 418 | 1.3.6.4.3.8.5.3 | SIT Operational Theme 1, 2, 3 (Batch 2) PIT Completion Report submitted to Programme for assurance | milestone | 0d | 2025-01-14 | 2025-01-14 | 416, 417FS+32d |  |  | 2024-11-29 | 2024-11-29 | 0d | 2024-01-05 | 2024-01-05 | 61d | 0d |  |  | PP | SI Test | DBT | 6.0 | Roger Robar | Design, Build & Test (PIT) | -14.29 | Red | RED | T3-DB-0165 | SITAG | T3 |
| 419 | 1.3.6.4.3.8.5.4 | SIT Operational Theme 1, 2, 3 (Batch 2) PIT Completion Report MHHS Review Completed | milestone | 0d | 2025-01-31 | 2025-01-31 | 406, 411, 414, 418FS+13d |  |  | 2025-01-31 | 2025-01-31 | 0d |  |  | 61d | 40d |  |  | SI Test | PP | DBT | 6.0 | Roger Robar | Design, Build & Test (PIT) | 2.71 | Green | RED | T3-DB-0166 | SITAG | T3 |
| 420 | 1.3.6.4.3.9 | **SIT Programme Participants PIT (SIT Operational Theme 3 (Batch 1))** |  | 76d | 2024-09-27 A | 2025-01-10 |  |  | 76d | 2024-09-27 | 2025-01-10 |  |  |  | 769d |  |  |  |  |  | DBT | 6.17 |  |  | -814.67 | Overdue Start | RED |  |  |  |
| 421 | 1.3.6.4.3.9.1 | **Test Approach & Plan** |  | 40d | 2024-09-27 A | 2024-11-21 A |  | 100% |  | 2024-09-27 | 2024-11-21 |  |  |  |  |  |  |  |  |  | DBT | 6.17 | Roger Rober |  | -814.67 | Overdue Start |  |  |  |  |
| 422 | 1.3.6.4.3.9.1.1 | SIT Operational PIT Test Approach& Plan (PIT) submitted to Programme for assurance | milestone | 0d | 2024-09-27 A | 2024-09-27 A |  | 100% |  | 2024-09-27 | 2024-09-27 |  |  |  |  |  | start no earlier than 2024-09-27 |  |  |  | DBT | 6.17 | Roger Rober |  |  | Complete | COMPLETE |  |  |  |
| 423 | 1.3.6.4.3.9.1.2 | SIT Operational Test approach and plan MHHS Review Completed | milestone | 0d | 2024-11-21 A | 2024-11-21 A | 422FS+40d | 100% |  | 2024-11-21 | 2024-11-21 |  |  |  |  |  |  |  |  |  | DBT | 6.17 | Roger Rober |  |  | Complete | COMPLETE |  |  |  |
| 424 | 1.3.6.4.3.9.2 | **Test Readiness Report** |  | 13d | 2024-10-04 | 2024-10-22 |  |  |  | 2024-10-04 | 2024-10-22 |  |  |  | 787d |  |  |  |  |  | DBT | 6.17 | Roger Rober |  | -814.67 | Overdue Start |  |  |  |  |
| 425 | 1.3.6.4.3.9.2.1 | Test readiness reporting |  | 13d | 2024-10-04 | 2024-10-22 | 422FS+5d |  |  | 2024-10-04 | 2024-10-22 |  |  |  | 787d | 0d |  |  |  |  | DBT | 6.17 | Roger Rober |  | -116.67 | Overdue Start | GREEN |  |  |  |
| 426 | 1.3.6.4.3.9.3 | **Requirements to test Traceability Matrix (RTTM)** |  | 20d | 2024-11-01 A | 2024-11-29 A |  | 100% |  | 2024-11-01 | 2024-11-29 |  |  |  |  |  |  |  |  |  | DBT | 6.17 | Roger Rober |  | -814.67 | Overdue Start |  |  |  |  |
| 427 | 1.3.6.4.3.9.3.1 | SIT Operational PIT RTTM submitted to Programme for assurance | milestone | 0d | 2024-11-01 A | 2024-11-01 A | 422FS+26d | 100% |  | 2024-11-01 | 2024-11-01 |  |  |  |  |  |  |  |  |  | DBT | 6.17 | Roger Rober |  |  | Complete | COMPLETE |  |  |  |
| 428 | 1.3.6.4.3.9.3.2 | SIT Operational RTTM MHHS Review Completed | milestone | 0d | 2024-11-29 A | 2024-11-29 A | 427FS+20d | 100% |  | 2024-11-29 | 2024-11-29 |  |  |  |  |  |  |  |  |  | DBT | 6.17 | Roger Rober |  |  | Complete | COMPLETE |  |  |  |
| 429 | 1.3.6.4.3.9.4 | **Test Scenarios** |  | 20d | 2024-11-01 A | 2024-11-29 A |  | 100% |  | 2024-11-01 | 2024-11-29 |  |  |  |  |  |  |  |  |  | DBT | 6.17 | Roger Rober |  | -814.67 | Overdue Start |  |  |  |  |
| 430 | 1.3.6.4.3.9.4.1 | SIT Operational PIT test scenarios submitted to Programme for assurance | milestone | 0d | 2024-11-01 A | 2024-11-01 A | 422FS+26d | 100% |  | 2024-11-01 | 2024-11-01 |  |  |  |  |  |  |  |  |  | DBT | 6.17 | Roger Rober |  |  | Complete | COMPLETE |  |  |  |
| 431 | 1.3.6.4.3.9.4.2 | SIT Operational Test scenarios MHHS Review Completed | milestone | 0d | 2024-11-29 A | 2024-11-29 A | 430FS+20d | 100% |  | 2024-11-29 | 2024-11-29 |  |  |  |  |  |  |  |  |  | DBT | 6.17 | Roger Rober |  |  | Complete | COMPLETE |  |  |  |
| 432 | 1.3.6.4.3.9.5 | **PIT execution** |  | 58d | 2024-10-23 A | 2025-01-10 |  |  | 58d | 2024-10-23 | 2025-01-10 |  |  |  | 769d |  |  |  |  |  | DBT | 6.17 | Roger Rober |  | -814.67 | Overdue Start |  |  |  |  |
| 433 | 1.3.6.4.3.9.5.1 | PIT Test Execution Progress Report |  | 40d | 2024-10-23 | 2024-12-17 | 425 |  |  | 2024-10-23 | 2024-12-17 |  |  |  | 787d |  |  |  |  |  | DBT | 6.17 | Roger Rober |  | -97.67 | Green | RED |  |  |  |
| 434 | 1.3.6.4.3.9.5.2 | PIT Execution |  | 39d | 2024-11-04 | 2024-12-26 | 430 |  |  | 2024-11-04 | 2024-12-26 |  |  |  | 780d |  |  |  |  |  | DBT | 6.17 | Roger Rober |  | -85.67 | Green | RED |  |  |  |
| 435 | 1.3.6.4.3.9.5.3 | SIT Operational Theme 3 (Batch 1) PIT Completion Report submitted to Programme for assurance | milestone | 0d | 2025-01-10 A | 2025-01-10 A | 416, 417FS+30d | 100% |  | 2025-01-10 | 2025-01-10 |  |  |  |  |  |  |  |  |  | DBT | 6.17 | Roger Rober |  |  | Complete | COMPLETE |  |  |  |
| 436 | 1.3.6.4.3.9.5.4 | SIT Operational Theme 3 (Batch 1) PIT Completion Report MHHS Review Completed | milestone | 0d | 2025-01-10 | 2025-01-10 | 440, 445, 448, 452, 435 |  |  | 2025-01-10 | 2025-01-10 |  |  |  | 769d |  |  |  |  |  | DBT | 6.17 | Roger Rober |  | -18.29 | Green | RED |  |  |  |

Notes:
- 410: 28/01/25 - 33/34 RTTM reviews completed. Status is Red because some Ops RTTMs have not yet been submitted. Programme continues to work with the PP to recieve the final RTTM so drafting of the Overarching Readiness Report can proceed on schedule.
- 411: 28/01/25 - 27/34 RTTM reviews completed. Status is Red because some Ops RTTMs have not yet been assured. Programme continues to work with PPs to close out outstanding feedback on RTTMs so drafting of the Overarching Readiness Report can proceed on schedule.
- 413: 28/01/25 - 33/34 test scenario reviews completed. Status is Red because some Ops test scenarios have not yet been submitted to the Programme for assurance. Programme continues to work with PPs to recieve final test scenario so drafting of the Overarching Readiness Report can proceed on schedule.
- 414: 28/01/25 - 28/34 test scenario reviews completed. Status is Red because some Ops test scenarios have not yet been submitted to the Programme for assurance. Programme continues to work with PPs to receive final test scenario so drafting of the Overarching Readiness Report can proceed on schedule.
- 418: 28/01/25 - 28/34 Operational PIT Completion Reports submitted. Status is Red because there is an outstanding report due. Programme continues to work with PPs to recieve reports so drafting of the Overarching Readiness Report can proceed on schedule.
- 419: 28/01/25 - 13/34 Ops Completion Reports assured by the Programme. Programme continues to work with PPs to close out outstanding feedback on scenarios so drafting of the Overarching Readiness Report can proceed on schedule. RAG is red because at current velocity assurance won't be completed by the deadline.
- 422: 27/01/25 - Programme created new activities to track Ops Theme 3 (Batch 1) PIT submission figures.
- 423: 27/01/25 - Programme created new activities to track Ops Theme 3 (Batch 1) PIT submission figures.
- 425: 27/01/25 - Programme created new activities to track Ops Theme 3 (Batch 1) PIT submission figures.
- 427: 27/01/25 - Programme created new activities to track Ops Theme 3 (Batch 1) PIT submission figures.
- 428: 27/01/25 - Programme created new activities to track Ops Theme 3 (Batch 1) PIT submission figures.
- 430: 27/01/25 - Programme created new activities to track Ops Theme 3 (Batch 1) PIT submission figures.
- 431: 27/01/25 - Programme created new activities to track Ops Theme 3 (Batch 1) PIT submission figures.
- 433: 27/01/25 - Programme created new activities to track Ops Theme 3 (Batch 1) PIT submission figures.
- 434: 27/01/25 - Programme created new activities to track Ops Theme 3 (Batch 1) PIT submission figures.
- 436: 27/01/25 - 11/13 Ops Theme 3 (Batch 1) PIT Completion Reports submitted. Programme workign with PPs to close out feedback ahead of Theme 3 (Batch 1) testing start on 03/02/25. Programme created new activities to track Ops Theme 3 (Batch 1) PIT submission figures.

| ID | WBS | Task | Type | Duration | Start | Finish | Predecessors | Complete | Baseline start | Baseline finish | Baseline duration | Baseline 1 start | Baseline 1 finish | Constraint | Baseline cost | Responsible | Involved | Text9 | Update Version | MHHS Resource Name | MHHS Programme Phase | Sched Status | RAG | Milestone ID | Text29 | Tier | Artefact ID |
| --- | --- | --- | --- | --- | --- | --- | --- | --- | --- | --- | --- | --- | --- | --- | --- | --- | --- | --- | --- | --- | --- | --- | --- | --- | --- | --- | --- |
| 437 | 1.3.6.4.4 | **All Suppliers DBT CIT (Entering at Interval 5)** |  | 71d | 2023-09-15 A | 2023-12-22 A |  | 100% | 2023-09-15 | 2023-12-22 | 300d | 2022-10-31 | 2025-03-14 |  | -0 | N/A | N/A | DBT | 6.0 | N/A | Design, Build & Test (PIT) |  |  |  |  |  |  |
| 438 | 1.3.6.4.4.1 | **Test Approach & Plan** |  | 20d | 2023-09-15 A | 2023-10-12 A |  | 100% | 2023-09-15 | 2023-10-12 | 19d | 2022-10-31 | 2023-09-29 |  | -0 | N/A | N/A | DBT | 6.0 | N/A | Design, Build & Test (PIT) |  |  |  |  |  |  |
| 439 | 1.3.6.4.4.1.1 | All SIT Suppliers Test Approach & Plans (PIT) submitted to Programme for assurance | milestone | 0d | 2023-09-15 A | 2023-09-15 A |  | 100% | 2023-09-15 | 2023-09-15 | 0d | 2023-09-15 | 2023-09-15 | start no earlier than 2023-09-15 |  | PP | SI Test | DBT | 6.0 |  | Design, Build & Test (PIT) | Complete | COMPLETE | T3-DB-0046 | SITAG | T3 |  |
| 440 | 1.3.6.4.4.1.2 | All SIT Suppliers Test Approach & Plans MHHS Review Completed | milestone | 0d | 2023-10-12 A | 2023-10-12 A | 439FS+20d | 100% | 2023-10-12 | 2023-10-12 | 0d | 2023-09-18 | 2023-09-29 |  |  | SI Test | PP | DBT | 6.0 |  | Design, Build & Test (PIT) | Complete | COMPLETE | T3-DB-0167 | SITAG | T3 |  |
| 441 | 1.3.6.4.4.2 | **Test Readiness Report** |  | 11d | 2023-09-29 A | 2023-10-13 A |  | 100% | 2023-09-29 | 2023-10-13 | 51d | 2023-09-29 | 2023-12-08 |  |  | N/A | N/A | DBT | 6.0 | N/A | Design, Build & Test (PIT) |  |  |  |  |  |  |
| 442 | 1.3.6.4.4.2.1 | Test readiness reporting |  | 11d | 2023-09-29 A | 2023-10-13 A | 439FS+10d | 100% | 2023-09-29 | 2023-10-13 | 51d | 2023-09-29 | 2023-12-08 |  |  | PP | 109 | DBT | 6.0 |  | Design, Build & Test (PIT) | Complete | COMPLETE |  |  |  |  |
| 443 | 1.3.6.4.4.3 | **Requirements to test Traceability Matrix (RTTM)** |  | 20d | 2023-10-06 A | 2023-11-03 A |  | 100% | 2023-10-06 | 2023-11-03 | 21d | 2022-10-31 | 2023-10-20 |  | -0 | N/A | N/A | DBT | 6.0 | N/A | Design, Build & Test (PIT) |  |  |  |  |  |  |
| 444 | 1.3.6.4.4.3.1 | All SIT Suppliers RTTMs submitted to Programme for assurance | milestone | 0d | 2023-10-06 A | 2023-10-06 A | 439FS+16d | 100% | 2023-10-06 | 2023-10-06 | 1d | 2023-10-06 | 2023-10-06 |  |  | PP | SI Test | DBT | 6.0 |  | Design, Build & Test (PIT) | Complete | COMPLETE | T3-DB-0064 | SITAG | T3 | MHHS-ART009 |
| 445 | 1.3.6.4.4.3.2 | All SIT Suppliers RTTMs MHHS Review Completed | milestone | 0d | 2023-11-03 A | 2023-11-03 A | 444FS+20d | 100% | 2023-11-03 | 2023-11-03 | 0d | 2023-10-09 | 2023-10-20 |  |  | SI Test | PP | DBT | 6.0 |  | Design, Build & Test (PIT) | Complete | COMPLETE | T3-DB-0168 | SITAG | T3 |  |
| 446 | 1.3.6.4.4.4 | **Test Scenarios** |  | 20d | 2023-10-05 A | 2023-11-02 A |  | 100% | 2023-10-05 | 2023-11-02 | 20d | 2022-10-31 | 2023-10-20 |  | -0 | N/A | N/A | DBT | 6.0 | N/A | Design, Build & Test (PIT) |  |  |  |  |  |  |
| 447 | 1.3.6.4.4.4.1 | All SIT Suppliers test scenarios' submitted to Programme for assurance | milestone | 0d | 2023-10-05 A | 2023-10-05 A | 439FS+15d | 100% | 2023-10-05 | 2023-10-05 | 0d | 2023-10-06 | 2023-10-06 |  |  | PP | SI Test | DBT | 6.0 |  | Design, Build & Test (PIT) | Complete | COMPLETE | T3-DB-0037 | SITAG | T3 |  |
| 448 | 1.3.6.4.4.4.2 | All SIT Suppliers Test scenarios' MHHS Review Completed | milestone | 0d | 2023-11-02 A | 2023-11-02 A | 447FS+20d | 100% | 2023-11-02 | 2023-11-02 | 0d | 2023-10-09 | 2023-10-20 |  |  | SI Test | PP | DBT | 6.0 |  | Design, Build & Test (PIT) | Complete | COMPLETE | T3-DB-0169 | SITAG | T3 |  |
| 449 | 1.3.6.4.4.5 | **PIT execution** |  | 51d | 2023-10-13 A | 2023-12-22 A |  | 100% | 2023-10-13 | 2023-12-22 | 300d | 2022-10-31 | 2023-12-08 |  | -0 | N/A | N/A | DBT | 6.0 | N/A | Design, Build & Test (PIT) |  |  |  |  |  |  |
| 450 | 1.3.6.4.4.5.1 | PIT Test Execution Progress Report |  | 40d | 2023-10-16 A | 2023-12-08 A | 447FS+5d, 442 | 100% | 2023-10-16 | 2023-12-08 | 40d | 2022-10-31 | 2023-12-01 |  |  | PP | SI Test | DBT | 6.0 |  | Design, Build & Test (PIT) | Complete | COMPLETE |  |  |  |  |
| 451 | 1.3.6.4.4.5.2 | PIT Execution |  | 41d | 2023-10-13 A | 2023-12-08 A | 447FS+5d | 100% | 2023-10-13 | 2023-12-08 | 290d | 2022-10-31 | 2023-12-08 |  |  | PP | SI Test | DBT | 6.0 |  | Design, Build & Test (PIT) | Complete | COMPLETE |  |  |  |  |
| 452 | 1.3.6.4.4.5.3 | All SIT Suppliers PIT Completion Reports submitted to Programme for assurance | milestone | 0d | 2023-12-08 A | 2023-12-08 A | 451, 450 | 100% | 2023-12-08 | 2023-12-08 | 0d | 2024-01-05 | 2024-01-05 |  |  | PP | SI Test | DBT | 6.0 |  | Design, Build & Test (PIT) | Complete | COMPLETE | T3-DB-0170 | SITAG | T3 |  |
| 453 | 1.3.6.4.4.5.4 | All SIT Suppliers PIT Completion Reports MHHS Review Completed | milestone | 0d | 2023-12-22 A | 2023-12-22 A | 452FS+10d, 440, 445, 448 | 100% | 2023-12-22 | 2023-12-22 | 0d |  |  |  |  | SI Test | PP | DBT | 6.0 |  | Design, Build & Test (PIT) | Complete | COMPLETE | T3-DB-0171 | SITAG | T3 |  |
| 454 | 1.3.6.4.5 | **All LDSO Network Operations DBT CIT (Entering at Interval 5)** |  | 71d | 2023-09-15 A | 2023-12-22 A |  | 100% | 2023-09-15 | 2023-12-22 | 310d | 2022-10-31 | 2025-03-14 |  | -0 | N/A | N/A | DBT | 5.0 | N/A | Design, Build & Test (PIT) |  |  |  |  |  |  |
| 455 | 1.3.6.4.5.1 | **Test Approach & Plan** |  | 71d | 2023-09-15 A | 2023-12-22 A |  | 100% | 2023-09-15 | 2023-12-22 | 310d | 2022-10-31 | 2023-08-11 |  | -0 | N/A | N/A | DBT | 5.0 | N/A | Design, Build & Test (PIT) |  |  |  |  |  |  |
| 456 | 1.3.6.4.5.1.1 | All Network Operation Test Approach & Plans (PIT) submitted to Programme for assurance | milestone | 0d | 2023-09-15 A | 2023-09-15 A |  | 100% | 2023-09-15 | 2023-09-15 | 0d | 2023-07-28 | 2023-07-28 | start no earlier than 2023-09-15 |  | PP | SI Test | DBT | 5.8 |  | Design, Build & Test (PIT) | Complete | COMPLETE | T3-DB-0054 | SITAG | T3 |  |
| 457 | 1.3.6.4.5.1.2 | All Network Operation Test Approach & Plans MHHS Review Completed | milestone | 0d | 2023-10-12 A | 2023-10-12 A | 456FS+20d | 100% | 2023-10-12 | 2023-10-12 | 0d | 2023-07-31 | 2023-08-11 |  |  | SI Test | PP | DBT | 5.8 |  | Design, Build & Test (PIT) | Complete | COMPLETE | T3-DB-0172 | SITAG | T3 |  |
| 458 | 1.3.6.4.5.1.3 | **Test Readiness Report** |  | 11d | 2023-09-29 A | 2023-10-13 A |  | 100% | 2023-09-29 | 2023-10-13 | 51d | 2023-08-11 | 2023-10-20 |  |  | N/A | N/A | DBT | 5.0 | N/A | Design, Build & Test (PIT) |  |  |  |  |  |  |
| 459 | 1.3.6.4.5.1.3.1 | Test readiness reporting |  | 11d | 2023-09-29 A | 2023-10-13 A | 456FS+10d | 100% | 2023-09-29 | 2023-10-13 | 51d | 2023-08-11 | 2023-10-20 |  |  | PP | 109 | DBT | 5.0 |  | Design, Build & Test (PIT) | Complete | COMPLETE |  |  |  |  |
| 460 | 1.3.6.4.5.1.4 | **Requirements to test Traceability Matrix (RTTM)** |  | 20d | 2023-10-05 A | 2023-11-02 A |  | 100% | 2023-10-05 | 2023-11-02 | 20d | 2022-10-31 | 2023-09-15 |  | -0 | N/A | N/A | DBT | 5.0 | N/A | Design, Build & Test (PIT) |  |  |  |  |  |  |
| 461 | 1.3.6.4.5.1.4.1 | All Network Operation RTTMs submitted to Programme for assurance | milestone | 0d | 2023-10-05 A | 2023-10-05 A | 456FS+15d | 100% | 2023-10-05 | 2023-10-05 | 0d | 2023-09-01 | 2023-09-01 | start no earlier than 2023-04-28 |  | PP | SI Test | DBT | 5.8 |  | Design, Build & Test (PIT) | Complete | COMPLETE | T3-DB-0062 | SITAG | T3 | MHHS-ART009 |
| 462 | 1.3.6.4.5.1.4.2 | All Network Operation RTTMs MHHS Review Completed | milestone | 0d | 2023-11-02 A | 2023-11-02 A | 461FS+20d | 100% | 2023-11-02 | 2023-11-02 | 0d | 2023-09-04 | 2023-09-15 |  |  | SI Test | PP | DBT | 5.14 |  | Design, Build & Test (PIT) | Complete | COMPLETE | T3-DB-0173 | SITAG | T3 |  |

| ID | WBS | Task | Type | Duration | Start | Finish | Predecessors | Complete | Actual start | Actual finish | Baseline start | Baseline finish | Baseline duration | Baseline 1 start | Baseline 1 finish | Constraint | Baseline cost | Responsible | Involved | Text9 | Update Version | MHHS Resource Name | MHHS Programme Phase | Sched Status | RAG | Milestone ID | Text29 | Tier | Artefact ID |
| --- | --- | --- | --- | --- | --- | --- | --- | --- | --- | --- | --- | --- | --- | --- | --- | --- | --- | --- | --- | --- | --- | --- | --- | --- | --- | --- | --- | --- | --- |
| 463 | 1.3.6.4.5.1.5 | **Test Scenarios** |  | 20d | 2023-10-05 A | 2023-11-02 A |  | 100% |  |  | 2023-10-05 | 2023-11-02 | 20d | 2022-10-31 | 2023-09-15 |  | -0 | N/A | N/A | DBT | 5.0 | N/A | Design, Build & Test (PIT) |  |  |  |  |  |  |
| 464 | 1.3.6.4.5.1.5.1 | All Network Operation test scenarios' submitted to Programme for assurance | milestone | 0d | 2023-10-05 A | 2023-10-05 A | 456FS+15d | 100% |  |  | 2023-10-05 | 2023-10-05 | 0d | 2023-09-01 | 2023-09-01 |  |  | PP | SI Test | DBT | 5.8 |  | Design, Build & Test (PIT) | Complete | COMPLETE | T3-DB-0011 | SITAG | T3 |  |
| 465 | 1.3.6.4.5.1.5.2 | All Network Operation test scenarios' MHHS Review Completed | milestone | 0d | 2023-11-02 A | 2023-11-02 A | 464FS+20d | 100% |  |  | 2023-11-02 | 2023-11-02 | 0d | 2023-09-04 | 2023-09-15 |  |  | SI Test | PP | DBT | 5.14 |  | Design, Build & Test (PIT) | Complete | COMPLETE | T3-DB-0174 | SITAG | T3 |  |
| 466 | 1.3.6.4.5.1.6 | **PIT execution** |  | 51d | 2023-10-13 A | 2023-12-22 A |  | 100% |  |  | 2023-10-13 | 2023-12-22 | 310d | 2022-10-31 | 2024-01-05 |  | -0 | N/A | N/A | DBT | 5.0 | N/A | Design, Build & Test (PIT) |  |  |  |  |  |  |
| 467 | 1.3.6.4.5.1.6.1 | PIT Test Execution Progress Report |  | 40d | 2023-10-16 A | 2023-12-08 A | 464FS+5d, 459 | 100% |  |  | 2023-10-16 | 2023-12-08 | 305d | 2022-10-31 | 2023-12-29 |  |  | PP | SI Test | DBT | 5.0 |  | Design, Build & Test (PIT) | Complete | COMPLETE |  |  |  |  |
| 468 | 1.3.6.4.5.1.6.2 | PIT Execution |  | 41d | 2023-10-13 A | 2023-12-08 A | 464FS+5d | 100% |  |  | 2023-10-13 | 2023-12-08 | 310d | 2022-10-31 | 2024-01-05 |  |  | PP | SI Test | DBT | 5.0 |  | Design, Build & Test (PIT) | Complete | COMPLETE |  |  |  |  |
| 469 | 1.3.6.4.5.1.6.3 | All Network Operation PIT (CIT interval 5) Completion Reports submitted to Programme for assurance | milestone | 0d | 2023-12-08 A | 2023-12-08 A | 468, 467 | 100% |  |  | 2023-12-08 | 2023-12-08 | 0d | 2024-01-05 | 2024-01-05 |  |  | PP | SI Test | DBT | 5.0 |  | Design, Build & Test (PIT) | Complete | COMPLETE | T3-DB-0175 | SITAG | T3 |  |
| 470 | 1.3.6.4.5.1.6.4 | All Network Operation PIT (CIT interval 5) Completion Reports MHHS Review Completed | milestone | 0d | 2023-12-22 A | 2023-12-22 A | 469FS+10d, 457, 462, 465 | 100% |  |  | 2023-12-22 | 2023-12-22 | 0d |  |  |  |  | SI Test | PP | DBT | 5.15 |  | Design, Build & Test (PIT) | Complete | COMPLETE | T3-DB-0176 | SITAG | T3 |  |
| 471 | 1.3.6.4.6 | **All UMSO DBT CIT (Entering at Interval 6)** |  | 81d | 2023-09-29 | 2024-01-19 A |  | 100% | 2023-10-13 |  | 2023-09-29 | 2024-01-19 | 320d | 2022-10-31 | 2024-05-13 |  | -0 | N/A | N/A | DBT | 5.0 | N/A | Design, Build & Test (PIT) |  |  |  |  |  |  |
| 472 | 1.3.6.4.6.1 | **Test Approach & Plan** |  | 20d | 2023-10-13 A | 2023-11-09 A |  | 100% |  |  | 2023-10-13 | 2023-11-09 | 40d | 2022-10-31 | 2023-09-29 |  | -0 | N/A | N/A | DBT | 5.0 | N/A | Design, Build & Test (PIT) |  |  |  |  |  |  |
| 473 | 1.3.6.4.6.1.1 | All UMSO Test Approach & Plans (PIT) submitted to Programme for assurance | milestone | 0d | 2023-10-13 A | 2023-10-13 A |  | 100% |  |  | 2023-10-13 | 2023-10-13 | 0d | 2023-09-15 | 2023-09-15 | start no earlier than 2023-10-13 |  | PP | SI Test | DBT | 5.11 |  | Design, Build & Test (PIT) | Complete | COMPLETE | T3-DB-0052 | SITAG | T3 |  |
| 474 | 1.3.6.4.6.1.2 | All UMSO Test Approach & Plans MHHS Review Completed | milestone | 0d | 2023-11-09 A | 2023-11-09 A | 473FS+20d | 100% |  |  | 2023-11-09 | 2023-11-09 | 0d | 2023-09-18 | 2023-09-29 |  |  | SI Test | PP | DBT | 5.10 |  | Design, Build & Test (PIT) | Complete | COMPLETE | T3-DB-0177 | SITAG | T3 |  |
| 475 | 1.3.6.4.6.2 | **Test Readiness Report** |  | 11d | 2023-09-29 | 2023-10-13 |  | 100% | 2023-10-27 | 2023-11-10 | 2023-09-29 | 2023-10-13 | 11d | 2023-09-29 | 2023-12-08 |  | -0 | N/A | N/A | DBT | 5.0 | N/A | Design, Build & Test (PIT) |  |  |  |  |  |  |
| 476 | 1.3.6.4.6.2.1 | Test readiness reporting |  | 11d | 2023-10-27 A | 2023-11-10 A | 473FS+10d | 100% |  |  | 2023-10-27 | 2023-11-10 | 11d | 2023-09-29 | 2023-12-08 |  |  | PP | 109 | DBT | 5.0 |  | Design, Build & Test (PIT) | Complete | COMPLETE |  |  |  |  |
| 477 | 1.3.6.4.6.3 | **Requirements to test Traceability Matrix (RTTM)** |  | 20d | 2023-10-05 | 2023-11-01 |  | 100% | 2023-11-02 | 2023-11-30 | 2023-10-05 | 2023-11-01 | 20d | 2022-10-31 | 2023-10-20 |  | -0 | N/A | N/A | DBT | 5.0 | N/A | Design, Build & Test (PIT) |  |  |  |  |  |  |
| 478 | 1.3.6.4.6.3.1 | All UMSO RTTMs submitted to Programme for assurance | milestone | 0d | 2023-11-02 A | 2023-11-02 A | 473FS+15d | 100% |  |  | 2023-11-02 | 2023-11-02 | 0d | 2023-10-06 | 2023-10-06 |  |  | PP | SI Test | DBT | 5.12 |  | Design, Build & Test (PIT) | Complete | COMPLETE | T3-DB-0060 | SITAG | T3 | MHHS-ART009 |
| 479 | 1.3.6.4.6.3.2 | All UMSO RTTMs MHHS Review Completed | milestone | 0d | 2023-11-30 A | 2023-11-30 A | 478FS+20d | 100% |  |  | 2023-11-30 | 2023-11-30 | 0d | 2023-10-09 | 2023-10-20 |  |  | SI Test | PP | DBT | 5.12 |  | Design, Build & Test (PIT) | Complete | COMPLETE | T3-DB-0178 | SITAG | T3 |  |
| 480 | 1.3.6.4.6.4 | **Test Scenarios** |  | 20d | 2023-10-05 | 2023-11-01 |  | 100% | 2023-11-02 | 2023-11-30 | 2023-10-05 | 2023-11-01 | 20d | 2022-10-31 | 2023-10-20 |  | -0 | N/A | N/A | DBT | 5.0 | N/A | Design, Build & Test (PIT) |  |  |  |  |  |  |
| 481 | 1.3.6.4.6.4.1 | All UMSO test scenarios' submitted to Programme for assurance | milestone | 0d | 2023-11-02 A | 2023-11-02 A | 473FS+15d | 100% |  |  | 2023-11-02 | 2023-11-02 | 0d | 2023-10-06 | 2023-10-06 |  |  | PP | SI Test | DBT | 5.12 |  | Design, Build & Test (PIT) | Complete | COMPLETE | T3-DB-0025 | SITAG | T3 |  |
| 482 | 1.3.6.4.6.4.2 | All UMSO Test scenarios' MHHS Review Completed | milestone | 0d | 2023-11-30 A | 2023-11-30 A | 481FS+20d | 100% |  |  | 2023-11-30 | 2023-11-30 | 0d | 2023-10-09 | 2023-10-20 |  |  | SI Test | PP | DBT | 5.10 |  | Design, Build & Test (PIT) | Complete | COMPLETE | T3-DB-0179 | SITAG | T3 |  |
| 483 | 1.3.6.4.6.5 | **PIT execution** |  | 51d | 2023-11-10 A | 2024-01-19 A |  | 100% |  |  | 2023-11-10 | 2024-01-19 | 320d | 2022-10-31 | 2023-12-08 |  | -0 | N/A | N/A | DBT | 5.0 | N/A | Design, Build & Test (PIT) |  |  |  |  |  |  |
| 484 | 1.3.6.4.6.5.1 | PIT Test Execution Progress Report |  | 40d | 2023-11-13 A | 2024-01-05 A | 481FS+5d, 476 | 100% |  |  | 2023-11-13 | 2024-01-05 | 40d | 2022-10-31 | 2023-12-01 |  |  | PP | SI Test | DBT | 5.0 |  | Design, Build & Test (PIT) | Complete | COMPLETE |  |  |  |  |
| 485 | 1.3.6.4.6.5.2 | PIT Execution |  | 40d | 2023-11-10 A | 2024-01-04 A | 481FS+5d | 100% |  |  | 2023-11-10 | 2024-01-04 | 290d | 2022-10-31 | 2023-12-08 |  |  | PP | SI Test | DBT | 5.0 |  | Design, Build & Test (PIT) | Complete | COMPLETE |  |  |  |  |
| 486 | 1.3.6.4.6.5.3 | All UMSO PIT (CIT interval 6) Completion Reports submitted to Programme for assurance | milestone | 0d | 2024-01-05 A | 2024-01-05 A | 485, 484 | 100% |  |  | 2024-01-05 | 2024-01-05 | 0d | 2024-01-05 | 2024-01-05 |  |  | PP | SI Test | DBT | 5.10 |  | Design, Build & Test (PIT) | Complete | COMPLETE | T3-DB-0180 | SITAG | T3 |  |
| 487 | 1.3.6.4.6.5.4 | All UMSO PIT (CIT interval 6) Completion Reports MHHS Review Completed | milestone | 0d | 2024-01-19 A | 2024-01-19 A | 474, 479, 482, 486FS+10d | 100% |  |  | 2024-01-19 | 2024-01-19 | 0d |  |  |  |  | SI Test | PP | DBT | 5.10 |  | Design, Build & Test (PIT) | Complete | COMPLETE | T3-DB-0181 | SITAG | T3 |  |

| ID | WBS | Task | Type | Duration | Start | Finish | Predecessors | Complete | Remaining | Baseline start | Baseline finish | Baseline duration | Baseline 1 start | Baseline 1 finish | Total slack | Constraint | Responsible | Involved | Text9 | Update Version | MHHS Resource Name | MHHS Programme Phase | Task Status | Sched Status | RAG | Milestone ID | Text29 | Tier | Artefact ID |
| --- | --- | --- | --- | --- | --- | --- | --- | --- | --- | --- | --- | --- | --- | --- | --- | --- | --- | --- | --- | --- | --- | --- | --- | --- | --- | --- | --- | --- | --- |
| 488 | 1.3.7 | **DBT Monitoring and Assurance** |  | 842d | 2022-10-31 A | 2026-01-20 |  | 69% | 262.62d | 2022-10-31 | 2026-01-20 | 842d | 2022-10-31 | 2026-01-19 | 502d |  | N/A | N/A | DBT | 5.0 | N/A | Design, Build & Test (PIT) |  |  |  |  |  |  |  |
| 489 | 1.3.7.1 | **Planning and DBT Progress Monitoring of PPs** |  | 696d | 2022-10-31 A | 2025-06-30 |  | 67% | 233d | 2022-10-31 | 2025-06-30 | 696d | 2022-10-31 | 2025-06-30 | 648d |  | N/A | N/A | DBT | 5.0 | N/A | Design, Build & Test (PIT) | M9 |  |  |  |  |  |  |
| 490 | 1.3.7.1.1 | Monitor Non-SIT PPs Planning and DBT1 progress (to inform confirmation of Qualification Testing Tranche participants milestones) |  | 696d | 2022-10-31 A | 2025-06-30 | 181SS | 67% | 233d | 2022-10-31 | 2025-06-30 | 696d | 2022-10-31 | 2025-06-30 | 648d |  | Code Bodies | SI Test,PPC | DBT | 5.0 | Roger Robar | Design, Build & Test (PIT) |  | Green | GREEN |  |  |  |  |
| 491 | 1.3.7.2 | **DBT Progress Monitoring of Consequential Change** |  | 774d | 2023-02-02 A | 2026-01-20 |  | 51% | 379d | 2023-02-02 | 2026-01-20 | 774d | 2023-02-01 | 2026-01-19 | 502d |  | N/A | N/A | DBT | 5.0 | N/A | Design, Build & Test (PIT) | M9 |  |  |  |  |  |  |
| 492 | 1.3.7.2.1 | Monitor & report data cleanse progress |  | 774d | 2023-02-02 A | 2026-01-20 |  | 51% | 379d | 2023-02-02 | 2026-01-20 | 774d | 2023-02-01 | 2026-01-19 | 502d |  | SI Test | PPC | DBT | 5.0 | Matthew Breen | Design, Build & Test (PIT) |  | Green | GREEN |  |  |  |  |
| 493 | 1.3.7.3 | **Design Assurance** |  | 713d | 2022-11-14 A | 2025-08-06 |  | 80% | 142.32d | 2022-11-14 | 2025-08-06 | 713d | 2022-11-14 | 2025-08-06 | 621d |  | N/A | N/A | DBT | 5.0 | N/A | Design, Build & Test (PIT) | M9 |  |  |  |  |  |  |
| 494 | 1.3.7.3.1 | **Design Assurance Readiness Assessment Preparation** |  | 39d | 2023-02-28 A | 2023-04-21 A |  | 100% |  | 2023-02-28 | 2023-04-21 | 39d | 2023-02-28 | 2023-04-21 |  |  | N/A | N/A | DBT | 5.0 | N/A | Design, Build & Test (PIT) |  |  |  |  |  |  |  |
| 495 | 1.3.7.3.1.1 | Set up FTIG |  | 15d | 2023-04-03 A | 2023-04-21 A |  | 100% |  | 2023-04-03 | 2023-04-21 | 15d | 2023-04-03 | 2023-04-21 |  | must start on 2023-04-03 | SI Design |  | DBT | 5.0 | Paul Pettitt | Design, Build & Test (PIT) |  | Complete | COMPLETE |  |  |  |  |
| 496 | 1.3.7.3.1.2 | Produce Draft Questions |  | 10d | 2023-02-28 A | 2023-03-13 A |  | 100% |  | 2023-02-28 | 2023-03-13 | 10d | 2023-02-28 | 2023-03-13 |  | must start on 2023-02-28 | SI Design |  | DBT | 5.0 | Paul Pettitt | Design, Build & Test (PIT) |  | Complete | COMPLETE |  |  |  |  |
| 497 | 1.3.7.3.1.3 | Pilot with SRO |  | 1d | 2023-03-14 A | 2023-03-14 A | 496 | 100% |  | 2023-03-14 | 2023-03-14 | 1d | 2023-03-14 | 2023-03-14 |  |  | SI Design |  | DBT | 5.0 | Paul Pettitt | Design, Build & Test (PIT) |  | Complete | COMPLETE |  |  |  |  |
| 498 | 1.3.7.3.1.4 | Finalise questions |  | 10d | 2023-03-15 A | 2023-03-28 A | 497 | 100% |  | 2023-03-15 | 2023-03-28 | 10d | 2023-03-15 | 2023-03-28 |  |  | SI Design |  | DBT | 5.0 | Paul Pettitt | Design, Build & Test (PIT) |  | Complete | COMPLETE |  |  |  |  |
| 499 | 1.3.7.3.1.5 | Prepare on-line RA tooling |  | 10d | 2023-03-29 A | 2023-04-11 A | 498 | 100% |  | 2023-03-29 | 2023-04-11 | 10d | 2023-03-29 | 2023-04-11 |  |  | SI Design |  | DBT | 5.0 | Paul Pettitt | Design, Build & Test (PIT) |  | Complete | COMPLETE |  |  |  |  |
| 500 | 1.3.7.3.1.6 | Prepare webinar content |  | 5d | 2023-03-20 A | 2023-03-24 A | 496FS+4d | 100% |  | 2023-03-20 | 2023-03-24 | 5d | 2023-03-20 | 2023-03-24 |  |  | SI Design |  | DBT | 5.0 | Paul Pettitt | Design, Build & Test (PIT) |  | Complete | COMPLETE |  |  |  |  |
| 501 | 1.3.7.3.1.7 | Conduct webinar |  | 1d | 2023-03-30 A | 2023-03-30 A | 500FS+3d | 100% |  | 2023-03-30 | 2023-03-30 | 1d | 2023-03-30 | 2023-03-30 |  |  | SI Design | PP | DBT | 5.0 | Paul Pettitt | Design, Build & Test (PIT) |  | Complete | COMPLETE |  |  |  |  |
| 502 | 1.3.7.3.2 | **Participant Design Assurance Approach** |  | 43d | 2022-11-14 A | 2023-01-11 A |  | 100% |  | 2022-11-14 | 2023-01-11 | 43d | 2022-11-14 | 2023-01-11 |  |  | N/A | N/A | DBT | 5.0 | N/A | Design, Build & Test (PIT) |  |  |  |  |  |  |  |
| 503 | 1.3.7.3.2.1 | Develop document |  | 20d | 2022-11-14 A | 2022-12-09 A | 47FS+10d | 100% |  | 2022-11-14 | 2022-12-09 | 20d | 2022-11-14 | 2022-12-09 |  | start no earlier than 2022-11-14 | SI Design | PP | DBT | 5.0 | Paul Pettitt | Design, Build & Test (PIT) |  | Complete | COMPLETE |  |  |  |  |
| 504 | 1.3.7.3.2.2 | Review document |  | 18d | 2022-12-12 A | 2023-01-04 A | 503 | 100% |  | 2022-12-12 | 2023-01-04 | 18d | 2022-12-12 | 2023-01-04 |  |  | PP | SI Design,IPA | DBT | 5.0 | Paul Pettitt | Design, Build & Test (PIT) |  | Complete | COMPLETE |  |  |  |  |
| 505 | 1.3.7.3.2.3 | Participant Design Assurance Approach approved | milestone | 0d | 2023-01-11 A | 2023-01-11 A | 504FF+5d | 100% |  | 2023-01-11 | 2023-01-11 | 0d | 2023-01-11 | 2023-01-11 |  |  | SI Design | PP | DBT | 5.0 | Paul Pettitt | Design, Build & Test (PIT) |  | Complete | COMPLETE | T3-DB-0012 | DAG | T3 |  |
| 506 | 1.3.7.3.3 | **Phase 1 - SIT Volunteers (Core Providers)** |  | 145d | 2023-04-10 A | 2023-10-27 A |  | 100% |  | 2023-04-10 | 2023-10-27 | 145d | 2023-04-10 | 2023-10-27 |  |  | N/A | N/A | DBT | 5.0 | N/A | Design, Build & Test (PIT) |  |  |  |  |  |  |  |
| 507 | 1.3.7.3.3.1 | Send on-line questionnaire to core capability providers and current SIT volunteers (from Round 3 consultation) |  | 1d | 2023-04-10 A | 2023-04-10 A |  | 100% |  | 2023-04-10 | 2023-04-10 | 1d | 2023-04-10 | 2023-04-10 |  | must start on 2023-04-10 | SI Design | PP | DBT | 5.0 | Paul Pettitt | Design, Build & Test (PIT) |  | Complete | COMPLETE |  |  |  |  |
| 508 | 1.3.7.3.3.2 | Participants Provide Responses to questionnaires |  | 15d | 2023-04-11 A | 2023-05-01 A | 507 | 100% |  | 2023-04-11 | 2023-05-01 | 15d | 2023-04-11 | 2023-05-01 |  |  | PP |  | DBT | 5.0 | Paul Pettitt | Design, Build & Test (PIT) |  | Complete | COMPLETE |  |  |  |  |
| 509 | 1.3.7.3.3.3 | Assess on-line responses and provided evidence |  | 5d | 2023-05-02 A | 2023-05-08 A | 508 | 100% |  | 2023-05-02 | 2023-05-08 | 5d | 2023-05-02 | 2023-05-08 |  |  | SI Design |  | DBT | 5.0 | Paul Pettitt | Design, Build & Test (PIT) |  | Complete | COMPLETE |  |  |  |  |
| 510 | 1.3.7.3.3.4 | Bi-lateral meeting with each responder, to walk and navigate through provided materials |  | 31d | 2023-05-09 A | 2023-06-20 A | 509 | 100% |  | 2023-05-09 | 2023-06-20 | 31d | 2023-05-09 | 2023-06-20 |  |  | SI Design | PP | DBT | 5.0 | Paul Pettitt | Design, Build & Test (PIT) |  | Complete | COMPLETE |  |  |  |  |
| 511 | 1.3.7.3.3.5 | Plan for, create and execute deep dive assurance interviews based on agreed priorities (participants, design areas) |  | 62d | 2023-06-07 A | 2023-08-31 A | 510FS-10d | 100% |  | 2023-06-07 | 2023-08-31 | 62d | 2023-06-07 | 2023-08-01 |  |  | SI Design |  | DBT | 5.2 | Paul Pettitt | Design, Build & Test (PIT) |  | Complete | COMPLETE |  |  |  |  |
| 512 | 1.3.7.3.3.6 | SI endorsement of participants’ design – assurance reports |  | 43d | 2023-08-02 A | 2023-09-29 A | 511FS-22d | 100% |  | 2023-08-02 | 2023-09-29 | 43d | 2023-08-02 | 2023-08-15 |  |  | SI Design |  | DBT | 5.2 | Paul Pettitt | Design, Build & Test (PIT) |  | Complete | COMPLETE |  |  |  |  |
| 513 | 1.3.7.3.3.7 | Post-assurance review of recommendations take-up by assured participants |  | 44d | 2023-08-29 A | 2023-10-27 A | 512SS+19d | 100% |  | 2023-08-29 | 2023-10-27 | 20d | 2023-08-16 | 2023-10-27 |  |  | SI Design |  | DBT | 5.2 | Paul Pettitt | Design, Build & Test (PIT) |  | Complete | COMPLETE |  |  |  |  |
| 514 | 1.3.7.3.3.8 | Phase 1 - SIT Volunteers (Core Providers) complete | milestone | 0d | 2023-10-27 A | 2023-10-27 A | 513 | 100% |  | 2023-10-27 | 2023-10-27 | 0d | 2023-10-27 | 2023-10-27 |  |  | SI Design |  | DBT | 5.11 | Paul Pettitt | Design, Build & Test (PIT) |  | Complete | COMPLETE | T2-DB-0100 | DAG | T2 | MHHS-ART002 |

| ID | WBS | Task | Type | Duration | Start | Finish | Predecessors | Complete | Remaining | Baseline start | Baseline finish | Baseline duration | Baseline 1 start | Baseline 1 finish | Total slack | Constraint | Baseline cost | Responsible | Involved | Text9 | Update Version | MHHS Resource Name | MHHS Programme Phase | Sched Status | RAG | Artefact ID | Milestone ID | Text29 | Tier | Task Status | Future RAG |
| --- | --- | --- | --- | --- | --- | --- | --- | --- | --- | --- | --- | --- | --- | --- | --- | --- | --- | --- | --- | --- | --- | --- | --- | --- | --- | --- | --- | --- | --- | --- | --- |
| 515 | 1.3.7.3.4 | **Phase 2 - SIT all other participants** |  | 143d | 2023-05-08 A | 2023-11-22 A |  | 100% |  | 2023-05-08 | 2023-11-22 | 143d | 2023-05-08 | 2023-11-22 |  |  |  | N/A | N/A | DBT | 5.0 | N/A | Design, Build & Test (PIT) |  |  |  |  |  |  |  |  |
| 516 | 1.3.7.3.4.1 | Send on-line questionnaire to core capability providers and current SIT volunteers (from Round 3 consultation) |  | 1d | 2023-05-08 A | 2023-05-08 A |  | 100% |  | 2023-05-08 | 2023-05-08 | 1d | 2023-05-08 | 2023-05-08 |  | must start on 2023-05-08 |  | SI Design | PP | DBT | 5.0 | Paul Pettitt | Design, Build & Test (PIT) | Complete | COMPLETE |  |  |  |  |  |  |
| 517 | 1.3.7.3.4.2 | Participants Provide Responses to questionnaires |  | 15d | 2023-05-09 A | 2023-05-29 A | 516 | 100% |  | 2023-05-09 | 2023-05-29 | 15d | 2023-05-09 | 2023-05-29 |  |  |  | PP |  | DBT | 5.0 | Paul Pettitt | Design, Build & Test (PIT) | Complete | COMPLETE |  |  |  |  |  |  |
| 518 | 1.3.7.3.4.3 | Assess on-line responses and provided evidence |  | 5d | 2023-05-30 A | 2023-06-05 A | 517 | 100% |  | 2023-05-30 | 2023-06-05 | 5d | 2023-05-30 | 2023-06-05 |  |  |  | SI Design |  | DBT | 5.0 | Paul Pettitt | Design, Build & Test (PIT) | Complete | COMPLETE |  |  |  |  |  |  |
| 519 | 1.3.7.3.4.4 | Bi-lateral meeting with each responder, to walk and navigate through provided materials |  | 84d | 2023-06-06 A | 2023-09-29 A | 518 | 100% |  | 2023-06-06 | 2023-09-29 | 84d | 2023-06-06 | 2023-07-18 |  |  |  | SI Design | PP | DBT | 5.2 | Paul Pettitt | Design, Build & Test (PIT) | Complete | COMPLETE |  |  |  |  |  |  |
| 520 | 1.3.7.3.4.5 | Plan for, create and execute deep dive assurance interviews based on agreed priorities (participants, design areas) |  | 69d | 2023-06-27 A | 2023-09-29 A | 519SS+15d | 100% |  | 2023-06-27 | 2023-09-29 | 69d | 2023-07-05 | 2023-08-29 |  |  |  | SI Design |  | DBT | 5.2 | Paul Pettitt | Design, Build & Test (PIT) | Complete | COMPLETE |  |  |  |  |  |  |
| 521 | 1.3.7.3.4.6 | SI endorsement of participants’ design – assurance reports |  | 54d | 2023-07-18 A | 2023-09-29 A | 520SS+15d | 100% |  | 2023-07-18 | 2023-09-29 | 54d | 2023-08-30 | 2023-09-12 |  |  |  | SI Design |  | DBT | 5.2 | Paul Pettitt | Design, Build & Test (PIT) | Complete | COMPLETE |  |  |  |  |  |  |
| 522 | 1.3.7.3.4.7 | Post-assurance review of recommendations take-up by assured participants |  | 73d | 2023-08-14 A | 2023-11-22 A | 521SS+19d | 100% |  | 2023-08-14 | 2023-11-22 | 38d | 2023-09-13 | 2023-11-22 |  |  |  | SI Design |  | DBT | 5.2 | Paul Pettitt | Design, Build & Test (PIT) | Complete | COMPLETE |  |  |  |  |  |  |
| 523 | 1.3.7.3.4.8 | SIT PPs design assurance (excl Migration/Reverse Migration) complete | milestone | 0d | 2023-11-22 A | 2023-11-22 A | 522 | 100% |  | 2023-11-22 | 2023-11-22 | 0d | 2023-11-22 | 2023-11-22 |  |  |  | SI Design |  | DBT | 5.11 | Paul Pettitt | Design, Build & Test (PIT) | Complete | COMPLETE | MHHS-ART002 | T2-DB-0200 | DAG | T2 |  |  |
| 524 | 1.3.7.3.5 | **Non-SIT PPs design assurance** |  | 445d | 2023-11-23 A | 2025-08-06 |  | 53% | 207d | 2023-11-23 | 2025-08-06 | 445d | 2023-11-23 | 2025-08-06 | 621d |  |  | N/A | N/A | DBT | 5.0 | N/A | Design, Build & Test (PIT) |  |  |  |  |  |  |  |  |
| 525 | 1.3.7.3.5.1 | Non-SIT PPs design assurance (risk-based sample) |  | 445d | 2023-11-23 A | 2025-08-06 | 523 | 53% | 207d | 2023-11-23 | 2025-08-06 | 445d | 2023-11-23 | 2025-08-06 | 621d |  |  | SI Design | PPC | DBT | 5.0 | Paul Pettitt | Design, Build & Test (PIT) | Green | GREEN |  |  |  |  |  |  |
| 526 | 1.3.7.4 | **Test Assurance** |  | 629d | 2023-02-01 A | 2025-06-30 |  | 71% | 180d | 2023-02-01 | 2025-06-30 | 696d | 2022-10-31 | 2025-06-30 | 648d |  |  | N/A | N/A | DBT | 5.0 | N/A | Design, Build & Test (PIT) |  |  |  |  |  |  | M9 |  |
| 527 | 1.3.7.4.1 | Non-SIT PPs test assurance |  | 629d | 2023-02-01 A | 2025-06-30 |  | 71% | 180d | 2023-02-01 | 2025-06-30 | 629d | 2023-02-01 | 2025-06-30 | 648d |  |  | Code Bodies | PP,PPC,SI Test | DBT | 5.0 | Roger Robar | Design, Build & Test (PIT) | Green | GREEN |  |  |  |  |  |  |
| 528 | 1.3.7.5 | **Pre-Qualification Guidance (PIT Guidance)** |  | 67d | 2022-10-31 A | 2023-01-31 A |  | 100% |  | 2022-10-31 | 2023-01-31 | 67d | 2022-10-31 | 2023-01-31 |  |  |  | N/A | N/A | DBT | 5.0 | N/A | Design, Build & Test (PIT) |  |  |  |  |  |  |  |  |
| 529 | 1.3.7.5.1 | Develop document (incl. collaboration with code bodies, as required) |  | 56d | 2022-10-31 A | 2023-01-16 A |  | 100% |  | 2022-10-31 | 2023-01-16 | 56d | 2022-10-31 | 2023-01-16 |  |  |  | SI Test | Code Bodies | DBT | 5.0 |  | Design, Build & Test (PIT) | Complete | COMPLETE |  |  |  |  |  |  |
| 530 | 1.3.7.5.2 | Review, update and agree Pre-Qualification Guidance internally |  | 11d | 2023-01-17 A | 2023-01-31 A | 529 | 100% |  | 2023-01-17 | 2023-01-31 | 11d | 2023-01-17 | 2023-01-31 |  |  |  | SRO Function | IPA,SI Test | DBT | 5.0 |  | Design, Build & Test (PIT) | Complete | COMPLETE |  |  |  |  |  |  |
| 531 | 1.3.7.6 | **External Programme Dependency Management** |  | 0d | 2022-11-03 A | 2022-11-03 A |  | 100% |  | 2022-11-03 | 2022-11-03 | 0d | 2022-11-03 | 2022-11-03 |  |  |  | N/A | N/A | DBT | 5.0 | N/A | Design, Build & Test (PIT) |  |  |  |  |  |  |  |  |
| 532 | 1.3.7.6.1 | **SLC47** |  | 0d | 2022-11-03 A | 2022-11-03 A |  | 100% |  | 2022-11-03 | 2022-11-03 | 0d | 2022-11-03 | 2022-11-03 |  |  |  | N/A | N/A | DBT | 5.0 | N/A | Design, Build & Test (PIT) |  |  |  |  |  |  |  |  |
| 533 | 1.3.7.6.1.1 | SLC47 implementation date | milestone | 0d | 2022-11-03 A | 2022-11-03 A |  | 100% |  | 2022-11-03 | 2022-11-03 | 0d | 2022-11-03 | 2022-11-03 |  | start no earlier than 2022-11-03 |  | Ofgem |  | DBT | 5.0 |  | Design, Build & Test (PIT) | Complete | COMPLETE |  |  |  |  |  |  |
| 534 | 1.4 | **SYSTEMS INTEGRATION TESTING (SIT)** |  | 910d? | 2022-10-31 A | 2026-04-24 |  | 74% | 240.09d? | 2022-10-31 | 2026-04-24 | 841d | 2022-10-31 | 2026-01-19 |  |  | -0 | N/A | N/A | SIT | 5.0 | N/A | Systems Integration Testing (SIT) |  |  |  |  | SITAG |  |  | 1 Aug 2023 - 30 Sep 2024 |
| 535 | 1.4.1 | **SIT Preparation** |  | 665d? | 2022-10-31 A | 2025-05-16 |  | 95% | 30.2d? | 2022-10-31 | 2025-05-16 | 611d | 2022-10-31 | 2025-03-10 | 679d |  | -0 | N/A | N/A | SIT | 5.0 | N/A | Systems Integration Testing (SIT) |  |  |  |  | SITAG |  |  |  |
| 536 | 1.4.1.1 | **Test Artefact Development** |  | 472d | 2022-10-31 A | 2024-08-21 |  | 99% | 2.69d | 2022-10-31 | 2024-08-21 | 472d | 2022-10-31 | 2023-09-01 | 872d |  | -0 | N/A | N/A | SIT | 5.0 | N/A | Systems Integration Testing (SIT) |  |  |  |  |  |  | M9 |  |
| 537 | 1.4.1.1.1 | **Environment Approach & Plan** |  | 460d | 2022-11-16 A | 2024-08-21 A |  | 100% |  | 2022-11-16 | 2024-08-21 | 460d | 2022-11-16 | 2023-06-30 |  |  | -0 | N/A | N/A | SIT | 5.0 | N/A | Systems Integration Testing (SIT) |  |  |  |  |  |  |  |  |
| 538 | 1.4.1.1.1.1 | Environment Approach & Plan approved | milestone | 0d | 2022-11-16 A | 2022-11-16 A |  | 100% |  | 2022-11-16 | 2022-11-16 | 0d | 2022-11-16 | 2022-11-16 |  | start no earlier than 2022-11-16 |  | SI Test | PP | SIT | 5.0 | Simon Berry | Systems Integration Testing (SIT) | Complete | COMPLETE | MHHS-ART139 | T3-TE-0010 | SITAG | T3 |  |  |
| 539 | 1.4.1.1.1.2 | Environment Approach & Plan - Work Off |  | 157d | 2022-11-17 A | 2023-06-23 A | 538FS+1d | 100% |  | 2022-11-17 | 2023-06-23 | 157d | 2022-11-17 | 2023-06-23 |  |  |  | SI Test | PP | SIT | 5.0 | Simon Berry | Systems Integration Testing (SIT) | Complete | COMPLETE |  |  |  |  |  |  |
| 540 | 1.4.1.1.1.3 | Environment Approach & Plan - Work Off Approved | milestone | 0d | 2023-08-16 A | 2023-08-16 A | 539FS+5d | 100% |  | 2023-08-16 | 2023-08-16 | 0d | 2023-06-30 | 2023-06-30 |  | start no earlier than 2023-08-16 |  | SI Test | PP | SIT | 5.0 | Simon Berry | Systems Integration Testing (SIT) | Complete | COMPLETE | MHHS-ART139 | T3-TE-0068 | SITAG | T3 |  |  |
| 541 | 1.4.1.1.1.4 | Environment Approach and Plan - SIT Functional | milestone | 0d | 2023-11-20 A | 2023-11-20 A |  | 100% |  | 2023-11-20 | 2023-11-20 | 0d |  |  |  | start no earlier than 2023-11-20 |  | SI Test | PP | SIT | 5.12 | Simon Berry | Systems Integration Testing (SIT) | Complete | COMPLETE | MHHS-DEL 618 | T3-TE-0090 | SITAG | T3 |  |  |
| 542 | 1.4.1.1.1.5 | Define Approach to Simulator for Non-SIT LDSO | milestone | 0d | 2023-11-15 A | 2023-11-15 A |  | 100% |  | 2023-11-15 | 2023-11-15 | 0d |  |  |  | start no earlier than 2023-11-15 |  | SI Test | PP | SIT | 5.12 | Simon Berry |  | Complete | COMPLETE |  |  |  |  |  |  |
| 543 | 1.4.1.1.1.6 | Environment Approach and Plan - Non SIT LDSO Testing | milestone | 0d | 2024-04-17 A | 2024-04-17 A |  | 100% |  | 2024-04-17 | 2024-04-17 | 0d |  |  |  | start no earlier than 2024-04-17 |  | SI Test | PP | SIT | 5.22 | Simon Berry | Systems Integration Testing (SIT) | Complete | COMPLETE | MHHS-DEL 619 | T3-TE-0091 | SITAG/QAG | T3 |  |  |
| 544 | 1.4.1.1.1.7 | Environment Approach and Plan - S and A Testing | milestone | 0d | 2024-07-17 A | 2024-07-17 A |  | 100% |  | 2024-07-17 | 2024-07-17 | 0d |  |  |  | start no earlier than 2024-07-17 |  | SI Test | PP | SIT | 5.27 | Simon Berry | Systems Integration Testing (SIT) | Complete | COMPLETE | MHHS-DEL 619 | T3-TE-0120 | SITAG/QAG | T3 |  |  |
| 545 | 1.4.1.1.1.8 | Environment Approach and Plan - SIT Non Functional | milestone | 0d | 2024-06-19 A | 2024-06-19 A |  | 100% |  | 2024-06-19 | 2024-06-19 | 0d |  |  |  | start no earlier than 2024-06-19 |  | SI Test | PP | SIT | 5.27 | Simon Berry | Systems Integration Testing (SIT) | Complete | COMPLETE | MHHS-DEL 620 | T3-TE-0092 | SITAG | T3 |  |  |
| 546 | 1.4.1.1.1.9 | Environment Approach and Plan - Sandbox | milestone | 0d | 2024-08-21 A | 2024-08-21 A |  | 100% |  | 2024-08-21 | 2024-08-21 | 0d |  |  |  | start no earlier than 2024-08-21 |  | SI Test | PP | SIT | 5.27 | Simon Berry | Systems Integration Testing (SIT) | Complete | COMPLETE | MHHS-DEL 621 | T3-TE-0093 | SITAG/QAG | T3 |  |  |

Notes:
- 535: Action: 11/3: Ask Simon B for the link (line 1312) dip onboarding to non sit ldso
- 537: Action: 16/8 - add to milestone register. Build out detail further
- 538: Action: 25/7 - Simon to provide update
- 539: Action: 25/7 - Simon to provide update
- 540: Action: 25/7 - Simon to provide update
- 541: Action: 16/8 - add to milestone register. Build out detail further
- 543: Action: 16/8 - add to milestone register. Build out detail further
- 544: Action: 16/8 - add to milestone register. Build out detail further
- 545: Action: 16/8 - add to milestone register. Build out detail further
- 546: Action: 16/8 - add to milestone register. Build out detail further

| ID | WBS | Task | Type | Duration | Start | Finish | Predecessors | Complete | Remaining | Baseline start | Baseline finish | Baseline duration | Baseline 1 start | Baseline 1 finish | Total slack | Constraint | Baseline cost | Responsible | Involved | Text9 | Update Version | MHHS Resource Name | MHHS Programme Phase | Sched Status | RAG | Task Status | Milestone ID | Text29 | Tier |
| --- | --- | --- | --- | --- | --- | --- | --- | --- | --- | --- | --- | --- | --- | --- | --- | --- | --- | --- | --- | --- | --- | --- | --- | --- | --- | --- | --- | --- | --- |
| 547 | 1.4.1.1.2 | **Overarching Test Scope (for all stages)** |  | 65d | 2022-10-31 A | 2023-01-27 A |  | 100% |  | 2022-10-31 | 2023-01-27 | 175d | 2022-10-31 | 2023-06-30 |  |  |  | N/A | N/A | SIT | 5.0 | N/A | Systems Integration Testing (SIT) |  |  |  |  |  |  |
| 548 | 1.4.1.1.2.1 | **Overarching Test Scope (excl. Migration/Reverse Migration, NFT and Ops components)** |  | 65d | 2022-10-31 A | 2023-01-27 A |  | 100% |  | 2022-10-31 | 2023-01-27 | 65d | 2022-10-31 | 2023-01-27 |  |  |  | N/A | N/A | SIT | 5.0 | N/A | Systems Integration Testing (SIT) |  |  |  |  |  |  |
| 549 | 1.4.1.1.2.1.1 | Develop document (excl Migration/Reverse Migration, NFT and Ops components) |  | 55d | 2022-10-31 A | 2023-01-13 A | 47 | 100% |  | 2022-10-31 | 2023-01-13 | 55d | 2022-10-31 | 2023-01-13 |  |  |  | SI Test |  | SIT | 5.0 |  | Systems Integration Testing (SIT) | Complete | COMPLETE |  |  |  |  |
| 550 | 1.4.1.1.2.1.2 | Review, update & agree document (excl Migration/Reverse Migration, NFT and Ops components) |  | 10d | 2023-01-16 A | 2023-01-27 A | 549 | 100% |  | 2023-01-16 | 2023-01-27 | 10d | 2023-01-16 | 2023-01-27 |  |  |  | SI Test | IPA,Code Bodies,PP | SIT | 5.0 |  | Systems Integration Testing (SIT) | Complete | COMPLETE |  |  |  |  |
| 551 | 1.4.1.1.3 | **Configuration and Release Management Approach & Plan** |  | 164d | 2022-11-01 A | 2023-06-16 A |  | 100% |  | 2022-11-01 | 2023-06-16 | 164d | 2022-11-01 | 2023-04-28 |  |  |  | N/A | N/A | SIT | 5.0 | N/A | Systems Integration Testing (SIT) |  |  | M9 |  |  |  |
| 552 | 1.4.1.1.3.1 | Develop document |  | 69d | 2022-11-01 A | 2023-06-16 A |  | 100% |  | 2022-11-01 | 2023-06-16 | 69d | 2022-11-01 | 2023-01-31 |  | start no earlier than 2022-11-01 |  | SI Test |  | SIT | 5.0 | Simon Berry | Systems Integration Testing (SIT) | Complete | COMPLETE |  |  |  |  |
| 553 | 1.4.1.1.3.2 | Review, update and agree Configuration and Release Management Approach & Plan internally |  | 63d | 2023-02-01 A | 2023-04-28 A | 552 | 100% |  | 2023-02-01 | 2023-04-28 | 63d | 2023-02-01 | 2023-04-28 |  |  |  | SRO Function | IPA,SI Test | SIT | 5.0 | Simon Berry | Systems Integration Testing (SIT) | Complete | COMPLETE |  |  |  |  |
| 554 | 1.4.1.1.4 | **Test Data Overarching Approach & Plan** |  | 179d | 2022-11-14 A | 2023-07-20 A |  | 100% |  | 2022-11-14 | 2023-07-20 | 179d | 2022-11-14 | 2023-05-18 |  |  |  | N/A | N/A | SIT | 5.0 | N/A | Systems Integration Testing (SIT) |  |  | M9 |  |  |  |
| 555 | 1.4.1.1.4.1 | Develop document |  | 20d | 2022-11-14 A | 2022-12-09 A |  | 100% |  | 2022-11-14 | 2022-12-09 | 20d | 2022-11-14 | 2022-12-09 |  | start no earlier than 2022-11-14 |  | SI Test | PP | SIT | 5.0 | Cesar Lopes | Systems Integration Testing (SIT) | Complete | COMPLETE |  |  |  |  |
| 556 | 1.4.1.1.4.2 | Document review and update |  | 155d | 2022-12-12 A | 2023-07-14 A | 555 | 100% |  | 2022-12-12 | 2023-07-14 | 155d | 2022-12-12 | 2023-05-17 |  |  |  | PP | SI Test,IPA | SIT | 5.0 | Cesar Lopes | Systems Integration Testing (SIT) | Complete | COMPLETE |  |  |  |  |
| 557 | 1.4.1.1.4.3 | Test Data Overarching Approach & Plan approved by TMAG | milestone | 0d | 2023-07-19 A | 2023-07-19 A | 556FS+3d | 100% |  | 2023-07-19 | 2023-07-19 | 0d | 2023-05-17 | 2023-05-17 |  |  |  | SRO Test | PP,IPA,Code Bodies | SIT | 5.0 | Cesar Lopes | Systems Integration Testing (SIT) | Complete | COMPLETE |  | T3-TE-0072 | SITAG | T3 |
| 558 | 1.4.1.1.4.4 | Document publication final version |  | 1d | 2023-07-20 A | 2023-07-20 A | 557 | 100% |  | 2023-07-20 | 2023-07-20 | 1d | 2023-05-18 | 2023-05-18 |  |  |  | SI Test |  | SIT | 5.0 | Cesar Lopes | Systems Integration Testing (SIT) | Complete | COMPLETE |  |  |  |  |
| 559 | 1.4.1.1.5 | **Interface Code of Connection (dates subject to DIP Service Provider's plan)** |  | 48d | 2023-03-01 A | 2023-05-05 A |  | 100% |  | 2023-03-01 | 2023-05-05 | 48d | 2023-03-01 | 2023-05-05 |  |  |  | N/A | N/A | SIT | 5.0 | N/A | Systems Integration Testing (SIT) |  |  |  |  |  |  |
| 560 | 1.4.1.1.5.1 | Develop Interface Code of Connection with DIP Service Provider |  | 43d | 2023-03-01 A | 2023-04-28 A |  | 100% |  | 2023-03-01 | 2023-04-28 | 43d | 2023-03-01 | 2023-04-28 |  | must start on 2023-03-01 |  | DIP Provider | SI Test | SIT | 5.0 |  | Systems Integration Testing (SIT) | Complete | COMPLETE |  |  |  |  |
| 561 | 1.4.1.1.5.2 | Interface Code of Connection approved at SDWG | milestone | 0d | 2023-05-05 A | 2023-05-05 A | 560FS+5d | 100% |  | 2023-05-05 | 2023-05-05 | 0d | 2023-05-05 | 2023-05-05 |  |  |  | SI Test | PP | SIT | 5.0 |  | Systems Integration Testing (SIT) | Complete | COMPLETE |  |  |  |  |
| 562 | 1.4.1.1.6 | **Test Traceability** |  | 165d | 2023-06-01 A | 2024-01-17 |  | 98% | 2.71d | 2023-06-01 | 2024-01-17 | 165d | 2023-06-01 | 2023-09-01 | 1026d |  | -0 | N/A | N/A | SIT | 5.0 | N/A | Systems Integration Testing (SIT) |  |  |  |  |  |  |
| 563 | 1.4.1.1.6.1 | RTM containing Method Statement Implied Requirements into Azure DevOps |  | 22d | 2023-06-01 A | 2023-06-30 A |  | 100% |  | 2023-06-01 | 2023-06-30 | 22d | 2023-06-01 | 2023-06-30 |  | must start on 2023-06-01 |  | SI Test |  | SIT | 5.0 |  | Systems Integration Testing (SIT) | Complete | COMPLETE |  |  |  |  |
| 564 | 1.4.1.1.6.2 | RTM Containing Interface Catalogue Implied Requirements |  | 27d | 2023-06-01 A | 2023-07-07 A |  | 100% |  | 2023-06-01 | 2023-07-07 | 27d | 2023-06-01 | 2023-07-07 |  | must start on 2023-06-01 |  | SI Test |  | SIT | 5.0 |  | Systems Integration Testing (SIT) | Complete | COMPLETE |  |  |  |  |
| 565 | 1.4.1.1.6.3 | SIT CIT Full Traceability & Coverage complete |  | 118d | 2023-07-10 A | 2023-12-20 A | 564, 563 | 100% |  | 2023-07-10 | 2023-12-20 | 110d | 2023-07-10 | 2023-07-28 |  |  |  | SI Test |  | SIT | 5.0 |  | Systems Integration Testing (SIT) | Complete | COMPLETE |  |  |  |  |
| 566 | 1.4.1.1.6.4 | SIT Functional Full Traceability & Coverage complete |  | 138d | 2023-07-10 A | 2024-01-17 | 564, 563 | 96% | 5d | 2023-07-10 | 2024-01-17 | 138d | 2023-07-10 | 2023-09-01 | 1026d |  |  | SI Test |  | SIT | 5.0 | Roger Robar | Systems Integration Testing (SIT) | Overdue | RED |  |  |  |  |
| 567 | 1.4.1.2 | **Test Tool Development** |  | 256d? | 2022-10-31 A | 2023-10-23 A |  | 100% |  | 2022-10-31 | 2023-10-23 | 175d | 2022-10-31 | 2023-06-30 |  |  |  | N/A | N/A | SIT | 5.0 | N/A | Systems Integration Testing (SIT) |  |  |  |  |  |  |
| 568 | 1.4.1.2.1 | **Test Management Tool** |  | 256d | 2022-10-31 A | 2023-10-23 A |  | 100% |  | 2022-10-31 | 2023-10-23 | 175d | 2022-10-31 | 2023-06-30 |  |  |  | N/A | N/A | SIT | 5.0 | N/A | Systems Integration Testing (SIT) |  |  |  |  |  |  |
| 569 | 1.4.1.2.1.1 | **Test Management Tool Implementation** |  | 256d | 2022-10-31 A | 2023-10-23 A |  | 100% |  | 2022-10-31 | 2023-10-23 | 175d | 2022-10-31 | 2023-06-30 |  |  |  | N/A | N/A | SIT | 5.0 | N/A | Systems Integration Testing (SIT) |  |  |  |  |  |  |
| 570 | 1.4.1.2.1.1.1 | Requirements identification |  | 40d | 2022-10-31 A | 2022-12-23 A |  | 100% |  | 2022-10-31 | 2022-12-23 | 40d | 2022-10-31 | 2022-12-23 |  |  |  | SI DevOps | SI Test | SIT | 5.0 | Simon Berry | Systems Integration Testing (SIT) | Complete | COMPLETE |  |  |  |  |
| 571 | 1.4.1.2.1.1.2 | Development |  | 125d | 2023-01-02 A | 2023-06-23 A | 570FS+5d | 100% |  | 2023-01-02 | 2023-06-23 | 125d | 2023-01-02 | 2023-06-23 |  |  |  | SI DevOps | SI Test | SIT | 5.0 | Simon Berry | Systems Integration Testing (SIT) | Complete | COMPLETE |  |  |  |  |
| 572 | 1.4.1.2.1.1.3 | Testing |  | 125d | 2023-01-02 A | 2023-06-23 A | 571FF | 100% |  | 2023-01-02 | 2023-06-23 | 125d | 2023-01-02 | 2023-06-23 |  |  |  | SI DevOps | SI Test | SIT | 5.0 | Simon Berry | Systems Integration Testing (SIT) | Complete | COMPLETE |  |  |  |  |
| 573 | 1.4.1.2.1.1.4 | Accept tool | milestone | 0d | 2023-06-23 A | 2023-06-23 A | 572FF | 100% |  | 2023-06-23 | 2023-06-23 | 0d | 2023-06-23 | 2023-06-23 |  |  |  | SI DevOps | SI Test | SIT | 5.0 | Simon Berry | Systems Integration Testing (SIT) | Complete | COMPLETE |  |  |  |  |
| 574 | 1.4.1.2.1.1.5 | Implementation |  | 1d | 2023-10-23 A | 2023-10-23 A | 573FS+85d | 100% |  | 2023-10-23 | 2023-10-23 | 1d | 2023-06-30 | 2023-06-30 |  |  |  | SI DevOps | PPC | SIT | 5.0 | Simon Berry | Systems Integration Testing (SIT) | Complete | COMPLETE |  |  |  |  |

Notes:
- 551: Action: 1280 DIP available for Onboarding (need to add a link - non sit ldso)

| ID | WBS | Task | Duration | Start | Finish | Predecessors | Complete | Baseline start | Baseline finish | Baseline duration | Baseline 1 start | Baseline 1 finish | Constraint | Responsible | Involved | Text9 | Update Version | MHHS Resource Name | MHHS Programme Phase | Sched Status | RAG | Task Status |
| --- | --- | --- | --- | --- | --- | --- | --- | --- | --- | --- | --- | --- | --- | --- | --- | --- | --- | --- | --- | --- | --- | --- |
| 575 | 1.4.1.2.1.2 | **Test Management Tool User Guide** | 115d | 2023-01-02 A | 2023-06-09 A |  | 100% | 2023-01-02 | 2023-06-09 | 115d | 2023-01-02 | 2023-06-09 |  | N/A | N/A | SIT | 5.0 | N/A | Systems Integration Testing (SIT) |  |  |  |
| 576 | 1.4.1.2.1.2.1 | Develop document | 100d | 2023-01-02 A | 2023-05-19 A | 571SS, 572SS | 100% | 2023-01-02 | 2023-05-19 | 100d | 2023-01-02 | 2023-05-19 | start no earlier than 2023-01-02 | SI DevOps |  | SIT | 5.0 |  | Systems Integration Testing (SIT) | Complete | COMPLETE |  |
| 577 | 1.4.1.2.1.2.2 | Review, update and agree Test Management Tool User Guide internally | 15d | 2023-05-22 A | 2023-06-09 A | 576 | 100% | 2023-05-22 | 2023-06-09 | 15d | 2023-05-22 | 2023-06-09 |  | SRO Function | SI DevOps,SI Test,IPA,PPC | SIT | 5.0 |  | Systems Integration Testing (SIT) | Complete | COMPLETE |  |
| 578 | 1.4.1.2.1.3 | **Test Management Tool Configuration Guide** | 60d | 2023-01-02 A | 2023-03-24 A |  | 100% | 2023-01-02 | 2023-03-24 | 60d | 2023-01-02 | 2023-03-24 |  | N/A | N/A | SIT | 5.0 | N/A | Systems Integration Testing (SIT) |  |  |  |
| 579 | 1.4.1.2.1.3.1 | Develop document | 45d | 2023-01-02 A | 2023-03-03 A | 570 | 100% | 2023-01-02 | 2023-03-03 | 45d | 2023-01-02 | 2023-03-03 | start no earlier than 2023-01-02 | SI DevOps | SI Test,IPA | SIT | 5.0 |  | Systems Integration Testing (SIT) | Complete | COMPLETE |  |
| 580 | 1.4.1.2.1.3.2 | Review, update and agree Test Management Tool Configuration Guide internally | 15d | 2023-03-06 A | 2023-03-24 A | 579 | 100% | 2023-03-06 | 2023-03-24 | 15d | 2023-03-06 | 2023-03-24 |  | SRO Function | SI DevOps,SI Test,IPA | SIT | 5.0 |  | Systems Integration Testing (SIT) | Complete | COMPLETE |  |
| 581 | 1.4.1.2.2 | **Secure Volunteer SIT Participants** | 163d? | 2023-01-31 A | 2023-09-14 A |  | 100% | 2023-01-31 | 2023-09-14 | 0d |  |  |  |  |  | SIT | 6.0 |  |  | Overdue Start |  | -680.67 |
| 582 | 1.4.1.2.2.1 | PPs decide whether to volunteer to participate in SIT and inform Programme of decision via Round 3 Replan consultation | 1d? | 2023-01-31 A | 2023-01-31 A |  | 100% | 2023-01-31 | 2023-01-31 | 0d |  |  | finish no earlier than 2023-01-31 | SI Test |  | SIT | 6.0 |  |  | Complete | COMPLETE |  |
| 583 | 1.4.1.2.2.2 | Assurance of SIT volunteers' plans (submitted via Round 3 Replan Consultation) | 1d? | 2023-02-14 A | 2023-02-14 A |  | 100% | 2023-02-14 | 2023-02-14 | 0d |  |  | finish no earlier than 2023-02-14 | SI Test |  | SIT | 6.0 |  |  | Complete | COMPLETE |  |
| 584 | 1.4.1.2.2.3 | SIT Participant Volunteers Identified | 1d? | 2023-02-14 A | 2023-02-14 A |  | 100% | 2023-02-14 | 2023-02-14 | 0d |  |  | start no earlier than 2023-02-14 | SI Test |  | SIT | 6.0 |  |  | Complete | COMPLETE |  |
| 585 | 1.4.1.2.2.4 | Engagement with SIT volunteers | 1d? | 2023-05-23 A | 2023-05-23 A |  | 100% | 2023-05-23 | 2023-05-23 | 0d |  |  | finish no earlier than 2023-05-23 | SI Test |  | SIT | 6.0 |  |  | Complete | COMPLETE |  |
| 586 | 1.4.1.2.2.5 | SIT Participants Agreed | 1d? | 2023-05-23 A | 2023-05-23 A |  | 100% | 2023-05-23 | 2023-05-23 | 0d |  |  | start no earlier than 2023-05-23 | SI Test |  | SIT | 6.0 |  |  | Complete | COMPLETE |  |
| 587 | 1.4.1.2.2.6 | **Data Protection Impact Assessment (DPIA)** | 11d? | 2023-06-30 A | 2023-07-14 A |  | 100% | 2023-06-30 | 2023-07-14 | 0d |  |  |  | SI Test |  | SIT | 6.0 |  |  | Overdue Start |  | -680.67 |
| 588 | 1.4.1.2.2.6.1 | Conduct DPIA on Overall Test Data Approach | 1d? | 2023-06-30 A | 2023-06-30 A |  | 100% | 2023-06-30 | 2023-06-30 | 0d |  |  | finish no earlier than 2023-06-30 | SI Test |  | SIT | 6.0 |  |  | Complete | COMPLETE |  |
| 589 | 1.4.1.2.2.6.2 | Revise Overarching Test Data Approach& plan for DPIA (if required), including engagement with DWG | 1d? | 2023-07-13 A | 2023-07-13 A |  | 100% | 2023-07-13 | 2023-07-13 | 0d |  |  | finish no earlier than 2023-07-13 | SI Test |  | SIT | 6.0 |  |  | Complete | COMPLETE |  |
| 590 | 1.4.1.2.2.6.3 | Review (internal), update and approve revised Overarching Test Data Approach& Plan (if required) | 1d? | 2023-07-14 A | 2023-07-14 A |  | 100% | 2023-07-14 | 2023-07-14 | 0d |  |  | start no earlier than 2023-07-14 | SI Test |  | SIT | 6.0 |  |  | Complete | COMPLETE |  |
| 591 | 1.4.1.2.2.7 | **Data Sharing Agreements** | 30d? | 2023-08-04 A | 2023-09-14 A |  | 100% | 2023-08-04 | 2023-09-14 | 0d |  |  |  | SI Test |  | SIT | 6.0 |  |  | Overdue Start | COMPLETE | -680.67 |
| 592 | 1.4.1.2.2.7.1 | Produce Data Sharing Agreement for Industry Review | 1d? | 2023-08-04 A | 2023-08-04 A |  | 100% | 2023-08-04 | 2023-08-04 | 0d |  |  | finish no earlier than 2023-08-04 | SI Test |  | SIT | 6.0 |  |  | Complete | COMPLETE |  |
| 593 | 1.4.1.2.2.7.2 | Manage Participant Queries and Contract Agreement Execution | 1d? | 2023-09-14 A | 2023-09-14 A |  | 100% | 2023-09-14 | 2023-09-14 | 0d |  |  | finish no earlier than 2023-09-14 | SI Test |  | SIT | 6.0 |  |  | Complete | COMPLETE |  |
| 594 | 1.4.1.2.2.7.3 | Data Sharing Agreements Complete | 1d? | 2023-09-14 A | 2023-09-14 A |  | 100% | 2023-09-14 | 2023-09-14 | 0d |  |  | start no earlier than 2023-09-14 | SI Test |  | SIT | 6.0 |  |  | Complete | COMPLETE |  |
| 595 | 1.4.1.2.2.8 | **Production Data Cut & Data Obfuscation** | 55d? | 2023-06-19 A | 2023-09-01 A |  | 100% | 2023-06-19 | 2023-09-01 | 0d |  |  |  |  |  | SIT | 6.0 |  |  | Overdue Start | COMPLETE | -680.67 |
| 596 | 1.4.1.2.2.8.1 | **SI Data Cut Preparation& Infrastructure** | 45d? | 2023-06-19 A | 2023-08-18 A |  | 100% | 2023-06-19 | 2023-08-18 | 0d |  |  |  |  |  | SIT | 6.0 |  |  | Overdue Start | COMPLETE | -680.67 |
| 597 | 1.4.1.2.2.8.1.1 | SI Data Cut Planning activities (incl. pre-cut and post-cut cleansing and population approach) | 1d? | 2023-06-19 A | 2023-06-19 A |  | 100% | 2023-06-19 | 2023-06-19 | 0d |  |  | finish no earlier than 2023-06-19 |  |  | SIT | 6.0 |  |  | Complete | COMPLETE |  |
| 598 | 1.4.1.2.2.8.1.2 | Set up SI database and transmission structure | 1d? | 2023-08-17 A | 2023-08-17 A |  | 100% | 2023-08-17 | 2023-08-17 | 0d |  |  | finish no earlier than 2023-08-17 |  |  | SIT | 6.0 |  |  | Complete | COMPLETE |  |
| 599 | 1.4.1.2.2.8.1.3 | Mechanism for transfer of data in place | 1d? | 2023-08-18 A | 2023-08-18 A |  | 100% | 2023-08-18 | 2023-08-18 | 0d |  |  | start no earlier than 2023-08-18 |  |  | SIT | 6.0 |  |  | Complete | COMPLETE |  |
| 600 | 1.4.1.2.2.8.1.4 | SI Data Cut Preparation& Infrastructure Complete | 1d? | 2023-08-18 A | 2023-08-18 A |  | 100% | 2023-08-18 | 2023-08-18 | 0d |  |  | start no earlier than 2023-08-18 |  |  | SIT | 6.0 |  |  | Complete | COMPLETE |  |

| ID | WBS | Task | Type | Duration | Start | Finish | Predecessors | Complete | Remaining | Baseline start | Baseline finish | Baseline duration | Baseline 1 start | Baseline 1 finish | Total slack | Constraint | Baseline cost | Text9 | Task Status | Update Version | Sched Status | RAG | Responsible | Involved | MHHS Resource Name | MHHS Programme Phase | Milestone ID | Text29 | Tier | Artefact ID |
| --- | --- | --- | --- | --- | --- | --- | --- | --- | --- | --- | --- | --- | --- | --- | --- | --- | --- | --- | --- | --- | --- | --- | --- | --- | --- | --- | --- | --- | --- | --- |
| 601 | 1.4.1.2.2.8.2 | **Production Data Cut** |  | 55d? | 2023-06-19 A | 2023-09-01 A |  | 100% |  | 2023-06-19 | 2023-09-01 | 0d |  |  |  |  |  | SIT | -680.67 | 6.0 | Overdue Start | COMPLETE |  |  |  |  |  |  |  |  |
| 602 | 1.4.1.2.2.8.2.1 | Notification of Production Data Cut issued to relevant participants |  | 1d? | 2023-06-19 A | 2023-06-19 A |  | 100% |  | 2023-06-19 | 2023-06-19 | 0d |  |  |  | start no earlier than 2023-06-19 |  | SIT |  | 6.0 | Complete | COMPLETE |  |  |  |  |  |  |  |  |
| 603 | 1.4.1.2.2.8.2.2 | Coordinate relevant participants taking data cut from production systems |  | 1d? | 2023-08-11 A | 2023-08-11 A |  | 100% |  | 2023-08-11 | 2023-08-11 | 0d |  |  |  | finish no earlier than 2023-08-11 |  | SIT |  | 6.0 | Complete | COMPLETE |  |  |  |  |  |  |  |  |
| 604 | 1.4.1.2.2.8.2.3 | Production data cut GONG decision |  | 1d? | 2023-08-16 A | 2023-08-16 A |  | 100% |  | 2023-08-16 | 2023-08-16 | 0d |  |  |  | start no earlier than 2023-08-16 |  | SIT |  | 6.0 | Complete | COMPLETE |  |  |  |  |  |  |  |  |
| 605 | 1.4.1.2.2.8.2.4 | Relevant participants take data cut from production systems (Saturday 19 August) |  | 1d? | 2023-08-21 A | 2023-08-21 A |  | 100% |  | 2023-08-21 | 2023-08-21 | 0d |  |  |  | start no earlier than 2023-08-21 |  | SIT |  | 6.0 | Complete | COMPLETE |  |  |  |  |  |  |  |  |
| 606 | 1.4.1.2.2.8.2.5 | EES transmit request data to SI |  | 1d? | 2023-08-25 A | 2023-08-25 A |  | 100% |  | 2023-08-25 | 2023-08-25 | 0d |  |  |  | finish no earlier than 2023-08-25 |  | SIT |  | 6.0 | Complete | COMPLETE |  |  |  |  |  |  |  |  |
| 607 | 1.4.1.2.2.8.2.6 | Check data alignment and integrity of data cut |  | 1d? | 2023-09-01 A | 2023-09-01 A |  | 100% |  | 2023-09-01 | 2023-09-01 | 0d |  |  |  | finish no earlier than 2023-09-01 |  | SIT |  | 6.0 | Complete | COMPLETE |  |  |  |  |  |  |  |  |
| 608 | 1.4.1.2.2.8.2.7 | Data cut from relevant participants' production systems completed (Saturday 19 August) |  | 1d? | 2023-08-21 A | 2023-08-21 A |  | 100% |  | 2023-08-21 | 2023-08-21 | 0d |  |  |  | start no earlier than 2023-08-21 |  | SIT |  | 6.0 | Complete | COMPLETE |  |  |  |  |  |  |  |  |
| 609 | 1.4.1.2.2.8.2.8 | Production Data Cut Complete |  | 1d? | 2023-08-21 A | 2023-08-21 A |  | 100% |  | 2023-08-21 | 2023-08-21 | 0d |  |  |  | start no earlier than 2023-08-21 |  | SIT |  | 6.0 | Complete | COMPLETE |  |  |  |  |  |  |  |  |
| 610 | 1.4.1.3 | **SIT Participation** |  | 147d | 2022-10-31 A | 2023-05-23 A |  | 100% |  | 2022-10-31 | 2023-05-23 | 147d | 2022-10-31 | 2023-05-23 |  |  |  | SIT |  | 5.0 |  |  | N/A | N/A | N/A | Systems Integration Testing (SIT) |  |  |  |  |
| 611 | 1.4.1.3.1 | PPs decide whether to volunteer to participate in SIT and inform Programme of decision via Round 3 Replan consultation |  | 67d | 2022-10-31 A | 2023-01-31 A | 34FF | 100% |  | 2022-10-31 | 2023-01-31 | 67d | 2022-10-31 | 2023-01-31 |  |  |  | SIT |  | 5.0 | Complete | COMPLETE | PP | SI Test,PMO |  | Systems Integration Testing (SIT) |  |  |  |  |
| 612 | 1.4.1.3.2 | Assurance of SIT volunteers' plans (submitted via Round 3 Replan Consultation) |  | 10d | 2023-02-01 A | 2023-02-14 A | 611, 34 | 100% |  | 2023-02-01 | 2023-02-14 | 10d | 2023-02-01 | 2023-02-14 |  |  |  | SIT |  | 5.0 | Complete | COMPLETE | SI Test | PP |  | Systems Integration Testing (SIT) |  |  |  |  |
| 613 | 1.4.1.3.3 | SIT Participant Volunteers Identified | milestone | 0d | 2023-02-14 A | 2023-02-14 A | 612FF | 100% |  | 2023-02-14 | 2023-02-14 | 0d | 2023-02-14 | 2023-02-14 |  |  |  | SIT |  | 5.0 | Complete | COMPLETE | SI Test | PP |  | Systems Integration Testing (SIT) | T2-TE-0100 | SITAG | T2 |  |
| 614 | 1.4.1.3.4 | Engagement with SIT volunteers |  | 147d | 2022-10-31 A | 2023-05-23 A |  | 100% |  | 2022-10-31 | 2023-05-23 | 147d | 2022-10-31 | 2023-05-23 |  |  |  | SIT |  | 5.0 | Complete | COMPLETE | SI Test | PP |  | Systems Integration Testing (SIT) |  |  |  |  |
| 615 | 1.4.1.3.5 | SIT Participants Agreed | milestone | 0d | 2023-05-23 A | 2023-05-23 A | 614, 649FS-74d | 100% |  | 2023-05-23 | 2023-05-23 | 0d | 2023-05-23 | 2023-05-23 |  |  |  | SIT |  | 5.0 | Complete | COMPLETE | SI Test | PP |  | Systems Integration Testing (SIT) | T2-TE-0150 | SITAG | T2 |  |
| 616 | 1.4.1.4 | **SIT Stage-Specific Preparation** |  | 665d? | 2022-10-31 A | 2025-05-16 |  | 94% | 36.59d? | 2022-10-31 | 2025-05-16 | 611d | 2022-10-31 | 2025-03-10 | 679d |  | -0 | SIT |  | 5.0 |  |  | N/A | N/A | N/A | Systems Integration Testing (SIT) |  | SITAG |  |  |
| 617 | 1.4.1.4.1 | **SIT Component Integration Preparation** |  | 320d | 2022-10-31 A | 2024-01-19 A |  | 100% |  | 2022-10-31 | 2024-01-19 | 321d | 2022-10-31 | 2024-01-22 |  |  | -0 | SIT |  | 5.0 |  |  | N/A | N/A | N/A | Systems Integration Testing (SIT) |  |  |  |  |
| 618 | 1.4.1.4.1.1 | **Test Approach & Plan** |  | 188d | 2022-10-31 A | 2023-07-19 A |  | 100% |  | 2022-10-31 | 2023-07-19 | 188d | 2022-10-31 | 2023-07-19 |  |  |  | SIT |  | 5.0 |  |  | N/A | N/A | N/A | Systems Integration Testing (SIT) |  |  |  |  |
| 619 | 1.4.1.4.1.1.1 | Develop document with SITWG |  | 159d | 2022-10-31 A | 2023-06-08 A |  | 100% |  | 2022-10-31 | 2023-06-08 | 159d | 2022-10-31 | 2023-05-12 |  |  |  | SIT |  | 5.0 | Complete | COMPLETE | SI Test |  |  | Systems Integration Testing (SIT) |  |  |  |  |
| 620 | 1.4.1.4.1.1.2 | Industry consultation |  | 10d | 2023-06-09 A | 2023-06-22 A | 619 | 100% |  | 2023-06-09 | 2023-06-22 | 10d |  |  |  |  |  | SIT |  | 5.1 | Complete | COMPLETE | PP |  |  | Systems Integration Testing (SIT) |  |  |  |  |
| 621 | 1.4.1.4.1.1.3 | Artefact review (via TMAG) and updates |  | 19d | 2023-06-23 A | 2023-07-19 A | 620 | 100% |  | 2023-06-23 | 2023-07-19 | 19d | 2023-06-09 | 2023-07-06 |  | finish no earlier than 2023-07-06 |  | SIT |  | 5.0 | Complete | COMPLETE | SI Test | PP,IPA,Code Bodies |  | Systems Integration Testing (SIT) |  |  |  |  |
| 622 | 1.4.1.4.1.1.4 | SIT Component Integration Testing Test Approach & Plan approved | milestone | 0d | 2023-07-19 A | 2023-07-19 A | 621 | 100% |  | 2023-07-19 | 2023-07-19 | 0d | 2023-07-19 | 2023-07-19 |  | finish no earlier than 2023-07-19 |  | SIT |  | 5.0 | Complete | COMPLETE | SI Test | PP |  | Systems Integration Testing (SIT) | T3-TE-0012 | SITAG | T3 | MHHS-ART073 |
| 623 | 1.4.1.4.1.2 | **Test Data Approach & Plan** |  | 29d | 2023-06-09 A | 2023-07-19 A |  | 100% |  | 2023-06-09 | 2023-07-19 | 29d | 2023-06-09 | 2023-07-19 |  |  |  | SIT |  | 5.0 |  |  | N/A | N/A | N/A | Systems Integration Testing (SIT) |  |  |  |  |
| 624 | 1.4.1.4.1.2.1 | Industry consultation |  | 10d | 2023-06-09 A | 2023-06-22 A | 620SS | 100% |  | 2023-06-09 | 2023-06-22 | 10d |  |  |  |  |  | SIT |  | 5.1 | Complete | COMPLETE | PP |  | Cesar Lopes | Systems Integration Testing (SIT) |  |  |  |  |
| 625 | 1.4.1.4.1.2.2 | Artefact review (via TMAG) and updates |  | 19d | 2023-06-23 A | 2023-07-19 A | 624 | 100% |  | 2023-06-23 | 2023-07-19 | 19d | 2023-06-09 | 2023-07-06 |  |  |  | SIT |  | 5.0 | Complete | COMPLETE | SI Test | PP | Cesar Lopes | Systems Integration Testing (SIT) |  |  |  |  |
| 626 | 1.4.1.4.1.2.3 | SIT Component Integration Testing Test Data Approach & Plan approved | milestone | 0d | 2023-07-19 A | 2023-07-19 A | 625 | 100% |  | 2023-07-19 | 2023-07-19 | 0d | 2023-07-19 | 2023-07-19 |  |  |  | SIT |  | 5.0 | Complete | COMPLETE | SI Test | IPA | Cesar Lopes | Systems Integration Testing (SIT) |  |  |  |  |

| ID | WBS | Task | Type | Duration | Start | Finish | Predecessors | Complete | Baseline start | Baseline finish | Baseline duration | Baseline 1 start | Baseline 1 finish | Constraint | Baseline cost | Responsible | Involved | Text9 | Update Version | MHHS Resource Name | MHHS Programme Phase | Sched Status | RAG | Artefact ID | Milestone ID | Text29 | Tier | Task Status |
| --- | --- | --- | --- | --- | --- | --- | --- | --- | --- | --- | --- | --- | --- | --- | --- | --- | --- | --- | --- | --- | --- | --- | --- | --- | --- | --- | --- | --- |
| 627 | 1.4.1.4.1.3 | **Test scenarios** |  | 173d | 2023-01-02 A | 2023-08-30 A |  | 100% | 2023-01-02 | 2023-08-30 | 173d | 2023-01-02 | 2023-06-02 |  |  | N/A | N/A | SIT | 5.0 | N/A | Systems Integration Testing (SIT) |  |  |  |  |  |  |  |
| 628 | 1.4.1.4.1.3.1 | Development of test scenarios | milestone | 0d | 2023-01-02 A | 2023-04-28 A | 619SS+45d | 100% | 2023-01-02 | 2023-04-28 | 85d | 2023-01-02 | 2023-04-28 |  |  | SI Test | PP, Code Bodies | SIT | 5.0 |  | Systems Integration Testing (SIT) | Complete | COMPLETE |  |  |  |  |  |
| 629 | 1.4.1.4.1.3.2 | Review test scenarios with SIT Working Group |  | 11d | 2023-02-01 A | 2023-08-09 A | 628SS+22d | 100% | 2023-02-01 | 2023-08-09 | 136d | 2023-02-01 | 2023-05-26 |  |  | SI Test | PP, Code Bodies, IPA | SIT | 5.0 |  | Systems Integration Testing (SIT) | Complete | COMPLETE |  |  |  |  |  |
| 630 | 1.4.1.4.1.3.3 | SIT Component Integration Testing Test scenarios approved | milestone | 0d | 2023-08-30 A | 2023-08-30 A | 629FS+15d | 100% | 2023-08-30 | 2023-08-30 | 0d | 2023-06-02 | 2023-06-02 |  |  | SI Test | PP | SIT | 5.6 |  | Systems Integration Testing (SIT) | Complete | COMPLETE | MHHS-ART148 | T3-TE-0014 | SITAG | T3 |  |
| 631 | 1.4.1.4.1.4 | **Test cases** |  | 160d | 2023-05-01 A | 2023-12-08 A |  | 100% | 2023-05-01 | 2023-12-08 | 160d | 2023-05-01 | 2023-09-01 |  |  | N/A | N/A | SIT | 5.6 | N/A | Systems Integration Testing (SIT) |  |  |  |  |  |  |  |
| 632 | 1.4.1.4.1.4.1 | **SI Test cases** |  | 160d | 2023-05-01 A | 2023-12-08 A |  | 100% | 2023-05-01 | 2023-12-08 | 160d | 2023-05-01 | 2023-09-01 |  |  | N/A | N/A | SIT | 5.6 | N/A | Systems Integration Testing (SIT) |  |  |  |  |  |  |  |
| 633 | 1.4.1.4.1.4.1.1 | **Batch 1 (CIT Intervals 1 and 2)** |  | 110d | 2023-05-01 A | 2023-09-29 A |  | 100% | 2023-05-01 | 2023-09-29 | 110d |  |  |  |  | N/A | N/A | SIT | 5.6 | N/A | Systems Integration Testing (SIT) |  |  |  |  |  |  | -290.67 |
| 634 | 1.4.1.4.1.4.1.1.1 | Develop Test cases |  | 100d | 2023-05-01 A | 2023-09-15 A | 628 | 100% | 2023-05-01 | 2023-09-15 | 100d | 2023-05-01 | 2023-07-28 |  |  | SI Test |  | SIT | 5.6 |  | Systems Integration Testing (SIT) | Complete | COMPLETE |  |  |  |  |  |
| 635 | 1.4.1.4.1.4.1.1.2 | Review Test cases with SIT Working Group |  | 9d | 2023-09-18 A | 2023-09-28 A | 634 | 100% | 2023-09-18 | 2023-09-28 | 9d | 2023-05-26 | 2023-08-25 |  |  | SI Test | PP,IPA | SIT | 5.6 |  | Systems Integration Testing (SIT) | Complete | COMPLETE |  |  |  |  |  |
| 636 | 1.4.1.4.1.4.1.1.3 | SIT Component Integration Testing Test cases Batch 1 (CIT Intervals 1 and 2) approved at ETMAG | milestone | 0d | 2023-09-29 A | 2023-09-29 A | 635FS+1d | 100% | 2023-09-29 | 2023-09-29 | 0d | 2023-09-01 | 2023-09-01 |  |  | SI Test | PP | SIT | 5.6 |  | Systems Integration Testing (SIT) | Complete | COMPLETE | MHHS-ART073 | T3-TE-0069 | SITAG | T3 |  |
| 637 | 1.4.1.4.1.4.1.2 | **Batch 2 (CIT Intervals 3 and 4)** |  | 25d | 2023-10-02 A | 2023-11-03 A |  | 100% | 2023-10-02 | 2023-11-03 | 25d |  |  |  |  | N/A | N/A | SIT | 5.6 | N/A | Systems Integration Testing (SIT) |  |  |  |  |  |  | -290.67 |
| 638 | 1.4.1.4.1.4.1.2.1 | Develop Test cases |  | 15d | 2023-10-02 A | 2023-10-20 A | 636 | 100% | 2023-10-02 | 2023-10-20 | 15d | 2023-05-01 | 2023-07-28 |  |  | SI Test |  | SIT | 5.6 |  | Systems Integration Testing (SIT) | Complete | COMPLETE |  |  |  |  |  |
| 639 | 1.4.1.4.1.4.1.2.2 | Review Test cases with SIT Working Group |  | 9d | 2023-10-23 A | 2023-11-02 A | 638 | 100% | 2023-10-23 | 2023-11-02 | 9d | 2023-05-26 | 2023-08-25 |  |  | SI Test | PP,IPA | SIT | 5.6 |  | Systems Integration Testing (SIT) | Complete | COMPLETE |  |  |  |  |  |
| 640 | 1.4.1.4.1.4.1.2.3 | SIT Component Integration Testing Test cases Batch 2 (CIT Intervals 3 and 4) approved at ETMAG | milestone | 0d | 2023-11-03 A | 2023-11-03 A | 639FS+1d | 100% | 2023-11-03 | 2023-11-03 | 0d | 2023-09-01 | 2023-09-01 |  |  | SI Test | PP | SIT | 5.11 |  | Systems Integration Testing (SIT) | Complete | COMPLETE |  | T3-TE-0104 | SITAG | T3 |  |
| 641 | 1.4.1.4.1.4.1.3 | **Batch 3 (CIT Intervals 5 and 6)** |  | 25d | 2023-11-03 A | 2023-12-08 A |  | 100% | 2023-11-03 | 2023-12-08 | 25d |  |  |  |  | N/A | N/A | SIT | 5.6 | N/A | Systems Integration Testing (SIT) |  |  |  |  |  |  | -290.67 |
| 642 | 1.4.1.4.1.4.1.3.1 | Develop Test cases |  | 15d | 2023-11-03 A | 2023-11-24 A | 640 | 100% | 2023-11-03 | 2023-11-24 | 15d | 2023-05-01 | 2023-07-28 |  |  | SI Test |  | SIT | 5.6 |  | Systems Integration Testing (SIT) | Complete | COMPLETE |  |  |  |  |  |
| 643 | 1.4.1.4.1.4.1.3.2 | Review Test cases with SIT Working Group |  | 9d | 2023-11-27 A | 2023-12-07 A | 642 | 100% | 2023-11-27 | 2023-12-07 | 9d | 2023-05-26 | 2023-08-25 |  |  | SI Test | PP,IPA | SIT | 5.6 |  | Systems Integration Testing (SIT) | Complete | COMPLETE |  |  |  |  |  |
| 644 | 1.4.1.4.1.4.1.3.3 | SIT Component Integration Testing Test cases Batch 3 (CIT Intervals 5 and 6) approved at ETMAG | milestone | 0d | 2023-12-08 A | 2023-12-08 A | 643FS+1d | 100% | 2023-12-08 | 2023-12-08 | 0d | 2023-09-01 | 2023-09-01 |  |  | SI Test | PP | SIT | 5.14 |  | Systems Integration Testing (SIT) | Complete | COMPLETE |  | T3-TE-0105 | SITAG | T3 |  |
| 645 | 1.4.1.4.1.5 | **CIT Interval 1 Preparation** |  | 283d | 2022-11-16 A | 2023-12-15 A |  | 100% | 2022-11-16 | 2023-12-15 | 278d | 2022-11-16 | 2023-10-23 |  | -0 | N/A | N/A | SIT | 5.6 | N/A | Systems Integration Testing (SIT) |  |  |  |  |  |  |  |
| 646 | 1.4.1.4.1.5.1 | **Environments (SIT A)** |  | 246d | 2022-11-16 A | 2023-10-25 A |  | 100% | 2022-11-16 | 2023-10-25 | 239d | 2022-11-16 | 2023-10-06 |  |  | N/A | N/A | SIT | 5.0 | N/A | Systems Integration Testing (SIT) |  |  |  |  |  |  |  |
| 647 | 1.4.1.4.1.5.1.1 | PPs register PKI Officers and request PKI certificates |  | 5d | 2023-10-09 A | 2023-10-13 A |  | 100% | 2023-10-09 | 2023-10-13 | 5d | 2023-08-28 | 2023-09-01 | start no earlier than 2023-10-09 |  | PP | DIP Provider | SIT | 5.5 | Simon Berry | Systems Integration Testing (SIT) | Complete | COMPLETE |  |  |  |  |  |
| 648 | 1.4.1.4.1.5.1.2 | PPs register PKI Officers and request PKI certificates Complete - Interval 1 | milestone | 0d | 2023-10-25 A | 2023-10-25 A | 647FS+8d | 100% | 2023-10-25 | 2023-10-25 | 0d |  |  |  |  | PP | DIP Provider | SIT | 5.10 | Simon Berry | Systems Integration Testing (SIT) | Complete | COMPLETE |  | T3-TE-0094 | SITAG | T3 |  |
| 649 | 1.4.1.4.1.5.1.3 | PP SIT A environment preparation (incl. security certificates and security compliance) |  | 238d | 2022-11-16 A | 2023-10-13 A | 538 | 100% | 2022-11-16 | 2023-10-13 | 208d | 2022-11-16 | 2023-09-01 |  |  | PP | SI Test | SIT | 5.8 | Simon Berry | Systems Integration Testing (SIT) | Complete | COMPLETE |  |  |  |  |  |
| 650 | 1.4.1.4.1.5.1.4 | SI coordinate SIT Participants' SIT A environment preparation |  | 238d | 2022-11-16 A | 2023-10-13 A | 649SS | 100% | 2022-11-16 | 2023-10-13 | 208d | 2022-11-16 | 2023-09-01 |  |  | SI Test | PP | SIT | 5.8 | Simon Berry | Systems Integration Testing (SIT) | Complete | COMPLETE |  |  |  |  |  |
| 651 | 1.4.1.4.1.5.1.5 | PP submit self-declaration of environment preparation complete (incl. security certificates and security compliance) to Programme for assurance | milestone | 0d | 2023-10-13 A | 2023-10-13 A | 649FF | 100% | 2023-10-13 | 2023-10-13 | 0d | 2023-09-01 | 2023-09-01 | start no earlier than 2023-10-13 |  | PP | SI Test | SIT | 5.8 | Simon Berry | Systems Integration Testing (SIT) | Complete | COMPLETE |  |  |  |  |  |
| 652 | 1.4.1.4.1.5.1.6 | SI assure PPs' self-declaration of environment preparation complete (incl. security certificates and security compliance) |  | 5d | 2023-10-16 A | 2023-10-20 A | 651FF+5d | 100% | 2023-10-16 | 2023-10-20 | 5d | 2023-09-04 | 2023-09-08 |  |  | SI Test | PP | SIT | 5.8 | Simon Berry | Systems Integration Testing (SIT) | Complete | COMPLETE |  |  |  |  |  |
| 653 | 1.4.1.4.1.5.1.7 | SIT Participants' SIT A environments ready to start connectivity proving CIT Interval 1 | milestone | 0d | 2023-09-01 A | 2023-09-01 A | 651SS | 100% | 2023-09-01 | 2023-09-01 | 0d | 2023-09-01 | 2023-09-01 |  |  | PP | PP,IPA | SIT | 5.6 | Simon Berry | Systems Integration Testing (SIT) | Complete | COMPLETE | MHHS-ART139 | T3-TE-0019 | SITAG | T3 |  |
| 654 | 1.4.1.4.1.5.1.8 | PP SIT A environment connectivity proving |  | 10d | 2023-09-04 A | 2023-09-15 A | 653 | 100% | 2023-09-04 | 2023-09-15 | 20d | 2023-09-04 | 2023-09-29 |  |  | PP | SI Test | SIT | 5.8 | Simon Berry | Systems Integration Testing (SIT) | Complete | COMPLETE |  |  |  |  |  |
| 655 | 1.4.1.4.1.5.1.9 | SI coordinate SIT Participants' SIT A environment connectivity proving |  | 10d | 2023-09-04 A | 2023-09-15 A | 654SS | 100% | 2023-09-04 | 2023-09-15 | 20d | 2023-09-04 | 2023-09-29 |  |  | SI Test | PP | SIT | 5.8 | Simon Berry | Systems Integration Testing (SIT) | Complete | COMPLETE |  |  |  |  |  |
| 656 | 1.4.1.4.1.5.1.10 | PP deployment of MHHS solution code to SIT A environments |  | 10d | 2023-09-25 A | 2023-10-06 A | 697FF | 100% | 2023-09-25 | 2023-10-06 | 10d | 2023-09-18 | 2023-09-29 |  |  | PP | SI Test | SIT | 5.0 | Simon Berry | Systems Integration Testing (SIT) | Complete | COMPLETE |  |  |  |  |  |
| 657 | 1.4.1.4.1.5.1.11 | SI coordinate deployment of MHHS solution code to SIT Participants' SIT A environments |  | 10d | 2023-09-25 A | 2023-10-06 A | 697FF | 100% | 2023-09-25 | 2023-10-06 | 10d | 2023-09-18 | 2023-09-29 |  |  | SI Test | PP | SIT | 5.0 | Simon Berry | Systems Integration Testing (SIT) | Complete | COMPLETE |  |  |  |  |  |
| 658 | 1.4.1.4.1.5.1.12 | PP submit evidence of SIT A environment connectivity proving and code deployment completion to Programme for assurance |  | 30d | 2023-09-04 A | 2023-10-13 A | 654SS | 100% | 2023-09-04 | 2023-10-13 | 20d | 2023-09-04 | 2023-09-29 |  |  | PP | SI Test | SIT | 5.8 | Simon Berry | Systems Integration Testing (SIT) | Complete | COMPLETE |  |  |  |  |  |
| 659 | 1.4.1.4.1.5.1.13 | SI assurance of SIT Participants' SIT A environment connectivity proving and code deployment completion |  | 25d | 2023-09-18 A | 2023-10-20 A | 658FF+5d | 100% | 2023-09-18 | 2023-10-20 | 25d | 2023-09-04 | 2023-10-06 |  |  | SI Test | PP | SIT | 5.8 | Simon Berry | Systems Integration Testing (SIT) | Complete | COMPLETE |  |  |  |  |  |

Notes:
- 636: Guidance: 18/8 - needs to finish on 29/9 for ETWAG / Action: 18/8 - needs to finish on 29/9 for ETWAG. Update Milestone register after approval
- 640: Guidance: 18/8 - needs to finish on 3/11 for ETWAG / Action: 18/8 - needs to finish on 29/9 for ETWAG
- 644: Guidance: 28/11 - Red because TMAG date has moved from 8/12 to 20/12 due to reduction in Dec TMAGs. No impact. No action

| ID | WBS | Task | Type | Duration | Start | Finish | Predecessors | Complete | Baseline start | Baseline finish | Baseline duration | Baseline cost | Responsible | Involved | Text9 | Task Status | Update Version | MHHS Resource Name | MHHS Programme Phase | Sched Status | RAG | Action | Milestone ID | Text29 | Tier | Artefact ID |
| --- | --- | --- | --- | --- | --- | --- | --- | --- | --- | --- | --- | --- | --- | --- | --- | --- | --- | --- | --- | --- | --- | --- | --- | --- | --- | --- |
| 660 | 1.4.1.4.1.5.2 | **Test Data - ISD Creation** |  | 9d | 2023-08-22 A | 2023-09-01 A |  | 100% | 2023-08-22 | 2023-09-01 | 9d |  | N/A | N/A | SIT | -275.67 | 5.5 | N/A | Systems Integration Testing (SIT) |  |  |  |  |  |  |  |
| 661 | 1.4.1.4.1.5.2.1 | Set-up Market Participants and DIP ID Data |  | 8d | 2023-08-22 A | 2023-08-31 A |  | 100% | 2023-08-22 | 2023-08-31 | 8d |  | SI Test Data | SI Test, DIP, Helix | SIT |  | 5.5 | Cesar Lopes | Systems Integration Testing (SIT) | Complete | COMPLETE |  |  |  |  |  |
| 662 | 1.4.1.4.1.5.2.2 | Distribute ISD Data to Participants |  | 1d | 2023-09-01 A | 2023-09-01 A | 661 | 100% | 2023-09-01 | 2023-09-01 | 1d |  | SI Test Data | SI Test, DIP, Helix | SIT |  | 5.5 | Cesar Lopes | Systems Integration Testing (SIT) | Complete | COMPLETE |  |  |  |  |  |
| 663 | 1.4.1.4.1.5.2.3 | Test Data - ISD Creation Complete | milestone | 0d | 2023-09-01 A | 2023-09-01 A | 662 | 100% | 2023-09-01 | 2023-09-01 | 0d |  | SI Test Data | SI Test, DIP, Helix | SIT |  | 5.5 | Cesar Lopes | Systems Integration Testing (SIT) | Complete | COMPLETE | 3/8 - add as t3 milestones. Awaiting approval at TMAG | T3-TE-0083 | SITAG | T3 |  |
| 664 | 1.4.1.4.1.5.3 | **Test Data - SFTP Onboarding** |  | 70d | 2023-08-21 A | 2023-11-24 A |  | 100% | 2023-08-21 | 2023-11-24 | 70d | -0 | N/A | N/A | SIT | -275.67 | 5.5 | N/A | Systems Integration Testing (SIT) |  |  |  |  |  |  |  |
| 665 | 1.4.1.4.1.5.3.1 | Create Containers and Keys for Participants |  | 3d | 2023-08-21 A | 2023-08-23 A |  | 100% | 2023-08-21 | 2023-08-23 | 3d |  | SI Test Data | SI Test | SIT |  | 5.5 | Cesar Lopes | Systems Integration Testing (SIT) | Complete | COMPLETE |  |  |  |  |  |
| 666 | 1.4.1.4.1.5.3.2 | Share SFTP Access with Participants |  | 5d | 2023-08-24 A | 2023-08-30 A | 665 | 100% | 2023-08-24 | 2023-08-30 | 5d |  | SI Test Data | SI Test, PP | SIT |  | 5.5 | Cesar Lopes | Systems Integration Testing (SIT) | Complete | COMPLETE |  |  |  |  |  |
| 667 | 1.4.1.4.1.5.3.3 | Test SFTP Connectivity |  | 5d | 2023-08-31 A | 2023-09-06 A | 666 | 100% | 2023-08-31 | 2023-09-06 | 5d |  | SI Test Data | SI Test, PP | SIT |  | 5.5 | Cesar Lopes | Systems Integration Testing (SIT) | Complete | COMPLETE |  |  |  |  |  |
| 668 | 1.4.1.4.1.5.3.4 | Test Data - SFTP Onboarding Complete | milestone | 0d | 2023-11-24 A | 2023-11-24 A | 667FS+57d | 100% | 2023-11-24 | 2023-11-24 | 0d |  | SI Test Data | SI Test, PP | SIT |  | 5.13 | Cesar Lopes | Systems Integration Testing (SIT) | Complete | COMPLETE |  | T3-TE-0084 | SITAG | T3 |  |
| 669 | 1.4.1.4.1.5.4 | **Test Data - Provide Sample Files** |  | 10d | 2023-08-21 A | 2023-09-01 A |  | 100% | 2023-08-21 | 2023-09-01 | 10d |  | N/A | N/A | SIT | -275.67 | 5.5 | N/A | Systems Integration Testing (SIT) |  |  |  |  |  |  |  |
| 670 | 1.4.1.4.1.5.4.1 | Generate Sample Files off IF Messages |  | 8d | 2023-08-21 A | 2023-08-30 A |  | 100% | 2023-08-21 | 2023-08-30 | 8d |  | SI Test Data | SI Test | SIT |  | 5.5 | Cesar Lopes | Systems Integration Testing (SIT) | Complete | COMPLETE |  |  |  |  |  |
| 671 | 1.4.1.4.1.5.4.2 | Transmit Sample Files off IF Messages to Participants (More detail needs to be planned for a POC) |  | 2d | 2023-08-31 A | 2023-09-01 A | 670 | 100% | 2023-08-31 | 2023-09-01 | 2d |  | SI Test Data | SI Test | SIT |  | 5.5 | Cesar Lopes | Systems Integration Testing (SIT) | Complete | COMPLETE |  |  |  |  |  |
| 672 | 1.4.1.4.1.5.4.3 | Test Data - Provide Sample Files Complete | milestone | 0d | 2023-09-01 A | 2023-09-01 A | 671 | 100% | 2023-09-01 | 2023-09-01 | 0d |  | SI Test Data | SI Test | SIT |  | 5.5 | Cesar Lopes | Systems Integration Testing (SIT) | Complete | COMPLETE | 3/8 - add as t3 milestones. Awaiting approval at TMAG | T3-TE-0085 | SITAG | T3 |  |
| 673 | 1.4.1.4.1.5.5 | **Test Data - Detailed SIT Data Load Guidance** |  | 65d | 2023-09-07 A | 2023-12-06 A |  | 100% | 2023-09-07 | 2023-12-06 | 62d | -0 | N/A | N/A | SIT | -275.67 | 5.5 | N/A | Systems Integration Testing (SIT) |  |  |  |  |  |  |  |
| 674 | 1.4.1.4.1.5.5.1 | Document Guidance |  | 21d | 2023-09-07 A | 2023-10-05 A | 672FS+3d | 100% | 2023-09-07 | 2023-10-05 | 16d |  | SI Test Data | SI Test | SIT |  | 5.9 | Cesar Lopes | Systems Integration Testing (SIT) | Complete | COMPLETE |  |  |  |  |  |
| 675 | 1.4.1.4.1.5.5.2 | Provide Guidance to PPs |  | 1d | 2023-10-06 A | 2023-10-06 A | 674 | 100% | 2023-10-06 | 2023-10-06 | 1d |  | SI Test Data | SI Test | SIT |  | 5.9 | Cesar Lopes | Systems Integration Testing (SIT) | Complete | COMPLETE |  |  |  |  |  |
| 676 | 1.4.1.4.1.5.5.3 | Test Data - Detailed SIT Functional Data Load Guidance Complete | milestone | 0d | 2023-12-06 A | 2023-12-06 A | 675FS+43d | 100% | 2023-12-06 | 2023-12-06 | 0d |  | SI Test Data | SI Test | SIT |  | 5.13 | Richard Puddephatt | Systems Integration Testing (SIT) | Complete | COMPLETE |  | T3-TE-0095 | SITAG | T3 | MHHS-DEL 1545 |
| 677 | 1.4.1.4.1.5.6 | **Test Data - Population of Data Items for Testing Guidance - Draft** |  | 80d | 2023-08-17 A | 2023-12-06 A |  | 100% | 2023-08-17 | 2023-12-06 | 77d | -0 | N/A | N/A | SIT | -275.67 | 5.5 | N/A | Systems Integration Testing (SIT) |  |  |  |  |  |  |  |
| 678 | 1.4.1.4.1.5.6.1 | Document Guidance - Draft |  | 11d | 2023-08-17 A | 2023-08-31 A | 867 | 100% | 2023-08-17 | 2023-08-31 | 11d |  | SI Test Data | SI Test | SIT |  | 5.6 | Cesar Lopes | Systems Integration Testing (SIT) | Complete | COMPLETE |  |  |  |  |  |
| 679 | 1.4.1.4.1.5.6.2 | Provide Guidance to PPs - Draft |  | 1d | 2023-09-01 A | 2023-09-01 A | 678 | 100% | 2023-09-01 | 2023-09-01 | 1d |  | SI Test Data | SI Test | SIT |  | 5.6 | Cesar Lopes | Systems Integration Testing (SIT) | Complete | COMPLETE |  |  |  |  |  |
| 680 | 1.4.1.4.1.5.6.3 | Test Data - Population of Data Items for Testing Guidance - Draft Complete | milestone | 0d | 2023-12-06 A | 2023-12-06 A | 679FS+68d | 100% | 2023-12-06 | 2023-12-06 | 0d |  | SI Test Data | SI Test | SIT |  | 5.13 | Richard Puddephatt | Systems Integration Testing (SIT) | Complete | COMPLETE |  | T3-TE-0096 | SITAG | T3 | MHHS-DEL 816 |
| 681 | 1.4.1.4.1.5.7 | **Test Data - Population of Data Items for Testing Guidance - Final** |  | 87d | 2023-08-17 A | 2023-12-15 A |  | 100% | 2023-08-17 | 2023-12-15 | 45d |  | N/A | N/A | SIT | -275.67 | 5.5 | N/A | Systems Integration Testing (SIT) |  |  |  |  |  |  |  |
| 682 | 1.4.1.4.1.5.7.1 | Update Document Guidance With PPS Feedback |  | 81d | 2023-08-17 A | 2023-12-07 A | 678SS | 100% | 2023-08-17 | 2023-12-07 | 44d |  | SI Test Data | SI Test | SIT |  | 5.5 | Richard Puddephatt | Systems Integration Testing (SIT) | Complete | COMPLETE |  |  |  |  |  |
| 683 | 1.4.1.4.1.5.7.2 | Provide Final Guidance to PPs |  | 1d | 2023-12-08 A | 2023-12-08 A | 682 | 100% | 2023-12-08 | 2023-12-08 | 1d |  | SI Test Data | SI Test | SIT |  | 5.5 | Richard Puddephatt | Systems Integration Testing (SIT) | Complete | COMPLETE |  |  |  |  |  |
| 684 | 1.4.1.4.1.5.7.3 | Test Data - Population of Data Items for Testing Guidance - Final Complete | milestone | 0d | 2023-12-15 A | 2023-12-15 A | 683FS+5d | 100% | 2023-12-15 | 2023-12-15 | 0d |  | SI Test Data | SI Test | SIT |  | 5.14 | Richard Puddephatt | Systems Integration Testing (SIT) | Complete | COMPLETE |  | T3-TE-0097 | SITAG | T3 | MHHS-DEL 816 |

| ID | WBS | Task | Type | Duration | Start | Finish | Predecessors | Complete | Baseline start | Baseline finish | Baseline duration | Baseline 1 start | Baseline 1 finish | Constraint | Baseline cost | Responsible | Involved | Text9 | Update Version | MHHS Resource Name | MHHS Programme Phase | Sched Status | RAG | Artefact ID | Milestone ID | Text29 | Tier |
| --- | --- | --- | --- | --- | --- | --- | --- | --- | --- | --- | --- | --- | --- | --- | --- | --- | --- | --- | --- | --- | --- | --- | --- | --- | --- | --- | --- |
| 685 | 1.4.1.4.1.5.8 | **Test Data (SIT A) Interval 1** |  | 40d | 2023-09-04 A | 2023-10-27 A |  | 100% | 2023-09-04 | 2023-10-27 | 20d | 2023-09-04 | 2023-09-29 |  |  | N/A | N/A | SIT | 5.0 | N/A | Systems Integration Testing (SIT) |  |  |  |  |  |  |
| 686 | 1.4.1.4.1.5.8.1 | Run data allocation |  | 4d | 2023-09-04 A | 2023-09-07 A | 626, 663 | 100% | 2023-09-04 | 2023-09-07 | 4d | 2023-09-04 | 2023-09-07 |  |  | SI Test |  | SIT | 5.0 | Cesar Lopes | Systems Integration Testing (SIT) | Complete | COMPLETE |  |  |  |  |
| 687 | 1.4.1.4.1.5.8.2 | Cleanse, anonymise and populate data post cut |  | 4d | 2023-09-08 A | 2023-09-13 A | 686 | 100% | 2023-09-08 | 2023-09-13 | 4d | 2023-09-08 | 2023-09-13 |  |  | SI Test |  | SIT | 5.0 | Cesar Lopes | Systems Integration Testing (SIT) | Complete | COMPLETE |  |  |  |  |
| 688 | 1.4.1.4.1.5.8.3 | Transmit data sets to PPs |  | 3d | 2023-09-15 A | 2023-09-19 A | 687 | 100% | 2023-09-15 | 2023-09-19 | 1d | 2023-09-14 | 2023-09-15 |  |  | SI Test |  | SIT | 5.0 | Cesar Lopes | Systems Integration Testing (SIT) | Complete | COMPLETE |  |  |  |  |
| 689 | 1.4.1.4.1.5.8.4 | PP - Load test data to test environments |  | 7d | 2023-09-20 A | 2023-09-28 A | 688, 672 | 100% | 2023-09-20 | 2023-09-28 | 5d | 2023-09-18 | 2023-09-22 |  |  | PP |  | SIT | 5.0 | Cesar Lopes | Systems Integration Testing (SIT) | Complete | COMPLETE |  |  |  |  |
| 690 | 1.4.1.4.1.5.8.5 | PP Check data integrity on test environment |  | 1d | 2023-09-29 A | 2023-09-29 A | 689 | 100% | 2023-09-29 | 2023-09-29 | 5d | 2023-09-25 | 2023-09-29 |  |  | PP |  | SIT | 5.0 | Cesar Lopes | Systems Integration Testing (SIT) | Complete | COMPLETE |  |  |  |  |
| 691 | 1.4.1.4.1.5.8.6 | PP submit self-declaration to Programme to confirm loading & verification of test data | milestone | 0d | 2023-09-29 A | 2023-09-29 A | 690FF | 100% | 2023-09-29 | 2023-09-29 | 0d | 2023-09-29 | 2023-09-29 |  |  | PP | SI Test | SIT | 5.0 | Cesar Lopes | Systems Integration Testing (SIT) | Complete | COMPLETE |  |  |  |  |
| 692 | 1.4.1.4.1.5.8.7 | Test Data (SIT A) Interval 1 Complete | milestone | 0d | 2023-10-27 A | 2023-10-27 A | 691FS+20d | 100% | 2023-10-27 | 2023-10-27 | 0d |  |  |  |  | SI Test | PP | SIT | 5.10 | Cesar Lopes | Systems Integration Testing (SIT) | Complete | COMPLETE | MHHS-ART148/169 | T3-TE-0073 | SITAG | T3 |
| 693 | 1.4.1.4.1.5.9 | **Other Preparation** |  | 45d | 2023-07-03 A | 2023-09-01 A |  | 100% | 2023-07-03 | 2023-09-01 | 45d | 2023-07-03 | 2023-09-01 |  |  | N/A | N/A | SIT | 5.0 | N/A | Systems Integration Testing (SIT) |  |  |  |  |  |  |
| 694 | 1.4.1.4.1.5.9.1 | Onboarding of Test Participants to Test Management Tool (Azure DevOps) |  | 45d | 2023-07-03 A | 2023-09-01 A | 653SF | 100% | 2023-07-03 | 2023-09-01 | 45d | 2023-07-03 | 2023-09-01 |  |  | SI Test | PP | SIT | 5.0 |  | Systems Integration Testing (SIT) | Complete | COMPLETE |  |  |  |  |
| 695 | 1.4.1.4.1.5.9.2 | Test Management Tool onboarding |  | 45d | 2023-07-03 A | 2023-09-01 A | 653SF | 100% | 2023-07-03 | 2023-09-01 | 45d | 2023-07-03 | 2023-09-01 |  |  | PP | SI Test | SIT | 5.0 |  | Systems Integration Testing (SIT) | Complete | COMPLETE |  |  |  |  |
| 696 | 1.4.1.4.1.5.10 | **SIT Component Integration Test Readiness Report** |  | 28d | 2023-09-14 A | 2023-10-23 A |  | 100% | 2023-09-14 | 2023-10-23 | 9d | 2023-09-11 | 2023-10-20 |  |  | N/A | N/A | SIT | 5.6 | N/A | Systems Integration Testing (SIT) |  |  |  |  |  |  |
| 697 | 1.4.1.4.1.5.10.1 | PP submit Test Readiness Report to Programme for assurance | milestone | 0d | 2023-10-20 A | 2023-10-20 A | 695, 636, 692 | 100% | 2023-10-20 | 2023-10-20 | 0d | 2023-09-29 | 2023-09-29 | start no earlier than 2023-10-09 |  | PP | SI Test | SIT | 5.6 |  | Systems Integration Testing (SIT) | Complete | COMPLETE |  |  |  |  |
| 698 | 1.4.1.4.1.5.10.2 | SI assure Test Participants' Test Readiness Reports |  | 1d | 2023-10-23 A | 2023-10-23 A | 697SS | 100% | 2023-10-23 | 2023-10-23 | 5d | 2023-10-02 | 2023-10-06 |  |  | SI Test | PP,IPA | SIT | 5.6 |  | Systems Integration Testing (SIT) | Complete | COMPLETE |  |  |  |  |
| 699 | 1.4.1.4.1.5.10.3 | SI develop Overarching SIT Component Integration Test Readiness Report |  | 23d | 2023-09-14 A | 2023-10-16 A | 622FS+40d | 100% | 2023-09-14 | 2023-10-16 | 4d | 2023-09-11 | 2023-10-06 |  |  | SI Test |  | SIT | 5.6 |  | Systems Integration Testing (SIT) | Complete | COMPLETE |  |  |  |  |
| 700 | 1.4.1.4.1.5.10.4 | Artefact review (via TMAG) and updates |  | 4d | 2023-10-17 A | 2023-10-20 A | 699 | 100% | 2023-10-17 | 2023-10-20 | 5d | 2023-10-09 | 2023-10-20 |  |  | SI Test | PP,IPA | SIT | 5.6 |  | Systems Integration Testing (SIT) | Complete | COMPLETE |  |  |  |  |
| 701 | 1.4.1.4.1.5.11 | SIT Component Integration Testing 1 Preparation Complete (incl. approval of SI SIT Component Integration Test Readiness Report) | milestone | 0d | 2023-10-27 A | 2023-10-27 A | 700FS+1d, 697, 653, 695, 692, 252, 257, 246, 266, 267, 698 | 100% | 2023-10-27 | 2023-10-27 | 0d | 2023-10-23 | 2023-10-23 |  |  | SI Test | PP,IPA | SIT | 5.11 |  | Systems Integration Testing (SIT) | Complete | COMPLETE | MHHS-ART071 | T2-TE-0250 | SITAG | T2 |
| 702 | 1.4.1.4.1.6 | **CIT Interval 2 Preparation** |  | 103d | 2023-07-03 A | 2023-11-22 A |  | 100% | 2023-07-03 | 2023-11-22 | 95d | 2022-11-16 | 2023-11-06 |  | -0 | N/A | N/A | SIT | 5.0 | N/A | Systems Integration Testing (SIT) |  |  |  |  |  |  |
| 703 | 1.4.1.4.1.6.1 | **Environments (SIT A)** |  | 43d | 2023-09-22 A | 2023-11-22 A |  | 100% | 2023-09-22 | 2023-11-22 | 35d | 2022-11-16 | 2023-10-27 |  | -0 | N/A | N/A | SIT | 5.0 | N/A | Systems Integration Testing (SIT) |  |  |  |  |  |  |
| 704 | 1.4.1.4.1.6.1.1 | SIT Participants' SIT A environments ready to start connectivity proving CIT Interval 2 | milestone | 0d | 2023-09-22 A | 2023-09-22 A |  | 100% | 2023-09-22 | 2023-09-22 | 0d | 2023-09-22 | 2023-09-22 |  |  | PP | PP,IPA | SIT | 5.6 | Simon Berry | Systems Integration Testing (SIT) | Complete | COMPLETE | MHHS-ART139 | T3-TE-0020 | SITAG | T3 |
| 705 | 1.4.1.4.1.6.1.2 | Programme Participants Ready to Start Connectivity Proving | milestone | 0d | 2023-09-22 A | 2023-09-22 A |  | 100% | 2023-09-22 | 2023-09-22 | 0d |  |  | finish no earlier than 2023-09-22 |  | PP |  | SIT | 5.10 | Simon Berry | Systems Integration Testing (SIT) | Complete | COMPLETE |  |  |  |  |
| 706 | 1.4.1.4.1.6.1.3 | Internal Connectivity Proving Phase |  | 10d | 2023-09-25 A | 2023-10-06 A | 705 | 100% | 2023-09-25 | 2023-10-06 | 10d |  |  |  |  | PP |  | SIT | 5.10 | Simon Berry | Systems Integration Testing (SIT) | Complete | COMPLETE |  |  |  |  |
| 707 | 1.4.1.4.1.6.1.4 | Internal Connectivity Proving Phase Complete | milestone | 0d | 2023-10-06 A | 2023-10-06 A | 706 | 100% | 2023-10-06 | 2023-10-06 | 0d |  |  | start no earlier than 2023-10-06 |  | PP |  | SIT | 5.10 | Simon Berry | Systems Integration Testing (SIT) | Complete | COMPLETE |  |  |  |  |
| 708 | 1.4.1.4.1.6.1.5 | DIP Onboarding Activity (1. PKI Officers and Certificates, 2. Set-up Validation, 3. End Point Creation, 4. Controlled Smoke Test ) |  | 28d | 2023-10-16 A | 2023-11-22 A | 707FS+5d | 100% | 2023-10-16 | 2023-11-22 | 20d |  |  |  |  | PP |  | SIT | 5.10 | Simon Berry | Systems Integration Testing (SIT) | Complete | COMPLETE |  |  |  |  |
| 709 | 1.4.1.4.1.6.1.6 | DIP Onboarding Complete | milestone | 0d | 2023-11-22 A | 2023-11-22 A | 708 | 100% | 2023-11-22 | 2023-11-22 | 0d |  |  |  |  | PP |  | SIT | 5.10 | Simon Berry | Systems Integration Testing (SIT) | Complete | COMPLETE |  |  |  |  |
| 710 | 1.4.1.4.1.6.1.7 | PPs Register PKI Officers and request PKI certificates Complete - Interval 2 | milestone | 0d | 2023-11-22 A | 2023-11-22 A | 709 | 100% | 2023-11-22 | 2023-11-22 | 0d |  |  |  |  | PP | DIP Provider | SIT | 5.15 | Simon Berry | Systems Integration Testing (SIT) | Complete | COMPLETE |  | T3-TE-0098 | SITAG | T3 |
| 711 | 1.4.1.4.1.6.1.8 | PP Code Deployment | milestone | 0d | 2023-10-20 A | 2023-10-20 A |  | 100% | 2023-10-20 | 2023-10-20 | 0d |  |  | start no earlier than 2023-10-20 |  | PP |  | SIT | 5.10 | Simon Berry | Systems Integration Testing (SIT) | Complete | COMPLETE |  |  |  |  |

Notes:
- 692: Action: 28/7: CH: Needs to be set-up as a reporting milestone. 31/7: Check with Cesar if has been approved so can be baselined
- 696: Action: 21/8 - Rework with Lee
- 698: Action: 21/8 - Rework with Lee
- 699: Action: 21/8 - Rework with Lee
- 700: Action: 21/8 - Rework with Lee

| ID | WBS | Task | Type | Duration | Start | Finish | Predecessors | Complete | Baseline start | Baseline finish | Baseline duration | Baseline 1 start | Baseline 1 finish | Constraint | Baseline cost | Responsible | Involved | Text9 | Update Version | MHHS Resource Name | MHHS Programme Phase | Sched Status | RAG | Artefact ID | Milestone ID | Text29 | Tier |
| --- | --- | --- | --- | --- | --- | --- | --- | --- | --- | --- | --- | --- | --- | --- | --- | --- | --- | --- | --- | --- | --- | --- | --- | --- | --- | --- | --- |
| 712 | 1.4.1.4.1.6.2 | **Test Data (SIT A) Interval 2** |  | 43d | 2023-09-20 A | 2023-11-17 A |  | 100% | 2023-09-20 | 2023-11-17 | 25d | 2023-09-18 | 2023-10-20 |  |  | N/A | N/A | SIT | 5.0 | N/A | Systems Integration Testing (SIT) |  |  |  |  |  |  |
| 713 | 1.4.1.4.1.6.2.1 | Run data allocation |  | 7d | 2023-09-20 A | 2023-09-28 A | 689SS | 100% | 2023-09-20 | 2023-09-28 | 5d | 2023-09-18 | 2023-09-22 |  |  | SI Test |  | SIT | 5.0 | Cesar Lopes | Systems Integration Testing (SIT) | Complete | COMPLETE |  |  |  |  |
| 714 | 1.4.1.4.1.6.2.2 | Cleanse and populate data post cut |  | 2d | 2023-09-29 A | 2023-10-02 A | 713 | 100% | 2023-09-29 | 2023-10-02 | 5d | 2023-09-25 | 2023-09-29 |  |  | SI Test |  | SIT | 5.0 | Cesar Lopes | Systems Integration Testing (SIT) | Complete | COMPLETE |  |  |  |  |
| 715 | 1.4.1.4.1.6.2.3 | Transmit data sets to PPs |  | 1d | 2023-10-03 A | 2023-10-03 A | 714 | 100% | 2023-10-03 | 2023-10-03 | 2d | 2023-10-02 | 2023-10-03 |  |  | SI Test |  | SIT | 5.0 | Cesar Lopes | Systems Integration Testing (SIT) | Complete | COMPLETE |  |  |  |  |
| 716 | 1.4.1.4.1.6.2.4 | PP - Load test data to test environments |  | 33d | 2023-10-04 A | 2023-11-17 A | 715 | 100% | 2023-10-04 | 2023-11-17 | 8d | 2023-10-04 | 2023-10-13 |  |  | PP |  | SIT | 5.0 | Cesar Lopes | Systems Integration Testing (SIT) | Complete | COMPLETE |  |  |  |  |
| 717 | 1.4.1.4.1.6.2.5 | PP Check data integrity on test environment |  | 15d | 2023-10-23 A | 2023-11-17 A | 716FF | 100% | 2023-10-23 | 2023-11-17 | 5d | 2023-10-16 | 2023-10-20 |  |  | PP |  | SIT | 5.0 | Cesar Lopes | Systems Integration Testing (SIT) | Complete | COMPLETE |  |  |  |  |
| 718 | 1.4.1.4.1.6.2.6 | PP submit self-declaration to Programme to confirm loading & verification of test data | milestone | 0d | 2023-11-17 A | 2023-11-17 A | 717FF | 100% | 2023-11-17 | 2023-11-17 | 0d | 2023-10-20 | 2023-10-20 |  |  | PP | SI Test | SIT | 5.0 | Cesar Lopes | Systems Integration Testing (SIT) | Complete | COMPLETE |  |  |  |  |
| 719 | 1.4.1.4.1.6.2.7 | Test Data (SIT A) Interval 2 Complete | milestone | 0d | 2023-11-17 A | 2023-11-17 A | 718 | 100% | 2023-11-17 | 2023-11-17 | 0d |  |  |  |  | SI Test | PP | SIT | 5.12 | Cesar Lopes | Systems Integration Testing (SIT) | Complete | COMPLETE | MHHS-ART148/169 | T3-TE-0074 | SITAG | T3 |
| 720 | 1.4.1.4.1.6.3 | **Other Preparation** |  | 87d | 2023-07-03 A | 2023-10-31 A |  | 100% | 2023-07-03 | 2023-10-31 | 87d | 2023-07-03 | 2023-09-22 |  | -0 | N/A | N/A | SIT | 5.0 | N/A | Systems Integration Testing (SIT) |  |  |  |  |  |  |
| 721 | 1.4.1.4.1.6.3.1 | Onboarding of Test Participants to Test Management Tool (Azure DevOps) |  | 60d | 2023-07-03 A | 2023-09-22 A | 704SF | 100% | 2023-07-03 | 2023-09-22 | 60d | 2023-07-03 | 2023-09-22 |  |  | SI Test | PP | SIT | 5.0 |  | Systems Integration Testing (SIT) | Complete | COMPLETE |  |  |  |  |
| 722 | 1.4.1.4.1.6.3.2 | Test Management Tool onboarding |  | 27d | 2023-09-25 A | 2023-10-31 A | 721 | 100% | 2023-09-25 | 2023-10-31 | 27d | 2023-07-03 | 2023-09-22 |  |  | PP | SI Test | SIT | 5.0 | Simon Berry | Systems Integration Testing (SIT) | Complete | COMPLETE |  |  |  |  |
| 723 | 1.4.1.4.1.6.4 | **SIT Component Integration Test Readiness Report** |  | 25d | 2023-10-02 A | 2023-11-03 A |  | 100% | 2023-10-02 | 2023-11-03 | 25d | 2023-10-02 | 2023-11-03 |  |  | N/A | N/A | SIT | 5.0 | N/A | Systems Integration Testing (SIT) |  |  |  |  |  |  |
| 724 | 1.4.1.4.1.6.4.1 | PP submit Test Readiness Report to Programme for assurance | milestone | 0d | 2023-10-25 A | 2023-10-25 A | 636FS+18d | 100% | 2023-10-25 | 2023-10-25 | 0d | 2023-10-20 | 2023-10-20 |  |  | PP | SI Test | SIT | 5.0 |  | Systems Integration Testing (SIT) | Complete | COMPLETE |  |  |  |  |
| 725 | 1.4.1.4.1.6.4.2 | SI assure Test Participants' Test Readiness Reports |  | 2d | 2023-10-26 A | 2023-10-27 A | 724 | 100% | 2023-10-26 | 2023-10-27 | 5d | 2023-10-23 | 2023-10-27 |  |  | SI Test | PP,IPA | SIT | 5.0 |  | Systems Integration Testing (SIT) | Complete | COMPLETE |  |  |  |  |
| 726 | 1.4.1.4.1.6.4.3 | SI develop Overarching SIT Component Integration Test Readiness Report |  | 20d | 2023-10-02 A | 2023-10-27 A | 725FF | 100% | 2023-10-02 | 2023-10-27 | 20d | 2023-10-02 | 2023-10-27 |  |  | SI Test |  | SIT | 5.0 |  | Systems Integration Testing (SIT) | Complete | COMPLETE |  |  |  |  |
| 727 | 1.4.1.4.1.6.4.4 | Artefact review (via TMAG) and updates |  | 5d | 2023-10-30 A | 2023-11-03 A | 726 | 100% | 2023-10-30 | 2023-11-03 | 5d | 2023-10-30 | 2023-11-03 |  |  | SI Test | PP,IPA | SIT | 5.0 |  | Systems Integration Testing (SIT) | Complete | COMPLETE |  |  |  |  |
| 728 | 1.4.1.4.1.6.5 | SIT Component Integration Testing 2 Preparation Complete (incl. approval of SI SIT Component Integration Test Readiness Report) | milestone | 0d | 2023-11-06 A | 2023-11-06 A | 722, 727FS+1d, 704, 315 | 100% | 2023-11-06 | 2023-11-06 | 0d | 2023-11-06 | 2023-11-06 |  |  | SI Test | PP,IPA | SIT | 5.11 |  | Systems Integration Testing (SIT) | Complete | COMPLETE | MHHS-ART071 | T2-TE-0300 | SITAG | T2 |
| 729 | 1.4.1.4.1.7 | **CIT Interval 3 Preparation** |  | 54d | 2023-10-03 A | 2023-12-15 A |  | 100% | 2023-10-03 | 2023-12-15 | 91d | 2022-11-16 | 2023-11-20 |  | -0 | N/A | N/A | SIT | 5.0 | N/A | Systems Integration Testing (SIT) |  |  |  |  |  |  |
| 730 | 1.4.1.4.1.7.1 | **PIT Test Completion Report (incl. evidence)** |  | 26d | 2023-10-13 A | 2023-11-17 A |  | 100% | 2023-10-13 | 2023-11-17 | 21d | 2023-10-13 | 2023-11-10 |  |  | N/A | N/A | SIT | 5.0 | N/A | Systems Integration Testing (SIT) |  |  |  |  |  |  |
| 731 | 1.4.1.4.1.7.1.1 | Submit draft PIT Test Completion Report (incl. evidence) and submit to Programme for assurance |  | 11d | 2023-10-13 A | 2023-10-27 A |  | 100% | 2023-10-13 | 2023-10-27 | 1d | 2023-10-13 | 2023-10-13 | must start on 2023-10-13 |  | PP | SI Test | SIT | 5.0 |  | Systems Integration Testing (SIT) | Complete | COMPLETE |  |  |  |  |
| 732 | 1.4.1.4.1.7.1.2 | Finalise PIT Test Completion Report (incl. evidence) |  | 5d | 2023-10-30 A | 2023-11-03 A | 731 | 100% | 2023-10-30 | 2023-11-03 | 15d | 2023-10-16 | 2023-11-03 |  |  | PP | SI Test | SIT | 5.0 |  | Systems Integration Testing (SIT) | Complete | COMPLETE |  |  |  |  |
| 733 | 1.4.1.4.1.7.1.3 | PP PIT Completion Report (excl. Migration/Reverse Migration) submitted to Programme for assurance CIT Interval 3 | milestone | 0d | 2023-11-03 A | 2023-11-03 A | 732, 79, 95 | 100% | 2023-11-03 | 2023-11-03 | 0d | 2023-11-03 | 2023-11-03 |  |  | PP | SI Test | SIT | 5.11 |  | Systems Integration Testing (SIT) | Complete | COMPLETE |  | T3-DB-0017 | SITAG | T3 |
| 734 | 1.4.1.4.1.7.1.4 | PP Final PIT Completion Reports assured by SI |  | 10d | 2023-11-06 A | 2023-11-17 A | 733 | 100% | 2023-11-06 | 2023-11-17 | 5d | 2023-11-06 | 2023-11-10 |  |  | SI Test | PP | SIT | 5.0 |  | Systems Integration Testing (SIT) | Complete | COMPLETE |  |  |  |  |
| 735 | 1.4.1.4.1.7.2 | **Environments (SIT A)** |  | 51d | 2023-10-06 A | 2023-12-15 A |  | 100% | 2023-10-06 | 2023-12-15 | 26d | 2022-11-16 | 2023-11-10 |  | -0 | N/A | N/A | SIT | 5.0 | N/A | Systems Integration Testing (SIT) |  |  |  |  |  |  |
| 736 | 1.4.1.4.1.7.2.1 | Programme Participants Ready to Start Connectivity Proving | milestone | 0d | 2023-10-06 A | 2023-10-06 A |  | 100% | 2023-10-06 | 2023-10-06 | 0d |  |  | start no earlier than 2023-10-06 |  | PP | PP.SI Test | SIT | 5.10 | Simon Berry | Systems Integration Testing (SIT) | Complete | COMPLETE |  |  |  |  |
| 737 | 1.4.1.4.1.7.2.2 | SIT Participants' SIT A environments ready to start connectivity proving CIT Interval 3 | milestone | 0d | 2023-10-06 A | 2023-10-06 A | 736 | 100% | 2023-10-06 | 2023-10-06 | 0d | 2023-10-06 | 2023-10-06 |  |  | PP | PP,SI Test | SIT | 5.10 | Simon Berry | Systems Integration Testing (SIT) | Complete | COMPLETE | MHHS-ART139 | T3-TE-0021 | SITAG | T3 |
| 738 | 1.4.1.4.1.7.2.3 | Internal Connectivity Proving Phase |  | 10d | 2023-10-09 A | 2023-10-20 A | 736FS+1d | 100% | 2023-10-09 | 2023-10-20 | 10d |  |  |  |  | PP | PP,SI Test | SIT | 5.10 | Simon Berry | Systems Integration Testing (SIT) | Complete | COMPLETE |  |  |  |  |
| 739 | 1.4.1.4.1.7.2.4 | Internal Connectivity Proving Phase Complete | milestone | 0d | 2023-10-20 A | 2023-10-20 A | 738 | 100% | 2023-10-20 | 2023-10-20 | 0d |  |  |  |  | PP | PP,SI Test | SIT | 5.10 | Simon Berry | Systems Integration Testing (SIT) | Complete | COMPLETE |  |  |  |  |
| 740 | 1.4.1.4.1.7.2.5 | DIP Onboarding Activity (1. PKI Officers and Certificates, 2. Set-up Validation, 3. End Point Creation, 4. Controlled Smoke Test ) |  | 35d | 2023-10-30 A | 2023-12-15 A | 739FS+5d | 100% | 2023-10-30 | 2023-12-15 | 10d |  |  |  |  | PP | PP,DIP Provider | SIT | 5.10 | Simon Berry | Systems Integration Testing (SIT) | Complete | COMPLETE |  |  |  |  |
| 741 | 1.4.1.4.1.7.2.6 | DIP Onboarding Complete | milestone | 0d | 2023-12-15 A | 2023-12-15 A | 740 | 100% | 2023-12-15 | 2023-12-15 | 0d |  |  |  |  | PP | PP,DIP Provider | SIT | 5.10 | Simon Berry | Systems Integration Testing (SIT) | Complete | COMPLETE |  |  |  |  |
| 742 | 1.4.1.4.1.7.2.7 | PPs Register PKI Officers and Request PKI certificates Complete - Interval 3 | milestone | 0d | 2023-12-15 A | 2023-12-15 A | 741FF | 100% | 2023-12-15 | 2023-12-15 | 0d | 2023-10-02 | 2023-10-06 |  |  | PP | PP,DIP Provider | SIT | 5.13 | Simon Berry | Systems Integration Testing (SIT) | Complete | COMPLETE |  | T3-TE-0099 | SITAG | T3 |
| 743 | 1.4.1.4.1.7.2.8 | PP Code Deployment | milestone | 0d | 2023-11-10 A | 2023-11-10 A | 739FS+15d | 100% | 2023-11-10 | 2023-11-10 | 0d |  |  | start no earlier than 2023-10-20 |  | PP | PP | SIT | 5.10 | Simon Berry | Systems Integration Testing (SIT) | Complete | COMPLETE |  |  |  |  |

Notes:
- 719: Action: 28/7: CH: Needs to be set-up as a reporting milestone. 31/7: Check with Cesar if has been approved so can be baselined
- 737: Action: 30/8 - lee said date is 30/10

| ID | WBS | Task | Type | Duration | Start | Finish | Predecessors | Complete | Baseline start | Baseline finish | Baseline duration | Baseline 1 start | Baseline 1 finish | Constraint | Baseline cost | Responsible | Involved | Text9 | Update Version | MHHS Resource Name | MHHS Programme Phase | Sched Status | RAG | Artefact ID | Milestone ID | Text29 | Tier |
| --- | --- | --- | --- | --- | --- | --- | --- | --- | --- | --- | --- | --- | --- | --- | --- | --- | --- | --- | --- | --- | --- | --- | --- | --- | --- | --- | --- |
| 744 | 1.4.1.4.1.7.3 | **Test Data (SIT A) Interval 3** |  | 34d | 2023-10-03 A | 2023-11-17 A |  | 100% | 2023-10-03 | 2023-11-17 | 25d | 2023-10-02 | 2023-11-03 |  |  | N/A | N/A | SIT | 5.0 | N/A | Systems Integration Testing (SIT) |  |  |  |  |  |  |
| 745 | 1.4.1.4.1.7.3.1 | Run data allocation |  | 4d | 2023-10-03 A | 2023-10-06 A | 715SS | 100% | 2023-10-03 | 2023-10-06 | 5d | 2023-10-02 | 2023-10-06 |  |  | SI Test |  | SIT | 5.0 | Cesar Lopes | Systems Integration Testing (SIT) | Complete | COMPLETE |  |  |  |  |
| 746 | 1.4.1.4.1.7.3.2 | Cleanse and populate data post cut |  | 5d | 2023-10-09 A | 2023-10-13 A | 745 | 100% | 2023-10-09 | 2023-10-13 | 5d | 2023-10-09 | 2023-10-13 |  |  | SI Test |  | SIT | 5.0 | Cesar Lopes | Systems Integration Testing (SIT) | Complete | COMPLETE |  |  |  |  |
| 747 | 1.4.1.4.1.7.3.3 | Transmit data sets to PPs |  | 2d | 2023-10-16 A | 2023-10-17 A | 746 | 100% | 2023-10-16 | 2023-10-17 | 2d | 2023-10-16 | 2023-10-17 |  |  | SI Test |  | SIT | 5.0 | Cesar Lopes | Systems Integration Testing (SIT) | Complete | COMPLETE |  |  |  |  |
| 748 | 1.4.1.4.1.7.3.4 | PP - Load test data to test environments |  | 8d | 2023-10-18 A | 2023-10-27 A | 747 | 100% | 2023-10-18 | 2023-10-27 | 8d | 2023-10-18 | 2023-10-27 |  |  | PP |  | SIT | 5.0 | Cesar Lopes | Systems Integration Testing (SIT) | Complete | COMPLETE |  |  |  |  |
| 749 | 1.4.1.4.1.7.3.5 | PP Check data integrity on test environment |  | 15d | 2023-10-30 A | 2023-11-17 A | 748 | 100% | 2023-10-30 | 2023-11-17 | 5d | 2023-10-30 | 2023-11-03 |  |  | PP |  | SIT | 5.0 | Cesar Lopes | Systems Integration Testing (SIT) | Complete | COMPLETE |  |  |  |  |
| 750 | 1.4.1.4.1.7.3.6 | PP submit self-declaration to Programme to confirm loading & verification of test data | milestone | 0d | 2023-11-17 A | 2023-11-17 A | 749FF | 100% | 2023-11-17 | 2023-11-17 | 0d | 2023-11-03 | 2023-11-03 |  |  | PP | SI Test | SIT | 5.0 | Cesar Lopes | Systems Integration Testing (SIT) | Complete | COMPLETE |  |  |  |  |
| 751 | 1.4.1.4.1.7.3.7 | Test Data (SIT A) Interval 3 Complete | milestone | 0d | 2023-11-17 A | 2023-11-17 A | 750 | 100% | 2023-11-17 | 2023-11-17 | 0d |  |  |  |  | SI Test | PP | SIT | 5.13 | Cesar Lopes | Systems Integration Testing (SIT) | Complete | COMPLETE | MHHS-ART148/169 | T3-TE-0075 | SITAG | T3 |
| 752 | 1.4.1.4.1.7.4 | **Other Preparation** |  | 25d | 2023-10-16 A | 2023-11-17 A |  | 100% | 2023-10-16 | 2023-11-17 | 60d | 2023-07-17 | 2023-10-06 |  |  | N/A | N/A | SIT | 5.0 | N/A | Systems Integration Testing (SIT) |  |  |  |  |  |  |
| 753 | 1.4.1.4.1.7.4.1 | Onboarding of Test Participants to Test Management Tool (Azure DevOps) |  | 25d | 2023-10-16 A | 2023-11-17 A |  | 100% | 2023-10-16 | 2023-11-17 | 60d | 2023-07-17 | 2023-10-06 | start no earlier than 2023-10-16 |  | SI Test | PP | SIT | 5.0 | Simon Berry | Systems Integration Testing (SIT) | Complete | COMPLETE |  |  |  |  |
| 754 | 1.4.1.4.1.7.4.2 | Test Management Tool onboarding |  | 25d | 2023-10-16 A | 2023-11-17 A |  | 100% | 2023-10-16 | 2023-11-17 | 60d | 2023-07-17 | 2023-10-06 | start no earlier than 2023-10-16 |  | PP | SI Test | SIT | 5.0 | Simon Berry | Systems Integration Testing (SIT) | Complete | COMPLETE |  |  |  |  |
| 755 | 1.4.1.4.1.7.5 | **SIT Component Integration Test Readiness Report** |  | 25d | 2023-10-16 A | 2023-11-17 A |  | 100% | 2023-10-16 | 2023-11-17 | 25d | 2023-10-16 | 2023-11-17 |  |  | N/A | N/A | SIT | 5.0 | N/A | Systems Integration Testing (SIT) |  |  |  |  |  |  |
| 756 | 1.4.1.4.1.7.5.1 | PP submit Test Readiness Report to Programme for assurance | milestone | 0d | 2023-11-03 A | 2023-11-03 A | 640 | 100% | 2023-11-03 | 2023-11-03 | 0d | 2023-11-03 | 2023-11-03 |  |  | PP | SI Test | SIT | 5.0 |  | Systems Integration Testing (SIT) | Complete | COMPLETE |  |  |  |  |
| 757 | 1.4.1.4.1.7.5.2 | SI assure Test Participants' Test Readiness Reports |  | 5d | 2023-11-06 A | 2023-11-10 A | 756FF+5d | 100% | 2023-11-06 | 2023-11-10 | 5d | 2023-11-06 | 2023-11-10 |  |  | SI Test | PP,IPA | SIT | 5.0 |  | Systems Integration Testing (SIT) | Complete | COMPLETE |  |  |  |  |
| 758 | 1.4.1.4.1.7.5.3 | SI develop Overarching SIT Component Integration Test Readiness Report |  | 20d | 2023-10-16 A | 2023-11-10 A | 757FF | 100% | 2023-10-16 | 2023-11-10 | 20d | 2023-10-16 | 2023-11-10 |  |  | SI Test |  | SIT | 5.0 |  | Systems Integration Testing (SIT) | Complete | COMPLETE |  |  |  |  |
| 759 | 1.4.1.4.1.7.5.4 | Artefact review (via TMAG) and updates |  | 5d | 2023-11-13 A | 2023-11-17 A | 758 | 100% | 2023-11-13 | 2023-11-17 | 5d | 2023-11-13 | 2023-11-17 |  |  | SI Test | PP,IPA | SIT | 5.0 |  | Systems Integration Testing (SIT) | Complete | COMPLETE |  |  |  |  |
| 760 | 1.4.1.4.1.7.6 | SIT Component Integration Testing 3 Preparation Complete (incl. approval of SI SIT Component Integration Test Readiness Report) | milestone | 0d | 2023-11-20 A | 2023-11-20 A | 759FS+1d, 733, 737, 756, 754, 751, 333 | 100% | 2023-11-20 | 2023-11-20 | 0d | 2023-11-20 | 2023-11-20 |  |  | SI Test | PP,IPA | SIT | 5.12 |  | Systems Integration Testing (SIT) | Complete | COMPLETE | MHHS-ART071 | T2-TE-0350 | SITAG | T2 |
| 761 | 1.4.1.4.1.8 | **CIT Interval 4 Preparation** |  | 36d | 2023-10-16 A | 2023-12-04 A |  | 100% | 2023-10-16 | 2023-12-04 | 36d | 2022-11-16 | 2023-12-04 |  | -0 | N/A | N/A | SIT | 5.0 | N/A | Systems Integration Testing (SIT) |  |  |  |  |  |  |
| 762 | 1.4.1.4.1.8.1 | **PIT Test Completion Report (incl. evidence)** |  | 21d | 2023-10-27 A | 2023-11-24 A |  | 100% | 2023-10-27 | 2023-11-24 | 21d | 2023-10-27 | 2023-11-24 |  |  | N/A | N/A | SIT | 5.0 | N/A | Systems Integration Testing (SIT) |  |  |  |  |  |  |
| 763 | 1.4.1.4.1.8.1.1 | Submit draft PIT Test Completion Report (incl. evidence) and submit to Programme for assurance |  | 1d | 2023-10-27 A | 2023-10-27 A |  | 100% | 2023-10-27 | 2023-10-27 | 1d | 2023-10-27 | 2023-10-27 | must start on 2023-10-27 |  | PP | SI Test | SIT | 5.0 |  | Systems Integration Testing (SIT) | Complete | COMPLETE |  |  |  |  |
| 764 | 1.4.1.4.1.8.1.2 | Finalise PIT Test Completion Report (incl. evidence) |  | 15d | 2023-10-30 A | 2023-11-17 A | 763 | 100% | 2023-10-30 | 2023-11-17 | 15d | 2023-10-30 | 2023-11-17 |  |  | PP | SI Test | SIT | 5.0 |  | Systems Integration Testing (SIT) | Complete | COMPLETE |  |  |  |  |
| 765 | 1.4.1.4.1.8.1.3 | PP PIT Completion Report (excl. Migration/Reverse Migration) submitted to Programme for assurance CIT Interval 4 | milestone | 0d | 2023-11-17 A | 2023-11-17 A | 764, 79, 95 | 100% | 2023-11-17 | 2023-11-17 | 0d | 2023-11-17 | 2023-11-17 |  |  | PP | SI Test | SIT | 5.13 |  | Systems Integration Testing (SIT) | Complete | COMPLETE |  | T3-DB-0019 | SITAG | T3 |
| 766 | 1.4.1.4.1.8.1.4 | PP Final PIT Completion Reports assured by SI |  | 5d | 2023-11-20 A | 2023-11-24 A | 765 | 100% | 2023-11-20 | 2023-11-24 | 5d | 2023-11-20 | 2023-11-24 |  |  | SI Test | PP | SIT | 5.0 |  | Systems Integration Testing (SIT) | Complete | COMPLETE |  |  |  |  |
| 767 | 1.4.1.4.1.8.2 | **Environments (SIT A)** |  | 25d | 2023-10-23 A | 2023-11-24 A |  | 100% | 2023-10-23 | 2023-11-24 | 25d | 2022-11-16 | 2023-11-24 |  | -0 | N/A | N/A | SIT | 5.0 | N/A | Systems Integration Testing (SIT) |  |  |  |  |  |  |
| 768 | 1.4.1.4.1.8.2.1 | Programme Participants Ready to Start Connectivity Proving | milestone | 0d | 2023-10-23 A | 2023-10-23 A |  | 100% | 2023-10-23 | 2023-10-23 | 0d |  |  | start no earlier than 2023-10-23 |  | PP |  | SIT | 5.10 | Simon Berry | Systems Integration Testing (SIT) | Complete | COMPLETE |  |  |  |  |
| 769 | 1.4.1.4.1.8.2.2 | SIT Participants' SIT A environments ready to start connectivity proving CIT Interval 4 | milestone | 0d | 2023-10-23 A | 2023-10-23 A | 768 | 100% | 2023-10-23 | 2023-10-23 | 0d | 2023-10-20 | 2023-10-20 |  |  | PP | PP,IPA | SIT | 5.10 | Simon Berry | Systems Integration Testing (SIT) | Complete | COMPLETE | MHHS-ART139 | T3-TE-0022 | SITAG | T3 |
| 770 | 1.4.1.4.1.8.2.3 | Internal Connectivity Proving Phase |  | 10d | 2023-10-23 A | 2023-11-03 A | 769 | 100% | 2023-10-23 | 2023-11-03 | 10d |  |  |  |  | PP |  | SIT | 5.10 | Simon Berry | Systems Integration Testing (SIT) | Complete | COMPLETE |  |  |  |  |
| 771 | 1.4.1.4.1.8.2.4 | Internal Connectivity Proving Phase Complete | milestone | 0d | 2023-11-03 A | 2023-11-03 A | 770 | 100% | 2023-11-03 | 2023-11-03 | 0d |  |  |  |  | PP |  | SIT | 5.10 | Simon Berry | Systems Integration Testing (SIT) | Complete | COMPLETE |  |  |  |  |
| 772 | 1.4.1.4.1.8.2.5 | DIP Onboarding Activity (1. PKI Officers and Certificates, 2. Set-up Validation, 3. End Point Creation, 4. Controlled Smoke Test ) |  | 10d | 2023-11-13 A | 2023-11-24 A | 771FS+5d | 100% | 2023-11-13 | 2023-11-24 | 10d |  |  |  |  | PP |  | SIT | 5.10 | Simon Berry | Systems Integration Testing (SIT) | Complete | COMPLETE |  |  |  |  |
| 773 | 1.4.1.4.1.8.2.6 | DIP Onboarding Complete | milestone | 0d | 2023-11-24 A | 2023-11-24 A | 772 | 100% | 2023-11-24 | 2023-11-24 | 0d |  |  |  |  | PP |  | SIT | 5.10 | Simon Berry | Systems Integration Testing (SIT) | Complete | COMPLETE |  |  |  |  |
| 774 | 1.4.1.4.1.8.2.7 | PPs register PKI Officers and Request PKI Certificates Complete - Interval 4 | milestone | 0d | 2023-11-24 A | 2023-11-24 A | 773 | 100% | 2023-11-24 | 2023-11-24 | 0d |  |  |  |  | PP | DIP Provider | SIT | 5.16 | Simon Berry | Systems Integration Testing (SIT) | Complete | COMPLETE |  | T3-TE-0100 | SITAG | T3 |
| 775 | 1.4.1.4.1.8.2.8 | PP Code Deployment | milestone | 0d | 2023-11-17 A | 2023-11-17 A |  | 100% | 2023-11-17 | 2023-11-17 | 0d |  |  | start no earlier than 2023-11-17 |  | PP |  | SIT | 5.10 | Simon Berry | Systems Integration Testing (SIT) | Complete | COMPLETE |  |  |  |  |

Notes:
- 751: Action: 28/7: CH: Needs to be set-up as a reporting milestone. 31/7: Check with Cesar if has been approved so can be baselined

| ID | WBS | Task | Type | Duration | Start | Finish | Predecessors | Complete | Baseline start | Baseline finish | Baseline duration | Baseline 1 start | Baseline 1 finish | Constraint | Baseline cost | Responsible | Involved | Text9 | Update Version | MHHS Resource Name | MHHS Programme Phase | Sched Status | RAG | Artefact ID | Milestone ID | Text29 | Tier |
| --- | --- | --- | --- | --- | --- | --- | --- | --- | --- | --- | --- | --- | --- | --- | --- | --- | --- | --- | --- | --- | --- | --- | --- | --- | --- | --- | --- |
| 776 | 1.4.1.4.1.8.3 | **Test Data (SIT A) Interval 4** |  | 30d | 2023-10-23 A | 2023-12-01 A |  | 100% | 2023-10-23 | 2023-12-01 | 25d | 2023-10-16 | 2023-11-17 |  |  | N/A | N/A | SIT | 5.0 | N/A | Systems Integration Testing (SIT) |  |  |  |  |  |  |
| 777 | 1.4.1.4.1.8.3.1 | Run data allocation |  | 5d | 2023-10-23 A | 2023-10-27 A | 746FS+5d | 100% | 2023-10-23 | 2023-10-27 | 5d | 2023-10-16 | 2023-10-20 |  |  | SI Test |  | SIT | 5.0 | Cesar Lopes | Systems Integration Testing (SIT) | Complete | COMPLETE |  |  |  |  |
| 778 | 1.4.1.4.1.8.3.2 | Cleanse and populate data post cut |  | 2d | 2023-10-30 A | 2023-10-31 A | 777 | 100% | 2023-10-30 | 2023-10-31 | 5d | 2023-10-23 | 2023-10-27 |  |  | SI Test |  | SIT | 5.0 | Cesar Lopes | Systems Integration Testing (SIT) | Complete | COMPLETE |  |  |  |  |
| 779 | 1.4.1.4.1.8.3.3 | Transmit data sets to PPs |  | 5d | 2023-11-01 A | 2023-11-07 A | 778 | 100% | 2023-11-01 | 2023-11-07 | 2d | 2023-10-30 | 2023-10-31 |  |  | SI Test |  | SIT | 5.0 | Cesar Lopes | Systems Integration Testing (SIT) | Complete | COMPLETE |  |  |  |  |
| 780 | 1.4.1.4.1.8.3.4 | PP - Load test data to test environments |  | 5d | 2023-11-08 A | 2023-11-14 A | 779 | 100% | 2023-11-08 | 2023-11-14 | 8d | 2023-11-01 | 2023-11-10 |  |  | PP |  | SIT | 5.0 | Cesar Lopes | Systems Integration Testing (SIT) | Complete | COMPLETE |  |  |  |  |
| 781 | 1.4.1.4.1.8.3.5 | PP Check data integrity on test environment |  | 13d | 2023-11-15 A | 2023-12-01 A | 780 | 100% | 2023-11-15 | 2023-12-01 | 5d | 2023-11-13 | 2023-11-17 |  |  | PP |  | SIT | 5.0 | Richard Puddephatt | Systems Integration Testing (SIT) | Complete | COMPLETE |  |  |  |  |
| 782 | 1.4.1.4.1.8.3.6 | PP submit self-declaration to Programme to confirm loading & verification of test data | milestone | 0d | 2023-12-01 A | 2023-12-01 A | 781FF | 100% | 2023-12-01 | 2023-12-01 | 0d | 2023-11-17 | 2023-11-17 |  |  | PP | SI Test | SIT | 5.0 | Richard Puddephatt | Systems Integration Testing (SIT) | Complete | COMPLETE |  |  |  |  |
| 783 | 1.4.1.4.1.8.3.7 | Test Data (SIT A) Interval 4 Complete | milestone | 0d | 2023-12-01 A | 2023-12-01 A | 782 | 100% | 2023-12-01 | 2023-12-01 | 0d |  |  |  |  | SI Test | PP | SIT | 5.13 | Richard Puddephatt | Systems Integration Testing (SIT) | Complete | COMPLETE | MHHS-ART148/169 | T3-TE-0076 | SITAG | T3 |
| 784 | 1.4.1.4.1.8.4 | **Other Preparation** |  | 25d | 2023-10-30 A | 2023-12-01 A |  | 100% | 2023-10-30 | 2023-12-01 | 25d | 2023-07-31 | 2023-10-20 |  | -0 | N/A | N/A | SIT | 5.0 | N/A | Systems Integration Testing (SIT) |  |  |  |  |  |  |
| 785 | 1.4.1.4.1.8.4.1 | Onboarding of Test Participants to Test Management Tool (Azure DevOps) |  | 25d | 2023-10-30 A | 2023-12-01 A |  | 100% | 2023-10-30 | 2023-12-01 | 25d | 2023-07-31 | 2023-10-20 | start no earlier than 2023-10-30 |  | SI Test | PP | SIT | 5.0 | Simon Berry | Systems Integration Testing (SIT) | Complete | COMPLETE |  |  |  |  |
| 786 | 1.4.1.4.1.8.4.2 | Test Management Tool onboarding |  | 25d | 2023-10-30 A | 2023-12-01 A |  | 100% | 2023-10-30 | 2023-12-01 | 25d | 2023-07-31 | 2023-10-20 | start no earlier than 2023-10-30 |  | PP | SI Test | SIT | 5.0 | Simon Berry | Systems Integration Testing (SIT) | Complete | COMPLETE |  |  |  |  |
| 787 | 1.4.1.4.1.8.5 | **SIT Component Integration Test Readiness Report** |  | 27d | 2023-10-16 A | 2023-11-21 A |  | 100% | 2023-10-16 | 2023-11-21 | 25d | 2023-10-30 | 2023-12-01 |  |  | N/A | N/A | SIT | 5.0 | N/A | Systems Integration Testing (SIT) |  |  |  |  |  |  |
| 788 | 1.4.1.4.1.8.5.1 | PP submit Test Readiness Report to Programme for assurance | milestone | 0d | 2023-11-03 A | 2023-11-03 A | 640 | 100% | 2023-11-03 | 2023-11-03 | 0d | 2023-11-17 | 2023-11-17 |  |  | PP | SI Test | SIT | 5.0 |  | Systems Integration Testing (SIT) | Complete | COMPLETE |  |  |  |  |
| 789 | 1.4.1.4.1.8.5.2 | SI assure Test Participants' Test Readiness Reports |  | 5d | 2023-11-06 A | 2023-11-10 A | 788FF+5d | 100% | 2023-11-06 | 2023-11-10 | 5d | 2023-11-20 | 2023-11-24 |  |  | SI Test | PP,IPA | SIT | 5.0 |  | Systems Integration Testing (SIT) | Complete | COMPLETE |  |  |  |  |
| 790 | 1.4.1.4.1.8.5.3 | SI develop Overarching SIT Component Integration Test Readiness Report |  | 20d | 2023-10-16 A | 2023-11-10 A | 789FF | 100% | 2023-10-16 | 2023-11-10 | 20d | 2023-10-30 | 2023-11-24 |  |  | SI Test |  | SIT | 5.0 |  | Systems Integration Testing (SIT) | Complete | COMPLETE |  |  |  |  |
| 791 | 1.4.1.4.1.8.5.4 | Artefact review (via SITAG) and updates |  | 7d | 2023-11-13 A | 2023-11-21 A | 790 | 100% | 2023-11-13 | 2023-11-21 | 5d | 2023-11-27 | 2023-12-01 |  |  | SI Test | PP,IPA | SIT | 5.0 |  | Systems Integration Testing (SIT) | Complete | COMPLETE |  |  |  |  |
| 792 | 1.4.1.4.1.8.6 | SIT Component Integration Testing 4 Preparation Complete (incl. approval of SI SIT Component Integration Test Readiness Report) | milestone | 0d | 2023-12-04 A | 2023-12-04 A | 791FS+2d, 765, 769, 788, 783, 350FS+1d | 100% | 2023-12-04 | 2023-12-04 | 0d | 2023-12-04 | 2023-12-04 |  |  | SI Test | PP,IPA | SIT | 5.13 |  | Systems Integration Testing (SIT) | Complete | COMPLETE | MHHS-ART071 | T2-TE-0400 | SITAG | T2 |
| 793 | 1.4.1.4.1.9 | **CIT Interval 5 Preparation** |  | 53d | 2023-11-01 A | 2024-01-12 A |  | 100% | 2023-11-01 | 2024-01-12 | 55d | 2022-11-16 | 2024-01-08 |  | -0 | N/A | N/A | SIT | 5.0 | N/A | Systems Integration Testing (SIT) |  |  |  |  |  |  |
| 794 | 1.4.1.4.1.9.1 | **PIT Test Completion Report (incl. evidence)** |  | 21d | 2023-11-17 A | 2023-12-15 A |  | 100% | 2023-11-17 | 2023-12-15 | 21d | 2023-11-17 | 2023-12-15 |  |  | N/A | N/A | SIT | 5.0 | N/A | Systems Integration Testing (SIT) |  |  |  |  |  |  |
| 795 | 1.4.1.4.1.9.1.1 | Submit draft PIT Test Completion Report (incl. evidence) and submit to Programme for assurance |  | 1d | 2023-11-17 A | 2023-11-17 A |  | 100% | 2023-11-17 | 2023-11-17 | 1d | 2023-11-17 | 2023-11-17 | must start on 2023-11-17 |  | PP | SI Test | SIT | 5.0 | Lee Cox | Systems Integration Testing (SIT) | Complete | COMPLETE |  |  |  |  |
| 796 | 1.4.1.4.1.9.1.2 | Finalise PIT Test Completion Report (incl. evidence) |  | 15d | 2023-11-20 A | 2023-12-08 A | 795 | 100% | 2023-11-20 | 2023-12-08 | 15d | 2023-11-20 | 2023-12-08 |  |  | PP | SI Test | SIT | 5.0 | Lee Cox | Systems Integration Testing (SIT) | Complete | COMPLETE |  |  |  |  |
| 797 | 1.4.1.4.1.9.1.3 | PP PIT Completion Report (excl. Migration/Reverse Migration) submitted to Programme for assurance CIT Interval 5 | milestone | 0d | 2023-12-08 A | 2023-12-08 A | 796, 79, 95 | 100% | 2023-12-08 | 2023-12-08 | 0d | 2023-12-08 | 2023-12-08 |  |  | PP | SI Test | SIT | 5.14 | Lee Cox | Systems Integration Testing (SIT) | Complete | COMPLETE |  | T3-DB-0021 | SITAG | T3 |
| 798 | 1.4.1.4.1.9.1.4 | PP Final PIT Completion Reports assured by SI |  | 5d | 2023-12-11 A | 2023-12-15 A | 797 | 100% | 2023-12-11 | 2023-12-15 | 5d | 2023-12-11 | 2023-12-15 |  |  | SI Test | PP | SIT | 5.0 | Lee Cox | Systems Integration Testing (SIT) | Complete | COMPLETE |  |  |  |  |
| 799 | 1.4.1.4.1.9.2 | **Environments (SIT A)** |  | 21d | 2023-11-10 A | 2023-12-08 A |  | 100% | 2023-11-10 | 2023-12-08 | 21d | 2022-11-16 | 2023-12-15 |  | -0 | N/A | N/A | SIT | 5.0 | N/A | Systems Integration Testing (SIT) |  |  |  |  |  |  |
| 800 | 1.4.1.4.1.9.2.1 | Programme Participants Ready to Start Connectivity Proving | milestone | 0d | 2023-11-10 A | 2023-11-10 A |  | 100% | 2023-11-10 | 2023-11-10 | 0d |  |  | start no earlier than 2023-11-10 |  | PP |  | SIT | 5.10 | Simon Berry | Systems Integration Testing (SIT) | Complete | COMPLETE |  |  |  |  |
| 801 | 1.4.1.4.1.9.2.2 | SIT Participants' SIT A environments ready to start connectivity proving CIT Interval 5 | milestone | 0d | 2023-11-10 A | 2023-11-10 A | 800 | 100% | 2023-11-10 | 2023-11-10 | 0d | 2023-11-10 | 2023-11-10 |  |  | PP | PP,IPA | SIT | 5.6 | Simon Berry | Systems Integration Testing (SIT) | Complete | COMPLETE | MHHS-ART139 | T3-TE-0023 | SITAG | T3 |
| 802 | 1.4.1.4.1.9.2.3 | Internal Connectivity Proving Phase |  | 10d | 2023-11-13 A | 2023-11-24 A | 800FS+1d | 100% | 2023-11-13 | 2023-11-24 | 10d |  |  |  |  | PP |  | SIT | 5.10 | Simon Berry | Systems Integration Testing (SIT) | Complete | COMPLETE |  |  |  |  |
| 803 | 1.4.1.4.1.9.2.4 | Internal Connectivity Proving Phase Complete | milestone | 0d | 2023-11-24 A | 2023-11-24 A | 802 | 100% | 2023-11-24 | 2023-11-24 | 0d |  |  |  |  | PP |  | SIT | 5.10 | Simon Berry | Systems Integration Testing (SIT) | Complete | COMPLETE |  |  |  |  |
| 804 | 1.4.1.4.1.9.2.5 | DIP Onboarding Activity (1. PKI Officers and Certificates, 2. Set-up Validation, 3. End Point Creation, 4. Controlled Smoke Test ) |  | 10d | 2023-11-27 A | 2023-12-08 A | 803 | 100% | 2023-11-27 | 2023-12-08 | 10d |  |  |  |  | PP |  | SIT | 5.10 | Simon Berry | Systems Integration Testing (SIT) | Complete | COMPLETE |  |  |  |  |
| 805 | 1.4.1.4.1.9.2.6 | DIP Onboarding Complete | milestone | 0d | 2023-12-08 A | 2023-12-08 A | 804 | 100% | 2023-12-08 | 2023-12-08 | 0d |  |  |  |  | PP |  | SIT | 5.10 | Simon Berry | Systems Integration Testing (SIT) | Complete | COMPLETE |  |  |  |  |
| 806 | 1.4.1.4.1.9.2.7 | PPs register PKI Officers and Request PKI Certificates Complete - Interval 5 | milestone | 0d | 2023-12-08 A | 2023-12-08 A | 805 | 100% | 2023-12-08 | 2023-12-08 | 0d | 2023-11-06 | 2023-11-10 |  |  | PP | DIP Provider | SIT | 5.17 | Simon Berry | Systems Integration Testing (SIT) | Complete | COMPLETE |  | T3-TE-0101 | SITAG | T3 |
| 807 | 1.4.1.4.1.9.2.8 | PP Code Deployment | milestone | 0d | 2023-12-08 A | 2023-12-08 A | 806 | 100% | 2023-12-08 | 2023-12-08 | 0d |  |  | start no earlier than 2023-10-20 |  | PP |  | SIT | 5.10 | Simon Berry | Systems Integration Testing (SIT) | Complete | COMPLETE |  |  |  |  |

| ID | WBS | Task | Type | Duration | Start | Finish | Predecessors | Complete | Baseline start | Baseline finish | Baseline duration | Baseline 1 start | Baseline 1 finish | Constraint | Baseline cost | Responsible | Involved | Text9 | Update Version | MHHS Resource Name | MHHS Programme Phase | Sched Status | RAG | Artefact ID | Milestone ID | Text29 | Tier |
| --- | --- | --- | --- | --- | --- | --- | --- | --- | --- | --- | --- | --- | --- | --- | --- | --- | --- | --- | --- | --- | --- | --- | --- | --- | --- | --- | --- |
| 808 | 1.4.1.4.1.9.3 | **Test Data (SIT A) Interval 5** |  | 33d | 2023-11-01 A | 2023-12-15 A |  | 100% | 2023-11-01 | 2023-12-15 | 30d | 2023-10-30 | 2023-12-08 |  |  | N/A | N/A | SIT | 5.0 | N/A | Systems Integration Testing (SIT) |  |  |  |  |  |  |
| 809 | 1.4.1.4.1.9.3.1 | Run data allocation |  | 5d | 2023-11-01 A | 2023-11-07 A | 779SS | 100% | 2023-11-01 | 2023-11-07 | 10d | 2023-10-30 | 2023-11-10 |  |  | SI Test |  | SIT | 5.0 | Cesar Lopes | Systems Integration Testing (SIT) | Complete | COMPLETE |  |  |  |  |
| 810 | 1.4.1.4.1.9.3.2 | Cleanse and populate data post cut |  | 8d | 2023-11-08 A | 2023-11-17 A | 809 | 100% | 2023-11-08 | 2023-11-17 | 5d | 2023-11-13 | 2023-11-17 |  |  | SI Test |  | SIT | 5.0 | Cesar Lopes | Systems Integration Testing (SIT) | Complete | COMPLETE |  |  |  |  |
| 811 | 1.4.1.4.1.9.3.3 | Transmit data sets to PPs |  | 2d | 2023-11-20 A | 2023-11-21 A | 810 | 100% | 2023-11-20 | 2023-11-21 | 2d | 2023-11-20 | 2023-11-21 |  |  | SI Test |  | SIT | 5.0 | Cesar Lopes | Systems Integration Testing (SIT) | Complete | COMPLETE |  |  |  |  |
| 812 | 1.4.1.4.1.9.3.4 | PP - Load test data to test environments |  | 8d | 2023-11-22 A | 2023-12-01 A | 811 | 100% | 2023-11-22 | 2023-12-01 | 8d | 2023-11-22 | 2023-12-01 |  |  | PP |  | SIT | 5.0 | Richard Puddephatt | Systems Integration Testing (SIT) | Complete | COMPLETE |  |  |  |  |
| 813 | 1.4.1.4.1.9.3.5 | PP Check data integrity on test environment |  | 10d | 2023-12-04 A | 2023-12-15 A | 812 | 100% | 2023-12-04 | 2023-12-15 | 5d | 2023-12-04 | 2023-12-08 |  |  | PP |  | SIT | 5.0 | Richard Puddephatt | Systems Integration Testing (SIT) | Complete | COMPLETE |  |  |  |  |
| 814 | 1.4.1.4.1.9.3.6 | PP submit self-declaration to Programme to confirm loading & verification of test data | milestone | 0d | 2023-12-15 A | 2023-12-15 A | 813FF | 100% | 2023-12-15 | 2023-12-15 | 0d | 2023-12-08 | 2023-12-08 |  |  | PP | SI Test | SIT | 5.0 | Richard Puddephatt | Systems Integration Testing (SIT) | Complete | COMPLETE |  |  |  |  |
| 815 | 1.4.1.4.1.9.3.7 | Test Data (SIT A) Interval 5 Complete | milestone | 0d | 2023-12-15 A | 2023-12-15 A | 814 | 100% | 2023-12-15 | 2023-12-15 | 0d |  |  |  |  | SI Test | PP | SIT | 5.14 | Richard Puddephatt | Systems Integration Testing (SIT) | Complete | COMPLETE | MHHS-ART148/169 | T3-TE-0077 | SITAG | T3 |
| 816 | 1.4.1.4.1.9.4 | **Other Preparation** |  | 40d | 2023-11-20 A | 2024-01-12 A |  | 100% | 2023-11-20 | 2024-01-12 | 40d | 2023-08-21 | 2023-11-10 |  | -0 | N/A | N/A | SIT | 5.0 | N/A | Systems Integration Testing (SIT) |  |  |  |  |  |  |
| 817 | 1.4.1.4.1.9.4.1 | Onboarding of Test Participants to Test Management Tool (Azure DevOps) |  | 40d | 2023-11-20 A | 2024-01-12 A |  | 100% | 2023-11-20 | 2024-01-12 | 40d | 2023-08-21 | 2023-11-10 | start no earlier than 2023-11-20 |  | SI Test | PP | SIT | 5.0 | Simon Berry | Systems Integration Testing (SIT) | Complete | COMPLETE |  |  |  |  |
| 818 | 1.4.1.4.1.9.4.2 | Test Management Tool onboarding |  | 36d | 2023-11-20 A | 2024-01-08 A |  | 100% | 2023-11-20 | 2024-01-08 | 36d | 2023-08-21 | 2023-11-10 | start no earlier than 2023-11-20 |  | PP | SI Test | SIT | 5.0 | Simon Berry | Systems Integration Testing (SIT) | Complete | COMPLETE |  |  |  |  |
| 819 | 1.4.1.4.1.9.5 | **SIT Component Integration Test Readiness Report** |  | 35d | 2023-11-20 A | 2024-01-05 A |  | 100% | 2023-11-20 | 2024-01-05 | 35d | 2023-11-20 | 2024-01-05 |  |  | N/A | N/A | SIT | 5.0 | N/A | Systems Integration Testing (SIT) |  |  |  |  |  |  |
| 820 | 1.4.1.4.1.9.5.1 | PP submit Test Readiness Report to Programme for assurance | milestone | 0d | 2023-12-08 A | 2023-12-08 A | 644 | 100% | 2023-12-08 | 2023-12-08 | 0d | 2023-12-08 | 2023-12-08 |  |  | PP | SI Test | SIT | 5.0 | Lee Cox | Systems Integration Testing (SIT) | Complete | COMPLETE |  |  |  |  |
| 821 | 1.4.1.4.1.9.5.2 | SI assure Test Participants' Test Readiness Reports |  | 5d | 2023-12-11 A | 2023-12-15 A | 820FF+5d | 100% | 2023-12-11 | 2023-12-15 | 5d | 2023-12-11 | 2023-12-15 |  |  | SI Test | PP,IPA | SIT | 5.0 | Lee Cox | Systems Integration Testing (SIT) | Complete | COMPLETE |  |  |  |  |
| 822 | 1.4.1.4.1.9.5.3 | SI develop Overarching SIT Component Integration Test Readiness Report |  | 20d | 2023-11-20 A | 2023-12-15 A | 821FF | 100% | 2023-11-20 | 2023-12-15 | 20d | 2023-11-20 | 2023-12-15 |  |  | SI Test |  | SIT | 5.0 | Lee Cox | Systems Integration Testing (SIT) | Complete | COMPLETE |  |  |  |  |
| 823 | 1.4.1.4.1.9.5.4 | Artefact review (via SITAG) and updates |  | 15d | 2023-12-18 A | 2024-01-05 A | 822 | 100% | 2023-12-18 | 2024-01-05 | 15d | 2023-12-18 | 2024-01-05 |  |  | SI Test | PP,IPA | SIT | 5.0 | Lee Cox | Systems Integration Testing (SIT) | Complete | COMPLETE |  |  |  |  |
| 824 | 1.4.1.4.1.9.6 | SIT Component Integration Testing 5 Preparation Complete (incl. approval of SI SIT Component Integration Test Readiness Report) | milestone | 0d | 2024-01-08 A | 2024-01-08 A | 823FS+1d, 797, 801, 818, 820, 815, 470, 453 | 100% | 2024-01-08 | 2024-01-08 | 0d | 2024-01-08 | 2024-01-08 |  |  | SI Test | PP,IPA | SIT | 5.15 |  | Systems Integration Testing (SIT) | Complete | COMPLETE | MHHS-ART071 | T2-TE-0450 | SITAG | T2 |
| 825 | 1.4.1.4.1.10 | **CIT Interval 6 Preparation** |  | 45d | 2023-11-20 A | 2024-01-19 A |  | 100% | 2023-11-20 | 2024-01-19 | 46d | 2022-11-16 | 2024-01-22 |  | -0 | N/A | N/A | SIT | 5.0 | N/A | Systems Integration Testing (SIT) |  |  |  |  |  |  |
| 826 | 1.4.1.4.1.10.1 | **PIT Test Completion Report (incl. evidence)** |  | 31d | 2023-12-01 A | 2024-01-12 A |  | 100% | 2023-12-01 | 2024-01-12 | 31d | 2023-12-01 | 2024-01-12 |  |  | N/A | N/A | SIT | 5.0 | N/A | Systems Integration Testing (SIT) |  |  |  |  |  |  |
| 827 | 1.4.1.4.1.10.1.1 | Submit draft PIT Test Completion Report (incl. evidence) and submit to Programme for assurance |  | 1d | 2023-12-01 A | 2023-12-01 A |  | 100% | 2023-12-01 | 2023-12-01 | 1d | 2023-12-01 | 2023-12-01 | must start on 2023-12-01 |  | PP | SI Test | SIT | 5.0 |  | Systems Integration Testing (SIT) | Complete | COMPLETE |  |  |  |  |
| 828 | 1.4.1.4.1.10.1.2 | Finalise PIT Test Completion Report (incl. evidence) |  | 25d | 2023-12-04 A | 2024-01-05 A | 827 | 100% | 2023-12-04 | 2024-01-05 | 25d | 2023-12-04 | 2024-01-05 |  |  | PP | SI Test | SIT | 5.0 |  | Systems Integration Testing (SIT) | Complete | COMPLETE |  |  |  |  |
| 829 | 1.4.1.4.1.10.1.3 | PP PIT Completion Report (excl. Migration/Reverse Migration) submitted to Programme for assurance CIT Interval 6 | milestone | 0d | 2024-01-05 A | 2024-01-05 A | 828, 79, 95, 272, 277, 280 | 100% | 2024-01-05 | 2024-01-05 | 0d | 2024-01-05 | 2024-01-05 |  |  | PP | SI Test | SIT | 5.19 |  | Systems Integration Testing (SIT) | Complete | COMPLETE |  | T3-DB-0023 | SITAG | T3 |
| 830 | 1.4.1.4.1.10.1.4 | PP Final PIT Completion Reports assured by SI |  | 5d | 2024-01-08 A | 2024-01-12 A | 829 | 100% | 2024-01-08 | 2024-01-12 | 5d | 2024-01-08 | 2024-01-12 |  |  | SI Test | PP | SIT | 5.19 |  | Systems Integration Testing (SIT) | Complete | COMPLETE |  |  |  |  |
| 831 | 1.4.1.4.1.10.2 | **Environments (SIT A)** |  | 30d | 2023-11-24 A | 2024-01-05 A |  | 100% | 2023-11-24 | 2024-01-05 | 30d | 2022-11-16 | 2024-01-05 |  | -0 | N/A | N/A | SIT | 5.0 | N/A | Systems Integration Testing (SIT) |  |  |  |  |  |  |
| 832 | 1.4.1.4.1.10.2.1 | Programme Participants Ready to Start Connectivity Proving | milestone | 0d | 2023-11-24 A | 2023-11-24 A |  | 100% | 2023-11-24 | 2023-11-24 | 0d |  |  | start no earlier than 2023-11-24 |  | PP |  | SIT | 5.10 | Simon Berry | Systems Integration Testing (SIT) | Complete | COMPLETE |  |  |  |  |
| 833 | 1.4.1.4.1.10.2.2 | SIT Participants' SIT A environments ready to start connectivity proving CIT Interval 6 | milestone | 0d | 2023-11-24 A | 2023-11-24 A | 832 | 100% | 2023-11-24 | 2023-11-24 | 0d | 2023-11-24 | 2023-11-24 |  |  | PP | PP,IPA | SIT | 5.6 | Simon Berry | Systems Integration Testing (SIT) | Complete | COMPLETE | MHHS-ART139 | T3-TE-0024 | SITAG | T3 |
| 834 | 1.4.1.4.1.10.2.3 | Internal Connectivity Proving Phase |  | 10d | 2023-11-27 A | 2023-12-08 A | 833FS+1d | 100% | 2023-11-27 | 2023-12-08 | 10d |  |  |  |  | PP |  | SIT | 5.10 | Simon Berry | Systems Integration Testing (SIT) | Complete | COMPLETE |  |  |  |  |
| 835 | 1.4.1.4.1.10.2.4 | Internal Connectivity Proving Phase Complete | milestone | 0d | 2023-12-08 A | 2023-12-08 A | 834 | 100% | 2023-12-08 | 2023-12-08 | 0d |  |  |  |  | PP |  | SIT | 5.10 | Simon Berry | Systems Integration Testing (SIT) | Complete | COMPLETE |  |  |  |  |
| 836 | 1.4.1.4.1.10.2.5 | DIP Onboarding Activity (1. PKI Officers and Certificates, 2. Set-up Validation, 3. End Point Creation, 4. Controlled Smoke Test ) |  | 5d | 2023-12-04 A | 2023-12-08 A | 833FS+6d | 100% | 2023-12-04 | 2023-12-08 | 5d |  |  |  |  | PP |  | SIT | 5.10 | Simon Berry | Systems Integration Testing (SIT) | Complete | COMPLETE |  |  |  |  |
| 837 | 1.4.1.4.1.10.2.6 | DIP Onboarding Complete | milestone | 0d | 2023-12-08 A | 2023-12-08 A | 836 | 100% | 2023-12-08 | 2023-12-08 | 0d |  |  |  |  | PP |  | SIT | 5.10 | Simon Berry | Systems Integration Testing (SIT) | Complete | COMPLETE |  |  |  |  |
| 838 | 1.4.1.4.1.10.2.7 | PPs register PKI Officers and Request PKI Certificates Complete - Interval 6 | milestone | 0d | 2023-12-08 A | 2023-12-08 A | 837 | 100% | 2023-12-08 | 2023-12-08 | 0d | 2023-11-20 | 2023-11-24 | start no earlier than 2023-12-08 |  | PP | DIP Provider | SIT | 5.17 | Simon Berry | Systems Integration Testing (SIT) | Complete | COMPLETE |  | T3-TE-0102 | SITAG | T3 |
| 839 | 1.4.1.4.1.10.2.8 | PP Code Deployment | milestone | 0d | 2024-01-05 A | 2024-01-05 A |  | 100% | 2024-01-05 | 2024-01-05 | 0d |  |  | start no earlier than 2024-01-05 |  | PP |  | SIT | 5.10 | Simon Berry | Systems Integration Testing (SIT) | Complete | COMPLETE |  |  |  |  |

Notes:
- 815: Action: 28/7: CH: Needs to be set-up as a reporting milestone. 31/7: Check with Cesar if has been approved so can be baselined

| ID | WBS | Task | Type | Duration | Start | Finish | Predecessors | Complete | Baseline start | Baseline finish | Baseline duration | Baseline 1 start | Baseline 1 finish | Constraint | Baseline cost | Responsible | Involved | Text9 | Update Version | MHHS Resource Name | MHHS Programme Phase | Sched Status | RAG | Artefact ID | Milestone ID | Text29 | Tier |
| --- | --- | --- | --- | --- | --- | --- | --- | --- | --- | --- | --- | --- | --- | --- | --- | --- | --- | --- | --- | --- | --- | --- | --- | --- | --- | --- | --- |
| 840 | 1.4.1.4.1.10.3 | **Test Data (SIT A) Interval 6** |  | 25d | 2023-11-20 A | 2023-12-22 A |  | 100% | 2023-11-20 | 2023-12-22 | 25d | 2023-11-20 | 2023-12-22 |  |  | N/A | N/A | SIT | 5.0 | N/A | Systems Integration Testing (SIT) |  |  |  |  |  |  |
| 841 | 1.4.1.4.1.10.3.1 | Run data allocation |  | 10d | 2023-11-20 A | 2023-12-01 A | 811SS | 100% | 2023-11-20 | 2023-12-01 | 5d | 2023-11-20 | 2023-11-24 |  |  | SI Test |  | SIT | 5.0 | Richard Puddephatt | Systems Integration Testing (SIT) | Complete | COMPLETE |  |  |  |  |
| 842 | 1.4.1.4.1.10.3.2 | Cleanse and populate data post cut |  | 1d | 2023-12-04 A | 2023-12-04 A | 841 | 100% | 2023-12-04 | 2023-12-04 | 5d | 2023-11-27 | 2023-12-01 |  |  | SI Test |  | SIT | 5.0 | Richard Puddephatt | Systems Integration Testing (SIT) | Complete | COMPLETE |  |  |  |  |
| 843 | 1.4.1.4.1.10.3.3 | Transmit data sets to PPs |  | 1d | 2023-12-05 A | 2023-12-05 A | 842 | 100% | 2023-12-05 | 2023-12-05 | 2d | 2023-12-04 | 2023-12-05 |  |  | SI Test |  | SIT | 5.0 | Richard Puddephatt | Systems Integration Testing (SIT) | Complete | COMPLETE |  |  |  |  |
| 844 | 1.4.1.4.1.10.3.4 | PP - Load test data to test environments |  | 8d | 2023-12-06 A | 2023-12-15 A | 843 | 100% | 2023-12-06 | 2023-12-15 | 8d | 2023-12-06 | 2023-12-15 |  |  | PP |  | SIT | 5.0 | Richard Puddephatt | Systems Integration Testing (SIT) | Complete | COMPLETE |  |  |  |  |
| 845 | 1.4.1.4.1.10.3.5 | PP Check data integrity on test environment |  | 5d | 2023-12-18 A | 2023-12-22 A | 844 | 100% | 2023-12-18 | 2023-12-22 | 5d | 2023-12-18 | 2023-12-22 |  |  | PP |  | SIT | 5.0 | Richard Puddephatt | Systems Integration Testing (SIT) | Complete | COMPLETE |  |  |  |  |
| 846 | 1.4.1.4.1.10.3.6 | PP submit self-declaration to Programme to confirm loading & verification of test data | milestone | 0d | 2023-12-22 A | 2023-12-22 A | 845FF | 100% | 2023-12-22 | 2023-12-22 | 0d | 2023-12-22 | 2023-12-22 |  |  | PP | SI Test | SIT | 5.0 | Richard Puddephatt | Systems Integration Testing (SIT) | Complete | COMPLETE |  |  |  |  |
| 847 | 1.4.1.4.1.10.3.7 | Test Data (SIT A) Interval 6 Complete | milestone | 0d | 2023-12-22 A | 2023-12-22 A | 846 | 100% | 2023-12-22 | 2023-12-22 | 0d |  |  |  |  | SI Test | PP | SIT | 5.5 | Richard Puddephatt | Systems Integration Testing (SIT) | Complete | COMPLETE | MHHS-ART148/169 | T3-TE-0078 | SITAG | T3 |
| 848 | 1.4.1.4.1.10.4 | **Other Preparation** |  | 31d | 2023-12-04 A | 2024-01-15 A |  | 100% | 2023-12-04 | 2024-01-15 | 31d | 2023-09-04 | 2023-11-24 |  | -0 | N/A | N/A | SIT | 5.0 | N/A | Systems Integration Testing (SIT) |  |  |  |  |  |  |
| 849 | 1.4.1.4.1.10.4.1 | Onboarding of Test Participants to Test Management Tool (Azure DevOps) |  | 31d | 2023-12-04 A | 2024-01-15 A |  | 100% | 2023-12-04 | 2024-01-15 | 31d | 2023-09-04 | 2023-11-24 | start no earlier than 2023-12-04 |  | SI Test | PP | SIT | 5.0 | Simon Berry | Systems Integration Testing (SIT) | Complete | COMPLETE |  |  |  |  |
| 850 | 1.4.1.4.1.10.4.2 | Test Management Tool onboarding |  | 31d | 2023-12-04 A | 2024-01-15 A |  | 100% | 2023-12-04 | 2024-01-15 | 31d | 2023-09-04 | 2023-11-24 | start no earlier than 2023-12-04 |  | PP | SI Test | SIT | 5.0 | Simon Berry | Systems Integration Testing (SIT) | Complete | COMPLETE |  |  |  |  |
| 851 | 1.4.1.4.1.10.5 | **SIT Component Integration Test Readiness Report** |  | 25d | 2023-11-20 A | 2023-12-22 A |  | 100% | 2023-11-20 | 2023-12-22 | 25d | 2023-12-18 | 2024-01-19 |  |  | N/A | N/A | SIT | 5.0 | N/A | Systems Integration Testing (SIT) |  |  |  |  |  |  |
| 852 | 1.4.1.4.1.10.5.1 | PP submit Test Readiness Report to Programme for assurance | milestone | 0d | 2023-12-08 A | 2023-12-08 A | 644 | 100% | 2023-12-08 | 2023-12-08 | 0d | 2024-01-05 | 2024-01-05 |  |  | PP | SI Test | SIT | 5.0 |  | Systems Integration Testing (SIT) | Complete | COMPLETE |  |  |  |  |
| 853 | 1.4.1.4.1.10.5.2 | SI assure Test Participants' Test Readiness Reports |  | 5d | 2023-12-11 A | 2023-12-15 A | 852FF+5d | 100% | 2023-12-11 | 2023-12-15 | 5d | 2024-01-08 | 2024-01-12 |  |  | SI Test | PP,IPA | SIT | 5.0 |  | Systems Integration Testing (SIT) | Complete | COMPLETE |  |  |  |  |
| 854 | 1.4.1.4.1.10.5.3 | SI develop Overarching SIT Component Integration Test Readiness Report |  | 20d | 2023-11-20 A | 2023-12-15 A | 853FF | 100% | 2023-11-20 | 2023-12-15 | 20d | 2023-12-18 | 2024-01-12 |  |  | SI Test |  | SIT | 5.0 |  | Systems Integration Testing (SIT) | Complete | COMPLETE |  |  |  |  |
| 855 | 1.4.1.4.1.10.5.4 | Artefact review (via TMAG) and updates |  | 5d | 2023-12-18 A | 2023-12-22 A | 854 | 100% | 2023-12-18 | 2023-12-22 | 5d | 2024-01-15 | 2024-01-19 |  |  | SI Test | PP,IPA | SIT | 5.0 |  | Systems Integration Testing (SIT) | Complete | COMPLETE |  |  |  |  |
| 856 | 1.4.1.4.1.10.6 | SIT Component Integration Testing 6 Preparation Complete (incl. approval of SI SIT Component Integration Test Readiness Report) | milestone | 0d | 2024-01-19 A | 2024-01-19 A | 855FS+1d, 829, 833, 850, 852, 847, 298, 487 | 100% | 2024-01-19 | 2024-01-19 | 0d | 2024-01-22 | 2024-01-22 |  |  | SI Test | PP,IPA | SIT | 5.15 |  | Systems Integration Testing (SIT) | Complete | COMPLETE | MHHS-ART071 | T2-TE-0500 | SITAG | T2 |
| 857 | 1.4.1.4.2 | **SIT Functional Preparation** |  | 595d? | 2022-10-31 A | 2025-02-07 A |  | 100% | 2022-10-31 | 2025-04-07 | 520d | 2022-10-31 | 2024-03-01 |  | -0 | N/A | N/A | SIT | 5.0 | N/A | Systems Integration Testing (SIT) |  |  |  |  | SITAG |  |
| 858 | 1.4.1.4.2.1 | Environment Approach and Plan - SIT Functional |  | 1d? | 2023-11-20 A | 2023-11-20 A |  | 100% | 2023-11-20 | 2023-11-20 | 0d |  |  | start no earlier than 2023-11-20 |  | SI Test |  | SIT | 6.0 |  |  | Complete | COMPLETE |  |  |  |  |
| 859 | 1.4.1.4.2.2 | **Test Approach & Plan** |  | 208d | 2022-10-31 A | 2023-08-16 A |  | 100% | 2022-10-31 | 2023-08-16 | 208d | 2022-10-31 | 2023-08-16 |  |  | N/A | N/A | SIT | 5.0 | N/A | Systems Integration Testing (SIT) |  |  |  |  |  |  |
| 860 | 1.4.1.4.2.2.1 | Develop document with SITWG |  | 179d | 2022-10-31 A | 2023-07-06 A |  | 100% | 2022-10-31 | 2023-07-06 | 179d | 2022-10-31 | 2023-07-06 | finish no earlier than 2023-07-06 |  | SI Test |  | SIT | 5.0 |  | Systems Integration Testing (SIT) | Complete | COMPLETE |  |  |  |  |
| 861 | 1.4.1.4.2.2.2 | Industry Consultation |  | 10d | 2023-07-07 A | 2023-07-20 A | 860 | 100% | 2023-07-07 | 2023-07-20 | 10d |  |  |  |  | PP |  | SIT | 5.1 |  | Systems Integration Testing (SIT) | Complete | COMPLETE |  |  |  |  |
| 862 | 1.4.1.4.2.2.3 | Artefact review (via TMAG) and updates |  | 19d | 2023-07-21 A | 2023-08-16 A | 861 | 100% | 2023-07-21 | 2023-08-16 | 19d | 2023-07-07 | 2023-08-03 | finish no earlier than 2023-08-03 |  | SI Test | PP,IPA,Code Bodies | SIT | 5.5 |  | Systems Integration Testing (SIT) | Complete | COMPLETE |  |  |  |  |
| 863 | 1.4.1.4.2.2.4 | SIT Functional Test Approach & Plan approved | milestone | 0d | 2023-08-16 A | 2023-08-16 A |  | 100% | 2023-08-16 | 2023-08-16 | 0d | 2023-08-16 | 2023-08-16 | finish no earlier than 2023-08-16 |  | SI Test | PP | SIT | 5.0 |  | Systems Integration Testing (SIT) | Complete | COMPLETE | MHHS-ART073 | T3-TE-0013 | SITAG | T3 |

Notes:
- 847: Action: 28/7: CH: Needs to be set-up as a reporting milestone. 31/7: Check with Cesar if has been approved so can be baselined

| ID | WBS | Task | Type | Duration | Start | Finish | Predecessors | Complete | Baseline start | Baseline finish | Baseline duration | Baseline 1 start | Baseline 1 finish | Constraint | Baseline cost | Responsible | Involved | Text9 | Update Version | MHHS Resource Name | MHHS Programme Phase | Sched Status | RAG | Artefact ID | Milestone ID | Text29 | Tier | Action | Guidance | Task Status |
| --- | --- | --- | --- | --- | --- | --- | --- | --- | --- | --- | --- | --- | --- | --- | --- | --- | --- | --- | --- | --- | --- | --- | --- | --- | --- | --- | --- | --- | --- | --- |
| 864 | 1.4.1.4.2.3 | **Test Data Approach & Plan** |  | 29d | 2023-07-07 A | 2023-08-16 A |  | 100% | 2023-07-07 | 2023-08-16 | 29d | 2023-07-07 | 2023-08-16 |  |  | N/A | N/A | SIT | 5.0 | N/A | Systems Integration Testing (SIT) |  |  |  |  |  |  |  |  |  |
| 865 | 1.4.1.4.2.3.1 | Industry Consultation |  | 10d | 2023-07-07 A | 2023-07-20 A | 861SS | 100% | 2023-07-07 | 2023-07-20 | 10d |  |  |  |  | PP |  | SIT | 5.1 | Cesar Lopes | Systems Integration Testing (SIT) | Complete | COMPLETE |  |  |  |  |  |  |  |
| 866 | 1.4.1.4.2.3.2 | Artefact review (via TMAG) and updates |  | 19d | 2023-07-21 A | 2023-08-16 A | 865 | 100% | 2023-07-21 | 2023-08-16 | 19d | 2023-07-07 | 2023-08-03 |  |  | SI Test |  | SIT | 5.5 | Cesar Lopes | Systems Integration Testing (SIT) | Complete | COMPLETE |  |  |  |  |  |  |  |
| 867 | 1.4.1.4.2.3.3 | SIT Functional Testing Test Data Approach & Plan approved | milestone | 0d | 2023-08-16 A | 2023-08-16 A | 866 | 100% | 2023-08-16 | 2023-08-16 | 0d | 2023-08-16 | 2023-08-16 |  |  | SI Test | PP,IPA | SIT | 5.5 | Cesar Lopes | Systems Integration Testing (SIT) | Complete | COMPLETE |  |  |  |  |  |  |  |
| 868 | 1.4.1.4.2.4 | **Test scenarios** |  | 298d | 2023-01-02 A | 2024-02-21 A |  | 100% | 2023-01-02 | 2024-02-21 | 298d | 2023-01-02 | 2023-06-02 |  | -0 | N/A | N/A | SIT | 5.0 | N/A | Systems Integration Testing (SIT) |  |  |  |  |  |  |  |  |  |
| 869 | 1.4.1.4.2.4.1 | Development of test scenarios |  | 85d | 2023-01-02 A | 2023-04-28 A | 860SS+45d | 100% | 2023-01-02 | 2023-04-28 | 85d | 2023-01-02 | 2023-04-28 |  |  | SI Test | PP, Code Bodies | SIT | 5.0 |  | Systems Integration Testing (SIT) | Complete | COMPLETE |  |  |  |  |  |  |  |
| 870 | 1.4.1.4.2.4.2 | Review test scenarios with SIT Working Group |  | 65d | 2023-08-17 A | 2023-11-15 A | 869FS+78d | 100% | 2023-08-17 | 2023-11-15 | 65d | 2023-02-01 | 2023-05-26 |  |  | SI Test | PP, Code Bodies, IPA | SIT | 5.0 |  | Systems Integration Testing (SIT) | Complete | COMPLETE |  |  |  |  |  |  |  |
| 871 | 1.4.1.4.2.4.3 | SIT Functional Testing Test scenarios (themes 1-5) approved | milestone | 0d | 2023-12-08 A | 2023-12-08 A | 870FS+17d | 100% | 2023-12-08 | 2023-12-08 | 0d | 2023-06-02 | 2023-06-02 |  |  | SI Test | PP | SIT | 5.14 |  | Systems Integration Testing (SIT) | Complete | COMPLETE | MMHS-ART073 | T3-TE-0015 | SITAG | T3 |  |  |  |
| 872 | 1.4.1.4.2.4.4 | SIT Functional Testing Test scenarios (themes 6,7,9) approved | milestone | 0d | 2024-01-17 A | 2024-01-17 A | 871FS+28d | 100% | 2024-01-17 | 2024-01-17 | 0d | 2023-06-02 | 2023-06-02 |  |  | SI Test | PP | SIT | 5.16 |  | Systems Integration Testing (SIT) | Complete | COMPLETE | MMHS-ART073 | T3-TE-0106 | SITAG | T3 |  |  |  |
| 873 | 1.4.1.4.2.4.5 | SIT Functional Testing Test scenarios (theme 8) approved | milestone | 0d | 2024-02-21 A | 2024-02-21 A | 872FS+25d | 100% | 2024-02-21 | 2024-02-21 | 0d | 2023-06-02 | 2023-06-02 |  |  | SI Test | PP | SIT | 5.14 |  | Systems Integration Testing (SIT) | Complete | COMPLETE | MMHS-ART073 | T3-TE-0107 | SITAG | T3 |  |  |  |
| 874 | 1.4.1.4.2.5 | **Test cases** |  | 465d? | 2023-05-01 A | 2025-02-07 A |  | 100% | 2023-05-01 | 2025-02-07 | 213d | 2023-05-01 | 2023-09-01 |  |  | N/A | N/A | SIT | 5.0 | N/A | Systems Integration Testing (SIT) |  |  |  |  |  |  | 25/7 - needs to be replanned |  |  |
| 875 | 1.4.1.4.2.5.1 | **SI Test cases** |  | 213d | 2023-05-01 A | 2024-02-21 A |  | 100% | 2023-05-01 | 2024-02-21 | 213d | 2023-05-01 | 2023-09-01 |  |  | N/A | N/A | SIT | 5.0 | N/A | Systems Integration Testing (SIT) |  |  |  |  |  |  | 25/7 - needs to be replanned |  |  |
| 876 | 1.4.1.4.2.5.1.1 | Development of Test cases |  | 150d | 2023-05-01 A | 2023-11-24 A | 869 | 100% | 2023-05-01 | 2023-11-24 | 150d | 2023-05-01 | 2023-07-28 |  |  | SI Test |  | SIT | 5.0 |  | Systems Integration Testing (SIT) | Complete | COMPLETE |  |  |  |  | 25/7 - needs to be replanned |  |  |
| 877 | 1.4.1.4.2.5.1.2 | Review Test cases with SIT Working Group |  | 78d | 2023-09-25 A | 2024-01-10 A | 876SS+105d | 100% | 2023-09-25 | 2024-01-10 | 78d | 2023-05-26 | 2023-08-25 |  |  | SI Test | PP,IPA | SIT | 5.0 |  | Systems Integration Testing (SIT) | Complete | COMPLETE |  |  |  |  | 25/7 - needs to be replanned |  |  |
| 878 | 1.4.1.4.2.5.1.3 | SIT Functional Testing Test Cases (themes 1-5) approved | milestone | 0d | 2024-01-17 A | 2024-01-17 A | 877FS+5d | 100% | 2024-01-17 | 2024-01-17 | 0d | 2023-09-01 | 2023-09-01 |  |  | SI Test | PP | SIT | 5.14 |  | Systems Integration Testing (SIT) | Complete | COMPLETE | MHHS-ART140 | T3-TE-0070 | SITAG | T3 |  | 2/1/24 - Approved at Dec TMAG |  |
| 879 | 1.4.1.4.2.5.1.4 | SIT Functional Testing Test cases (themes 6,7,9) approved | milestone | 0d | 2024-01-17 A | 2024-01-17 A | 878 | 100% | 2024-01-17 | 2024-01-17 | 0d | 2023-09-01 | 2023-09-01 |  |  | SI Test | PP | SIT | 5.14 |  | Systems Integration Testing (SIT) | Complete | COMPLETE | MHHS-ART140 | T3-TE-0108 | SITAG | T3 |  |  |  |
| 880 | 1.4.1.4.2.5.1.5 | SIT Functional Testing Test cases (theme 8) approved | milestone | 0d | 2024-02-21 A | 2024-02-21 A | 879FS+25d | 100% | 2024-02-21 | 2024-02-21 | 0d | 2023-09-01 | 2023-09-01 |  |  | SI Test | PP | SIT | 5.14 |  | Systems Integration Testing (SIT) | Complete | COMPLETE | MHHS-ART140 | T3-TE-0109 | SITAG | T3 |  |  |  |
| 881 | 1.4.1.4.2.5.2 | **SIT Functional Programme RTTM** |  | 74d? | 2024-07-29 A | 2024-11-07 A |  | 100% | 2024-07-29 | 2024-10-11 | 0d |  |  |  |  | SI Test |  | SIT | 6.0 | Kevin Davis |  | Overdue Start |  |  |  | SITAG |  |  |  | -687.67 |
| 882 | 1.4.1.4.2.5.2.1 | **RTTM Development** |  | 30d? | 2024-07-29 A | 2024-09-06 A |  | 100% | 2024-07-29 | 2024-09-20 | 0d |  |  |  |  | SI Test |  | SIT | 6.0 | Kevin Davis |  | Overdue Start |  |  |  | SITAG |  |  |  | -693.67 |
| 883 | 1.4.1.4.2.5.2.1.1 | Development of Manual SIT Functional RTTM |  | 30d? | 2024-07-29 A | 2024-09-06 A |  | 100% | 2024-07-29 | 2024-09-06 | 0d |  |  | start no earlier than 2024-07-29 |  | SI Test |  | SIT | 6.0 | Kevin Davis |  | Complete | COMPLETE |  |  | SITAG |  |  |  |  |
| 884 | 1.4.1.4.2.5.2.1.2 | Manual SIT Functional RTTM Complete | milestone | 0d? | 2024-09-06 A | 2024-09-06 A | 883 | 100% | 2024-09-06 | 2024-09-06 | 0d |  |  | start no earlier than 2024-07-29 |  | SI Test |  | SIT | 6.0 | Kevin Davis |  | Complete | COMPLETE |  |  | SITAG |  |  |  |  |
| 885 | 1.4.1.4.2.5.2.2 | **Gap analysis** |  | 54d? | 2024-08-26 A | 2024-11-07 A |  | 100% | 2024-08-26 | 2024-10-11 | 0d |  |  |  |  | SI Test |  | SIT | 6.0 | Kevin Davis |  | Overdue Start |  |  |  | SITAG |  |  |  | -693.67 |
| 886 | 1.4.1.4.2.5.2.2.1 | Identify gaps in test case coverage following RTTM review |  | 20d? | 2024-08-26 A | 2024-09-20 A |  | 100% | 2024-08-26 | 2024-09-20 | 0d |  |  |  |  | SI Test |  | SIT | 6.0 | Kevin Davis |  | Complete | COMPLETE |  |  | SITAG |  |  |  |  |
| 887 | 1.4.1.4.2.5.2.2.2 | Address gaps in test case coverage following RTTM review |  | 25d | 2024-09-09 A | 2024-10-11 A | 886SS+10d | 100% | 2024-09-09 | 2024-10-04 | 0d |  |  |  |  | SI Test |  | SIT | 6.0 | Kevin Davis |  | Complete | COMPLETE |  |  | SITAG |  |  |  |  |
| 888 | 1.4.1.4.2.5.2.2.3 | Gap analysis complete | milestone | 0d | 2024-10-11 A | 2024-10-11 A | 887 | 100% | 2024-10-11 | 2024-10-11 | 0d |  |  |  |  | SI Test |  | SIT | 6.11 | Kevin Davis |  | Complete | COMPLETE |  |  | SITAG |  |  |  |  |
| 889 | 1.4.1.4.2.5.2.2.4 | Test Script updates identified |  | 1d? | 2024-10-14 A | 2024-10-14 A | 888 | 100% | 2024-10-14 | 2024-10-14 | 0d |  |  |  |  | SI Test |  | SIT | 6.11 | Kevin Davis |  | Complete | COMPLETE |  |  | SITAG |  |  |  |  |
| 890 | 1.4.1.4.2.5.2.2.5 | Test Scripts updates |  | 1d | 2024-10-15 A | 2024-10-15 A | 889 | 100% | 2024-10-15 | 2024-10-15 | 0d |  |  |  |  | SI Test |  | SIT | 6.11 | Kevin Davis |  | Complete | COMPLETE |  |  | SITAG |  |  |  |  |
| 891 | 1.4.1.4.2.5.2.2.6 | RTTM Updated Additional Static RTTM WBS items |  | 10d | 2024-10-14 A | 2024-10-25 A | 889FS-1d | 100% | 2024-10-14 | 2024-10-25 | 0d |  |  |  |  | SI Test |  | SIT | 6.11 | Kevin Davis |  | Complete | COMPLETE |  |  | SITAG |  |  |  |  |
| 892 | 1.4.1.4.2.5.2.2.7 | Removal of de-scoped TCs from the RTTMs |  | 5d | 2024-10-21 A | 2024-10-25 A | 891FS-5d | 100% | 2024-10-21 | 2024-10-25 | 0d |  |  |  |  | SI Test |  | SIT | 6.11 | Kevin Davis |  | Complete | COMPLETE |  |  | SITAG |  |  |  |  |
| 893 | 1.4.1.4.2.5.2.2.8 | Update and stabilisation of all TC ADO IDs |  | 14d | 2024-10-21 A | 2024-11-07 A | 891FS-5d | 100% | 2024-10-21 | 2024-10-25 | 0d |  |  |  |  | SI Test |  | SIT | 6.12 | Kevin Davis |  | Complete | COMPLETE |  |  | SITAG |  |  |  |  |
| 894 | 1.4.1.4.2.5.2.2.9 | Addition and integration of Role tags to reqs in the Role RTTMs |  | 5d | 2024-10-21 A | 2024-10-25 A | 891FS-5d | 100% | 2024-10-21 | 2024-10-25 | 0d |  |  |  |  | SI Test |  | SIT | 6.11 | Kevin Davis |  | Complete | COMPLETE |  |  | SITAG |  |  |  |  |
| 895 | 1.4.1.4.2.5.2.2.10 | Update of the RTTM All sheet (porting of the individual RTTMs) |  | 7d | 2024-10-24 A | 2024-11-01 A | 891FS-2d | 100% | 2024-10-24 | 2024-10-25 | 0d |  |  |  |  | SI Test |  | SIT | 6.11 | Kevin Davis |  | Complete | COMPLETE |  |  | SITAG |  |  |  |  |
| 896 | 1.4.1.4.2.5.2.2.11 | Define Additional ADO Tags |  | 1d | 2024-10-23 A | 2024-10-23 A | 891FS-3d | 100% | 2024-10-23 | 2024-10-23 | 0d |  |  |  |  | SI Test |  | SIT | 6.11 | Kevin Davis |  | Complete | COMPLETE |  |  | SITAG |  |  |  |  |
| 897 | 1.4.1.4.2.5.2.2.12 | Functional RTTM ready for import into ADO | milestone | 0d | 2024-11-01 A | 2024-11-01 A | 895 | 100% | 2024-10-25 | 2024-10-25 | 0d |  |  |  |  | SI Test |  | SIT | 6.11 | Kevin Davis |  | Complete | COMPLETE |  |  | SITAG |  |  |  |  |
| 898 | 1.4.1.4.2.5.2.2.13 | Further Interative Deepdive on the requirements to testcase mapping |  | 9d | 2024-10-21 A | 2024-10-31 A | 895FS-10d | 100% | 2024-10-21 | 2024-10-31 | 0d |  |  |  |  | SI Test |  | SIT | 6.11 | Kevin Davis |  | Complete | COMPLETE |  |  | SITAG |  |  |  |  |
| 899 | 1.4.1.4.2.5.2.2.14 | Internal review |  | 5d | 2024-10-21 A | 2024-10-25 A | 898FS-9d | 100% | 2024-11-01 | 2024-11-05 | 0d |  |  |  |  | SI Test |  | SIT | 6.11 | Kevin Davis |  | Complete | COMPLETE |  |  | SITAG |  |  |  |  |
| 900 | 1.4.1.4.2.5.2.2.15 | Issue Static RTTM to Code Bodies |  | 1d? | 2024-10-29 A | 2024-10-29 A | 899FS+1d | 100% | 2024-11-06 | 2024-11-06 | 0d |  |  |  |  | SI Test |  | SIT | 6.11 | Kevin Davis |  | Complete | COMPLETE |  |  | SITAG |  |  |  |  |
| 901 | 1.4.1.4.2.5.2.2.16 | Code Body Acceptance of RTTM |  | 5d | 2024-10-30 A | 2024-11-05 A | 900 | 100% | 2024-11-07 | 2024-11-13 | 0d |  |  |  |  | Code Bodies |  | SIT | 6.11 | Kevin Davis |  | Complete | COMPLETE |  |  | SITAG |  |  |  |  |

| ID | WBS | Task | Type | Duration | Start | Finish | Predecessors | Complete | Baseline start | Baseline finish | Baseline duration | Constraint | Responsible | Text9 | Task Status | Update Version | Sched Status | MHHS Resource Name | Text29 | RAG | Milestone ID | Tier |
| --- | --- | --- | --- | --- | --- | --- | --- | --- | --- | --- | --- | --- | --- | --- | --- | --- | --- | --- | --- | --- | --- | --- |
| 902 | 1.4.1.4.2.5.3 | **Cycle 3 Test Evidence Capturing Approach** |  | 25d? | 2024-09-16 A | 2024-10-18 A |  | 100% | 2024-09-16 | 2024-10-18 | 0d |  | SI Test | SIT | -692.67 | 6.0 | Overdue Start | Ankur Pande | SITAG |  |  |  |
| 903 | 1.4.1.4.2.5.3.1 | Define guiding principles and proof of concept |  | 10d | 2024-09-16 A | 2024-09-27 A |  | 100% | 2024-09-16 | 2024-09-27 | 0d | start no earlier than 2024-09-16 | SI Test | SIT |  | 6.0 | Complete | Ankur Pande | SITAG | COMPLETE |  |  |
| 904 | 1.4.1.4.2.5.3.2 | Draft proposed test evidence capturing approach |  | 3d | 2024-09-30 A | 2024-10-02 A | 903 | 100% | 2024-09-30 | 2024-10-02 | 0d |  | SI Test | SIT |  | 6.0 | Complete | Ankur Pande | SITAG | COMPLETE |  |  |
| 905 | 1.4.1.4.2.5.3.3 | SRO review |  | 5d | 2024-10-03 A | 2024-10-09 A | 904 | 100% | 2024-10-03 | 2024-10-09 | 0d |  | SI Test | SIT |  | 6.0 | Complete | Ankur Pande | SITAG | COMPLETE |  |  |
| 906 | 1.4.1.4.2.5.3.4 | Present proposed approach |  | 1d? | 2024-10-11 A | 2024-10-11 A | 905FS+1d | 100% | 2024-10-11 | 2024-10-11 | 0d |  | SI Test | SIT |  | 6.0 | Complete | Ankur Pande | SITAG | COMPLETE |  |  |
| 907 | 1.4.1.4.2.5.3.5 | Incorporate feedback |  | 4d | 2024-10-14 A | 2024-10-17 A | 906 | 100% | 2024-10-14 | 2024-10-17 | 0d |  | SI Test | SIT |  | 6.0 | Complete | Ankur Pande | SITAG | COMPLETE |  |  |
| 908 | 1.4.1.4.2.5.3.6 | Publish proposed approach ahead of Cycle 3 start |  | 1d? | 2024-10-18 A | 2024-10-18 A | 907 | 100% | 2024-10-18 | 2024-10-18 | 0d |  | SI Test | SIT |  | 6.0 | Complete | Ankur Pande | SITAG | COMPLETE |  |  |
| 909 | 1.4.1.4.2.5.4 | **DITL Cycle 3 Pack Development** |  | 8d? | 2024-10-08 A | 2024-10-17 A |  | 100% | 2024-10-08 | 2024-10-17 | 0d |  | SI Test | SIT | 6.33 | 6.0 | No BL | Dom Mooney | SITAG |  |  |  |
| 910 | 1.4.1.4.2.5.4.1 | Programme Cycle 2 Retro |  | 1d? | 2024-10-08 A | 2024-10-08 A |  | 100% | 2024-10-08 | 2024-10-08 | 0d | start no earlier than 2024-10-08 | SI Test | SIT |  | 6.0 | Complete | Dom Mooney | SITAG | COMPLETE |  |  |
| 911 | 1.4.1.4.2.5.4.2 | Post-retro DITL Changes |  | 3d | 2024-10-09 A | 2024-10-11 A | 910 | 100% | 2024-10-09 | 2024-10-11 | 0d |  | SI Test | SIT |  | 6.0 | Complete | Dom Mooney | SITAG | COMPLETE |  |  |
| 912 | 1.4.1.4.2.5.4.3 | SRO Review |  | 2d | 2024-10-14 A | 2024-10-15 A | 911 | 100% | 2024-10-14 | 2024-10-15 | 0d |  | SI Test | SIT |  | 6.0 | Complete | Dom Mooney | SITAG | COMPLETE |  |  |
| 913 | 1.4.1.4.2.5.4.4 | Post-SRO Review Changes |  | 1d? | 2024-10-16 A | 2024-10-16 A | 912 | 100% | 2024-10-16 | 2024-10-16 | 0d |  | SI Test | SIT |  | 6.0 | Complete | Dom Mooney | SITAG | COMPLETE |  |  |
| 914 | 1.4.1.4.2.5.4.5 | Publish Cycle 3 DITL / Cycle 3 DITL Online Sessions for SIT PPs |  | 1d? | 2024-10-17 A | 2024-10-17 A | 913 | 100% | 2024-10-17 | 2024-10-17 | 0d |  | SI Test, PPs | SIT |  | 6.0 | Complete | Dom Mooney | SITAG | COMPLETE |  |  |
| 915 | 1.4.1.4.2.5.5 | **Test Script Exit Points** |  | 85d | 2024-10-14 A | 2025-02-07 A |  | 100% | 2024-10-14 | 2025-02-07 | 0d |  | SI Test | SIT | -694.67 | 6.0 | Overdue Start | Kevin Davis | SITAG |  |  |  |
| 916 | 1.4.1.4.2.5.5.1 | Implement exit points for Sprint 5 |  | 5d | 2024-10-14 A | 2024-10-18 A | 908FS-5d | 100% | 2024-10-14 | 2024-10-18 | 0d |  | SI Test | SIT |  | 6.0 | Complete | Kevin Davis | SITAG | COMPLETE |  |  |
| 917 | 1.4.1.4.2.5.5.2 | Identify exit points for Sprint 6 |  | 5d | 2024-11-07 A | 2024-11-13 A | 1513SS | 100% | 2024-10-21 | 2024-10-25 | 0d |  | SI Test | SIT |  | 6.0 | Complete | Kevin Davis | SITAG | COMPLETE |  |  |
| 918 | 1.4.1.4.2.5.5.3 | Identify exit points for Sprint 7 |  | 5d | 2024-11-08 A | 2024-11-14 A | 1514SS | 100% | 2024-11-04 | 2024-11-08 | 0d | start no earlier than 2024-11-08 | SI Test | SIT |  | 6.0 | Complete | Kevin Davis | SITAG | COMPLETE |  |  |
| 919 | 1.4.1.4.2.5.5.4 | Identify exit points for Sprint 8 |  | 5d | 2024-11-18 A | 2024-11-22 A | 1515SS | 100% | 2024-11-18 | 2024-11-22 | 0d |  | SI Test | SIT |  | 6.0 | Complete | Kevin Davis | SITAG | COMPLETE |  |  |
| 920 | 1.4.1.4.2.5.5.5 | Identify exit points for Sprint 9 |  | 5d | 2024-12-02 A | 2024-12-06 A | 1516SS | 100% | 2024-12-02 | 2024-12-06 | 0d |  | SI Test | SIT |  | 6.0 | Complete | Kevin Davis | SITAG | COMPLETE |  |  |
| 921 | 1.4.1.4.2.5.5.6 | Identify exit points for Sprint 10 |  | 5d | 2024-12-23 A | 2024-12-27 A | 1517SS | 100% | 2024-12-23 | 2024-12-27 | 0d |  | SI Test | SIT |  | 6.0 | Complete | Kevin Davis | SITAG | COMPLETE |  |  |
| 922 | 1.4.1.4.2.5.5.7 | Identify exit points for Sprint 11 |  | 5d | 2025-01-06 A | 2025-01-10 A | 1518SS | 100% | 2025-01-06 | 2025-01-10 | 0d |  | SI Test | SIT |  | 6.0 | Complete | Kevin Davis | SITAG | COMPLETE |  |  |
| 923 | 1.4.1.4.2.5.5.8 | Identify exit points for Sprint 12 |  | 5d | 2025-01-20 A | 2025-01-24 A | 1519SS | 100% | 2025-01-20 | 2025-01-24 | 0d |  | SI Test | SIT |  | 6.0 | Complete | Kevin Davis | SITAG | COMPLETE |  |  |
| 924 | 1.4.1.4.2.5.5.9 | Identify exit points for Sprint 13 |  | 5d | 2025-02-03 A | 2025-02-07 A | 1520SS | 100% | 2025-02-03 | 2025-02-07 | 0d |  | SI Test | SIT |  | 6.0 | Complete | Kevin Davis | SITAG | COMPLETE |  |  |
| 925 | 1.4.1.4.2.5.5.10 | Exit point identified and evidence capture flags updated | milestone | 0d | 2025-02-07 A | 2025-02-07 A | 924 | 100% | 2025-02-07 | 2025-02-07 | 0d |  | SI Test | SIT |  | 6.13 | Complete | Kevin Davis | SITAG | COMPLETE | T3-TE-0125 | T3 |

| ID | WBS | Task | Type | Duration | Start | Finish | Predecessors | Complete | Baseline start | Baseline finish | Baseline duration | Baseline 1 start | Baseline 1 finish | Constraint | Baseline cost | Responsible | Involved | Text9 | Update Version | MHHS Resource Name | MHHS Programme Phase | Text29 | Task Status | Sched Status | RAG | Action | Milestone ID | Tier | Artefact ID |
| --- | --- | --- | --- | --- | --- | --- | --- | --- | --- | --- | --- | --- | --- | --- | --- | --- | --- | --- | --- | --- | --- | --- | --- | --- | --- | --- | --- | --- | --- |
| 926 | 1.4.1.4.2.6 | **Environments (SIT-Staging)** |  | 10d | 2023-12-04 A | 2023-12-15 A |  | 100% | 2023-12-04 | 2023-12-15 | 323d | 2022-11-16 | 2024-02-09 |  |  | N/A | N/A | SIT | 5.0 | N/A | Systems Integration Testing (SIT) | SITAG |  |  |  |  |  |  |  |
| 927 | 1.4.1.4.2.6.1 | **SIT Functional pre-requisites** |  | 10d | 2023-12-04 A | 2023-12-15 A |  | 100% | 2023-12-04 | 2023-12-15 | 10d |  |  |  |  | N/A | N/A | SIT | 5.3 | N/A | Systems Integration Testing (SIT) | SITAG |  |  |  |  |  |  |  |
| 928 | 1.4.1.4.2.6.1.1 | **DCC** |  | 10d | 2023-12-04 A | 2023-12-15 A |  | 100% | 2023-12-04 | 2023-12-15 | 10d |  |  |  |  | N/A | N/A | SIT | 5.3 | N/A | Systems Integration Testing (SIT) | SITAG | -254.67 |  |  |  |  |  |  |
| 929 | 1.4.1.4.2.6.1.1.1 | **CSS** |  | 10d | 2023-12-04 A | 2023-12-15 A |  | 100% | 2023-12-04 | 2023-12-15 | 10d |  |  |  |  | N/A | N/A | SIT | 5.3 | N/A | Systems Integration Testing (SIT) | SITAG | -254.67 |  |  |  |  |  |  |
| 930 | 1.4.1.4.2.6.1.1.1.1 | SIT participants have requested DCC CSS PKI certificates for access to UIT-B environment |  | 10d | 2023-12-04 A | 2023-12-15 A |  | 100% | 2023-12-04 | 2023-12-15 | 10d |  |  | start no earlier than 2023-12-04 |  | SIT Participants (Suppliers & Third Parties) | PP | SIT | 5.3 | Simon Berry | Systems Integration Testing (SIT) | SITAG |  | Complete | COMPLETE |  |  |  |  |
| 931 | 1.4.1.4.2.6.1.1.1.2 | SIT participants have received DCC CSS PKI certificates for UIT-B environment | milestone | 0d | 2023-12-15 A | 2023-12-15 A | 930 | 100% | 2023-12-15 | 2023-12-15 | 0d |  |  |  |  | SIT Participants (Suppliers & Third Parties) | PP | SIT | 5.5 | Simon Berry | Systems Integration Testing (SIT) | SITAG |  | Complete | COMPLETE | 7/8 - added as a T3 milestone. Awaiting approval at TMAG | T3-TE-0088 | T3 |  |
| 932 | 1.4.1.4.2.6.1.1.2 | **DSP** |  | 10d | 2023-12-04 A | 2023-12-15 A |  | 100% | 2023-12-04 | 2023-12-15 | 10d |  |  |  |  | N/A | N/A | SIT | 5.3 | N/A | Systems Integration Testing (SIT) | SITAG | -254.67 |  |  |  |  |  |  |
| 933 | 1.4.1.4.2.6.1.1.2.1 | SIT participants have requested DCC DSP PKI certificates for access to UIT-B environment |  | 10d | 2023-12-04 A | 2023-12-15 A |  | 100% | 2023-12-04 | 2023-12-15 | 10d |  |  | start no earlier than 2023-12-04 |  | PPs in SDS Market Role | PP | SIT | 5.3 | Simon Berry | Systems Integration Testing (SIT) | SITAG |  | Complete | COMPLETE |  |  |  |  |
| 934 | 1.4.1.4.2.6.1.1.2.2 | SIT participants have received DCC DSP PKI certificates for UIT-B environment | milestone | 0d | 2023-12-15 A | 2023-12-15 A | 933 | 100% | 2023-12-15 | 2023-12-15 | 0d |  |  |  |  | PPs in SDS Market Role | PP | SIT | 5.5 | Simon Berry | Systems Integration Testing (SIT) | SITAG |  | Complete | COMPLETE | 7/8 - added as a T3 milestone. Awaiting approval at TMAG | T3-TE-0089 | T3 |  |
| 935 | 1.4.1.4.2.7 | **Stand up SIT A Environment** |  | 25d | 2024-02-05 A | 2024-03-08 A |  | 100% | 2024-02-05 | 2024-03-08 | 25d | 2024-02-05 | 2024-02-09 |  |  | N/A | N/A | SIT | 6.0 | N/A | Systems Integration Testing (SIT) | SITAG |  |  |  |  |  |  |  |
| 936 | 1.4.1.4.2.7.1 | **SIT Functional Connectivity Proving** |  | 15d | 2024-02-12 A | 2024-03-01 A |  | 100% | 2024-02-12 | 2024-03-01 | 20d |  |  |  |  | N/A | N/A | SIT | 5.5 | N/A | Systems Integration Testing (SIT) | SITAG | -288.67 |  |  |  |  |  |  |
| 937 | 1.4.1.4.2.7.1.1 | SIT Functional Connectivity Proving Period |  | 15d | 2024-02-12 A | 2024-03-01 A |  | 100% | 2024-02-12 | 2024-03-01 | 20d |  |  | start no earlier than 2024-01-08 |  | SI Test | PP | SIT | 5.19 | Simon Berry | Systems Integration Testing (SIT) | SITAG |  | Complete | COMPLETE |  |  |  |  |
| 938 | 1.4.1.4.2.7.1.2 | SIT Functional Connectivity Proving Complete | milestone | 0d | 2024-03-01 A | 2024-03-01 A | 937 | 100% | 2024-03-01 | 2024-03-01 | 0d |  |  | start no earlier than 2024-03-01 |  | SI Test | PP | SIT | 5.19 | Simon Berry | Systems Integration Testing (SIT) | SITAG |  | Complete | COMPLETE |  | T3-TE-0103 | T3 |  |
| 939 | 1.4.1.4.2.7.2 | **PP Environments (SIT A)** |  | 25d | 2024-02-05 A | 2024-03-08 A |  | 100% | 2024-02-05 | 2024-03-08 | 5d | 2024-02-05 | 2024-02-09 |  |  | N/A | N/A | SIT | 5.0 | N/A | Systems Integration Testing (SIT) | SITAG |  |  |  |  |  |  |  |
| 940 | 1.4.1.4.2.7.2.1 | Deployment of MHHS solution code to SIT A environments |  | 25d | 2024-02-05 A | 2024-03-08 A |  | 100% | 2024-02-05 | 2024-03-08 | 5d | 2024-02-05 | 2024-02-09 | start no earlier than 2024-02-05 |  | PP | SI Test | SIT | 5.0 | Simon Berry | Systems Integration Testing (SIT) | SITAG |  | Complete | COMPLETE |  |  |  |  |
| 941 | 1.4.1.4.2.7.3 | **SI Environments (SIT A)** |  | 25d | 2024-02-05 A | 2024-03-08 A |  | 100% | 2024-02-05 | 2024-03-08 | 5d | 2024-02-05 | 2024-02-09 |  |  | N/A | N/A | SIT | 5.0 | N/A | Systems Integration Testing (SIT) | SITAG |  |  |  |  |  |  |  |
| 942 | 1.4.1.4.2.7.3.1 | Coordinate deployment of MHHS solution code to SIT Participants' SIT A environments |  | 25d | 2024-02-05 A | 2024-03-08 A | 940SS | 100% | 2024-02-05 | 2024-03-08 | 5d | 2024-02-05 | 2024-02-09 |  |  | SI Test | PP | SIT | 5.0 | Simon Berry | Systems Integration Testing (SIT) | SITAG |  | Complete | COMPLETE |  |  |  |  |
| 943 | 1.4.1.4.2.8 | **Test data (SIT A)** |  | 221d? | 2023-12-18 A | 2024-10-21 A |  | 100% | 2023-12-18 | 2025-04-07 | 225d |  |  |  | -0 | N/A | N/A | SIT | 5.4 | N/A | Systems Integration Testing (SIT) | SITAG | -269.67 |  |  |  |  |  |  |
| 944 | 1.4.1.4.2.8.1 | **Cycle 1 Test data (SIT A)** |  | 55d | 2023-12-18 A | 2024-03-01 A |  | 100% | 2023-12-18 | 2024-03-01 | 55d |  |  |  | -0 | N/A | N/A | SIT | 5.4 | N/A | Systems Integration Testing (SIT) | SITAG | -269.67 |  |  |  |  |  |  |
| 945 | 1.4.1.4.2.8.1.1 | Prepare, Generate and Allocate Test Data |  | 28d | 2023-12-18 A | 2024-01-24 A | 676, 684 | 100% | 2023-12-18 | 2024-01-24 | 28d |  |  | start no earlier than 2023-12-11 |  | SI Test Data |  | SIT | 5.14 | Richard Puddephatt | Systems Integration Testing (SIT) | SITAG |  | Complete | COMPLETE |  |  |  |  |
| 946 | 1.4.1.4.2.8.1.2 | Transmit Data Sets to PPs |  | 4d | 2024-01-26 A | 2024-01-31 A | 945FS+1d | 100% | 2024-01-26 | 2024-01-31 | 2d |  |  |  |  | SI Test Data |  | SIT | 5.14 | Richard Puddephatt | Systems Integration Testing (SIT) | SITAG |  | Complete | COMPLETE |  |  |  |  |
| 947 | 1.4.1.4.2.8.1.3 | PP's Iterative load and data integrity check |  | 22d | 2024-02-01 A | 2024-03-01 A | 946 | 100% | 2024-02-01 | 2024-03-01 | 10d |  |  |  |  | PP |  | SIT | 5.14 | Richard Puddephatt | Systems Integration Testing (SIT) | SITAG |  | Complete | COMPLETE |  |  |  |  |
| 948 | 1.4.1.4.2.8.1.4 | Cycle 1 - PP's confirmation that test data is ready for SIT Functional | milestone | 0d | 2024-03-01 A | 2024-03-01 A | 947 | 100% | 2024-03-01 | 2024-03-01 | 0d |  |  |  |  | SI Test Data |  | SIT | 5.18 | Richard Puddephatt | Systems Integration Testing (SIT) | SITAG |  | Complete | COMPLETE | 2/8 - added as a T3 milestone. Awaiting approval at TMAG | T3-TE-0079 | T3 | MHHS-ART140 MHHS-ART169 |
| 949 | 1.4.1.4.2.8.2 | **Cycle 2 Test data (inc. Settlement Data) (SIT A)** |  | 57d | 2024-03-28 A | 2024-06-14 A |  | 100% | 2024-03-28 | 2024-06-14 | 47d |  |  |  | -0 | N/A | N/A | SIT | 6.0 | N/A | Systems Integration Testing (SIT) | SITAG |  |  |  |  |  |  |  |
| 950 | 1.4.1.4.2.8.2.1 | Prepare, Generate and Allocate Test Data |  | 31d | 2024-03-28 A | 2024-05-09 A | 948FS+18d | 100% | 2024-03-28 | 2024-05-09 | 31d |  |  |  |  | SI Test Data |  | SIT | 5.14 | Richard Puddephatt | Systems Integration Testing (SIT) | SITAG |  | Complete | COMPLETE |  |  |  |  |
| 951 | 1.4.1.4.2.8.2.2 | Transmit Data Sets to PPs |  | 3d | 2024-05-10 A | 2024-05-14 A | 950 | 100% | 2024-05-10 | 2024-05-14 | 3d |  |  |  |  | SI Test Data |  | SIT | 5.14 | Richard Puddephatt | Systems Integration Testing (SIT) | SITAG |  | Complete | COMPLETE |  |  |  |  |
| 952 | 1.4.1.4.2.8.2.3 | PP's Iterative load and data integrity check |  | 13d | 2024-05-15 A | 2024-05-31 A | 951 | 100% | 2024-05-15 | 2024-05-31 | 13d |  |  |  |  | PP |  | SIT | 5.14 | Richard Puddephatt | Systems Integration Testing (SIT) | SITAG |  | Complete | COMPLETE |  |  |  |  |
| 953 | 1.4.1.4.2.8.2.4 | Cycle 2 - PP's confirmation that test data is ready for SIT Functional | milestone | 0d | 2024-06-14 A | 2024-06-14 A | 952FS+10d | 100% | 2024-06-14 | 2024-06-14 | 0d |  |  |  |  | SI Test Data |  | SIT | 5.27 | Richard Puddephatt | Systems Integration Testing (SIT) | SITAG |  | Complete | COMPLETE | 2/8 - added as a T3 milestone. Awaiting approval at TMAG | T3-TE-0080 | T3 | MHHS-ART140 MHHS-ART169 |

| ID | WBS | Task | Duration | Start | Finish | Predecessors | Complete | Baseline start | Baseline finish | Baseline duration | Baseline 1 start | Baseline 1 finish | Constraint | Baseline cost | Responsible | Involved | Text9 | Update Version | MHHS Resource Name | MHHS Programme Phase | Text29 | Sched Status | RAG | Milestone ID |
| --- | --- | --- | --- | --- | --- | --- | --- | --- | --- | --- | --- | --- | --- | --- | --- | --- | --- | --- | --- | --- | --- | --- | --- | --- |
| 954 | 1.4.1.4.2.8.3 | **Cycle 3 Test data (SIT A) (2)** | 71d? | 2024-07-15 A | 2024-10-21 A |  | 100% | 2024-07-15 | 2024-10-21 | 41d |  |  |  | -0 | N/A | N/A | SIT | 5.4 | N/A | Systems Integration Testing (SIT) | SITAG |  |  |  |
| 955 | 1.4.1.4.2.8.3.1 | Cycle 3 data requirments analysis - check Cycle 2 data for gaps Check blocked test cases | 10d? | 2024-07-15 A | 2024-07-26 A |  | 100% | 2024-07-15 | 2024-07-26 | 0d |  |  | finish no earlier than 2024-07-26 |  |  |  | SIT | 6.0 | Richard Puddephatt |  | SITAG | Complete | COMPLETE |  |
| 956 | 1.4.1.4.2.8.3.2 | Provide DCC with MPANS for deletion secure file with password | 1d? | 2024-08-12 A | 2024-08-12 A |  | 100% | 2024-08-12 | 2024-08-12 | 0d |  |  |  |  |  |  | SIT | 6.0 | Richard Puddephatt |  | SITAG | Complete | COMPLETE |  |
| 957 | 1.4.1.4.2.8.3.3 | Receive MPANS from DCC to exclude | 1d? | 2024-08-09 A | 2024-08-09 A |  | 100% | 2024-08-09 | 2024-08-09 | 0d |  |  |  |  |  |  | SIT | 6.0 | Richard Puddephatt |  | SITAG | Complete | COMPLETE |  |
| 958 | 1.4.1.4.2.8.3.4 | Exclude MPANS from allocation | 1d | 2024-08-16 A | 2024-08-16 A |  | 100% | 2024-08-16 | 2024-08-16 | 0d |  |  |  |  |  |  | SIT | 6.0 | Richard Puddephatt |  | SITAG | Complete | COMPLETE |  |
| 959 | 1.4.1.4.2.8.3.5 | Allocate Cycle 3 MPANS | 16d? | 2024-08-06 A | 2024-08-27 A |  | 100% | 2024-08-06 | 2024-08-27 | 0d |  |  |  |  |  |  | SIT | 6.0 | Richard Puddephatt |  | SITAG | Complete | COMPLETE |  |
| 960 | 1.4.1.4.2.8.3.6 | Generate Cycle 3 Data | 2d? | 2024-08-27 A | 2024-08-28 A |  | 100% | 2024-08-27 | 2024-08-28 | 0d |  |  |  |  |  |  | SIT | 6.0 | Richard Puddephatt |  | SITAG | Complete | COMPLETE |  |
| 961 | 1.4.1.4.2.8.3.7 | Check data prior to sending to DCC | 5d? | 2024-08-22 A | 2024-08-28 A |  | 100% | 2024-08-22 | 2024-08-28 | 0d |  |  |  |  |  |  | SIT | 6.0 | Richard Puddephatt |  | SITAG | Complete | COMPLETE |  |
| 962 | 1.4.1.4.2.8.3.8 | Share Cycle 3 MPAN data with DCC | 1d? | 2024-08-29 A | 2024-08-29 A |  | 100% | 2024-08-29 | 2024-08-29 | 0d |  |  |  |  |  |  | SIT | 6.0 | Richard Puddephatt |  | SITAG | Complete | COMPLETE |  |
| 963 | 1.4.1.4.2.8.3.9 | DCC - load data and create registration Id's for Cycle 3 data | 13d? | 2024-08-27 A | 2024-09-12 A |  | 100% | 2024-08-27 | 2024-09-12 | 0d |  |  |  |  |  |  | SIT | 6.0 | Richard Puddephatt |  | SITAG | Complete | COMPLETE |  |
| 964 | 1.4.1.4.2.8.3.10 | Add registration ID's to Cycle 3 Data | 2d? | 2024-09-12 A | 2024-09-13 A |  | 100% | 2024-09-12 | 2024-09-13 | 0d |  |  |  |  |  |  | SIT | 6.0 | Richard Puddephatt |  | SITAG | Complete | COMPLETE |  |
| 965 | 1.4.1.4.2.8.3.11 | Share subset of data with St Cls for data load | 2d? | 2024-09-12 A | 2024-09-13 A |  | 100% | 2024-09-12 | 2024-09-13 | 0d |  |  |  |  |  |  | SIT | 6.0 | Richard Puddephatt |  | SITAG | Complete | COMPLETE |  |
| 966 | 1.4.1.4.2.8.3.12 | St Clements to run test with Subset of data - MPRS business process checks including Import/Export MPANS | 5d? | 2024-09-16 A | 2024-09-20 A |  | 100% | 2024-09-16 | 2024-09-20 | 0d |  |  |  |  |  |  | SIT | 6.0 | Richard Puddephatt |  | SITAG | Complete | COMPLETE |  |
| 967 | 1.4.1.4.2.8.3.13 | Send Cycle 3 data to partcipants for early sight of data | 3d? | 2024-09-25 A | 2024-09-27 A |  | 100% | 2024-09-25 | 2024-09-27 | 0d |  |  |  |  |  |  | SIT | 6.0 | Richard Puddephatt |  | SITAG | Complete | COMPLETE |  |
| 968 | 1.4.1.4.2.8.3.14 | St Clements MPRS data load bulk files for Cycle 3 | 15d? | 2024-09-23 A | 2024-10-11 A |  | 100% | 2024-09-23 | 2024-10-11 | 0d |  |  |  |  |  |  | SIT | 6.0 | Richard Puddephatt |  | SITAG | Complete | COMPLETE |  |
| 969 | 1.4.1.4.2.8.3.15 | New MPAN creation and load through DCC and St Clements | 1d? | 2024-10-11 A | 2024-10-11 A |  | 100% | 2024-10-11 | 2024-10-11 | 0d |  |  | start no earlier than 2024-10-11 |  |  |  | SIT | 6.0 | Richard Puddephatt |  | SITAG | Complete | COMPLETE |  |
| 970 | 1.4.1.4.2.8.3.16 | Share files with PP's and central parties | 1d | 2024-10-11 A | 2024-10-11 A |  | 100% | 2024-10-11 | 2024-10-11 | 0d |  |  | start no earlier than 2024-10-11 |  |  |  | SIT | 6.0 | Richard Puddephatt |  | SITAG | Complete | COMPLETE |  |
| 971 | 1.4.1.4.2.8.3.17 | Avanade to load data | 6d | 2024-10-14 A | 2024-10-21 A |  | 100% | 2024-10-14 | 2024-10-21 | 0d |  |  | start no earlier than 2024-10-14 |  |  |  | SIT | 6.0 | Richard Puddephatt |  | SITAG | Complete | COMPLETE |  |
| 972 | 1.4.1.4.2.8.3.18 | Helix to load data | 6d | 2024-10-14 A | 2024-10-21 A |  | 100% | 2024-10-14 | 2024-10-21 | 0d |  |  | start no earlier than 2024-10-14 |  |  |  | SIT | 6.0 | Richard Puddephatt |  | SITAG | Complete | COMPLETE |  |
| 973 | 1.4.1.4.2.8.3.19 | PP's and central parties to load all Cycle 3 data | 6d | 2024-10-14 A | 2024-10-21 A |  | 100% | 2024-10-14 | 2024-10-21 | 0d |  |  | start no earlier than 2024-10-14 |  |  |  | SIT | 6.0 | Richard Puddephatt |  | SITAG | Complete | COMPLETE |  |
| 974 | 1.4.1.4.2.8.3.20 | All parties to finalise data load | 1d? | 2024-10-21 A | 2024-10-21 A |  | 100% | 2024-10-21 | 2024-10-21 | 0d |  |  | start no earlier than 2024-10-21 |  | SI Data |  | SIT | 6.0 | Richard Puddephatt |  | SITAG | Complete | COMPLETE | T3-TE-0081 |
| 975 | 1.4.1.4.2.9 | **SIT Functional Test Readiness Report** | 45d | 2024-01-01 A | 2024-03-01 A |  | 100% | 2024-01-01 | 2024-03-01 | 44d | 2024-01-01 | 2024-02-23 |  | -0 | N/A | N/A | SIT | 5.0 | N/A | Systems Integration Testing (SIT) | SITAG |  |  |  |
| 976 | 1.4.1.4.2.9.1 | **PP SIT Functional Test Readiness Report** | 44d | 2024-01-01 A | 2024-02-29 A |  | 100% | 2024-01-01 | 2024-02-29 | 44d | 2024-01-01 | 2024-02-09 |  | -0 | N/A | N/A | SIT | 5.0 | N/A | Systems Integration Testing (SIT) | SITAG |  |  |  |
| 977 | 1.4.1.4.2.9.1.1 | Develop draft Test Readiness Report and submit to Programme for assurance | 21d | 2024-01-01 A | 2024-01-29 A |  | 100% | 2024-01-01 | 2024-01-29 | 20d | 2024-01-01 | 2024-01-29 | start no earlier than 2024-01-01 |  | PP | SI Test | SIT | 5.0 |  | Systems Integration Testing (SIT) | SITAG | Complete | COMPLETE |  |
| 978 | 1.4.1.4.2.9.1.2 | Placing Reliance Stage 2 Review | 34d | 2024-01-15 A | 2024-02-29 A | 977SS+10d | 100% | 2024-01-15 | 2024-02-29 | 34d |  |  |  |  | SI Test | PP | SIT | 5.12 |  | Systems Integration Testing (SIT) | SITAG | Complete | COMPLETE |  |
| 979 | 1.4.1.4.2.9.1.3 | Finalise Test Readiness Report and submit to Programme for assurance | 9d | 2024-01-30 A | 2024-02-09 A | 977 | 100% | 2024-01-30 | 2024-02-09 | 10d | 2024-01-29 | 2024-02-09 |  |  | PP | SI Test | SIT | 5.0 |  | Systems Integration Testing (SIT) | SITAG | Complete | COMPLETE |  |

| ID | WBS | Task | Type | Duration | Start | Finish | Predecessors | Complete | Remaining | Baseline start | Baseline finish | Baseline duration | Baseline 1 start | Baseline 1 finish | Total slack | Constraint | Baseline cost | Responsible | Involved | Text9 | Update Version | MHHS Resource Name | MHHS Programme Phase | Text29 | Sched Status | RAG | Milestone ID | Tier | Artefact ID | Task Status |
| --- | --- | --- | --- | --- | --- | --- | --- | --- | --- | --- | --- | --- | --- | --- | --- | --- | --- | --- | --- | --- | --- | --- | --- | --- | --- | --- | --- | --- | --- | --- |
| 980 | 1.4.1.4.2.9.2 | **SI SIT Functional Test Readiness Report** |  | 40d | 2024-01-01 A | 2024-02-23 A |  | 100% |  | 2024-01-01 | 2024-02-23 | 40d | 2024-01-01 | 2024-02-23 |  |  |  | N/A | N/A | SIT | 5.0 | N/A | Systems Integration Testing (SIT) | SITAG |  |  |  |  |  |  |
| 981 | 1.4.1.4.2.9.2.1 | Assure Test Participants' Test Readiness Reports |  | 35d | 2024-01-01 A | 2024-02-16 A | 977SS, 979FF+5d | 100% |  | 2024-01-01 | 2024-02-16 | 35d | 2024-01-01 | 2024-02-16 |  |  |  | SI Test | PP,IPA | SIT | 5.0 |  | Systems Integration Testing (SIT) | SITAG | Complete | COMPLETE |  |  |  |  |
| 982 | 1.4.1.4.2.9.2.2 | Develop Overarching SIT Functional Test Readiness Report |  | 20d | 2024-01-22 A | 2024-02-16 A | 981FF | 100% |  | 2024-01-22 | 2024-02-16 | 20d | 2024-01-22 | 2024-02-16 |  |  |  | SI Test |  | SIT | 5.0 |  | Systems Integration Testing (SIT) | SITAG | Complete | COMPLETE |  |  |  |  |
| 983 | 1.4.1.4.2.9.2.3 | Artefact review (via TMAG) and updates |  | 5d | 2024-02-19 A | 2024-02-23 A | 982 | 100% |  | 2024-02-19 | 2024-02-23 | 5d | 2024-02-19 | 2024-02-23 |  |  |  | SI Test | PP,IPA | SIT | 5.0 |  | Systems Integration Testing (SIT) | SITAG | Complete | COMPLETE |  |  |  |  |
| 984 | 1.4.1.4.2.9.3 | SIT Functional Testing Preparation Complete | milestone | 0d | 2024-03-01 A | 2024-03-01 A | 983FF+5d, 863, 367, 978, 871, 878, 948 | 100% |  | 2024-03-01 | 2024-03-01 | 0d | 2024-03-01 | 2024-03-01 |  |  |  | SI Test | PP,IPA | SIT | 5.0 |  | Systems Integration Testing (SIT) | SITAG | Complete | COMPLETE | T2-TE-0550 | T2 |  |  |
| 985 | 1.4.1.4.3 | **SIT Migration Testing Preparation** |  | 595d? | 2022-10-31 A | 2025-02-07 |  | 97% | 20.18d? | 2022-10-31 | 2024-10-04 | 420d | 2022-11-16 | 2024-06-03 | 749d |  | -0 | N/A | N/A | SIT | 5.21 | N/A | Systems Integration Testing (SIT) | SITAG |  |  |  |  |  |  |
| 986 | 1.4.1.4.3.1 | **Test Approach & Plan** |  | 75d | 2023-09-07 A | 2023-12-20 A |  | 100% |  | 2023-09-07 | 2023-12-20 | 75d | 2023-09-07 | 2023-12-20 |  |  | -0 | N/A | N/A | SIT | 5.0 |  | Systems Integration Testing (SIT) | SITAG |  |  |  |  |  |  |
| 987 | 1.4.1.4.3.1.1 | Develop document with SITWG |  | 32d | 2023-09-07 A | 2023-10-20 A | 2485 | 100% |  | 2023-09-07 | 2023-10-20 | 25d | 2023-09-07 | 2023-10-11 |  | finish no earlier than 2023-10-11 |  | SI Test |  | SIT | 5.0 |  | Systems Integration Testing (SIT) | SITAG | Complete | COMPLETE |  |  |  |  |
| 988 | 1.4.1.4.3.1.2 | Draft document review with Code Bodies |  | 8d | 2023-10-23 A | 2023-11-01 A | 987 | 100% |  | 2023-10-23 | 2023-11-01 | 10d | 2023-10-12 | 2023-10-25 |  |  |  | SI Test | Code Bodies | SIT | 5.0 |  | Systems Integration Testing (SIT) | SITAG | Complete | COMPLETE |  |  |  |  |
| 989 | 1.4.1.4.3.1.3 | Industry Consultation |  | 10d | 2023-11-02 A | 2023-11-15 A | 988 | 100% |  | 2023-11-02 | 2023-11-15 | 10d |  |  |  |  |  | PP |  | SIT | 5.1 |  | Systems Integration Testing (SIT) | SITAG | Complete | COMPLETE |  |  |  |  |
| 990 | 1.4.1.4.3.1.4 | Artefact review (via TMAG) and updates |  | 25d | 2023-11-16 A | 2023-12-20 A | 989 | 100% |  | 2023-11-16 | 2023-12-20 | 30d | 2023-10-26 | 2023-12-20 |  |  |  | SI Test | PP,IPA,Code Bodies | SIT | 5.0 |  | Systems Integration Testing (SIT) | SITAG | Complete | COMPLETE |  |  |  |  |
| 991 | 1.4.1.4.3.1.5 | SIT Migration Testing Test Approach & Plan approved | milestone | 0d | 2023-12-20 A | 2023-12-20 A | 990 | 100% |  | 2023-12-20 | 2023-12-20 | 1d | 2023-12-20 | 2023-12-20 |  | finish no earlier than 2023-12-20 |  | SI Test | PP | SIT | 5.14 |  | Systems Integration Testing (SIT) | SITAG | Complete | COMPLETE | T3-TE-0018 | T3 | MHHS-ART073 |  |
| 992 | 1.4.1.4.3.2 | **Test Data Approach & Plan** |  | 35d | 2023-11-02 A | 2023-12-20 A |  | 100% |  | 2023-11-02 | 2023-12-20 | 35d | 2023-10-26 | 2023-12-20 |  |  | -0 | N/A | N/A | SIT | 5.0 | N/A | Systems Integration Testing (SIT) | SITAG |  |  |  |  |  |  |
| 993 | 1.4.1.4.3.2.1 | Industry Consultation |  | 10d | 2023-11-02 A | 2023-11-15 A | 989SS | 100% |  | 2023-11-02 | 2023-11-15 | 10d |  |  |  |  |  | PP |  | SIT | 5.1 | PP | Systems Integration Testing (SIT) | SITAG | Complete | COMPLETE |  |  |  |  |
| 994 | 1.4.1.4.3.2.2 | Artefact review (via TMAG) and updates |  | 25d | 2023-11-16 A | 2023-12-20 A | 993 | 100% |  | 2023-11-16 | 2023-12-20 | 30d | 2023-10-26 | 2023-12-20 |  |  |  | SI Test Data |  | SIT | 5.0 | Richard Puddephatt | Systems Integration Testing (SIT) | SITAG | Complete | COMPLETE |  |  |  |  |
| 995 | 1.4.1.4.3.2.3 | SIT Migration Test Data Test Approach & Plan approved | milestone | 0d | 2023-12-20 A | 2023-12-20 A | 994 | 100% |  | 2023-12-20 | 2023-12-20 | 0d | 2023-12-20 | 2023-12-20 |  |  |  | SI Test Data | PP,IPA | SIT | 5.14 | Richard Puddephatt | Systems Integration Testing (SIT) | SITAG | Complete | COMPLETE |  |  |  |  |
| 996 | 1.4.1.4.3.3 | **Test scenarios & Test Cases** |  | 297d? | 2023-12-21 A | 2025-02-07 |  | 90% | 31.03d? | 2023-12-21 | 2024-10-04 | 65d | 2023-07-24 | 2024-01-17 | 749d |  | -0 | N/A | N/A | SIT | 5.16 | N/A | Systems Integration Testing (SIT) | SITAG |  |  |  |  |  |  |
| 997 | 1.4.1.4.3.3.1 | **Theme 1** |  | 65d | 2023-12-21 A | 2024-03-20 A |  | 100% |  | 2023-12-21 | 2024-03-20 | 65d |  |  |  |  | -0 | N/A | N/A | SIT | 5.16 | N/A | Systems Integration Testing (SIT) | SITAG |  |  |  |  |  | -448.67 |
| 998 | 1.4.1.4.3.3.1.1 | Develop Test Scenarios & Test Cases |  | 25d | 2023-12-21 A | 2024-01-24 A | 991 | 100% |  | 2023-12-21 | 2024-01-24 | 25d |  |  |  |  |  | SI Test | SI Test, PP | SIT | 5.16 |  |  | SITAG | Complete | COMPLETE |  |  |  |  |
| 999 | 1.4.1.4.3.3.1.2 | Industry Review Workshop |  | 1d | 2024-01-25 A | 2024-01-25 A | 998 | 100% |  | 2024-01-25 | 2024-01-25 | 1d |  |  |  |  |  | SI Test, PP | SI Test, PP | SIT | 5.16 |  |  | SITAG | Complete | COMPLETE |  |  |  |  |
| 1000 | 1.4.1.4.3.3.1.3 | Industry Consultation Review |  | 6d | 2024-02-05 A | 2024-02-12 A | 999FS+6d | 100% |  | 2024-02-05 | 2024-02-12 | 6d |  |  |  |  |  | SI Test, PP | SI Test, PP | SIT | 5.16 |  |  | SITAG | Complete | COMPLETE |  |  |  |  |
| 1001 | 1.4.1.4.3.3.1.4 | Review with SIT Working Group |  | 5d | 2024-02-29 A | 2024-03-06 A | 1000FS+12d | 100% |  | 2024-02-29 | 2024-03-06 | 5d |  |  |  |  |  | SI Test, PP | SI Test, PP | SIT | 5.19 |  |  | SITAG | Complete | COMPLETE |  |  |  |  |
| 1002 | 1.4.1.4.3.3.1.5 | SIT Migration Test scenarios & Test Cases Approved - Theme 1 | milestone | 0d | 2024-03-20 A | 2024-03-20 A | 1001FS+10d | 100% |  | 2024-03-20 | 2024-03-20 | 0d |  |  |  |  |  | SI Test | SI Test, PP | SIT | 5.21 |  | Systems Integration Testing (SIT) | SITAG | Complete | COMPLETE | T3-TE-0110 | T3 |  |  |
| 1003 | 1.4.1.4.3.3.2 | **Theme 2** |  | 85d | 2023-12-21 A | 2024-04-17 A |  | 100% |  | 2023-12-21 | 2024-04-17 | 85d |  |  |  |  | -0 | N/A | N/A | SIT | 5.16 | N/A | Systems Integration Testing (SIT) | SITAG |  |  |  |  |  | -448.67 |
| 1004 | 1.4.1.4.3.3.2.1 | Develop Test Scenarios & Test Cases |  | 40d | 2023-12-21 A | 2024-02-14 A | 991 | 100% |  | 2023-12-21 | 2024-02-14 | 40d |  |  |  |  |  | SI Test | SI Test, PP | SIT | 5.16 |  |  | SITAG | Complete | COMPLETE |  |  |  |  |
| 1005 | 1.4.1.4.3.3.2.2 | Industry Review Workshop |  | 1d | 2024-02-15 A | 2024-02-15 A | 1004 | 100% |  | 2024-02-15 | 2024-02-15 | 1d |  |  |  |  |  | SI Test, PP | SI Test, PP | SIT | 5.16 |  |  | SITAG | Complete | COMPLETE |  |  |  |  |
| 1006 | 1.4.1.4.3.3.2.3 | Industry Consultation Review |  | 6d | 2024-02-26 A | 2024-03-04 A | 1005FS+6d | 100% |  | 2024-02-26 | 2024-03-04 | 6d |  |  |  |  |  | SI Test, PP | SI Test, PP | SIT | 5.19 |  |  | SITAG | Complete | COMPLETE |  |  |  |  |
| 1007 | 1.4.1.4.3.3.2.4 | Review with SIT Working Group |  | 5d | 2024-03-28 A | 2024-04-03 A | 1006FS+17d | 100% |  | 2024-03-28 | 2024-04-03 | 5d |  |  |  |  |  | SI Test, PP | SI Test, PP | SIT | 5.16 |  |  | SITAG | Complete | COMPLETE |  |  |  |  |
| 1008 | 1.4.1.4.3.3.2.5 | SIT Migration Test scenarios & Test Cases Approved - Theme 2 | milestone | 0d | 2024-04-17 A | 2024-04-17 A | 1007FS+10d | 100% |  | 2024-04-17 | 2024-04-17 | 0d |  |  |  |  |  | SI Test | SI Test, PP | SIT | 5.22 |  | Systems Integration Testing (SIT) | SITAG | Complete | COMPLETE | T3-TE-0111 | T3 |  |  |

| ID | WBS | Task | Type | Duration | Start | Finish | Predecessors | Complete | Remaining | Baseline start | Baseline finish | Baseline duration | Total slack | Constraint | Baseline cost | Responsible | Involved | Text9 | Task Status | Update Version | MHHS Resource Name | MHHS Programme Phase | Text29 | Sched Status | RAG | Milestone ID | Tier |
| --- | --- | --- | --- | --- | --- | --- | --- | --- | --- | --- | --- | --- | --- | --- | --- | --- | --- | --- | --- | --- | --- | --- | --- | --- | --- | --- | --- |
| 1009 | 1.4.1.4.3.3.3 | **Theme 3** |  | 85d | 2023-12-21 A | 2024-04-17 A |  | 100% |  | 2023-12-21 | 2024-04-17 | 85d |  |  | -0 | N/A | N/A | SIT | -448.67 | 5.16 | N/A | Systems Integration Testing (SIT) | SITAG |  |  |  |  |
| 1010 | 1.4.1.4.3.3.3.1 | Develop Test Scenarios & Test Cases |  | 55d | 2023-12-21 A | 2024-03-06 A | 991 | 100% |  | 2023-12-21 | 2024-03-06 | 55d |  |  |  | SI Test | SI Test, PP | SIT |  | 5.19 |  |  | SITAG | Complete | COMPLETE |  |  |
| 1011 | 1.4.1.4.3.3.3.2 | Industry Review Workshop |  | 1d | 2024-03-07 A | 2024-03-07 A | 1010 | 100% |  | 2024-03-07 | 2024-03-07 | 1d |  |  |  | SI Test, PP | SI Test, PP | SIT |  | 5.16 |  |  | SITAG | Complete | COMPLETE |  |  |
| 1012 | 1.4.1.4.3.3.3.3 | Industry Consultation Review |  | 6d | 2024-03-13 A | 2024-03-20 A | 1011FS+3d | 100% |  | 2024-03-13 | 2024-03-20 | 6d |  |  |  | SI Test, PP | SI Test, PP | SIT |  | 5.16 |  |  | SITAG | Complete | COMPLETE |  |  |
| 1013 | 1.4.1.4.3.3.3.4 | Review with SIT Working Group |  | 5d | 2024-03-28 A | 2024-04-03 A | 1012FS+5d | 100% |  | 2024-03-28 | 2024-04-03 | 5d |  |  |  | SI Test, PP | SI Test, PP | SIT |  | 5.16 |  |  | SITAG | Complete | COMPLETE |  |  |
| 1014 | 1.4.1.4.3.3.3.5 | SIT Migration Test scenarios & Test Cases Approved - Theme 3 | milestone | 0d | 2024-04-17 A | 2024-04-17 A | 1013FS+10d | 100% |  | 2024-04-17 | 2024-04-17 | 0d |  |  |  | SI Test | SI Test, PP | SIT |  | 5.22 |  | Systems Integration Testing (SIT) | SITAG | Complete | COMPLETE | T3-TE-0112 | T3 |
| 1015 | 1.4.1.4.3.3.4 | **RTTM Development** |  | 17d | 2024-08-29 A | 2024-09-20 A |  | 100% |  | 2024-08-29 | 2024-10-04 | 0d |  |  |  | SI Test |  | SIT | -693.67 | 6.0 | Ankur Pande |  | SITAG |  |  |  |  |
| 1016 | 1.4.1.4.3.3.4.1 | Develop Manual SIT Migration RTTM |  | 17d | 2024-08-29 A | 2024-09-20 A |  | 100% |  | 2024-08-29 | 2024-09-20 | 0d |  | start no earlier than 2024-08-29 |  | SI Test |  | SIT |  | 6.0 | Ankur Pande |  | SITAG | Complete | COMPLETE |  |  |
| 1017 | 1.4.1.4.3.3.4.2 | Manual SIT Migration RTTM Complete | milestone | 0d | 2024-09-20 A | 2024-09-20 A | 1016 | 100% |  | 2024-09-20 | 2024-09-20 | 0d |  |  |  | SI Test |  | SIT |  | 6.0 | Ankur Pande |  | SITAG | Complete | COMPLETE |  |  |
| 1018 | 1.4.1.4.3.3.5 | **Gap analysis** |  | 107d? | 2024-09-12 A | 2025-02-07 |  | 78% | 23.12d? | 2024-09-12 | 2024-10-04 | 0d | 749d |  |  | SI Test |  | SIT | -693.67 | 6.0 | Ankur Pande |  | SITAG |  |  |  |  |
| 1019 | 1.4.1.4.3.3.5.1 | Identify gaps in test case coverage following RTTM review. |  | 12d | 2024-09-12 A | 2024-09-27 A | 1016SS+10d | 100% |  | 2024-09-12 | 2024-09-27 | 0d |  |  |  | SI Test |  | SIT |  | 6.0 | Ankur Pande |  | SITAG | Complete | COMPLETE |  |  |
| 1020 | 1.4.1.4.3.3.5.2 | Address gaps in test case coverage following RTTM review. |  | 17d | 2024-09-19 A | 2024-10-11 A | 1019SS+5d | 100% |  | 2024-09-19 | 2024-10-04 | 0d |  |  |  | SI Test |  | SIT |  | 6.0 | Ankur Pande |  | SITAG | Complete | COMPLETE |  |  |
| 1021 | 1.4.1.4.3.3.5.3 | Gap analysis complete | milestone | 0d? | 2024-10-11 A | 2024-10-11 A | 1020 | 100% |  | 2024-10-04 | 2024-10-04 | 0d |  |  |  | SI Test |  | SIT |  | 6.0 | Ankur Pande |  | SITAG | Complete | COMPLETE |  |  |
| 1022 | 1.4.1.4.3.3.5.4 | Test Script updates identified |  | 1d? | 2024-10-14 A | 2024-10-14 A | 1021 | 100% |  | 2024-10-14 | 2024-10-14 | 0d |  |  |  | SI Test |  | SIT |  | 6.11 | Ankur Pande |  | SITAG | Complete | COMPLETE |  |  |
| 1023 | 1.4.1.4.3.3.5.5 | Test Scripts updates |  | 16d? | 2024-10-14 A | 2024-11-04 A | 1022FS-1d | 100% |  | 2024-10-14 | 2024-11-04 | 0d |  |  |  | SI Test |  | SIT |  | 6.11 | Ankur Pande |  | SITAG | Complete | COMPLETE |  |  |
| 1024 | 1.4.1.4.3.3.5.6 | RTTM Updated |  | 1d? | 2024-10-29 A | 2024-10-29 A | 1023FS-5d | 100% |  | 2024-10-29 | 2024-10-29 | 0d |  |  |  | SI Test |  | SIT |  | 6.11 | Ankur Pande |  | SITAG | Complete | COMPLETE |  |  |
| 1025 | 1.4.1.4.3.3.5.7 | Removal of de-scoped TCs from the RTTMs |  | 2d | 2024-10-31 A | 2024-11-01 A | 1023FS-3d | 100% |  | 2024-10-31 | 2024-11-01 | 0d |  |  |  | SI Test |  | SIT |  | 6.11 | Ankur Pande |  | SITAG | Complete | COMPLETE |  |  |
| 1026 | 1.4.1.4.3.3.5.8 | Update and stabilisation of all TC ADO IDs |  | 2d | 2024-10-31 A | 2024-11-01 A | 1023FS-3d | 100% |  | 2024-10-31 | 2024-11-01 | 0d |  |  |  | SI Test |  | SIT |  | 6.11 | Ankur Pande |  | SITAG | Complete | COMPLETE |  |  |
| 1027 | 1.4.1.4.3.3.5.9 | Addition and integration of Role tags to reqs in the Role RTTMs |  | 3d | 2024-10-30 A | 2024-11-01 A | 1023FS-4d | 100% |  | 2024-10-30 | 2024-11-01 | 0d |  |  |  | SI Test |  | SIT |  | 6.11 | Ankur Pande |  | SITAG | Complete | COMPLETE |  |  |
| 1028 | 1.4.1.4.3.3.5.10 | Update of the RTTM All sheet (porting of the individual RTTMs) |  | 2d | 2024-10-31 A | 2024-11-01 A | 1023FS-3d | 100% |  | 2024-10-31 | 2024-11-01 | 0d |  |  |  | SI Test |  | SIT |  | 6.11 | Ankur Pande |  | SITAG | Complete | COMPLETE |  |  |
| 1029 | 1.4.1.4.3.3.5.11 | ADO IDs corrected |  | 1d? | 2024-11-04 A | 2024-11-04 A | 1028 | 100% |  | 2024-11-04 | 2024-11-04 | 0d |  | start no earlier than 2024-10-16 |  | SI Test |  | SIT |  | 6.11 | Ankur Pande |  | SITAG | Complete | COMPLETE |  |  |
| 1030 | 1.4.1.4.3.3.5.12 | Migration RTTM ready for import into ADO | milestone | 0d | 2024-11-04 A | 2024-11-04 A | 1029 | 100% |  | 2024-11-04 | 2024-11-04 | 0d |  |  |  | SI Test |  | SIT |  | 6.11 | Ankur Pande |  | SITAG | Complete | COMPLETE |  |  |
| 1031 | 1.4.1.4.3.3.5.13 | Issue Static RTTM to Code Bodies |  | 1d? | 2024-11-05 A | 2024-11-05 A | 1030 | 100% |  | 2024-11-05 | 2024-11-05 | 0d |  |  |  | SI Test |  | SIT |  | 6.11 | Ankur Pande |  | SITAG | Complete | COMPLETE |  |  |
| 1032 | 1.4.1.4.3.3.5.14 | Implement Code Bodies feedback on RTTM |  | 6d | 2024-11-06 A | 2024-11-13 A | 1031 | 100% |  | 2024-11-06 | 2024-11-13 | 0d |  |  |  | SI Test |  | SIT |  | 6.12 | Ankur Pande |  | SITAG | Complete | COMPLETE |  |  |
| 1033 | 1.4.1.4.3.3.5.15 | Code Body Acceptance of RTTM | milestone | 0d | 2024-11-13 A | 2024-11-13 A | 1031, 1032 | 100% |  | 2024-11-06 | 2024-11-13 | 0d |  |  |  | SI Test |  | SIT |  | 6.11 | Ankur Pande |  | SITAG | Complete | COMPLETE |  |  |

| ID | WBS | Task | Type | Duration | Start | Finish | Predecessors | Complete | Remaining | Actual start | Baseline start | Baseline finish | Baseline duration | Total slack | Free slack | Constraint | Text9 | Task Status | Update Version | MHHS Resource Name | Text29 | Sched Status | RAG | Responsible | Milestone ID | Tier |
| --- | --- | --- | --- | --- | --- | --- | --- | --- | --- | --- | --- | --- | --- | --- | --- | --- | --- | --- | --- | --- | --- | --- | --- | --- | --- | --- |
| 1034 | 1.4.1.4.3.3.5.16 | **ADO Clean-up** |  | 17d? | 2024-10-24 | 2024-11-15 A |  | 100% |  | 2024-10-25 | 2024-10-24 | 2024-11-15 | 0d |  |  |  | SIT | -727.67 | 6.11 | Heath Thomas | SITAG |  |  |  |  |  |
| 1035 | 1.4.1.4.3.3.5.16.1 | Theme alignment |  | 1d? | 2024-10-28 A | 2024-10-28 A |  | 100% |  |  | 2024-10-28 | 2024-10-28 | 0d |  |  | start no earlier than 2024-10-28 | SIT |  | 6.11 | Heath Thomas | SITAG | Complete | COMPLETE |  |  |  |
| 1036 | 1.4.1.4.3.3.5.16.2 | Understand Additional suffix Fields in ADO as defined by Kevin |  | 1d? | 2024-10-25 A | 2024-10-25 A |  | 100% |  |  | 2024-10-25 | 2024-10-25 | 0d |  |  | finish no earlier than 2024-10-25 | SIT |  | 6.11 | Heath Thomas | SITAG | Complete | COMPLETE |  |  |  |
| 1037 | 1.4.1.4.3.3.5.16.3 | Correct Missing Test Case References |  | 1d? | 2024-10-28 A | 2024-10-28 A |  | 100% |  |  | 2024-10-28 | 2024-10-28 | 0d |  |  | start no earlier than 2024-10-28 | SIT |  | 6.11 | Heath Thomas | SITAG | Complete | COMPLETE |  |  |  |
| 1038 | 1.4.1.4.3.3.5.16.4 | Load Functional RTTMs into ADO |  | 1d? | 2024-10-28 A | 2024-10-28 A |  | 100% |  |  | 2024-10-28 | 2024-10-28 | 0d |  |  | start no earlier than 2024-10-28 | SIT |  | 6.11 | Heath Thomas | SITAG | Complete | COMPLETE |  |  |  |
| 1039 | 1.4.1.4.3.3.5.16.5 | Load Migration RTTMs into ADO |  | 1d? | 2024-11-06 A | 2024-11-06 A |  | 100% |  |  | 2024-11-06 | 2024-11-06 | 0d |  |  | start no earlier than 2024-11-06 | SIT |  | 6.11 | Heath Thomas | SITAG | Complete | COMPLETE |  |  |  |
| 1040 | 1.4.1.4.3.3.5.16.6 | Confirm Missing fields in ADO are resolved |  | 1d? | 2024-11-07 A | 2024-11-07 A |  | 100% |  |  | 2024-11-07 | 2024-11-07 | 0d |  |  | finish no earlier than 2024-11-07 | SIT |  | 6.11 | Heath Thomas | SITAG | Complete | COMPLETE |  |  |  |
| 1041 | 1.4.1.4.3.3.5.16.7 | Reload Functional RTTM into ADO |  | 1d? | 2024-11-07 A | 2024-11-07 A |  | 100% |  |  | 2024-11-07 | 2024-11-07 | 0d |  |  | start no earlier than 2024-11-07 | SIT |  | 6.11 | Heath Thomas | SITAG | Complete | COMPLETE |  |  |  |
| 1042 | 1.4.1.4.3.3.5.16.8 | **ADO Design Documentation** |  | 10d? | 2024-11-04 | 2024-11-15 A |  | 100% |  | 2024-11-15 | 2024-11-04 | 2024-11-15 | 0d |  |  |  | SIT | -727.67 | 6.11 | Heath Thomas | SITAG |  |  |  |  |  |
| 1043 | 1.4.1.4.3.3.5.16.8.1 | Produce ADO high Level Design and Data Model |  | 1d? | 2024-11-15 A | 2024-11-15 A |  | 100% |  |  | 2024-11-15 | 2024-11-15 | 0d |  |  | finish no earlier than 2024-11-15 | SIT |  | 6.11 | Heath Thomas | SITAG | Complete | COMPLETE |  |  |  |
| 1044 | 1.4.1.4.3.3.5.16.8.2 | Produce Report derivation document |  | 1d? | 2024-11-15 A | 2024-11-15 A |  | 100% |  |  | 2024-11-15 | 2024-11-15 | 0d |  |  | finish no earlier than 2024-11-15 | SIT |  | 6.11 | Heath Thomas | SITAG | Complete | COMPLETE |  |  |  |
| 1045 | 1.4.1.4.3.3.5.17 | **Test Case Rationalisation (Functional + Migration)** |  | 67d | 2024-11-07 A | 2025-02-07 |  | 61% | 26.35d |  | 2024-11-07 | 2024-12-20 | 0d | 749d |  |  | SIT | -727.67 | 6.11 | Roger Robar | SITAG |  |  |  |  |  |
| 1046 | 1.4.1.4.3.3.5.17.1 | Internal preliminary rationalisation workshop 1 |  | 1d | 2024-11-07 A | 2024-11-07 A | 1031FS+1d | 100% |  |  | 2024-11-07 | 2024-11-07 | 0d |  |  |  | SIT |  | 6.11 | Roger Robar | SITAG | Complete | COMPLETE |  |  |  |
| 1047 | 1.4.1.4.3.3.5.17.2 | Baseline RTTMs | milestone | 0d | 2024-11-13 A | 2024-11-13 A | 1033, 901 | 100% |  |  | 2024-11-13 | 2024-11-13 | 0d |  |  |  | SIT |  | 6.11 | Roger Robar | SITAG | Complete | COMPLETE |  |  |  |
| 1048 | 1.4.1.4.3.3.5.17.3 | Baseline test cases | milestone | 0d | 2024-11-13 A | 2024-11-13 A | 1033 | 100% |  |  | 2024-11-13 | 2024-11-13 | 0d |  |  |  | SIT |  | 6.11 | Roger Robar | SITAG | Complete | COMPLETE |  |  |  |
| 1049 | 1.4.1.4.3.3.5.17.4 | Produce requirements / test case analysis doc |  | 1d | 2024-11-14 A | 2024-11-14 A | 1048 | 100% |  |  | 2024-11-14 | 2024-11-14 | 0d |  |  |  | SIT |  | 6.11 | Roger Robar | SITAG | Complete | COMPLETE |  |  |  |
| 1050 | 1.4.1.4.3.3.5.17.5 | Internal finalisation rationalisation workshop 2 |  | 13d | 2024-11-15 A | 2024-12-03 A | 1049 | 100% |  |  | 2024-11-15 | 2024-12-03 | 0d |  |  |  | SIT |  | 6.17 | Roger Robar | SITAG | Complete | COMPLETE |  |  |  |
| 1051 | 1.4.1.4.3.3.5.17.6 | SRO walkthrough |  | 1d | 2024-12-04 A | 2024-12-04 A | 1050 | 100% |  |  | 2024-12-04 | 2024-12-04 | 0d |  |  |  | SIT |  | 6.17 | Roger Robar | SITAG | Complete | COMPLETE |  |  |  |
| 1052 | 1.4.1.4.3.3.5.17.7 | Code Bodies walkthrough |  | 1d | 2024-12-04 A | 2024-12-04 A | 1050 | 100% |  |  | 2024-12-04 | 2024-12-04 | 0d |  |  |  | SIT |  | 6.17 | Roger Robar | SITAG | Complete | COMPLETE |  |  |  |
| 1053 | 1.4.1.4.3.3.5.17.8 | Send invites to PPs for walkthrough |  | 1d | 2024-12-04 A | 2024-12-04 A | 1052FS-1d | 100% |  |  | 2024-12-04 | 2024-12-04 | 0d |  |  |  | SIT |  | 6.17 | Roger Robar | SITAG | Complete | COMPLETE |  |  |  |
| 1054 | 1.4.1.4.3.3.5.17.9 | PP walkthrough |  | 1d | 2024-12-17 A | 2024-12-17 A | 1053FS+8d | 100% |  |  | 2024-12-17 | 2024-12-17 | 0d |  |  |  | SIT |  | 6.17 | Roger Robar | SITAG | Complete | COMPLETE |  |  |  |
| 1055 | 1.4.1.4.3.3.5.17.10 | Update requirements / test case analysis doc |  | 29d | 2024-12-05 A | 2025-01-14 A | 1053 | 100% |  |  | 2024-12-05 | 2025-01-14 |  |  |  |  | SIT |  | 6.17 | Roger Robar | SITAG | Complete | COMPLETE |  |  |  |
| 1056 | 1.4.1.4.3.3.5.17.11 | SITWG Paper Day | milestone | 0d | 2025-01-14 A | 2025-01-14 A | 1055 | 100% |  |  | 2025-01-14 | 2025-01-14 | 0d |  |  |  | SIT |  | 6.17 | Roger Robar | SITAG | Complete | COMPLETE |  |  |  |
| 1057 | 1.4.1.4.3.3.5.17.12 | SITWG recommendation on requirements / test case analysis doc | milestone | 0d | 2025-01-21 A | 2025-01-21 A | 1056FS+5d | 100% |  |  | 2025-01-21 | 2025-01-21 | 0d |  |  |  | SIT |  | 6.17 | Roger Robar | SITAG | Complete | COMPLETE |  |  |  |
| 1058 | 1.4.1.4.3.3.5.17.13 | Issue to SITAG / SITAG paper day | milestone | 0d | 2025-01-22 A | 2025-01-22 A | 1057FS+1d | 100% |  |  | 2025-01-22 | 2025-01-22 | 0d |  |  |  | SIT |  | 6.17 | Roger Robar | SITAG | Complete | COMPLETE |  |  |  |
| 1059 | 1.4.1.4.3.3.5.17.14 | Prepare ADO update |  | 6d | 2025-01-22 A | 2025-01-29 A | 1057 | 100% |  |  | 2025-01-22 | 2025-01-29 | 0d |  |  |  | SIT |  | 6.17 | Roger Robar | SITAG | Complete | COMPLETE |  |  |  |
| 1060 | 1.4.1.4.3.3.5.17.15 | Sign off by SITAG | milestone | 0d | 2025-01-29 | 2025-01-29 | 1058FS+5d |  |  |  | 2025-01-29 | 2025-01-29 | 0d | 749d | 0d |  | SIT | 0.71 | 6.17 | Roger Robar | SITAG | Green | GREEN |  |  |  |
| 1061 | 1.4.1.4.3.3.5.17.16 | Update ADO |  | 7d | 2025-01-30 | 2025-02-07 | 1060 |  |  |  | 2025-01-30 | 2025-02-07 | 0d | 749d | 0d |  | SIT | 1.33 | 6.17 | Roger Robar | SITAG | Green | GREEN |  |  |  |
| 1062 | 1.4.1.4.3.3.5.17.17 | Update all ADO reporting |  | 7d | 2025-01-30 | 2025-02-07 | 1060 |  |  |  | 2025-01-30 | 2025-02-07 | 0d | 749d | 0d |  | SIT | 1.33 | 6.17 | Roger Robar | SITAG | Green | GREEN |  |  |  |
| 1063 | 1.4.1.4.3.3.5.17.18 | Update test cases |  | 7d | 2025-01-30 | 2025-02-07 | 1060 |  |  |  | 2025-01-30 | 2025-02-07 |  | 749d | 0d |  | SIT | 1.33 | 6.17 | Roger Robar | SITAG | Green | GREEN |  |  |  |
| 1064 | 1.4.1.4.3.3.5.17.19 | Update RTTM |  | 7d | 2025-01-30 | 2025-02-07 | 1060 |  |  |  | 2025-01-30 | 2025-02-07 |  | 749d | 0d |  | SIT | 1.33 | 6.17 | Roger Robar | SITAG | Green | GREEN |  |  |  |
| 1065 | 1.4.1.4.3.3.5.17.20 | Update master test case spreadsheet |  | 7d | 2025-01-30 | 2025-02-07 | 1060 |  |  |  | 2025-01-30 | 2025-02-07 |  | 749d | 0d |  | SIT | 1.33 | 6.17 | Roger Robar | SITAG | Green | GREEN |  |  |  |
| 1066 | 1.4.1.4.3.3.5.17.21 | Test Case Rationalisation complete | milestone | 0d | 2025-02-07 | 2025-02-07 | 1061, 1062, 1060, 1063, 1064, 1065 |  |  |  | 2025-02-07 | 2025-02-07 | 0d | 749d |  |  | SIT | 9.71 | 6.17 | Roger Robar | SITAG | Green | GREEN | SI Test | T3-TE-0141 | T3 |

Notes:
- 1050: 29/01/25 - SITAG approved an updated Rationalisation plan in January, so this date have been rebaselined.
- 1051: 29/01/25 - SITAG approved an updated Rationalisation plan in January, so this date have been rebaselined.
- 1052: 29/01/25 - SITAG approved an updated Rationalisation plan in January, so this date have been rebaselined.
- 1053: 29/01/25 - SITAG approved an updated Rationalisation plan in January, so this date have been rebaselined.
- 1054: 29/01/25 - SITAG approved an updated Rationalisation plan in January, so this date have been rebaselined.
- 1055: 29/01/25 - SITAG approved an updated Rationalisation plan in January, so this date have been rebaselined.
- 1056: 29/01/25 - SITAG approved an updated Rationalisation plan in January, so this date have been rebaselined.
- 1057: 29/01/25 - SITAG approved an updated Rationalisation plan in January, so this date have been rebaselined.
- 1058: 29/01/25 - SITAG approved an updated Rationalisation plan in January, so this date have been rebaselined.
- 1059: 29/01/25 - SITAG approved an updated Rationalisation plan in January, so this date have been rebaselined.
- 1060: 29/01/25 - SITAG approved an updated Rationalisation plan in January, so this date have been rebaselined. SITAG also signed off the rationalisation doc, closing this milestone.
- 1061: 29/01/25 - SITAG approved an updated Rationalisation plan in January, so this date have been rebaselined.
- 1062: 29/01/25 - SITAG approved an updated Rationalisation plan in January, so this date have been rebaselined.
- 1063: 29/01/25 - SITAG approved an updated Rationalisation plan in January, so this date have been rebaselined.
- 1064: 29/01/25 - SITAG approved an updated Rationalisation plan in January, so this date have been rebaselined.
- 1065: 29/01/25 - SITAG approved an updated Rationalisation plan in January, so this date have been rebaselined.
- 1066: 29/01/25 - SITAG approved an updated Rationalisation plan in January, so this date have been rebaselined.

| ID | WBS | Task | Type | Duration | Start | Finish | Predecessors | Complete | Remaining | Baseline start | Baseline finish | Baseline duration | Baseline 1 start | Baseline 1 finish | Total slack | Constraint | Baseline cost | Responsible | Involved | Text9 | Update Version | MHHS Resource Name | MHHS Programme Phase | Text29 | Sched Status | RAG | Milestone ID | Tier | Artefact ID | Guidance |
| --- | --- | --- | --- | --- | --- | --- | --- | --- | --- | --- | --- | --- | --- | --- | --- | --- | --- | --- | --- | --- | --- | --- | --- | --- | --- | --- | --- | --- | --- | --- |
| 1067 | 1.4.1.4.3.4 | **Environments (SIT B)** |  | 435d | 2022-10-31 A | 2024-06-28 A |  | 100% |  | 2022-10-31 | 2024-06-28 | 420d | 2022-11-16 | 2024-05-13 |  |  | -0 | N/A | N/A | SIT | 5.0 | N/A | Systems Integration Testing (SIT) | SITAG |  |  |  |  |  |  |
| 1068 | 1.4.1.4.3.4.1 | **PP Environments (SIT B)** |  | 41d | 2024-05-03 A | 2024-06-28 A |  | 100% |  | 2024-05-03 | 2024-06-28 | 26d | 2022-11-16 | 2024-05-13 |  |  | -0 | N/A | N/A | SIT | 5.0 | N/A | Systems Integration Testing (SIT) | SITAG |  |  |  |  |  |  |
| 1069 | 1.4.1.4.3.4.1.1 | PP Environments available | milestone | 0d | 2024-05-03 A | 2024-05-03 A | 538 | 100% |  | 2024-05-03 | 2024-05-03 | 0d | 2022-11-16 | 2024-04-01 |  | start no earlier than 2024-05-03 |  | PP | SI Test | SIT | 5.21 | Simon Berry | Systems Integration Testing (SIT) | SITAG | Complete | COMPLETE |  |  |  |  |
| 1070 | 1.4.1.4.3.4.1.2 | PP Onboarding / Smoke test |  | 35d | 2024-05-13 A | 2024-06-28 A | 1069FS+6d | 100% |  | 2024-05-13 | 2024-06-28 | 20d | 2022-11-16 | 2024-04-01 |  |  |  | PP | SI Test | SIT | 5.21 | Simon Berry | Systems Integration Testing (SIT) | SITAG | Complete | COMPLETE |  |  |  |  |
| 1071 | 1.4.1.4.3.4.1.3 | DTN Connectivity Proving Complete |  | 5d | 2024-06-10 A | 2024-06-14 A | 1069FS+26d | 100% |  | 2024-06-10 | 2024-06-14 | 0d | 2024-04-15 | 2024-04-26 |  |  |  | PP | SI Test | SIT | 5.21 | Simon Berry | Systems Integration Testing (SIT) | SITAG | Complete | COMPLETE |  |  |  |  |
| 1072 | 1.4.1.4.3.4.1.4 | PP Code Deployment | milestone | 0d | 2024-06-14 A | 2024-06-14 A | 1071 | 100% |  | 2024-06-14 | 2024-06-14 | 0d | 2024-04-29 | 2024-05-13 |  |  |  | PP | SI Test | SIT | 5.21 | Simon Berry | Systems Integration Testing (SIT) | SITAG | Complete | COMPLETE |  |  |  |  |
| 1073 | 1.4.1.4.3.4.2 | **SI Environments (SIT B)** |  | 425d | 2022-10-31 A | 2024-06-14 A |  | 100% |  | 2022-10-31 | 2024-06-14 | 420d | 2022-11-16 | 2024-05-10 |  |  | -0 | N/A | N/A | SIT | 5.0 | N/A | Systems Integration Testing (SIT) | SITAG |  |  |  |  |  |  |
| 1074 | 1.4.1.4.3.4.2.1 | Coordinate SIT Participants' SIT B environment preparation |  | 420d | 2022-10-31 A | 2024-06-07 A |  | 100% |  | 2022-10-31 | 2024-06-07 | 420d | 2022-11-16 | 2024-04-01 |  |  |  | SI Test | PP | SIT | 5.21 | Simon Berry | Systems Integration Testing (SIT) | SITAG | Complete | COMPLETE |  |  |  |  |
| 1075 | 1.4.1.4.3.4.2.2 | Assure PPs' self-declaration of environment preparation complete (incl. security certificates and security compliance) | milestone | 0d | 2024-06-07 A | 2024-06-07 A | 1074 | 100% |  | 2024-06-07 | 2024-06-07 | 0d | 2022-11-16 | 2024-03-29 |  |  |  | SI Test | PP | SIT | 5.21 | Simon Berry | Systems Integration Testing (SIT) | SITAG | Complete | COMPLETE |  |  |  |  |
| 1076 | 1.4.1.4.3.4.2.3 | SIT Participants' SIT B environments ready to start connectivity proving (incl. certificates and security compliance) | milestone | 0d | 2024-06-05 A | 2024-06-05 A | 1069FS+24d | 100% |  | 2024-06-05 | 2024-06-05 | 0d | 2024-04-01 | 2024-04-01 |  |  |  | SI Test | PP,IPA | SIT | 5.26 | Simon Berry | Systems Integration Testing (SIT) | SITAG | Complete | COMPLETE | T3-TE-0033 | T3 |  |  |
| 1077 | 1.4.1.4.3.4.2.4 | Coordinate SIT Participants' SIT B environment connectivity proving |  | 2d | 2024-06-06 A | 2024-06-07 A | 1076 | 100% |  | 2024-06-06 | 2024-06-07 | 19d | 2024-04-01 | 2024-04-26 |  |  |  | SI Test | PP | SIT | 5.21 | Simon Berry | Systems Integration Testing (SIT) | SITAG | Complete | COMPLETE |  |  |  |  |
| 1078 | 1.4.1.4.3.4.2.5 | Coordinate deployment of MHHS solution code to SIT Participants' SIT B environments | milestone | 0d | 2024-06-14 A | 2024-06-14 A | 1072 | 100% |  | 2024-06-14 | 2024-06-14 | 4d | 2024-04-15 | 2024-04-26 |  |  |  | SI Test | PP | SIT | 5.21 | Simon Berry | Systems Integration Testing (SIT) | SITAG | Complete | COMPLETE |  |  |  |  |
| 1079 | 1.4.1.4.3.5 | **SIT Migration Test Readiness Report** |  | 44d | 2024-04-02 A | 2024-05-31 A |  | 100% |  | 2024-04-02 | 2024-05-31 | 44d | 2024-04-02 | 2024-05-27 |  |  | -0 | N/A | N/A | SIT | 5.0 | N/A | Systems Integration Testing (SIT) | SITAG |  |  |  |  |  |  |
| 1080 | 1.4.1.4.3.5.1 | **PP SIT Migration Test Readiness Report** |  | 44d | 2024-04-02 A | 2024-05-31 A |  | 100% |  | 2024-04-02 | 2024-05-31 | 44d | 2024-04-02 | 2024-05-13 |  |  | -0 | N/A | N/A | SIT | 5.0 | N/A | Systems Integration Testing (SIT) | SITAG |  |  |  |  |  |  |
| 1081 | 1.4.1.4.3.5.1.1 | Develop draft Test Readiness Report and submit to Programme for assurance |  | 20d | 2024-04-02 A | 2024-04-29 A |  | 100% |  | 2024-04-02 | 2024-04-29 | 20d | 2024-04-02 | 2024-04-30 |  | start no earlier than 2024-04-02 |  | PP | SI Test | SIT | 5.0 |  | Systems Integration Testing (SIT) | SITAG | Complete | COMPLETE |  |  |  |  |
| 1082 | 1.4.1.4.3.5.1.2 | Placing Reliance Stage 2 Review |  | 35d | 2024-04-15 A | 2024-05-31 A | 1081SS+9d | 100% |  | 2024-04-15 | 2024-05-31 | 35d |  |  |  |  |  | SI Test | PP | SIT | 5.12 |  | Systems Integration Testing (SIT) | SITAG | Complete | COMPLETE |  |  |  |  |
| 1083 | 1.4.1.4.3.5.1.3 | Finalise Test Readiness Report and submit to Programme for assurance |  | 10d | 2024-04-30 A | 2024-05-13 A | 1081 | 100% |  | 2024-04-30 | 2024-05-13 | 10d | 2024-04-30 | 2024-05-13 |  |  |  | PP | SI Test | SIT | 5.0 |  | Systems Integration Testing (SIT) | SITAG | Complete | COMPLETE |  |  |  |  |
| 1084 | 1.4.1.4.3.5.2 | **SI SIT Migration Test Readiness Report** |  | 40d | 2024-04-02 A | 2024-05-27 A |  | 100% |  | 2024-04-02 | 2024-05-27 | 40d | 2024-04-02 | 2024-05-27 |  |  |  | N/A | N/A | SIT | 5.0 | N/A | Systems Integration Testing (SIT) | SITAG |  |  |  |  |  |  |
| 1085 | 1.4.1.4.3.5.2.1 | Assure Test Participants' Test Readiness Reports |  | 35d | 2024-04-02 A | 2024-05-20 A | 1081SS, 1083FF+5d | 100% |  | 2024-04-02 | 2024-05-20 | 35d | 2024-04-02 | 2024-05-20 |  |  |  | SI Test | PP,IPA | SIT | 5.0 |  | Systems Integration Testing (SIT) | SITAG | Complete | COMPLETE |  |  |  |  |
| 1086 | 1.4.1.4.3.5.2.2 | Develop Overarching SIT Migration Test Readiness Report |  | 20d | 2024-04-23 A | 2024-05-20 A | 1085FF | 100% |  | 2024-04-23 | 2024-05-20 | 20d | 2024-04-23 | 2024-05-20 |  |  |  | SI Test |  | SIT | 5.0 |  | Systems Integration Testing (SIT) | SITAG | Complete | COMPLETE |  |  |  |  |
| 1087 | 1.4.1.4.3.5.2.3 | Artefact review (via SITAG) and updates |  | 5d | 2024-05-21 A | 2024-05-27 A | 1086 | 100% |  | 2024-05-21 | 2024-05-27 | 5d | 2024-05-21 | 2024-05-27 |  |  |  | SI Test | PP,IPA | SIT | 5.0 |  | Systems Integration Testing (SIT) | SITAG | Complete | COMPLETE |  |  |  |  |
| 1088 | 1.4.1.4.3.6 | SIT Migration Testing Preparation Complete | milestone | 0d | 2024-06-03 A | 2024-06-03 A | 1087FF+5d, 991, 384, 1082, 1002, 1008, 1014 | 100% |  | 2024-06-03 | 2024-06-03 | 0d | 2024-06-03 | 2024-06-03 |  |  |  | SI Test | PP,IPA | SIT | 5.0 |  | Systems Integration Testing (SIT) | SITAG | Complete | COMPLETE | T2-TE-0650 | T2 |  |  |
| 1089 | 1.4.1.4.4 | **SIT Non-Functional Preparation** |  | 347d? | 2023-11-30 A | 2025-03-28 |  | 85% | 52.8d? | 2023-11-30 | 2025-03-14 | 193d | 2023-07-03 | 2024-08-26 | 714d |  | -0 | N/A | N/A | SIT | 5.0 | N/A | Systems Integration Testing (SIT) | SITAG |  |  |  |  |  |  |
| 1090 | 1.4.1.4.4.1 | **Test Approach & Plan** |  | 120d | 2023-11-30 A | 2024-05-15 A |  | 100% |  | 2023-11-30 | 2024-05-15 | 120d | 2023-11-30 | 2024-03-20 |  |  | -0 | N/A | N/A | SIT | 5.0 | N/A | Systems Integration Testing (SIT) | SITAG |  |  |  |  |  |  |
| 1091 | 1.4.1.4.4.1.1 | Develop document with SITWG |  | 67d | 2023-11-30 A | 2024-03-01 A |  | 100% |  | 2023-11-30 | 2024-03-01 | 67d | 2023-11-30 | 2024-01-10 |  | must start on 2023-11-30 |  | SI Test |  | SIT | 5.0 |  | Systems Integration Testing (SIT) | SITAG | Complete | COMPLETE |  |  |  |  |
| 1092 | 1.4.1.4.4.1.2 | Draft document review with Code Bodies |  | 10d | 2024-03-04 A | 2024-03-15 A | 1091 | 100% |  | 2024-03-04 | 2024-03-15 | 10d | 2024-01-11 | 2024-01-24 |  |  |  | SI Test | Code Bodies | SIT | 5.0 |  | Systems Integration Testing (SIT) | SITAG | Complete | COMPLETE |  |  |  |  |
| 1093 | 1.4.1.4.4.1.3 | Industry Consultation |  | 10d | 2024-03-18 A | 2024-03-29 A | 1092 | 100% |  | 2024-03-18 | 2024-03-29 | 10d |  |  |  |  |  | PP |  | SIT | 5.1 |  | Systems Integration Testing (SIT) | SITAG | Complete | COMPLETE |  |  |  |  |
| 1094 | 1.4.1.4.4.1.4 | Industry Assurance Review |  | 5d | 2024-04-11 A | 2024-04-17 A | 1093FS+8d | 100% |  | 2024-04-11 | 2024-04-17 | 5d |  |  |  |  |  |  |  | SIT | 5.16 |  |  | SITAG | Complete | COMPLETE |  |  |  |  |
| 1095 | 1.4.1.4.4.1.5 | SIT Non-Functional Testing Test Approach & Plan approved | milestone | 0d | 2024-05-15 A | 2024-05-15 A | 1094FS+20d | 100% |  | 2024-05-15 | 2024-05-15 | 0d | 2024-03-20 | 2024-03-20 |  |  |  | SI Test | PP | SIT | 5.30 | Roger Robar | Systems Integration Testing (SIT) | SITAG | Complete | COMPLETE | T3-TE-0026 | T3 | MHHS-ART073 | 30/7/24: Approved at esitag on 26/7/24 |

| ID | WBS | Task | Type | Duration | Start | Finish | Predecessors | Complete | Remaining | Actual finish | Baseline start | Baseline finish | Baseline duration | Baseline 1 start | Baseline 1 finish | Constraint | Baseline cost | Responsible | Involved | Text9 | Update Version | MHHS Resource Name | MHHS Programme Phase | Text29 | Sched Status | RAG | Milestone ID | Tier | Task Status | Guidance |
| --- | --- | --- | --- | --- | --- | --- | --- | --- | --- | --- | --- | --- | --- | --- | --- | --- | --- | --- | --- | --- | --- | --- | --- | --- | --- | --- | --- | --- | --- | --- |
| 1096 | 1.4.1.4.4.2 | **Test Data Approach & Plan** |  | 41d | 2024-03-20 A | 2024-05-15 A |  | 100% |  |  | 2024-03-20 | 2024-05-15 | 41d | 2024-01-25 | 2024-03-20 |  | -0 | N/A | N/A | SIT | 5.0 | N/A | Systems Integration Testing (SIT) | SITAG |  |  |  |  |  |  |
| 1097 | 1.4.1.4.4.2.1 | Industry Consultation |  | 14d | 2024-03-20 A | 2024-04-08 A | 1093SS+2d | 100% |  |  | 2024-03-20 | 2024-04-08 | 14d |  |  |  |  | PP |  | SIT | 5.1 | Richard Puddephatt | Systems Integration Testing (SIT) | SITAG | Complete | COMPLETE |  |  |  |  |
| 1098 | 1.4.1.4.4.2.2 | Artefact review (via SITAG) and updates |  | 27d | 2024-04-09 A | 2024-05-15 A | 1097 | 100% |  |  | 2024-04-09 | 2024-05-15 | 27d | 2024-01-25 | 2024-03-13 |  |  | SI Test |  | SIT | 5.0 | Richard Puddephatt | Systems Integration Testing (SIT) | SITAG | Complete | COMPLETE |  |  |  |  |
| 1099 | 1.4.1.4.4.2.3 | SIT Non-Functional Testing Test Data Approach & Plan approved | milestone | 0d | 2024-05-15 A | 2024-05-15 A | 1095FF, 1098 | 100% |  |  | 2024-05-15 | 2024-05-15 | 0d | 2024-03-20 | 2024-03-20 |  |  | SI Test | PP,IPA | SIT | 5.24 | Richard Puddephatt | Systems Integration Testing (SIT) | SITAG | Complete | COMPLETE | T3-TE-0113 | T3 |  |  |
| 1100 | 1.4.1.4.4.3 | **Test scenarios & Test Cases** |  | 98d? | 2024-03-04 A | 2024-07-17 |  | 99% | 0d? |  | 2024-03-04 | 2024-07-17 | 123d | 2023-07-24 | 2024-01-17 |  | -0 | N/A | N/A | SIT | 5.21 | N/A | Systems Integration Testing (SIT) | SITAG |  |  |  |  |  |  |
| 1101 | 1.4.1.4.4.3.1 | **Theme 1** |  | 78d | 2024-03-04 A | 2024-06-19 A |  | 100% |  |  | 2024-03-04 | 2024-06-19 | 78d |  |  |  | -0 | N/A | N/A | SIT | 5.21 | N/A | Systems Integration Testing (SIT) | SITAG |  |  |  |  | -448.67 |  |
| 1102 | 1.4.1.4.4.3.1.1 | Develop Test Scenarios & Test Cases |  | 33d | 2024-03-04 A | 2024-04-17 A | 1091 | 100% |  |  | 2024-03-04 | 2024-04-17 | 33d |  |  |  |  | SI Test | SI Test, PP | SIT | 5.21 |  |  | SITAG | Complete | COMPLETE |  |  |  |  |
| 1103 | 1.4.1.4.4.3.1.2 | Industry Review Workshop |  | 1d | 2024-04-18 A | 2024-04-18 A | 1102 | 100% |  |  | 2024-04-18 | 2024-04-18 | 1d |  |  |  |  | SI Test, PP | SI Test, PP | SIT | 5.21 |  |  | SITAG | Complete | COMPLETE |  |  |  |  |
| 1104 | 1.4.1.4.4.3.1.3 | Industry Consultation Review |  | 7d | 2024-05-02 A | 2024-05-10 A | 1103FS+9d | 100% |  |  | 2024-05-02 | 2024-05-10 | 7d |  |  |  |  | SI Test, PP | SI Test, PP | SIT | 5.21 |  |  | SITAG | Complete | COMPLETE |  |  |  |  |
| 1105 | 1.4.1.4.4.3.1.4 | Review with NFT Working Group |  | 5d | 2024-05-31 A | 2024-06-06 A | 1104FS+14d | 100% |  |  | 2024-05-31 | 2024-06-06 | 5d |  |  |  |  | SI Test, PP | SI Test, PP | SIT | 5.21 |  |  | SITAG | Complete | COMPLETE |  |  |  |  |
| 1106 | 1.4.1.4.4.3.1.5 | SIT NFT Scenarios & Test Cases Approved - Theme 1 | milestone | 0d | 2024-06-19 A | 2024-06-19 A | 1105FS+9d | 100% |  |  | 2024-06-19 | 2024-06-19 | 0d |  |  |  |  | SI Test | SI Test, PP | SIT | 5.30 | Roger Robar | Systems Integration Testing (SIT) | SITAG | Complete | COMPLETE | T3-TE-0114 | T3 |  | 30/7/24: Approved at esitag on 26/7/24 |
| 1107 | 1.4.1.4.4.3.2 | **Theme 2** |  | 98d | 2024-03-04 A | 2024-07-17 A |  | 100% |  |  | 2024-03-04 | 2024-07-17 | 98d |  |  |  |  | N/A | N/A | SIT | 5.21 | N/A | Systems Integration Testing (SIT) | SITAG |  |  |  |  | -448.67 |  |
| 1108 | 1.4.1.4.4.3.2.1 | Develop Test Scenarios & Test Cases |  | 53d | 2024-03-04 A | 2024-05-15 A | 1091 | 100% |  |  | 2024-03-04 | 2024-05-15 | 53d |  |  |  |  | SI Test | SI Test, PP | SIT | 5.21 |  |  | SITAG | Complete | COMPLETE |  |  |  |  |
| 1109 | 1.4.1.4.4.3.2.2 | Industry Review Workshop |  | 1d | 2024-05-16 A | 2024-05-16 A | 1108 | 100% |  |  | 2024-05-16 | 2024-05-16 | 1d |  |  |  |  | SI Test, PP | SI Test, PP | SIT | 5.21 |  |  | SITAG | Complete | COMPLETE |  |  |  |  |
| 1110 | 1.4.1.4.4.3.2.3 | Industry Consultation Review |  | 7d | 2024-05-20 A | 2024-05-28 A | 1109FS+1d | 100% |  |  | 2024-05-20 | 2024-05-28 | 7d |  |  |  |  | SI Test, PP | SI Test, PP | SIT | 5.21 |  |  | SITAG | Complete | COMPLETE |  |  |  |  |
| 1111 | 1.4.1.4.4.3.2.4 | Review with NFT Working Group |  | 5d | 2024-06-28 A | 2024-07-04 A | 1110FS+22d | 100% |  |  | 2024-06-28 | 2024-07-04 | 5d |  |  |  |  | SI Test, PP | SI Test, PP | SIT | 5.21 |  |  | SITAG | Complete | COMPLETE |  |  |  |  |
| 1112 | 1.4.1.4.4.3.2.5 | SIT NFT Scenarios & Test Cases Approved - Theme 2 | milestone | 0d | 2024-07-17 A | 2024-07-17 A | 1111FS+9d | 100% |  |  | 2024-07-17 | 2024-07-17 | 0d |  |  |  |  | SI Test | SI Test, PP | SIT | 5.22 |  | Systems Integration Testing (SIT) | SITAG | Complete | COMPLETE | T3-TE-0115 | T3 |  |  |
| 1113 | 1.4.1.4.4.3.3 | **Theme 3** |  | 98d? | 2024-03-04 A | 2024-07-17 |  | 100% |  | 2024-09-18 | 2024-03-04 | 2024-07-17 | 123d |  |  |  | -0 | N/A | N/A | SIT | 6.0 | N/A | Systems Integration Testing (SIT) | SITAG |  |  |  |  | -448.67 |  |
| 1114 | 1.4.1.4.4.3.3.1 | Develop Test Scenarios & Test Cases |  | 63d | 2024-03-04 A | 2024-05-29 A | 1091 | 100% |  |  | 2024-03-04 | 2024-05-29 | 63d |  |  |  |  | SI Test | SI Test, PP | SIT | 6.0 |  |  | SITAG | Complete | COMPLETE |  |  |  |  |
| 1115 | 1.4.1.4.4.3.3.2 | Industry Review Workshop |  | 1d | 2024-05-30 A | 2024-05-30 A | 1114 | 100% |  |  | 2024-05-30 | 2024-05-30 | 1d |  |  |  |  | SI Test, PP | SI Test, PP | SIT | 6.0 |  |  | SITAG | Complete | COMPLETE |  |  |  |  |
| 1116 | 1.4.1.4.4.3.3.3 | Industry Consultation Review |  | 6d | 2024-06-10 A | 2024-06-17 A | 1115FS+6d | 100% |  |  | 2024-06-10 | 2024-06-17 | 6d |  |  |  |  | SI Test, PP | SI Test, PP | SIT | 6.0 |  |  | SITAG | Complete | COMPLETE |  |  |  |  |
| 1117 | 1.4.1.4.4.3.3.4 | Review with NFT Working Group |  | 5d | 2024-06-28 A | 2024-07-04 A | 1116FS+8d | 100% |  |  | 2024-06-28 | 2024-07-04 | 30d |  |  |  |  | SI Test, PP | SI Test, PP | SIT | 6.0 | Roger Robar |  | SITAG | Complete | COMPLETE |  |  |  |  |
| 1118 | 1.4.1.4.4.3.3.5 | SIT NFT Scenarios & Test Cases Approved - Theme 3 | milestone | 0d | 2024-09-18 A | 2024-09-18 A | 1117FS+9d | 100% |  |  | 2024-09-18 | 2024-09-18 | 0d |  |  | start no earlier than 2024-09-18 |  | SI Test | SI Test, PP | SIT | 5.30 | Roger Robar | Systems Integration Testing (SIT) | SITAG | Complete | COMPLETE | T3-TE-0116 | T3 |  | 31/7/24: baseline date change approved at esitag on 26/7/24 |
| 1119 | 1.4.1.4.4.3.4 | **SIT NFT Programme RTTM** |  | 45d | 2024-09-18 A | 2024-11-19 A |  | 100% |  |  | 2024-09-18 | 2024-10-16 | 0d |  |  |  |  |  |  | SIT | 6.11 | David O'Riordan |  | SITAG |  |  |  |  | -197.67 |  |
| 1120 | 1.4.1.4.4.3.4.1 | Develop Manual SIT NFT RTTM |  | 30d | 2024-09-18 A | 2024-10-29 A | 1118 | 100% |  |  | 2024-09-18 | 2024-10-29 | 0d |  |  |  |  |  |  | SIT | 6.11 | David O'Riordan |  | SITAG | Complete | COMPLETE |  |  |  |  |
| 1121 | 1.4.1.4.4.3.4.2 | LDP peer review |  | 10d | 2024-10-30 A | 2024-11-12 A | 1120 | 100% |  |  | 2024-10-30 | 2024-11-12 | 0d |  |  |  |  |  |  | SIT | 6.11 | David O'Riordan |  | SITAG | Complete | COMPLETE |  |  |  |  |
| 1122 | 1.4.1.4.4.3.4.3 | Review with SRO |  | 5d | 2024-11-13 A | 2024-11-19 A | 1121 | 100% |  |  | 2024-11-13 | 2024-11-19 | 0d |  |  |  |  |  |  | SIT | 6.11 | David O'Riordan |  | SITAG | Complete | COMPLETE |  |  |  |  |
| 1123 | 1.4.1.4.4.3.4.4 | DIP Manager / Code Bodies / Full SRO to review |  | 5d | 2024-11-13 A | 2024-11-19 A | 1121 | 100% |  |  | 2024-11-13 | 2024-11-19 | 0d |  |  |  |  |  |  | SIT | 6.12 | David O'Riordan |  | SITAG | Complete | COMPLETE |  |  |  |  |
| 1124 | 1.4.1.4.4.3.4.5 | DIP Manager / Code Bodies / Full SRO acceptance of RTTM | milestone | 0d | 2024-11-19 A | 2024-11-19 A | 1123 | 100% |  |  | 2024-11-19 | 2024-11-19 | 0d |  |  |  |  |  |  | SIT | 6.16 | David O'Riordan |  | SITAG | Complete | COMPLETE |  |  |  |  |
| 1125 | 1.4.1.4.4.3.4.6 | Manual SIT NFT RTTM Complete | milestone | 0d | 2024-11-19 A | 2024-11-19 A | 1122, 1123 | 100% |  |  | 2024-11-19 | 2024-11-19 | 0d |  |  |  |  |  |  | SIT | 6.11 | David O'Riordan |  | SITAG | Complete | COMPLETE |  |  |  |  |

| ID | WBS | Task | Type | Duration | Start | Finish | Predecessors | Complete | Remaining | Baseline start | Baseline finish | Baseline duration | Baseline 1 start | Baseline 1 finish | Total slack | Free slack | Constraint | Baseline cost | Responsible | Text9 | Task Status | Update Version | Sched Status | MHHS Resource Name | Text29 | RAG | Involved | MHHS Programme Phase | Action | Milestone ID | Tier |
| --- | --- | --- | --- | --- | --- | --- | --- | --- | --- | --- | --- | --- | --- | --- | --- | --- | --- | --- | --- | --- | --- | --- | --- | --- | --- | --- | --- | --- | --- | --- | --- |
| 1126 | 1.4.1.4.4.3.5 | **NFT (Theme 1, 2 and 3) DITL** |  | 18d | 2025-02-03 A | 2025-02-26 |  | 99% | 0d | 2024-10-08 | 2024-10-17 | 0d |  |  | 736d |  |  |  | SI Test | SIT | 6.33 | 6.15 | No BL | David O'Riordan | SITAG |  |  |  |  |  |  |
| 1127 | 1.4.1.4.4.3.5.1 | DITL Development |  | 10d | 2025-02-03 A | 2025-02-14 A |  | 100% |  | 2025-02-03 | 2025-02-14 | 0d |  |  |  |  | start no earlier than 2025-02-03 |  | SI Test | SIT |  | 6.15 | Complete | David O'Riordan | SITAG | COMPLETE |  |  |  |  |  |
| 1128 | 1.4.1.4.4.3.5.2 | SRO Review |  | 5d | 2025-02-17 A | 2025-02-21 A | 1127 | 100% |  | 2025-02-17 | 2025-02-21 | 0d |  |  |  |  |  |  | SI Test | SIT |  | 6.15 | Complete | David O'Riordan | SITAG | COMPLETE |  |  |  |  |  |
| 1129 | 1.4.1.4.4.3.5.3 | Post-SRO Review Changes |  | 3d | 2025-02-24 A | 2025-02-26 A | 1128 | 100% |  | 2025-02-24 | 2025-02-26 | 0d |  |  |  |  |  |  | SI Test | SIT |  | 6.15 | Complete | David O'Riordan | SITAG | COMPLETE |  |  |  |  |  |
| 1130 | 1.4.1.4.4.3.5.4 | Programme DITL walkthrough with PPs on Theme 1, 2 and 3 | milestone | 0d | 2025-02-26 | 2025-02-26 | 1129 |  |  | 2025-02-26 | 2025-02-26 | 0d |  |  | 736d |  |  |  | SI Test | SIT | 28.71 | 6.15 | Green | David O'Riordan | SITAG | GREEN |  |  |  |  |  |
| 1131 | 1.4.1.4.4.3.6 | **NFT Performance Tool Theme 1 Setup** |  | 268d? | 2024-03-04 A | 2025-03-12 A |  | 100% |  | 2024-03-04 | 2025-01-10 | 0d |  |  |  |  |  |  |  | SIT | -205.67 | 6.1 |  | David O'Riordan | SITAG |  |  |  |  |  |  |
| 1132 | 1.4.1.4.4.3.6.1 | Theme 1 injection tool initial POC |  | 85d? | 2024-03-04 A | 2024-06-28 A |  | 100% |  | 2024-03-04 | 2024-06-28 | 0d |  |  |  |  |  |  |  | SIT |  | 6.1 | Complete | David O'Riordan | SITAG | COMPLETE |  |  |  |  |  |
| 1133 | 1.4.1.4.4.3.6.2 | Theme 1 injection tool configuration and validation against DIP SIM (IR7.1) |  | 38d | 2024-07-01 A | 2024-08-21 A | 1132 | 100% |  | 2024-07-01 | 2024-08-21 | 0d |  |  |  |  |  |  |  | SIT |  | 6.1 | Complete | David O'Riordan | SITAG | COMPLETE |  |  |  |  |  |
| 1134 | 1.4.1.4.4.3.6.3 | Theme 1 injection tool configuration and validation against DIP SIM (IR8.1) |  | 29d | 2024-08-22 A | 2024-10-01 A | 1133 | 100% |  | 2024-08-22 | 2024-10-01 | 0d |  |  |  |  |  |  |  | SIT |  | 6.1 | Complete | David O'Riordan | SITAG | COMPLETE |  |  |  |  |  |
| 1135 | 1.4.1.4.4.3.6.4 | Theme 1 injection tool configuration and validation againast UIT DIP (IR8.1) |  | 11d | 2024-10-02 A | 2024-10-16 A | 1134 | 100% |  | 2024-10-02 | 2024-10-16 | 0d |  |  |  |  |  |  |  | SIT |  | 6.1 | Complete | David O'Riordan | SITAG | COMPLETE |  |  |  |  |  |
| 1136 | 1.4.1.4.4.3.6.5 | Theme 1 injection tool configuration and validation against SIT-B DIP (IR8.4) |  | 3d? | 2025-03-10 A | 2025-03-12 A | 1557FS+10d | 100% |  | 2025-01-06 | 2025-01-08 | 0d |  |  |  |  |  |  |  | SIT |  | 6.1 | Complete | David O'Riordan | SITAG | COMPLETE |  |  |  |  |  |
| 1137 | 1.4.1.4.4.4 | **Environments (SIT B)** |  | 134d | 2024-08-27 A | 2025-02-28 |  |  | 134d | 2024-08-27 | 2025-01-03 | 0d | 2024-07-30 | 2024-08-05 | 20d |  |  | -0 | N/A | SIT |  | 5.0 |  | Heath Thomas | SITAG |  | N/A | Systems Integration Testing (SIT) |  |  |  |
| 1138 | 1.4.1.4.4.4.1 | **PP Environments (SIT B)** |  | 0d | 2024-08-27 A | 2024-08-27 A |  | 100% |  | 2024-08-27 | 2024-08-27 | 0d | 2024-07-30 | 2024-08-05 |  |  |  | -0 | N/A | SIT |  | 5.0 |  | Heath Thomas | SITAG |  | N/A | Systems Integration Testing (SIT) |  |  |  |
| 1139 | 1.4.1.4.4.4.1.1 | Deployment of MHHS solution code to SIT B environments | milestone | 0d | 2024-08-27 A | 2024-08-27 A |  | 100% |  | 2024-08-27 | 2024-08-27 | 0d | 2024-07-30 | 2024-08-05 |  |  | start no earlier than 2024-08-27 |  | PP | SIT |  | 5.21 | Complete | Heath Thomas | SITAG | COMPLETE | SI Test | Systems Integration Testing (SIT) | 26/3/24: Lee said change to SB and align to IR7 |  |  |
| 1140 | 1.4.1.4.4.4.2 | **SI Environments (SIT B)** |  | 0d | 2024-08-27 A | 2024-08-27 A |  | 100% |  | 2024-08-27 | 2024-08-27 | 0d | 2024-07-30 | 2024-08-05 |  |  |  | -0 | N/A | SIT |  | 5.0 |  | Heath Thomas | SITAG |  | N/A | Systems Integration Testing (SIT) |  |  |  |
| 1141 | 1.4.1.4.4.4.2.1 | Coordinate deployment of MHHS solution code to SIT Participants' SIT B environments | milestone | 0d | 2024-08-27 A | 2024-08-27 A | 1139SS | 100% |  | 2024-08-27 | 2024-08-27 | 0d | 2024-07-30 | 2024-08-05 |  |  |  |  | SI Test | SIT |  | 5.21 | Complete | Heath Thomas | SITAG | COMPLETE | PP | Systems Integration Testing (SIT) |  |  |  |
| 1142 | 1.4.1.4.4.4.3 | **Helix and Avanade Environments Upscale** |  | 5d | 2025-02-24 | 2025-02-28 |  |  |  | 2024-12-23 | 2025-01-03 | 0d |  |  | 20d |  |  |  |  | SIT | -686.67 | 6.0 | Overdue Start | Heath Thomas | SITAG |  |  |  |  |  |  |
| 1143 | 1.4.1.4.4.4.3.1 | Environment Uplift Window |  | 5d | 2025-02-24 | 2025-02-28 | 1557 |  |  | 2025-02-24 | 2025-02-28 | 0d |  |  | 20d | 0d |  |  |  | SIT | 26.33 | 6.0 | Green | Heath Thomas | SITAG | GREEN |  |  |  |  |  |
| 1144 | 1.4.1.4.4.5 | **Test Data - Non-Functional and Operational (SIT B)** |  | 25d? | 2025-02-24 | 2025-03-28 |  |  |  | 2025-01-06 | 2025-03-14 | 0d |  |  | 1d |  |  |  |  | SIT | -686.67 | 6.0 | Overdue Start | Heath Thomas | SITAG |  |  |  |  |  |  |
| 1145 | 1.4.1.4.4.5.1 | **Data Load** |  | 25d? | 2025-02-24 | 2025-03-28 |  |  |  | 2025-01-06 | 2025-03-14 | 0d |  |  | 1d |  |  |  |  | SIT | -689.67 | 6.0 | Overdue Start | Richard Puddephatt | SITAG |  |  |  |  |  |  |
| 1146 | 1.4.1.4.4.5.1.1 | Non-Functional Theme 1 (Avenade) Data Load |  | 5d? | 2025-02-24 | 2025-02-28 | 1557 |  |  | 2025-02-24 | 2025-02-28 | 0d |  |  | 1d | 0d |  |  | SI Test | SIT | 26.33 | 6.15 | Green | Richard Puddephatt | SITAG | GREEN |  |  |  | T3-TE-0126 | T3 |
| 1147 | 1.4.1.4.4.5.1.2 | Non-Functional Theme 2 & 3 (Helix, Avenade & PPs) Data Load |  | 5d | 2025-03-24 | 2025-03-28 | 1616 |  |  | 2025-03-24 | 2025-03-28 | 0d |  |  | 1d | 0d |  |  | SI Test | SIT | 54.33 | 6.15 | Green | Richard Puddephatt | SITAG | GREEN |  |  |  | T3-TE-0127 | T3 |
| 1148 | 1.4.1.4.4.5.1.3 | Non-Functional Themes 2 & 3 (LDSO's and DCC) Data Load |  | 15d | 2025-03-03 | 2025-03-21 | 1143 |  |  | 2025-03-03 | 2025-03-21 | 0d |  |  | 60d | 4d |  |  | SI Test | SIT | 33.33 | 6.15 | Green | Richard Puddephatt | SITAG | GREEN |  |  |  | T3-TE-0128 | T3 |
| 1149 | 1.4.1.4.4.5.1.4 | Operational Themes 1, 2 & 3 (Batch 2) (LDSO's and DCC) Data Load |  | 20d? | 2025-03-03 | 2025-03-28 | 1143 |  |  | 2025-03-03 | 2025-03-28 | 0d |  |  | 20d | 0d | start no earlier than 2025-01-06 |  | SI Test | SIT | 33.33 | 6.15 | Green | Richard Puddephatt | SITAG | GREEN |  |  |  | T3-TE-0129 | T3 |
| 1150 | 1.4.1.4.4.5.1.5 | Operational Themes 1, 2 & 3 (Batch 2) (Helix, Avenade & PPs) Data Load |  | 5d | 2025-03-24 | 2025-03-28 | 1616 |  |  | 2025-03-24 | 2025-03-28 | 0d |  |  | 20d | 0d |  |  | SI Test | SIT | 54.33 | 6.15 | Green | Richard Puddephatt | SITAG | GREEN |  |  |  | T3-TE-0130 | T3 |
| 1151 | 1.4.1.4.4.5.1.6 | Non-Functional and Operational Test Data Preparation Complete | milestone | 0d | 2025-03-28 | 2025-03-28 | 1150 |  |  | 2025-03-28 | 2025-03-28 | 0d |  |  | 714d |  |  |  | SI Test | SIT | 58.71 | 6.15 | Green | Richard Puddephatt | SITAG | GREEN |  |  |  | T3-TE-0131 | T3 |

Notes:
- 1136: Notes (2): 20/01/25 - Action to expand this section to reflect activity needed.

| ID | WBS | Task | Type | Duration | Start | Finish | Predecessors | Complete | Remaining | Baseline start | Baseline finish | Baseline duration | Baseline 1 start | Baseline 1 finish | Total slack | Free slack | Constraint | Baseline cost | Responsible | Involved | Text9 | Update Version | MHHS Resource Name | MHHS Programme Phase | Text29 | Sched Status | RAG | Task Status | Milestone ID |
| --- | --- | --- | --- | --- | --- | --- | --- | --- | --- | --- | --- | --- | --- | --- | --- | --- | --- | --- | --- | --- | --- | --- | --- | --- | --- | --- | --- | --- | --- |
| 1152 | 1.4.1.4.4.6 | **SIT Non-Functional Test Readiness Report** |  | 49d | 2025-01-20 A | 2025-03-28 |  | 41% | 28.92d | 2024-06-25 | 2025-03-07 | 44d | 2024-06-25 | 2024-08-19 | 715d |  |  | -0 | N/A | N/A | SIT | 5.0 | Roger Robar | Systems Integration Testing (SIT) | SITAG |  |  |  |  |
| 1153 | 1.4.1.4.4.6.1 | **SIT Non-Functional Theme 1 Overarching Test Readiness Report** |  | 29d | 2025-01-21 A | 2025-02-28 |  | 25% | 21.75d | 2024-06-25 | 2025-01-10 | 40d | 2024-06-25 | 2024-08-19 | 734d |  |  |  | N/A | N/A | SIT | 6.17 | Roger Robar | Systems Integration Testing (SIT) | SITAG |  |  |  |  |
| 1154 | 1.4.1.4.4.6.1.1 | Develop Overarching SIT Non-Functional Theme 1 Overarching Test Readiness Report |  | 11d | 2025-01-21 A | 2025-02-04 | 401 | 50% | 5.5d | 2025-01-21 | 2025-02-04 | 20d | 2024-07-16 | 2024-08-12 | 736d | 0d | finish no earlier than 2025-02-04 |  | SI Test |  | SIT | 6.17 | Roger Robar | Systems Integration Testing (SIT) | SITAG | Green | GREEN |  |  |
| 1155 | 1.4.1.4.4.6.1.2 | SRO review |  | 5d | 2025-02-05 | 2025-02-11 | 1154 |  |  | 2025-02-05 | 2025-02-11 |  |  |  | 736d | 0d | finish no earlier than 2025-02-10 |  |  |  | SIT | 6.17 | Roger Robar |  | SITAG | Green | GREEN | 7.33 |  |
| 1156 | 1.4.1.4.4.6.1.3 | NFTWG paper day | milestone | 0d | 2025-02-11 | 2025-02-11 | 1155 |  |  | 2025-02-11 | 2025-02-11 |  |  |  | 736d | 0d | finish no earlier than 2025-02-11 |  |  |  | SIT | 6.17 | Roger Robar |  | SITAG | Green | GREEN | 13.71 |  |
| 1157 | 1.4.1.4.4.6.1.4 | NFTWG review the Non-Functional Theme 1 Overarching Test Readiness Report | milestone | 0d | 2025-02-18 | 2025-02-18 | 1156FS+5d |  |  | 2025-02-18 | 2025-02-18 |  |  |  | 736d | 0d |  |  |  |  | SIT | 6.17 | Roger Robar |  | SITAG | Green | GREEN | 20.71 |  |
| 1158 | 1.4.1.4.4.6.1.5 | Update Non-Functional Theme 1 Overarching Test Readiness Report following SRO / NFTWG feedback |  | 6d | 2025-02-19 | 2025-02-26 | 1155, 1157 |  |  | 2025-02-19 | 2025-02-26 |  |  |  | 736d | 0d | finish no earlier than 2025-02-26 |  |  |  | SIT | 6.17 | Roger Robar |  | SITAG | Green | GREEN | 21.33 |  |
| 1159 | 1.4.1.4.4.6.1.6 | FTIG Recommendation | milestone | 0d | 2025-02-21 | 2025-02-21 | 1157FS+3d |  |  | 2025-02-21 | 2025-02-21 | 0d |  |  | 739d |  |  |  |  |  | SIT | 6.17 |  |  |  | Green | GREEN | 23.71 |  |
| 1160 | 1.4.1.4.4.6.1.7 | eSITAG paper day | milestone | 0d | 2025-02-26 | 2025-02-26 | 1158 |  |  | 2025-02-26 | 2025-02-26 |  |  |  | 736d |  | finish no earlier than 2025-02-21 |  |  |  | SIT | 6.17 | Roger Robar |  | SITAG | Green | GREEN | 28.71 |  |
| 1161 | 1.4.1.4.4.6.1.8 | Esitag approve Non-Functional Theme 1 Overarching Test Readiness Report | milestone | 0d | 2025-02-28 | 2025-02-28 | 1146 |  |  | 2025-02-28 | 2025-02-28 |  |  |  | 1d | 0d |  |  | SI Test |  | SIT | 6.17 | Roger Robar |  | SITAG | Green | GREEN | 30.71 | T3-TE-0190 |
| 1162 | 1.4.1.4.4.6.2 | **SIT Non-Functional Overarching Test Readiness Report Theme 2 & 3** |  | 28d | 2025-02-18 A | 2025-03-28 |  | 13% | 24.33d | 2025-02-18 | 2025-03-28 |  |  |  | 715d |  |  |  | SI Test |  | SIT | 6.17 | Roger Robar |  | SITAG |  |  | -779.67 |  |
| 1163 | 1.4.1.4.4.6.2.1 | Develop Overarching SIT Non-Functional Overarching Test Readiness Report Theme 2 & 3 |  | 11d | 2025-02-18 A | 2025-03-04 |  | 25% | 8.25d | 2025-02-18 | 2025-03-04 |  |  |  | 732d | 11d | finish no earlier than 2025-03-04 |  |  |  | SIT | 6.17 | Roger Robar |  | SITAG | Green | GREEN |  |  |
| 1164 | 1.4.1.4.4.6.2.2 | SRO review |  | 5d | 2025-03-05 | 2025-03-11 | 1163SS |  |  | 2025-03-05 | 2025-03-11 |  |  |  | 58d | 0d | start no earlier than 2025-03-05 |  |  |  | SIT | 6.17 | Roger Robar |  | SITAG | Green | GREEN | 35.33 |  |
| 1165 | 1.4.1.4.4.6.2.3 | NFTWG paper day | milestone | 0d | 2025-03-11 | 2025-03-11 | 1164 |  |  | 2025-03-11 | 2025-03-11 |  |  |  | 58d | 0d | finish no earlier than 2025-03-11 |  |  |  | SIT | 6.17 | Roger Robar |  | SITAG | Green | GREEN | 41.71 |  |
| 1166 | 1.4.1.4.4.6.2.4 | NFTWG review the Non-Functional Overarching Test Readiness Report Theme 2 & 3 | milestone | 0d | 2025-03-18 | 2025-03-18 | 1165FS+5d |  |  | 2025-03-18 | 2025-03-18 |  |  |  | 58d | 0d | finish no earlier than 2025-03-18 |  |  |  | SIT | 6.17 | Roger Robar |  | SITAG | Green | GREEN | 48.71 |  |
| 1167 | 1.4.1.4.4.6.2.5 | Update Non-Functional Overarching Test Readiness Report Theme 2 & 3 following SRO / NFTWG feedback |  | 5d | 2025-03-19 | 2025-03-25 | 1164, 1166 |  |  | 2025-03-19 | 2025-03-25 |  |  |  | 58d | 0d |  |  |  |  | SIT | 6.17 | Roger Robar |  | SITAG | Green | GREEN | 49.33 |  |
| 1168 | 1.4.1.4.4.6.2.6 | FTIG Recommendation | milestone | 0d | 2025-03-21 | 2025-03-21 | 1166FS+3d |  |  | 2025-03-21 | 2025-03-21 |  |  |  | 60d | 2d |  |  |  |  | SIT | 6.17 |  |  |  | Green | GREEN | 51.71 |  |
| 1169 | 1.4.1.4.4.6.2.7 | eSITAG paper day | milestone | 0d | 2025-03-25 | 2025-03-25 | 1167, 1168 |  |  | 2025-03-25 | 2025-03-25 |  |  |  | 58d | 2d | start no earlier than 2025-03-21 |  |  |  | SIT | 6.17 | Roger Robar |  | SITAG | Green | GREEN | 55.71 |  |
| 1170 | 1.4.1.4.4.6.2.8 | eSITAG approve Non-Functional Overarching Test Readiness Report Theme 2 & 3 | milestone | 0d | 2025-03-28 | 2025-03-28 | 1147FS-1d, 1148, 1169 |  |  | 2025-03-28 | 2025-03-28 |  |  |  | 56d | 0d |  |  | SI Test |  | SIT | 6.17 | Roger Robar |  | SITAG | Green | GREEN | 58.33 | T3-TE-0191 |
| 1171 | 1.4.1.4.4.6.3 | **SIT Non-Functional Execution Model** |  | 42d | 2025-01-20 A | 2025-03-18 |  | 63% | 15.63d | 2025-01-20 | 2025-02-12 |  |  |  | 722d |  |  |  |  |  | SIT | 6.15 | David O'Riordan |  | SITAG | Overdue Start |  | -778.67 |  |
| 1172 | 1.4.1.4.4.6.3.1 | **Theme 1** |  | 22d | 2025-01-20 A | 2025-02-18 |  | 99% | 0d | 2025-01-20 | 2025-02-12 |  |  |  | 742d |  |  |  |  |  | SIT | 6.15 | David O'Riordan |  | SITAG | Overdue Start | RED | -778.67 |  |
| 1173 | 1.4.1.4.4.6.3.1.1 | Develop execution model Theme 1 |  | 3d | 2025-01-20 A | 2025-01-22 A |  | 100% |  | 2025-01-20 | 2025-01-22 | 0d |  |  |  |  | start no earlier than 2025-01-20 |  |  |  | SIT | 6.15 | David O'Riordan |  | SITAG | Complete | COMPLETE |  |  |
| 1174 | 1.4.1.4.4.6.3.1.2 | SRO provide feedback |  | 5d | 2025-01-23 A | 2025-01-29 A | 1173 | 100% |  | 2025-01-23 | 2025-01-29 | 0d |  |  |  |  |  |  |  |  | SIT | 6.15 | David O'Riordan |  | SITAG | Complete | COMPLETE |  |  |
| 1175 | 1.4.1.4.4.6.3.1.3 | Address SRO feedback on execution model |  | 2d | 2025-01-30 A | 2025-01-31 A | 1174 | 100% |  | 2025-01-30 | 2025-01-31 | 0d |  |  |  |  |  |  |  |  | SIT | 6.15 | David O'Riordan |  | SITAG | Complete | COMPLETE |  |  |
| 1176 | 1.4.1.4.4.6.3.1.4 | Finalise execution model |  | 3d | 2025-02-03 A | 2025-02-05 A | 1175 | 100% |  | 2025-02-03 | 2025-02-05 | 0d |  |  |  |  |  |  |  |  | SIT | 6.15 | David O'Riordan |  | SITAG | Complete | COMPLETE |  |  |
| 1177 | 1.4.1.4.4.6.3.1.5 | NFTWG paper day | milestone | 0d | 2025-02-11 | 2025-02-11 | 1176FS+4d |  |  | 2025-02-05 | 2025-02-05 | 0d |  |  | 742d | 0d |  |  |  |  | SIT | 6.17 | David O'Riordan |  | SITAG | yellow | RED | 13.71 |  |
| 1178 | 1.4.1.4.4.6.3.1.6 | NFTWG update on execution model | milestone | 0d | 2025-02-18 | 2025-02-18 | 1177FS+5d |  |  | 2025-02-12 | 2025-02-12 | 0d |  |  | 742d |  |  |  |  |  | SIT | 6.17 | David O'Riordan |  | SITAG | yellow | RED | 20.71 |  |

Notes:
- 1154: 29/01/25 - SITAG approved an updated governance timeframes for the NF and Ops Overarching Test Readiness Report, this activity has been rebaselined to reflect this. Status is Green, while there is still PIT documentation required from PPs / to be assured by the programme, it's expected this will be recieved and completed before the deadline.
- 1155: 29/01/25 - SITAG approved updated governance timeframes for the NF and Ops Overarching Test Readiness Report, this activity has been rebaselined to reflect this.
- 1156: 29/01/25 - SITAG approved updated governance timeframes for the NF and Ops Overarching Test Readiness Report, this activity has been rebaselined to reflect this.
- 1157: 29/01/25 - SITAG approved updated governance timeframes for the NF and Ops Overarching Test Readiness Report, this activity has been rebaselined to reflect this.
- 1158: 29/01/25 - SITAG approved an updated governance approach for the NF and Ops Overarching Test Readiness Report, this activity has been rebaselined to reflect this.
- 1159: 29/01/25 - SITAG approved an updated governance approach for the NF and Ops Overarching Test Readiness Report, this activity has been rebaselined to reflect this.
- 1160: 29/01/25 - SITAG approved an updated governance approach for the NF and Ops Overarching Test Readiness Report, this activity has been rebaselined to reflect this.
- 1161: 29/01/25 - SITAG approved the creation of a milestone ID for this activity in January.
- 1163: 29/01/25 - SITAG approved an updated governance timeframes for the NF and Ops Overarching Test Readiness Report, this activity has been rebaselined to reflect this. Status is Green, while there is still PIT documentation required from PPs / to be assured by the programme, it's expected this will be recieved and completed before the deadline.
- 1164: 29/01/25 - SITAG approved an updated governance timeframes for the NF and Ops Overarching Test Readiness Report, this activity has been rebaselined to reflect this. Status is Green, while there is still PIT documentation required from PPs and to be assure
- 1165: 29/01/25 - SITAG approved an updated governance timeframes for the NF and Ops Overarching Test Readiness Report, this activity has been rebaselined to reflect this. Status is Green, while there is still PIT documentation required from PPs and to be assure
- 1166: 29/01/25 - SITAG approved an updated governance timeframes for the NF and Ops Overarching Test Readiness Report, this activity has been rebaselined to reflect this. Status is Green, while there is still PIT documentation required from PPs and to be assure
- 1167: 29/01/25 - SITAG approved an updated governance timeframes for the NF and Ops Overarching Test Readiness Report, this activity has been rebaselined to reflect this. Status is Green, while there is still PIT documentation required from PPs and to be assure
- 1168: 29/01/25 - SITAG approved an updated governance timeframes for the NF and Ops Overarching Test Readiness Report, this activity has been rebaselined to reflect this. Status is Green, while there is still PIT documentation required from PPs and to be assure
- 1169: 29/01/25 - SITAG approved an updated governance timeframes for the NF and Ops Overarching Test Readiness Report, this activity has been rebaselined to reflect this. Status is Green, while there is still PIT documentation required from PPs and to be assure
- 1170: 29/01/25 - SITAG approved the creation of a milestone ID for this activity in January.
- 1177: 27/01/25 - v6.16 of the plan had the NF Execution Model being presented to SITWG. Programme has determined that its more appropriate for it to go to the NFTWG instead. Forecast updated to reflect this, but falls behind baseline, hence Red RAG rating, but this activity is on track.
- 1178: 27/01/25 - v6.16 of the plan had the NF Execution Model being presented to SITWG. Programme has determined that its more appropriate for it to go to the NFTWG instead. Forecast updated to reflect this, but falls behind baseline, hence Red RAG rating, but this activity is on track.

| ID | WBS | Task | Type | Duration | Start | Finish | Predecessors | Complete | Remaining | Baseline start | Baseline finish | Baseline duration | Baseline 1 start | Baseline 1 finish | Total slack | Free slack | Constraint | Baseline cost | Text9 | Task Status | Update Version | Sched Status | MHHS Resource Name | Text29 | RAG | Responsible | Involved | MHHS Programme Phase | Tier | Milestone ID | Artefact ID | Guidance |
| --- | --- | --- | --- | --- | --- | --- | --- | --- | --- | --- | --- | --- | --- | --- | --- | --- | --- | --- | --- | --- | --- | --- | --- | --- | --- | --- | --- | --- | --- | --- | --- | --- |
| 1179 | 1.4.1.4.4.6.3.2 | **Theme 2 & 3** |  | 42d | 2025-01-20 A | 2025-03-18 |  | 99% | 0d | 2025-01-20 | 2025-02-12 | 0d |  |  | 722d |  |  |  | SIT | -778.67 | 6.15 | Overdue Start | David O'Riordan | SITAG |  |  |  |  |  |  |  |  |
| 1180 | 1.4.1.4.4.6.3.2.1 | Develop execution model Theme 2 & 3 |  | 3d | 2025-01-20 A | 2025-01-22 A |  | 100% |  | 2025-01-20 | 2025-01-22 | 0d |  |  |  |  | start no earlier than 2025-01-20 |  | SIT |  | 6.15 | Complete | David O'Riordan | SITAG | COMPLETE |  |  |  |  |  |  |  |
| 1181 | 1.4.1.4.4.6.3.2.2 | SRO provide feedback |  | 5d | 2025-01-23 A | 2025-01-29 A | 1180 | 100% |  | 2025-01-23 | 2025-01-29 | 0d |  |  |  |  |  |  | SIT |  | 6.15 | Complete | David O'Riordan | SITAG | COMPLETE |  |  |  |  |  |  |  |
| 1182 | 1.4.1.4.4.6.3.2.3 | Address SRO feedback on execution model |  | 2d | 2025-01-30 A | 2025-01-31 A | 1181 | 100% |  | 2025-01-30 | 2025-01-31 | 0d |  |  |  |  |  |  | SIT |  | 6.15 | Complete | David O'Riordan | SITAG | COMPLETE |  |  |  |  |  |  |  |
| 1183 | 1.4.1.4.4.6.3.2.4 | Finalise execution model |  | 3d | 2025-02-03 A | 2025-02-05 A | 1182 | 100% |  | 2025-02-03 | 2025-02-05 | 0d |  |  |  |  |  |  | SIT |  | 6.15 | Complete | David O'Riordan | SITAG | COMPLETE |  |  |  |  |  |  |  |
| 1184 | 1.4.1.4.4.6.3.2.5 | NFTWG paper day | milestone | 0d | 2025-03-11 | 2025-03-11 | 1183FS+24d |  |  | 2025-02-05 | 2025-02-05 | 0d |  |  | 722d | 0d |  |  | SIT | 41.71 | 6.17 | Red | David O'Riordan | SITAG | RED |  |  |  |  |  |  |  |
| 1185 | 1.4.1.4.4.6.3.2.6 | NFTWG update on execution model | milestone | 0d | 2025-03-18 | 2025-03-18 | 1184FS+5d |  |  | 2025-02-12 | 2025-02-12 |  |  |  | 722d |  |  |  | SIT | 48.71 | 6.17 | Red | David O'Riordan | SITAG | RED |  |  |  |  |  |  |  |
| 1186 | 1.4.1.4.4.6.3.3 | **SIT Non-Functional Progress reporting** |  | 17d | 2025-01-23 A | 2025-02-14 |  | 6% | 16d | 2024-12-30 | 2025-01-24 |  |  |  | 125d |  |  |  | SIT | -778.67 | 6.14 | Overdue Start | David O'Riordan | SITAG | RED |  |  |  |  |  |  |  |
| 1187 | 1.4.1.4.4.6.3.3.1 | Determine reporting methodology |  | 2d | 2025-01-23 A | 2025-01-24 | 1180, 1173 | 50% | 1d | 2025-01-23 | 2025-01-24 |  |  |  | 125d | 0d |  |  | SIT |  | 6.14 | Green | David O'Riordan | SITAG | RED |  |  |  |  |  |  |  |
| 1188 | 1.4.1.4.4.6.3.3.2 | Implement reporting |  | 15d | 2025-01-27 | 2025-02-14 | 863, 401, 1106, 1112, 1118, 1187 |  |  | 2025-01-27 | 2025-02-14 | 0d | 2024-08-26 | 2024-08-26 | 125d | 30d |  |  | SIT | -1.67 | 6.14 | Green | David O'Riordan | SITAG | GREEN | SI Test | PP,IPA | Systems Integration Testing (SIT) | T2 |  |  |  |
| 1189 | 1.4.1.4.4.7 | SIT Non-Functional Testing Preparation Complete Theme 1 | milestone | 0d | 2025-02-28 | 2025-02-28 | 1146 |  |  | 2025-02-28 | 2025-02-28 |  |  |  | 734d |  | start no earlier than 2025-02-28 |  | SIT | 30.71 | 6.15 | Green | David O'Riordan | SITAG | GREEN | SI Test |  |  |  | T2-TE-0700 |  |  |
| 1190 | 1.4.1.4.4.8 | SIT Non-Functional Testing Preparation Complete Theme 2 & 3 | milestone | 0d | 2025-03-28 | 2025-03-28 | 1147, 1148, 402FS+5d |  |  | 2025-03-28 | 2025-03-28 |  |  |  | 714d |  |  |  | SIT | 58.71 | 6.15 | Green | David O'Riordan | SITAG | GREEN | SI Test |  |  | T2 | T2-TE-1100 |  |  |
| 1191 | 1.4.1.4.5 | **SIT Operational Preparation** |  | 590d? | 2022-10-31 A | 2025-01-31 |  | 95% | 31.81d? | 2024-02-01 | 2025-01-31 | 283d | 2023-08-03 | 2025-03-10 | 754d |  |  | -0 | SIT |  | 5.0 |  | N/A | SITAG |  | N/A | N/A | Systems Integration Testing (SIT) |  |  |  |  |
| 1192 | 1.4.1.4.5.1 | **Test Approach & Plan** |  | 75d | 2024-02-01 A | 2024-05-15 A |  | 100% |  | 2024-02-01 | 2024-05-15 | 75d | 2024-02-01 | 2024-05-15 |  |  |  | -0 | SIT |  | 5.0 |  | N/A | SITAG |  | N/A | N/A | Systems Integration Testing (SIT) |  |  |  |  |
| 1193 | 1.4.1.4.5.1.1 | Develop document with SITWG |  | 25d | 2024-02-01 A | 2024-03-06 A |  | 100% |  | 2024-02-01 | 2024-03-06 | 25d | 2024-02-01 | 2024-03-06 |  |  | must start on 2024-02-01 |  | SIT |  | 5.0 | Complete |  | SITAG | COMPLETE | SI Test |  | Systems Integration Testing (SIT) |  |  |  |  |
| 1194 | 1.4.1.4.5.1.2 | Draft document review with Code Bodies |  | 4d | 2024-03-21 A | 2024-03-26 A | 1193FS+10d | 100% |  | 2024-03-21 | 2024-03-26 | 10d | 2024-03-07 | 2024-03-20 |  |  |  |  | SIT |  | 5.0 | Complete |  | SITAG | COMPLETE | SI Test | Code Bodies | Systems Integration Testing (SIT) |  |  |  |  |
| 1195 | 1.4.1.4.5.1.3 | Industry Consultation |  | 10d | 2024-03-27 A | 2024-04-09 A | 1194 | 100% |  | 2024-03-27 | 2024-04-09 | 10d |  |  |  |  |  |  | SIT |  | 5.1 | Complete |  | SITAG | COMPLETE | PP |  | Systems Integration Testing (SIT) |  |  |  |  |
| 1196 | 1.4.1.4.5.1.4 | Artefact review (via SITAG) and updates |  | 26d | 2024-04-10 A | 2024-05-15 A | 1195 | 100% |  | 2024-04-10 | 2024-05-15 | 30d | 2024-03-21 | 2024-05-15 |  |  |  |  | SIT |  | 5.0 | Complete |  | SITAG | COMPLETE | SI Test | PP,IPA,Code Bodies | Systems Integration Testing (SIT) |  |  |  |  |
| 1197 | 1.4.1.4.5.1.5 | SIT Operational Testing Test Approach & Plan approved | milestone | 0d | 2024-05-15 A | 2024-05-15 A | 1196 | 100% |  | 2024-05-15 | 2024-05-15 | 0d | 2024-05-15 | 2024-05-15 |  |  |  |  | SIT |  | 5.24 | Complete |  | SITAG | COMPLETE | SI Test | PP | Systems Integration Testing (SIT) | T3 | T3-TE-0029 | MHHS-ART073 |  |
| 1198 | 1.4.1.4.5.2 | **Test Data Approach & Plan** |  | 36d | 2024-03-27 A | 2024-05-15 A |  | 100% |  | 2024-03-27 | 2024-05-15 | 36d | 2024-03-21 | 2024-05-15 |  |  |  | -0 | SIT |  | 5.0 |  | N/A | SITAG |  | N/A | N/A | Systems Integration Testing (SIT) |  |  |  |  |
| 1199 | 1.4.1.4.5.2.1 | Industry Consultation |  | 10d | 2024-03-27 A | 2024-04-09 A | 1195SS | 100% |  | 2024-03-27 | 2024-04-09 | 10d |  |  |  |  |  |  | SIT |  | 5.1 | Complete | Richard Puddephatt | SITAG | COMPLETE | PP |  | Systems Integration Testing (SIT) |  |  |  |  |
| 1200 | 1.4.1.4.5.2.2 | Artefact review (via SITAG) and updates |  | 26d | 2024-04-10 A | 2024-05-15 A | 1199 | 100% |  | 2024-04-10 | 2024-05-15 | 26d | 2024-03-21 | 2024-05-15 |  |  |  |  | SIT |  | 5.0 | Complete | Richard Puddephatt | SITAG | COMPLETE | SI Test |  | Systems Integration Testing (SIT) |  |  |  |  |
| 1201 | 1.4.1.4.5.2.3 | SIT Operational Testing Test Data Approach & Plan approved | milestone | 0d | 2024-05-15 A | 2024-05-15 A | 1200 | 100% |  | 2024-05-15 | 2024-05-15 | 0d | 2024-05-15 | 2024-05-15 |  |  |  |  | SIT |  | 5.0 | Complete | Richard Puddephatt | SITAG | COMPLETE | SI Test | PP,IPA | Systems Integration Testing (SIT) |  |  |  |  |
| 1202 | 1.4.1.4.5.3 | **Test scenarios & Test Cases** |  | 108d | 2024-04-10 A | 2024-09-06 A |  | 100% |  | 2024-04-10 | 2025-01-31 | 116d | 2023-07-24 | 2024-01-17 |  |  |  | -0 | SIT |  | 5.21 |  | Richard Puddephatt | SITAG |  | N/A | N/A | Systems Integration Testing (SIT) |  |  |  |  |
| 1203 | 1.4.1.4.5.3.1 | **Theme 1** |  | 108d | 2024-04-10 A | 2024-09-06 A |  | 100% |  | 2024-04-10 | 2024-09-06 | 96d |  |  |  |  |  | -0 | SIT | -448.67 | 6.0 |  | Richard Puddephatt | SITAG |  | N/A | N/A | Systems Integration Testing (SIT) |  |  |  |  |
| 1204 | 1.4.1.4.5.3.1.1 | Develop Test Scenarios & Test Cases |  | 53d | 2024-04-10 A | 2024-06-21 A | 1195 | 100% |  | 2024-04-10 | 2024-06-21 | 16d |  |  |  |  |  |  | SIT |  | 6.0 | Complete | Richard Puddephatt | SITAG | COMPLETE | SI Test | SI Test, PP |  |  |  |  |  |
| 1205 | 1.4.1.4.5.3.1.2 | Industry Review Workshop |  | 1d | 2024-06-24 A | 2024-06-24 A | 1204 | 100% |  | 2024-06-24 | 2024-06-24 | 1d |  |  |  |  |  |  | SIT |  | 6.0 | Complete | Richard Puddephatt | SITAG | COMPLETE | SI Test, PP | SI Test, PP |  |  |  |  |  |
| 1206 | 1.4.1.4.5.3.1.3 | Industry Consultation Review |  | 6d | 2024-07-02 A | 2024-07-09 A | 1205FS+17d | 100% |  | 2024-07-02 | 2024-07-09 | 6d |  |  |  |  |  |  | SIT |  | 6.0 | Complete | Richard Puddephatt | SITAG | COMPLETE | SI Test, PP | SI Test, PP |  |  |  |  |  |
| 1207 | 1.4.1.4.5.3.1.4 | Review with SIT Working Group |  | 5d | 2024-08-19 A | 2024-08-23 A | 1206FS+16d | 100% |  | 2024-08-19 | 2024-08-23 | 5d |  |  |  |  |  |  | SIT |  | 6.0 | Complete | Richard Puddephatt | SITAG | COMPLETE | SI Test, PP | SI Test, PP |  |  |  |  |  |
| 1208 | 1.4.1.4.5.3.1.5 | SIT Operational Scenarios & Test Cases Approved - Theme 1 | milestone | 0d | 2024-09-06 A | 2024-09-06 A | 1207FS+10d | 100% |  | 2024-09-06 | 2024-09-06 | 0d |  |  |  |  | start no earlier than 2024-09-06 |  | SIT |  | 6.0 | Complete | Richard Puddephatt | SITAG | COMPLETE | SI Test | SI Test, PP | Systems Integration Testing (SIT) | T3 | T3-TE-0117 |  | 31/7/24: baseline date change approved at esitag on 26/7/24 |

Notes:
- 1184: 27/01/25 - v6.16 of the plan had the NF Execution Model being presented to SITWG. Programme has determined that its more appropriate for it to go to the NFTWG instead. Also decided NF Theme 2 and 3 presentation should take place in March, nearer testing. Forecast updated to reflect this, but falls behind baseline, hence Red RAG rating, but this activity is on track.
- 1185: 27/01/25 - v6.16 of the plan had the NF Execution Model being presented to SITWG. Programme has determined that its more appropriate for it to go to the NFTWG instead. Also decided NF Theme 2 and 3 presentation should take place in March, nearer testing.
- 1187: 27/01/25 - Still feedback required before this can be concluded.

| ID | WBS | Task | Type | Duration | Start | Finish | Predecessors | Complete | Remaining | Baseline start | Baseline finish | Baseline duration | Total slack | Constraint | Responsible | Involved | Text9 | Task Status | Update Version | MHHS Resource Name | MHHS Programme Phase | Text29 | Sched Status | RAG | Milestone ID | Tier |
| --- | --- | --- | --- | --- | --- | --- | --- | --- | --- | --- | --- | --- | --- | --- | --- | --- | --- | --- | --- | --- | --- | --- | --- | --- | --- | --- |
| 1209 | 1.4.1.4.5.3.2 | **Theme 2** |  | 107d | 2024-04-10 A | 2024-09-06 A |  | 100% |  | 2024-04-10 | 2024-09-06 | 71d |  |  | N/A | N/A | SIT | -448.67 | 6.0 | Richard Puddephatt | Systems Integration Testing (SIT) | SITAG |  |  |  |  |
| 1210 | 1.4.1.4.5.3.2.1 | Develop Test Scenarios & Test Cases |  | 53d | 2024-04-10 A | 2024-06-21 A | 1195 | 100% |  | 2024-04-10 | 2024-06-21 | 31d |  | finish no earlier than 2024-06-21 | SI Test | SI Test, PP | SIT |  | 6.0 | Richard Puddephatt |  | SITAG | Complete | COMPLETE |  |  |
| 1211 | 1.4.1.4.5.3.2.2 | Industry Review Workshop |  | 1d | 2024-06-24 A | 2024-06-24 A | 1210 | 100% |  | 2024-06-24 | 2024-06-24 | 1d |  |  | SI Test, PP | SI Test, PP | SIT |  | 6.0 | Richard Puddephatt |  | SITAG | Complete | COMPLETE |  |  |
| 1212 | 1.4.1.4.5.3.2.3 | Industry Consultation Review |  | 6d | 2024-07-02 A | 2024-07-09 A | 1211FS+7d | 100% |  | 2024-07-02 | 2024-07-09 | 6d |  |  | SI Test, PP | SI Test, PP | SIT |  | 6.0 | Richard Puddephatt |  | SITAG | Complete | COMPLETE |  |  |
| 1213 | 1.4.1.4.5.3.2.4 | Review with SIT Working Group |  | 5d | 2024-08-19 A | 2024-08-23 A | 1212FS+11d | 100% |  | 2024-08-19 | 2024-08-23 | 5d |  |  | SI Test, PP | SI Test, PP | SIT |  | 6.0 | Richard Puddephatt |  | SITAG | Complete | COMPLETE |  |  |
| 1214 | 1.4.1.4.5.3.2.5 | SIT Operational Scenarios & Test Cases Approved - Theme 2 | milestone | 0d | 2024-09-06 A | 2024-09-06 A | 1213FS+10d | 100% |  | 2024-09-06 | 2024-09-06 | 0d |  |  | SI Test | SI Test, PP | SIT |  | 6.0 | Richard Puddephatt | Systems Integration Testing (SIT) | SITAG | Complete | COMPLETE | T3-TE-0118 | T3 |
| 1215 | 1.4.1.4.5.4 | **SIT Operations Manual** |  | 590d? | 2022-10-31 A | 2025-01-31 |  | 93% | 39.92d? | 2022-10-31 | 2025-01-31 |  | 754d |  |  |  | SIT | -755.67 | 6.13 | Helix |  |  | Overdue Start |  |  |  |
| 1216 | 1.4.1.4.5.4.1 | **Version 1 SIT Operations Manual** |  | 35d | 2024-10-07 A | 2024-11-22 A |  | 100% |  | 2024-10-07 | 2024-11-22 |  |  |  |  |  | SIT | -755.67 | 6.13 | Helix |  |  | Overdue Start |  |  |  |
| 1217 | 1.4.1.4.5.4.1.1 | Creation of SIT Operations Manual Template |  | 8d | 2024-10-07 A | 2024-10-16 A |  | 100% |  | 2024-10-07 | 2024-10-16 |  |  | start no earlier than 2024-10-07 |  |  | SIT |  | 6.13 | Helix |  |  | Complete | COMPLETE |  |  |
| 1218 | 1.4.1.4.5.4.1.2 | November TORWG Paper Day | milestone | 0d | 2024-11-07 A | 2024-11-07 A | 1217FS+16d | 100% |  | 2024-11-07 | 2024-11-07 |  |  |  |  |  | SIT |  | 6.13 | Helix |  |  | Complete | COMPLETE |  |  |
| 1219 | 1.4.1.4.5.4.1.3 | November TORWG (Timeline and Next Steps for SIT Operations Manual) | milestone | 0d | 2024-11-14 A | 2024-11-14 A | 1218FS+5d | 100% |  | 2024-11-14 | 2024-11-14 |  |  |  |  |  | SIT |  | 6.13 | Helix |  |  | Complete | COMPLETE |  |  |
| 1220 | 1.4.1.4.5.4.1.4 | SIT Operations Manual Version 1 Shared with MHHSP | milestone | 0d | 2024-11-11 A | 2024-11-11 A | 1217FS+18d | 100% |  | 2024-11-11 | 2024-11-11 |  |  |  |  |  | SIT |  | 6.13 | Helix |  |  | Complete | COMPLETE |  |  |
| 1221 | 1.4.1.4.5.4.1.5 | MHHSP provide feedback on SIT Operations Manual Version 1 |  | 9d | 2024-11-12 A | 2024-11-22 A | 1220 | 100% |  | 2024-11-12 | 2024-11-22 |  |  |  |  |  | SIT |  | 6.13 | Helix |  |  | Complete | COMPLETE |  |  |
| 1222 | 1.4.1.4.5.4.1.6 | SIT Operations Manual Version 1 Shared with Programme Participants | milestone | 0d | 2024-11-13 A | 2024-11-13 A | 1217FS+20d | 100% |  | 2024-11-13 | 2024-11-13 |  |  |  |  |  | SIT |  | 6.13 | Helix |  |  | Complete | COMPLETE |  |  |
| 1223 | 1.4.1.4.5.4.1.7 | PPs provide feedback on SIT Operations Manual Version 1 |  | 7d | 2024-11-14 A | 2024-11-22 A | 1222 | 100% |  | 2024-11-14 | 2024-11-22 |  |  |  |  |  | SIT |  | 6.13 | Helix |  |  | Complete | COMPLETE |  |  |
| 1224 | 1.4.1.4.5.4.1.8 | Programme Participants and MHHSP Feedback and Actions Received (SIT Ops Manual Version 1) | milestone | 0d | 2024-11-22 A | 2024-11-22 A | 1223, 1221 | 100% |  | 2024-11-22 | 2024-11-22 |  |  |  |  |  | SIT |  | 6.13 | Helix |  |  | Complete | COMPLETE |  |  |
| 1225 | 1.4.1.4.5.4.2 | **Version 2 SIT Operations Manual** |  | 27d | 2024-11-12 A | 2024-12-18 A |  | 100% |  | 2024-11-12 | 2024-12-18 |  |  |  |  |  | SIT | -755.67 | 6.13 | Helix |  |  | Overdue Start |  |  |  |
| 1226 | 1.4.1.4.5.4.2.1 | Version 2 SIT Operations Manual (Composition) |  | 12d | 2024-11-12 A | 2024-11-27 A | 1218FS+2d | 100% |  | 2024-11-12 | 2024-11-27 |  |  |  |  |  | SIT |  | 6.13 | Helix |  |  | Complete | COMPLETE |  |  |
| 1227 | 1.4.1.4.5.4.2.2 | Version 2 SIT Operations Manual Completed | milestone | 0d | 2024-11-27 A | 2024-11-27 A | 1226 | 100% |  | 2024-11-27 | 2024-11-27 |  |  |  | Helix |  | SIT |  | 6.13 | Helix |  | MCAG | Complete | COMPLETE | T3-TE-0132 | T3 |
| 1228 | 1.4.1.4.5.4.2.3 | Version 2 SIT Operations Manual Shared with MHHSP & PPs for TORWG (Consultation Starts) | milestone | 0d | 2024-11-27 A | 2024-11-27 A | 1227 | 100% |  | 2024-11-27 | 2024-11-27 |  |  |  | Helix |  | SIT |  | 6.13 | Helix |  |  | Complete | COMPLETE |  |  |
| 1229 | 1.4.1.4.5.4.2.4 | Version 2 SIT Ops Manual - PP Consultation (Iterative Feedback Process) |  | 10d | 2024-11-28 A | 2024-12-11 A | 1228 | 100% |  | 2024-11-28 | 2024-12-11 |  |  |  | Helix |  | SIT |  | 6.13 | Helix |  |  | Complete | COMPLETE |  |  |
| 1230 | 1.4.1.4.5.4.2.5 | Version 2 SIT Ops Manual - PP Consultation Completed | milestone | 0d | 2024-12-11 A | 2024-12-11 A | 1229 | 100% |  | 2024-12-11 | 2024-12-11 |  |  |  | Helix |  | SIT |  | 6.13 | Helix |  |  | Complete | COMPLETE |  |  |
| 1231 | 1.4.1.4.5.4.2.6 | December TORWG Paper Day | milestone | 0d | 2024-12-04 A | 2024-12-04 A | 1226FS+5d | 100% |  | 2024-12-04 | 2024-12-04 |  |  |  | Helix |  | SIT |  | 6.13 | Helix |  |  | Complete | COMPLETE |  |  |
| 1232 | 1.4.1.4.5.4.2.7 | December TORWG (Initial Feedback, Common Themes and Comments) | milestone | 0d | 2024-12-11 A | 2024-12-11 A | 1231FS+5d | 100% |  | 2024-12-11 | 2024-12-11 |  |  |  | Helix |  | SIT |  | 6.13 | Helix |  |  | Complete | COMPLETE |  |  |
| 1233 | 1.4.1.4.5.4.2.8 | December Extraordinary TORWG Paper Day | milestone | 0d | 2024-12-11 A | 2024-12-11 A | 1230 | 100% |  | 2024-12-11 | 2024-12-11 |  |  |  | Helix |  | SIT |  | 6.13 | Helix |  |  | Complete | COMPLETE |  |  |
| 1234 | 1.4.1.4.5.4.2.9 | Publication of key themes from consultation to eTORWG |  | 2d | 2024-12-12 A | 2024-12-13 A | 1233 | 100% |  | 2024-12-12 | 2024-12-13 |  |  |  | Helix |  | SIT |  | 6.14 |  |  |  | Complete | COMPLETE |  |  |
| 1235 | 1.4.1.4.5.4.2.10 | December Extraordinary TORWG (Summary of Version 2 Feedback and Response Approach Shared with PPs) | milestone | 0d | 2024-12-18 A | 2024-12-18 A | 1234FS+3d | 100% |  | 2024-12-18 | 2024-12-18 |  |  |  | Helix |  | SIT |  | 6.13 | Helix |  |  | Complete | COMPLETE |  |  |

| ID | WBS | Task | Type | Duration | Start | Finish | Predecessors | Complete | Remaining | Actual start | Actual finish | Baseline start | Baseline finish | Baseline duration | Total slack | Free slack | Constraint | Responsible | Text9 | Task Status | Update Version | Sched Status | MHHS Resource Name | RAG | Milestone ID | Text29 | Tier |
| --- | --- | --- | --- | --- | --- | --- | --- | --- | --- | --- | --- | --- | --- | --- | --- | --- | --- | --- | --- | --- | --- | --- | --- | --- | --- | --- | --- |
| 1236 | 1.4.1.4.5.4.3 | **Version 3 (Final) SIT Operations Manual** |  | 44d | 2024-11-28 A | 2025-01-28 |  | 99% | 0d |  |  | 2024-11-28 | 2025-01-28 |  | 757d |  |  | Helix | SIT | -755.67 | 6.13 | Overdue Start | Helix |  |  |  |  |
| 1237 | 1.4.1.4.5.4.3.1 | Update SIT Operations Manual (Final) Version 3 (with Comments Received From Version 2) [Pre-Christmas Furlough] |  | 17d | 2024-11-28 A | 2024-12-20 A | 1227, 181FF | 100% |  |  |  | 2024-11-28 | 2024-12-20 |  |  |  |  | Helix | SIT |  | 6.13 | Complete | Helix | COMPLETE |  |  |  |
| 1238 | 1.4.1.4.5.4.3.2 | Update SIT Operations Manual (Final) Version 3 (with Comments Received From Version 2) [Post-Christmas Furlough] |  | 5d | 2025-01-02 A | 2025-01-08 A | 1237FS+8d | 100% |  |  |  | 2025-01-02 | 2025-01-08 |  |  |  |  | Helix | SIT |  | 6.13 | Complete | Helix | COMPLETE |  |  |  |
| 1239 | 1.4.1.4.5.4.3.3 | SIT Operations Manual (Final) Version 3 Completed | milestone | 0d | 2025-01-08 A | 2025-01-08 A | 1238 | 100% |  |  |  | 2025-01-08 | 2025-01-08 |  |  |  |  | Helix | SIT |  | 6.13 | Complete | Helix | COMPLETE | T3-TE-0133 | MCAG | T3 |
| 1240 | 1.4.1.4.5.4.3.4 | January TORWG Paper Day | milestone | 0d | 2025-01-08 A | 2025-01-08 A | 1239 | 100% |  |  |  | 2025-01-08 | 2025-01-08 |  |  |  |  | Helix | SIT |  | 6.13 | Complete | Helix | COMPLETE |  |  |  |
| 1241 | 1.4.1.4.5.4.3.5 | January TORWG (SIT Operations Manual Agreement) [Assurance Meeting] | milestone | 0d | 2025-01-15 A | 2025-01-15 A | 1240FS+5d | 100% |  |  |  | 2025-01-15 | 2025-01-15 |  |  |  |  | Helix | SIT |  | 6.13 | Complete | Helix | COMPLETE |  |  |  |
| 1242 | 1.4.1.4.5.4.3.6 | January MCAG Paper Day (Final SIT Operations Manual Submitted) | milestone | 0d | 2025-01-21 A | 2025-01-21 A | 1241FS+4d | 100% |  |  |  | 2025-01-21 | 2025-01-21 |  |  |  |  | Helix | SIT |  | 6.13 | Complete | Helix | COMPLETE |  |  |  |
| 1243 | 1.4.1.4.5.4.3.7 | January MCAG (Final SIT Operations Manual Endorsement) [Advisory Group Sign-off] | milestone | 0d | 2025-01-28 | 2025-01-28 | 1242FS+5d |  |  |  |  | 2025-01-28 | 2025-01-28 |  | 757d | 3d |  | Helix | SIT | -0.29 | 6.13 | Green | Helix | GREEN | T3-TE-0135 | MCAG | T3 |
| 1244 | 1.4.1.4.5.4.4 | **Elexon / Helix Service Now Test Prep** |  | 119d? | 2024-08-01 A | 2025-01-14 A |  | 100% |  |  |  | 2024-07-15 | 2025-01-31 | 0d |  |  |  | Helix | SIT | -688.67 | 6.13 | Overdue Start | Helix |  |  |  |  |
| 1245 | 1.4.1.4.5.4.4.1 | **Incident Management Build** |  | 75d? | 2024-08-05 A | 2024-11-15 A |  | 100% |  |  |  | 2024-08-05 | 2024-11-15 | 0d |  |  |  | Helix | SIT | -728.67 | 6.13 | Overdue Start | Helix |  |  |  |  |
| 1246 | 1.4.1.4.5.4.4.1.1 | Build |  | 40d | 2024-08-05 A | 2024-09-27 A |  | 100% |  |  |  | 2024-09-27 | 2024-09-27 | 0d |  |  | finish no earlier than 2024-09-27 | Helix | SIT |  | 6.13 | Complete | Helix | COMPLETE |  |  |  |
| 1247 | 1.4.1.4.5.4.4.1.2 | Test |  | 15d | 2024-09-30 A | 2024-10-18 A | 1246 | 100% |  |  |  | 2024-10-18 | 2024-10-18 | 0d |  |  | finish no earlier than 2024-10-18 | Helix | SIT |  | 6.13 | Complete | Helix | COMPLETE |  |  |  |
| 1248 | 1.4.1.4.5.4.4.1.3 | Deploy |  | 20d | 2024-10-21 A | 2024-11-15 A | 1247 | 100% |  |  |  | 2024-11-15 | 2024-11-15 | 0d |  |  | finish no earlier than 2024-11-15 | Helix | SIT |  | 6.13 | Complete | Helix | COMPLETE |  |  |  |
| 1249 | 1.4.1.4.5.4.4.1.4 | Incident Management Build & Configuration Complete | milestone | 0d | 2024-11-15 A | 2024-11-15 A | 1248 | 100% |  |  |  | 2024-11-15 | 2024-11-15 |  |  |  |  | Helix | SIT |  | 6.13 | Complete | Helix | COMPLETE |  |  |  |
| 1250 | 1.4.1.4.5.4.4.2 | **Major Incident Management Build & Configuration** |  | 0d? | 2024-11-15 | 2024-11-15 |  | 100% |  | 2024-10-02 | 2025-01-14 | 2024-10-02 | 2025-01-14 | 0d |  |  |  | Helix | SIT | -728.67 | 6.13 | Overdue Start | Helix |  |  |  |  |
| 1251 | 1.4.1.4.5.4.4.2.1 | Build |  | 40d | 2024-10-02 A | 2024-11-26 A |  | 100% |  |  |  | 2024-11-26 | 2024-11-26 | 0d |  |  | finish no earlier than 2024-11-26 | Helix | SIT |  | 6.13 | Complete | Helix | COMPLETE |  |  |  |
| 1252 | 1.4.1.4.5.4.4.2.2 | Test |  | 15d | 2024-11-27 A | 2024-12-17 A | 1251 | 100% |  |  |  | 2024-12-17 | 2024-12-17 | 0d |  |  | finish no earlier than 2024-12-17 | Helix | SIT |  | 6.13 | Complete | Helix | COMPLETE |  |  |  |
| 1253 | 1.4.1.4.5.4.4.2.3 | Deploy |  | 20d | 2024-12-18 A | 2025-01-14 A | 1252 | 100% |  |  |  | 2025-01-14 | 2025-01-14 | 0d |  |  | finish no earlier than 2025-01-14 | Helix | SIT |  | 6.13 | Complete | Helix | COMPLETE |  |  |  |
| 1254 | 1.4.1.4.5.4.4.2.4 | Major Incident Management Build & Configuration Complete | milestone | 0d | 2025-01-14 A | 2025-01-14 A | 1253 | 100% |  |  |  | 2025-01-14 | 2025-01-14 |  |  |  |  | Helix | SIT |  | 6.13 | Complete | Helix | COMPLETE |  |  |  |
| 1255 | 1.4.1.4.5.4.4.3 | **Knowledge Management Build & Configuration** |  | 75d? | 2024-10-02 A | 2025-01-14 A |  | 100% |  |  |  | 2024-10-02 | 2025-01-14 | 0d |  |  |  | Helix | SIT | -728.67 | 6.13 | Overdue Start | Helix |  |  |  |  |
| 1256 | 1.4.1.4.5.4.4.3.1 | Build |  | 40d | 2024-10-02 A | 2024-11-26 A |  | 100% |  |  |  | 2024-11-26 | 2024-11-26 | 0d |  |  | finish no earlier than 2024-11-26 | Helix | SIT |  | 6.13 | Complete | Helix | COMPLETE |  |  |  |
| 1257 | 1.4.1.4.5.4.4.3.2 | Test |  | 15d | 2024-11-27 A | 2024-12-17 A | 1256 | 100% |  |  |  | 2024-12-17 | 2024-12-17 | 0d |  |  | finish no earlier than 2024-12-17 | Helix | SIT |  | 6.13 | Complete | Helix | COMPLETE |  |  |  |
| 1258 | 1.4.1.4.5.4.4.3.3 | Deploy |  | 20d | 2024-12-18 A | 2025-01-14 A | 1257 | 100% |  |  |  | 2025-01-14 | 2025-01-14 | 0d |  |  | finish no earlier than 2025-01-14 | Helix | SIT |  | 6.13 | Complete | Helix | COMPLETE |  |  |  |
| 1259 | 1.4.1.4.5.4.4.3.4 | Knowledge Management Build & Configuration Complete | milestone | 0d | 2025-01-14 A | 2025-01-14 A | 1258 | 100% |  |  |  | 2025-01-14 | 2025-01-14 |  |  |  |  | Helix | SIT |  | 6.13 | Complete | Helix | COMPLETE |  |  |  |

Notes:
- 1254: 29/01/25 - Added baseline date.
- 1259: 29/01/25 - Added baseline date.

| ID | WBS | Task | Type | Duration | Start | Finish | Predecessors | Complete | Actual start | Actual finish | Baseline start | Baseline finish | Baseline duration | Constraint | Responsible | Text9 | Task Status | Update Version | Sched Status | MHHS Resource Name | RAG | Milestone ID | Text29 | Tier |
| --- | --- | --- | --- | --- | --- | --- | --- | --- | --- | --- | --- | --- | --- | --- | --- | --- | --- | --- | --- | --- | --- | --- | --- | --- |
| 1260 | 1.4.1.4.5.4.4.4 | **Problem Management Build & Configuration** |  | 1d? | 2024-08-01 | 2024-08-01 |  | 100% | 2024-10-02 | 2025-01-14 | 2024-10-02 | 2025-01-14 | 0d |  | Helix | SIT | -728.67 | 6.13 | Overdue Start | Helix |  |  |  |  |
| 1261 | 1.4.1.4.5.4.4.4.1 | Build |  | 40d | 2024-10-02 A | 2024-11-26 A |  | 100% |  |  | 2024-11-26 | 2024-11-26 | 0d | finish no earlier than 2024-11-26 | Helix | SIT |  | 6.13 | Complete | Helix | COMPLETE |  |  |  |
| 1262 | 1.4.1.4.5.4.4.4.2 | Test |  | 15d | 2024-11-27 A | 2024-12-17 A | 1261 | 100% |  |  | 2024-12-17 | 2024-12-17 | 0d | finish no earlier than 2024-12-17 | Helix | SIT |  | 6.13 | Complete | Helix | COMPLETE |  |  |  |
| 1263 | 1.4.1.4.5.4.4.4.3 | Deploy |  | 20d | 2024-12-18 A | 2025-01-14 A | 1262 | 100% |  |  | 2025-01-14 | 2025-01-14 | 0d | finish no earlier than 2025-01-14 | Helix | SIT |  | 6.13 | Complete | Helix | COMPLETE |  |  |  |
| 1264 | 1.4.1.4.5.4.4.4.4 | Problem Management Build & Configuration Complete | milestone | 0d | 2025-01-14 A | 2025-01-14 A | 1263 | 100% |  |  | 2025-01-14 | 2025-01-14 |  | start no earlier than 2025-01-14 | Helix | SIT |  | 6.13 | Complete | Helix | COMPLETE |  |  |  |
| 1265 | 1.4.1.4.5.4.4.5 | **Change Management Build & Configuration** |  | 75d? | 2024-10-02 A | 2025-01-14 A |  | 100% |  |  | 2024-10-02 | 2025-01-14 | 0d |  | Helix | SIT | -728.67 | 6.13 | Overdue Start | Helix |  |  |  |  |
| 1266 | 1.4.1.4.5.4.4.5.1 | Build |  | 40d | 2024-10-02 A | 2024-11-26 A |  | 100% |  |  | 2024-11-26 | 2024-11-26 | 0d | finish no earlier than 2024-11-26 | Helix | SIT |  | 6.13 | Complete | Helix | COMPLETE |  |  |  |
| 1267 | 1.4.1.4.5.4.4.5.2 | Test |  | 15d | 2024-11-27 A | 2024-12-17 A | 1266 | 100% |  |  | 2024-12-17 | 2024-12-17 | 0d | finish no earlier than 2024-12-17 | Helix | SIT |  | 6.13 | Complete | Helix | COMPLETE |  |  |  |
| 1268 | 1.4.1.4.5.4.4.5.3 | Deploy |  | 20d | 2024-12-18 A | 2025-01-14 A | 1267 | 100% |  |  | 2025-01-14 | 2025-01-14 | 0d | finish no earlier than 2025-01-14 | Helix | SIT |  | 6.13 | Complete | Helix | COMPLETE |  |  |  |
| 1269 | 1.4.1.4.5.4.4.5.4 | Change Management Build & Configuration Complete | milestone | 0d | 2025-01-14 A | 2025-01-14 A | 1268 | 100% |  |  | 2025-01-14 | 2025-01-14 |  | start no earlier than 2025-01-14 | Helix | SIT |  | 6.13 | Complete | Helix | COMPLETE |  |  |  |
| 1270 | 1.4.1.4.5.4.4.6 | **Service Catalogue Management Build & Configuration** |  | 75d? | 2024-10-02 A | 2025-01-14 A |  | 100% |  |  | 2024-10-02 | 2025-01-14 | 0d |  | Helix | SIT | -728.67 | 6.13 | Overdue Start | Helix |  |  |  |  |
| 1271 | 1.4.1.4.5.4.4.6.1 | Build |  | 40d | 2024-10-02 A | 2024-11-26 A |  | 100% |  |  | 2024-11-26 | 2024-11-26 | 0d | finish no earlier than 2024-11-26 | Helix | SIT |  | 6.13 | Complete | Helix | COMPLETE |  |  |  |
| 1272 | 1.4.1.4.5.4.4.6.2 | Test |  | 15d | 2024-11-27 A | 2024-12-17 A | 1271 | 100% |  |  | 2024-12-17 | 2024-12-17 | 0d | finish no earlier than 2024-12-17 | Helix | SIT |  | 6.13 | Complete | Helix | COMPLETE |  |  |  |
| 1273 | 1.4.1.4.5.4.4.6.3 | Deploy |  | 20d | 2024-12-18 A | 2025-01-14 A | 1272 | 100% |  |  | 2025-01-14 | 2025-01-14 | 0d | finish no earlier than 2025-01-14 | Helix | SIT |  | 6.13 | Complete | Helix | COMPLETE |  |  |  |
| 1274 | 1.4.1.4.5.4.4.6.4 | Service Catalogue Management Build & Configuration Complete | milestone | 0d | 2025-01-14 A | 2025-01-14 A | 1273 | 100% |  |  | 2025-01-14 | 2025-01-14 |  | start no earlier than 2025-01-14 | Helix | SIT |  | 6.13 | Complete | Helix | COMPLETE |  |  |  |
| 1275 | 1.4.1.4.5.4.4.7 | ServiceNow SIT Ops Available | milestone | 0d? | 2025-01-14 A | 2025-01-14 A | 1249, 1254, 1259, 1264, 1269, 1274 | 100% |  |  | 2025-01-14 | 2025-01-14 | 0d | start no earlier than 2024-09-09 | Helix | SIT |  | 6.13 | Complete | Helix | COMPLETE | T3-TE-0136 | SITAG | T3 |
| 1276 | 1.4.1.4.5.4.4.8 | **Helix Service Management Documentation (Service Design Pack)** |  | 115d | 2024-08-01 A | 2025-01-08 A |  | 100% |  |  | 2024-09-09 | 2025-01-31 | 0d |  | Helix | SIT | -49.67 | 6.0 | Overdue Start | Helix |  |  |  |  |
| 1277 | 1.4.1.4.5.4.4.8.1 | Document Drafting |  | 95d | 2024-08-01 A | 2024-12-11 A |  | 100% |  |  | 2024-08-01 | 2024-12-11 | 0d | finish no earlier than 2024-12-11 | Helix | SIT |  | 6.11 | Complete | Helix | COMPLETE |  |  |  |
| 1278 | 1.4.1.4.5.4.4.8.2 | Internal Elexon Review |  | 3d | 2025-01-06 A | 2025-01-08 A | 1277 | 100% |  |  | 2024-12-12 | 2024-12-16 | 0d | finish no earlier than 2024-12-16 | Helix | SIT |  | 6.11 | Complete | Helix | COMPLETE |  |  |  |
| 1279 | 1.4.1.4.5.4.4.8.3 | Elexon Service Panel Sign off | milestone | 0d | 2025-01-08 A | 2025-01-08 A | 1278 | 100% |  |  | 2024-12-20 | 2024-12-20 | 0d | start no earlier than 2024-12-20 | Helix | SIT |  | 6.11 | Complete | Helix | COMPLETE |  |  |  |
| 1280 | 1.4.1.4.5.4.5 | **Incident Management Support** |  | 1d? | 2022-10-31 | 2022-10-31 |  | 100% | 2024-12-02 | 2025-01-17 | 2022-10-31 | 2022-10-31 |  |  | Helix | SIT | -755.67 | 6.13 | Overdue Start | Helix | 25d |  |  |  |
| 1281 | 1.4.1.4.5.4.5.1 | Identify Relevant Stakeholders to Support Incident Management Process |  | 10d | 2024-12-02 A | 2024-12-13 A |  | 100% |  |  | 2024-11-18 | 2024-11-29 | 0d | start no earlier than 2024-12-02 | Helix | SIT |  | 6.13 | Complete | Helix | COMPLETE |  |  |  |
| 1282 | 1.4.1.4.5.4.5.2 | Schedule Time to Upskill Stakeholders |  | 5d | 2024-12-16 A | 2024-12-20 A | 1281 | 100% |  |  | 2024-12-02 | 2024-12-06 | 0d |  | Helix | SIT |  | 6.13 | Complete | Helix | COMPLETE |  |  |  |
| 1283 | 1.4.1.4.5.4.5.3 | Helix Stakeholders Attendance at MHHS Defect Triage Meetings [Meeting Dates to be Confirmed] |  | 10d | 2025-01-06 A | 2025-01-17 A | 1282FS+10d | 100% |  |  | 2024-12-09 | 2024-12-20 | 0d |  | Helix | SIT |  | 6.13 | Complete | Helix | COMPLETE |  |  |  |
| 1284 | 1.4.1.4.5.4.6 | SIT Service Readiness (Elexon & Helix) Completed | milestone | 0d | 2025-01-17 A | 2025-01-17 A | 1283 | 100% |  |  | 2024-12-20 | 2024-12-20 | 0d |  | Helix | SIT |  | 6.13 | Complete | Helix | COMPLETE |  |  |  |

Notes:
- 1264: 29/01/25 - Added baseline date.
- 1269: 29/01/25 - Added baseline date.
- 1274: 29/01/25 - Added baseline date.

| ID | WBS | Task | Type | Duration | Start | Finish | Predecessors | Complete | Remaining | Baseline start | Baseline finish | Baseline duration | Total slack | Free slack | Constraint | Responsible | Text9 | Update Version | Sched Status | MHHS Resource Name | RAG | Task Status | Milestone ID | Text29 | Tier |
| --- | --- | --- | --- | --- | --- | --- | --- | --- | --- | --- | --- | --- | --- | --- | --- | --- | --- | --- | --- | --- | --- | --- | --- | --- | --- |
| 1285 | 1.4.1.4.5.4.7 | **SIT Service Readiness (External Parties)** |  | 85d | 2024-10-07 A | 2025-01-31 |  | 99% | 0d | 2024-09-30 | 2025-01-06 | 0d | 754d |  |  | Helix | SIT | 6.13 | Overdue | Helix | GREEN |  |  |  |  |
| 1286 | 1.4.1.4.5.4.7.1 | **Helix Engagement & Comms** |  | 71d | 2024-10-07 A | 2025-01-13 A |  | 100% |  | 2024-09-30 | 2025-01-06 | 0d |  |  |  | Helix | SIT | 6.13 | Green | Helix | GREEN |  |  |  |  |
| 1287 | 1.4.1.4.5.4.7.1.1 | Engagement Execution |  | 71d | 2024-10-07 A | 2025-01-13 A |  | 100% |  | 2024-10-07 | 2025-01-06 | 0d |  |  | finish no earlier than 2025-01-13 | Helix | SIT | 6.13 | Complete | Helix | COMPLETE |  |  |  |  |
| 1288 | 1.4.1.4.5.4.7.1.2 | Information Gathering |  | 32d | 2024-11-29 A | 2025-01-13 A |  | 100% |  | 2024-10-31 | 2024-11-27 | 0d |  |  | finish no earlier than 2025-01-13 | Helix | SIT | 6.13 | Complete | Helix | COMPLETE |  |  |  |  |
| 1289 | 1.4.1.4.5.4.7.1.3 | SIT Participants Preparation |  | 9d | 2024-11-28 A | 2024-12-10 A |  | 100% |  | 2024-11-22 | 2025-01-06 | 0d |  |  | start no earlier than 2024-11-28 | Helix | SIT | 6.13 | Complete | Helix | COMPLETE |  |  |  |  |
| 1290 | 1.4.1.4.5.4.7.2 | SIT Service Readiness (External Parties) Completed | milestone | 0d | 2025-01-31 | 2025-01-31 | 1287FS+9d, 1288, 1289, 1307 |  |  | 2025-01-06 | 2025-01-06 | 0d | 754d | 0d |  | Helix | SIT | 6.13 | Red | Helix | RED | 2.71 |  |  |  |
| 1291 | 1.4.1.4.5.4.8 | **ServiceNow Support Portal Onboarding (Helix Suppliers & SIT Participants)** |  | 78d? | 2024-10-02 A | 2025-01-17 |  | 57% | 33.33d? | 2024-10-02 | 2025-01-17 | 0d |  |  |  | Helix | SIT | 6.13 | Overdue Start | Helix | RED | -755.67 |  |  |  |
| 1292 | 1.4.1.4.5.4.8.1 | **ServiceNow Portal Preparation and Planning** |  | 40d? | 2024-10-02 A | 2024-11-26 A |  | 100% |  | 2024-10-02 | 2024-11-26 | 0d |  |  |  | Helix | SIT | 6.13 | Overdue Start | Helix |  | -755.67 |  |  |  |
| 1293 | 1.4.1.4.5.4.8.1.1 | Define Supplier Requirements |  | 30d? | 2024-10-02 A | 2024-11-12 A |  | 100% |  | 2024-10-02 | 2024-11-12 | 0d |  |  | start no earlier than 2024-10-02 | Helix | SIT | 6.13 | Complete | Helix | COMPLETE |  |  |  |  |
| 1294 | 1.4.1.4.5.4.8.1.2 | Determine Supplier ServiceNow modules |  | 10d? | 2024-11-13 A | 2024-11-26 A | 1293 | 100% |  | 2024-11-13 | 2024-11-26 | 0d |  |  | finish no earlier than 2024-11-26 | Helix | SIT | 6.13 | Complete | Helix | COMPLETE |  |  |  |  |
| 1295 | 1.4.1.4.5.4.8.1.3 | Review compliance requirements, including data privacy and access limitations. |  | 10d? | 2024-11-13 A | 2024-11-26 A | 1293 | 100% |  | 2024-11-13 | 2024-11-26 | 0d |  |  | finish no earlier than 2024-11-26 | Helix | SIT | 6.13 | Complete | Helix | COMPLETE |  |  |  |  |
| 1296 | 1.4.1.4.5.4.8.1.4 | Conduct a security assessment to ensure the supplier complies with organisational policies. |  | 10d? | 2024-11-13 A | 2024-11-26 A | 1293 | 100% |  | 2024-11-13 | 2024-11-26 | 0d |  |  | finish no earlier than 2024-11-26 | Helix | SIT | 6.13 | Complete | Helix | COMPLETE |  |  |  |  |
| 1297 | 1.4.1.4.5.4.8.2 | **ServiceNow Portal System Configuration** |  | 48d? | 2024-11-27 A | 2025-01-31 |  | 41% | 28.22d? | 2024-11-27 | 2025-01-07 | 0d |  |  |  | Helix | SIT | 6.13 | Overdue Start | Helix |  | -755.67 |  |  |  |
| 1298 | 1.4.1.4.5.4.8.2.1 | Create Supplier User Accounts |  | 48d | 2024-11-27 A | 2025-01-31 | 1296 | 59% | 19.62d | 2024-11-27 | 2024-12-10 | 0d | 754d | 0d | finish no earlier than 2025-01-31 | Helix | SIT | 6.13 | Red | Helix | RED |  |  |  |  |
| 1299 | 1.4.1.4.5.4.8.2.2 | Assign appropriate access based on the supplier’s needs and security requirements (e.g., read-only access, submit requests, etc.). |  | 25d? | 2024-12-30 A | 2025-01-31 | 1298FF | 24% | 19d? | 2024-12-11 | 2024-12-24 | 0d | 754d | 0d | finish no earlier than 2024-12-24 | Helix | SIT | 6.13 | Red | Helix | RED |  |  |  |  |
| 1300 | 1.4.1.4.5.4.8.2.3 | Configure Access Controls |  | 25d? | 2024-12-30 A | 2025-01-31 | 1299FF | 24% | 19d? | 2024-12-25 | 2025-01-07 | 0d | 754d | 0d | finish no earlier than 2025-01-07 | Helix | SIT | 6.13 | Red | Helix | RED |  |  |  |  |
| 1301 | 1.4.1.4.5.4.8.3 | **ServiceNow Portal Training and Documentation** |  | 20d? | 2025-01-06 A | 2025-01-31 |  | 24% | 15.24d? | 2025-01-06 | 2025-01-10 | 0d |  |  |  | Helix | SIT | 6.13 | Overdue Start | Helix |  | -755.67 |  |  |  |
| 1302 | 1.4.1.4.5.4.8.3.1 | Provide Training to the Supplier |  | 1d | 2025-01-31 | 2025-01-31 |  |  |  | 2025-01-06 | 2025-01-10 | 0d | 754d | 0d | finish no earlier than 2025-01-31 | Helix | SIT | 6.13 | Red | Helix | RED | 2.33 |  |  |  |
| 1303 | 1.4.1.4.5.4.8.3.2 | Create Supplier Training Documentation |  | 20d | 2025-01-06 A | 2025-01-31 |  | 25% | 15d | 2025-01-06 | 2025-01-10 | 0d | 754d | 0d | finish no earlier than 2025-01-31 | Helix | SIT | 6.13 | Red | Helix | RED |  |  |  |  |
| 1304 | 1.4.1.4.5.4.8.4 | **ServiceNow Portal Testing and Validation** |  | 18d | 2025-01-08 | 2025-01-31 |  |  |  | 2025-01-08 | 2025-01-17 | 0d |  |  |  | Helix | SIT | 6.13 | Overdue Start | Helix |  | -755.67 |  |  |  |
| 1305 | 1.4.1.4.5.4.8.4.1 | Conduct User Acceptance Testing (UAT) |  | 1d | 2025-01-31 | 2025-01-31 | 1302SS |  |  | 2025-01-13 | 2025-01-17 | 0d | 754d |  | finish no earlier than 2025-01-17 | Helix | SIT | 6.13 | Red | Helix | RED | 2.33 |  |  |  |
| 1306 | 1.4.1.4.5.4.8.4.2 | Validate Access and Security Controls |  | 4d | 2025-01-28 | 2025-01-31 |  |  |  | 2025-01-13 | 2025-01-17 | 0d | 754d | 0d | finish no earlier than 2025-01-31 | Helix | SIT | 6.13 | Red | Helix | RED | -0.67 |  |  |  |
| 1307 | 1.4.1.4.5.4.8.5 | ServiceNow Support Portal Onboarding (Helix Suppliers& SIT Participants) Completed | milestone | 0d | 2025-01-31 | 2025-01-31 | 1296, 1300, 1303, 1306, 1302 |  |  | 2025-01-17 | 2025-01-17 | 0d | 754d | 0d | start no earlier than 2025-01-17 | Helix | SIT | 6.13 | Red | Helix | RED | 2.71 |  |  |  |
| 1308 | 1.4.1.4.5.4.9 | Stage 1 - Helix SIT Operational Readiness Completed | milestone | 0d | 2025-01-31 | 2025-01-31 | 1290, 1275, 1243 |  |  | 2025-01-31 | 2025-01-31 | 0d | 754d |  | start no earlier than 2025-01-31 | Helix | SIT | 6.13 | Green | Helix | GREEN | 2.71 | T3-TE-0137 | SITAG | T3 |

Notes:
- 1290: 27/01/25 - External party readiness for SIT Service was delayed because onboarding and training of external parties has taken longer than expected. Readiness will be compeleted by 31/01/25, allowing SIT Ops Theme 3 (Batch 1) testing to commence on 03/02/25 as planned.
- 1298: 27/01/25 - Delay in collating user info has delayed completion of this activity, but Helix will have this completed by 31/01/25, in time for SIT Ops Theme 3 (Batch 1) to start on 03/02/25, as planned.
- 1299: 27/01/25 - Delay in collating user info has delayed completion of this activity, but Helix now have this completed by 31/01/25, in time for SIT Ops Theme 3 (Batch 1) to start on 03/02/25, as planned.
- 1300: 27/01/25 - Delay in collating user info has delayed completion of this activity, but Helix now have this completed by 31/01/25, in time for SIT Ops Theme 3 (Batch 1) to start on 03/02/25, as planned.
- 1302: 27/01/25 - Training for ServiceNow has been shifted a few times, to ensure that it works for Suppliers, hence why the forecast has shifted behind the baseline. Training dates have now been confirmed and will be completed by 31/01/25, in time for SIT Ops Theme 3 (Batch 1) to start on 03/02/25, as planned.
- 1303: 27/01/25 - On track for completion for 31/01/25, in time for SIT Ops Theme 3 (Batch 1) to start on 03/02/25, as planned.
- 1307: 27/01/25 - Onboarding deadline has been updated to reflect updated supplier ServiceNow training. This will be completed by 31/01/25, in time for SIT Ops Theme 3 (Batch 1) to start on 03/02/25, as planned.
- 1308: 27/01/25 - Helix confirmed they are on track to complete their Operational Readiness on 31/01/25, in time for SIT Ops Theme 3 (Batch 1) to start on 03/02/25, as planned.

| ID | WBS | Task | Type | Duration | Start | Finish | Predecessors | Complete | Baseline start | Baseline finish | Baseline duration | Constraint | Baseline cost | Responsible | Involved | Text9 | Task Status | Update Version | MHHS Resource Name | MHHS Programme Phase | Text29 | Sched Status | RAG | Milestone ID | Tier | Guidance |
| --- | --- | --- | --- | --- | --- | --- | --- | --- | --- | --- | --- | --- | --- | --- | --- | --- | --- | --- | --- | --- | --- | --- | --- | --- | --- | --- |
| 1309 | 1.4.1.4.5.4.10 | **Theme 3 (Batch 2)** |  | 65d | 2024-09-19 A | 2024-12-18 A |  | 100% | 2024-09-19 | 2024-12-11 | 116d |  | -0 | N/A | N/A | SIT | -448.67 | 6.0 | Steve Evans | Systems Integration Testing (SIT) | SITAG |  |  |  |  |  |
| 1310 | 1.4.1.4.5.4.10.1 | Conclude BCDR Scope with SRO, Code Bodies and DIP Manager |  | 22d | 2024-09-19 A | 2024-10-18 A |  | 100% | 2024-09-19 | 2024-10-18 | 0d | start no earlier than 2024-09-19 |  |  |  | SIT |  | 6.0 | Steve Evans |  | SITAG | Complete | COMPLETE |  |  |  |
| 1311 | 1.4.1.4.5.4.10.2 | Develop BDCR Test Scenarios & Test Cases (Batch 2) |  | 10d | 2024-10-14 A | 2024-10-25 A | 1310 | 100% | 2024-10-14 | 2024-10-25 | 0d |  |  |  |  | SIT |  | 6.0 | Steve Evans |  | SITAG | Complete | COMPLETE |  |  |  |
| 1312 | 1.4.1.4.5.4.10.3 | Develop DIP Test Scenarios and Test Cases (Batch 2) |  | 27d | 2024-09-19 A | 2024-10-25 A |  | 100% | 2024-09-19 | 2024-10-25 | 0d | start no earlier than 2024-09-19 |  |  |  | SIT |  | 6.0 | Steve Evans |  | SITAG | Complete | COMPLETE |  |  |  |
| 1313 | 1.4.1.4.5.4.10.4 | SRO Review |  | 5d | 2024-10-28 A | 2024-11-01 A | 1312 | 100% | 2024-10-28 | 2024-11-01 | 0d | start no earlier than 2024-10-28 |  |  |  | SIT |  | 6.0 | Steve Evans |  | SITAG | Complete | COMPLETE |  |  |  |
| 1314 | 1.4.1.4.5.4.10.5 | Industry Consultation (Batch 2) |  | 10d | 2024-11-11 A | 2024-11-22 A | 1313 | 100% | 2024-11-11 | 2024-11-22 | 1d |  |  | SI Test, PP | SI Test, PP | SIT |  | 6.0 | Steve Evans |  | SITAG | Complete | COMPLETE |  |  |  |
| 1315 | 1.4.1.4.5.4.10.6 | Review Feedback and Update |  | 4d | 2024-11-25 A | 2024-11-28 A | 1314 | 100% | 2024-11-25 | 2024-11-29 | 0d |  |  | SI Test |  | SIT |  | 6.13 | Steve Evans |  | SITAG | Complete | COMPLETE |  |  |  |
| 1316 | 1.4.1.4.5.4.10.7 | SITWG paper day | milestone | 0d | 2024-11-28 A | 2024-11-28 A | 1315 | 100% | 2024-11-28 | 2024-11-28 | 0d |  |  |  |  | SIT |  | 6.13 | Steve Evans |  | SITAG | Complete | COMPLETE |  |  |  |
| 1317 | 1.4.1.4.5.4.10.8 | Review with SIT WG (Batch 2) |  | 5d | 2024-11-29 A | 2024-12-05 A | 1316 | 100% | 2024-11-29 | 2024-12-05 | 0d |  |  | SI Test |  | SIT |  | 6.13 | Steve Evans |  | SITAG | Complete | COMPLETE |  |  |  |
| 1318 | 1.4.1.4.5.4.10.9 | SITWG endorse Theme 3 (Batch 2) | milestone | 0d | 2024-12-05 A | 2024-12-05 A | 1317 | 100% | 2024-12-05 | 2024-12-05 | 0d |  |  |  |  | SIT |  | 6.13 | Steve Evans |  | SITAG | Complete | COMPLETE |  |  |  |
| 1319 | 1.4.1.4.5.4.10.10 | SITAG paper day | milestone | 0d | 2024-12-11 A | 2024-12-11 A | 1318FS+4d | 100% | 2024-12-11 | 2024-12-11 | 0d |  |  |  |  | SIT |  | 6.13 | Steve Evans |  | SITAG | Complete | COMPLETE |  |  |  |
| 1320 | 1.4.1.4.5.4.10.11 | SITAG approve Theme 3 (Batch 2) |  | 1d | 2024-12-18 A | 2024-12-18 A | 1319FS+4d | 100% | 2024-12-18 | 2024-12-18 | 0d |  |  | SI Test |  | SIT |  | 6.13 | Steve Evans |  | SITAG | Complete | COMPLETE | T3-TE-0138 | T3 |  |
| 1321 | 1.4.1.4.5.4.11 | **Theme 3 (Batch 1)** |  | 181d? | 2024-04-10 A | 2024-12-18 A |  | 100% | 2024-04-10 | 2024-12-11 | 0d |  |  | SI Test |  | SIT | -688.67 | 6.0 | Steve Evans |  | SITAG | Overdue Start |  |  |  |  |
| 1322 | 1.4.1.4.5.4.11.1 | Develop Test Scenarios & Test Cases (Batch 1) |  | 78d | 2024-04-10 A | 2024-07-26 A | 1195 | 100% | 2024-04-10 | 2024-07-26 | 46d |  |  | SI Test | SI Test, PP | SIT |  | 6.0 | Steve Evans |  | SITAG | Complete | COMPLETE |  |  |  |
| 1323 | 1.4.1.4.5.4.11.2 | Conclude Industry Consultation (Batch 1) |  | 11d | 2024-09-05 A | 2024-09-19 A |  | 100% | 2024-09-05 | 2024-09-19 | 0d | start no earlier than 2024-09-05 |  | SI Test |  | SIT |  | 6.0 | Steve Evans |  | SITAG | Complete | COMPLETE |  |  |  |
| 1324 | 1.4.1.4.5.4.11.3 | Review Feedback and Update |  | 5d | 2024-09-20 A | 2024-09-26 A | 1323 | 100% | 2024-09-20 | 2024-09-26 | 0d |  |  | SI Test |  | SIT |  | 6.0 | Steve Evans |  | SITAG | Complete | COMPLETE |  |  |  |
| 1325 | 1.4.1.4.5.4.11.4 | Draft Test Cases from Feedback and LLSD |  | 15d? | 2024-09-30 A | 2024-10-18 A | 1324FS+1d, 1337 | 100% | 2024-09-30 | 2024-10-18 | 0d |  |  | SI Test |  | SIT |  | 6.0 | Steve Evans |  | SITAG | Complete | COMPLETE |  |  |  |
| 1326 | 1.4.1.4.5.4.11.5 | SRO Review |  | 5d? | 2024-10-21 A | 2024-10-25 A | 1325 | 100% | 2024-10-21 | 2024-10-25 | 0d |  |  | SI Test |  | SIT |  | 6.0 | Steve Evans |  | SITAG | Complete | COMPLETE |  |  |  |
| 1327 | 1.4.1.4.5.4.11.6 | Industry Consultation |  | 10d? | 2024-10-28 A | 2024-11-08 A | 1326 | 100% | 2024-10-28 | 2024-11-08 | 0d |  |  | SI Test |  | SIT |  | 6.0 | Steve Evans |  | SITAG | Complete | COMPLETE |  |  |  |
| 1328 | 1.4.1.4.5.4.11.7 | Review Feedback and Update |  | 10d | 2024-11-11 A | 2024-11-22 A | 1327 | 100% | 2024-11-11 | 2024-11-15 | 0d |  |  | SI Test |  | SIT |  | 6.0 | Steve Evans |  | SITAG | Complete | COMPLETE |  |  |  |
| 1329 | 1.4.1.4.5.4.11.8 | SITWG paper day | milestone | 0d | 2024-11-28 A | 2024-11-28 A | 1328FS+4d | 100% | 2024-11-28 | 2024-11-28 |  |  |  |  |  | SIT |  | 6.13 | Steve Evans |  | SITAG | Complete | COMPLETE |  |  |  |
| 1330 | 1.4.1.4.5.4.11.9 | Review with SITWG (Batch 1) |  | 5d | 2024-11-29 A | 2024-12-05 A | 1329 | 100% | 2024-11-29 | 2024-12-05 | 0d |  |  | SI Test |  | SIT |  | 6.13 | Steve Evans |  | SITAG | Complete | COMPLETE |  |  |  |
| 1331 | 1.4.1.4.5.4.11.10 | SITWG endorse Theme 3 (Batch 1) | milestone | 0d | 2024-12-05 A | 2024-12-05 A | 1330 | 100% | 2024-12-05 | 2024-12-05 |  |  |  |  |  | SIT |  | 6.13 | Steve Evans |  | SITAG | Complete | COMPLETE |  |  |  |
| 1332 | 1.4.1.4.5.4.11.11 | SITAG paper day | milestone | 0d | 2024-12-11 A | 2024-12-11 A | 1331FS+4d | 100% | 2024-12-11 | 2024-12-11 |  |  |  |  |  | SIT |  | 6.13 | Steve Evans |  | SITAG | Complete | COMPLETE |  |  |  |
| 1333 | 1.4.1.4.5.4.11.12 | SITAG approve Theme 3 (Batch 1) | milestone | 0d | 2024-12-18 A | 2024-12-18 A | 1332FS+5d | 100% | 2024-12-18 | 2024-12-18 | 0d |  |  | SI Test |  | SIT |  | 6.13 | Steve Evans |  | SITAG | Complete | COMPLETE | T3-TE-0139 | T3 |  |
| 1334 | 1.4.1.4.5.4.11.13 | SIT Operational Scenarios & Test Cases Approved - Theme 3 (Batch 1 + 2) | milestone | 0d | 2024-12-18 A | 2024-12-18 A | 1337, 1320, 1333 | 100% | 2024-12-18 | 2024-12-18 | 0d |  |  | SI Test | SI Test, PP | SIT |  | 6.13 | Steve Evans | Systems Integration Testing (SIT) | SITAG | Complete | COMPLETE | T3-TE-0119 | T3 | 31/7/24: baseline date change approved at esitag on 26/7/24 |

Notes:
- 1318: 28/01/24 - This was endorsed with caveat that two test cases should be descoped, but this does not impact successor activity and still meant Batch was endorsed. Programme will consult industry on these two cases, with a date to be confirmed.

| ID | WBS | Task | Type | Duration | Start | Finish | Predecessors | Complete | Remaining | Baseline start | Baseline finish | Baseline duration | Baseline 1 start | Baseline 1 finish | Constraint | Baseline cost | Responsible | Text9 | Task Status | Update Version | Sched Status | MHHS Resource Name | Text29 | RAG | Involved | MHHS Programme Phase | Milestone ID |
| --- | --- | --- | --- | --- | --- | --- | --- | --- | --- | --- | --- | --- | --- | --- | --- | --- | --- | --- | --- | --- | --- | --- | --- | --- | --- | --- | --- |
| 1335 | 1.4.1.4.5.4.12 | **Helix SDD and LLSD Development and Approval** |  | 1d | 2024-09-27 A | 2024-09-30 A |  | 100% |  | 2024-09-27 | 2024-09-30 | 0d |  |  |  |  | SI Test | SIT | -688.67 | 6.0 | Overdue Start | Steve Evans | SITAG |  |  |  |  |
| 1336 | 1.4.1.4.5.4.12.1 | Development | milestone | 0d | 2024-09-27 A | 2024-09-27 A |  | 100% |  | 2024-09-27 | 2024-09-27 | 0d |  |  | start no earlier than 2024-09-27 |  | SI Test | SIT |  | 6.0 | Complete | Steve Evans | SITAG | COMPLETE |  |  |  |
| 1337 | 1.4.1.4.5.4.12.2 | Approval | milestone | 0d | 2024-09-30 A | 2024-09-30 A |  | 100% |  | 2024-09-30 | 2024-09-30 | 0d |  |  | start no earlier than 2024-09-30 |  | SI Test | SIT |  | 6.0 | Complete | Steve Evans | SITAG | COMPLETE |  |  |  |
| 1338 | 1.4.1.4.5.5 | **SIT Operational Programme RTTM (Theme 3 (Batch 1))** |  | 35d | 2024-12-09 A | 2025-01-24 A |  | 100% |  | 2024-12-12 | 2025-01-17 | 0d |  |  |  |  | SI Test | SIT | -686.67 | 6.12 | Overdue Start | Steve Evans | SITAG |  |  |  |  |
| 1339 | 1.4.1.4.5.5.1 | Develop SIT Operational Theme 3 (Batch 1) RTTM |  | 25d | 2024-12-09 A | 2025-01-10 A | 1334FF | 100% |  | 2024-12-12 | 2025-01-10 | 0d |  |  |  |  | SI Test | SIT |  | 6.16 | Complete | Steve Evans | SITAG | COMPLETE |  |  |  |
| 1340 | 1.4.1.4.5.5.2 | SRO review of Manual SIT Operational Theme 3 (Batch 1) RTTM |  | 5d | 2025-01-13 A | 2025-01-17 A | 1339 | 100% |  | 2025-01-13 | 2025-01-17 |  |  |  |  |  |  | SIT |  | 6.16 | Complete | Steve Evans | SITAG | COMPLETE |  |  |  |
| 1341 | 1.4.1.4.5.5.3 | DIP Manager / Code Bodies / Full SRO to review |  | 5d | 2025-01-20 A | 2025-01-24 A | 1340 | 100% |  | 2025-01-20 | 2025-01-24 |  |  |  |  |  |  | SIT |  | 6.16 | Complete | Steve Evans | SITAG | COMPLETE |  |  |  |
| 1342 | 1.4.1.4.5.5.4 | DIP Manager / Code Bodies / Full SRO acceptance of Theme 3 (Batch 1) Operational RTTM | milestone | 0d | 2025-01-24 A | 2025-01-24 A | 1341 | 100% |  | 2025-01-24 | 2025-01-24 | 0d |  |  |  |  |  | SIT |  | 6.16 | Complete | Steve Evans | SITAG | COMPLETE |  |  |  |
| 1343 | 1.4.1.4.5.5.5 | SIT Operational RTTM Complete | milestone | 0d | 2025-01-24 A | 2025-01-24 A | 1339, 1342 | 100% |  | 2025-01-10 | 2025-01-10 | 0d |  |  |  |  | SI Test | SIT |  | 6.12 | Complete | Steve Evans | SITAG | COMPLETE |  |  |  |
| 1344 | 1.4.1.4.5.6 | **SIT Operational Theme 3 (Batch 1) DITL** |  | 17d | 2025-01-06 A | 2025-01-28 A |  | 100% |  | 2024-10-08 | 2024-10-17 | 0d |  |  |  |  | SI Test | SIT | 6.33 | 6.15 | No BL | Steve Evans | SITAG |  |  |  |  |
| 1345 | 1.4.1.4.5.6.1 | DITL + Familiarisation session development |  | 8d | 2025-01-06 A | 2025-01-15 A |  | 100% |  | 2025-01-06 | 2025-01-17 | 0d |  |  | start no earlier than 2025-01-06 |  | SI Test | SIT |  | 6.15 | Complete | Steve Evans | SITAG | COMPLETE |  |  |  |
| 1346 | 1.4.1.4.5.6.2 | SRO Review |  | 5d | 2025-01-16 A | 2025-01-22 A | 1345 | 100% |  | 2025-01-20 | 2025-01-24 | 0d |  |  |  |  | SI Test | SIT |  | 6.15 | Complete | Steve Evans | SITAG | COMPLETE |  |  |  |
| 1347 | 1.4.1.4.5.6.3 | Post-SRO Review Changes |  | 2d | 2025-01-23 A | 2025-01-24 A | 1346 | 100% |  | 2025-01-23 | 2025-01-24 |  |  |  |  |  |  | SIT |  | 6.16 | Complete | Steve Evans |  | COMPLETE |  |  |  |
| 1348 | 1.4.1.4.5.6.4 | Familiarisation session Service Management test case schedule + mapping | milestone | 0d | 2025-01-24 A | 2025-01-24 A | 1347 | 100% |  | 2025-01-24 | 2025-01-24 |  |  |  |  |  |  | SIT |  | 6.16 | Complete | Steve Evans |  | COMPLETE |  |  |  |
| 1349 | 1.4.1.4.5.6.5 | Publish Cycle 3 DITL / Cycle 3 DITL Online Sessions for SIT PPs | milestone | 0d | 2025-01-28 A | 2025-01-28 A | 1348FS+2d | 100% |  | 2025-01-28 | 2025-01-28 | 0d |  |  |  |  | SI Test | SIT |  | 6.16 | Complete | Steve Evans | SITAG | COMPLETE |  |  |  |
| 1350 | 1.4.1.4.5.7 | **Defect Management** |  | 15d? | 2025-01-06 A | 2025-01-24 A |  | 100% |  | 2025-01-06 | 2025-01-24 |  |  |  |  |  |  | SIT | -807.67 | 6.17 |  |  |  |  |  |  |  |
| 1351 | 1.4.1.4.5.7.1 | Develop defect management approach |  | 10d? | 2025-01-06 A | 2025-01-17 A |  | 100% |  | 2025-01-06 | 2025-01-17 |  |  |  | start no earlier than 2025-01-06 |  |  | SIT |  | 6.17 | Complete |  |  | COMPLETE |  |  |  |
| 1352 | 1.4.1.4.5.7.2 | Defect management approach agreed |  | 5d? | 2025-01-20 A | 2025-01-24 A | 1351 | 100% |  | 2025-01-20 | 2025-01-24 |  |  |  |  |  |  | SIT |  | 6.17 | Complete |  |  | COMPLETE |  |  |  |
| 1353 | 1.4.1.4.5.8 | **Environments (SIT B)** |  | 0d | 2024-10-07 A | 2024-10-07 A |  | 100% |  | 2024-10-07 | 2024-10-07 | 0d | 2024-09-03 | 2024-09-09 |  | -0 | N/A | SIT |  | 5.0 |  | Heath Thomas | SITAG |  | N/A | Systems Integration Testing (SIT) |  |
| 1354 | 1.4.1.4.5.8.1 | **PP Environments (SIT B)** |  | 0d | 2024-10-07 A | 2024-10-07 A |  | 100% |  | 2024-10-07 | 2024-10-07 | 0d | 2024-09-03 | 2024-09-09 |  | -0 | N/A | SIT |  | 5.0 |  | Heath Thomas | SITAG |  | N/A | Systems Integration Testing (SIT) |  |
| 1355 | 1.4.1.4.5.8.1.1 | Deployment of MHHS solution code to SIT B environments | milestone | 0d | 2024-10-07 A | 2024-10-07 A | 141 | 100% |  | 2024-10-07 | 2024-10-07 | 0d | 2024-09-03 | 2024-09-09 | start no earlier than 2024-08-27 |  | PP | SIT |  | 5.21 | Complete | Heath Thomas | SITAG | COMPLETE | SI Test | Systems Integration Testing (SIT) |  |
| 1356 | 1.4.1.4.5.8.2 | **SI Environments (SIT B)** |  | 0d | 2024-10-07 A | 2024-10-07 A |  | 100% |  | 2024-10-07 | 2024-10-07 | 0d | 2024-09-03 | 2024-09-09 |  | -0 | N/A | SIT |  | 5.0 |  | Heath Thomas | SITAG |  | N/A | Systems Integration Testing (SIT) |  |
| 1357 | 1.4.1.4.5.8.2.1 | Coordinate deployment of MHHS solution code to SIT Participants' SIT B environments | milestone | 0d | 2024-10-07 A | 2024-10-07 A | 1355SS | 100% |  | 2024-10-07 | 2024-10-07 | 0d | 2024-09-03 | 2024-09-09 |  |  | SI Test | SIT |  | 5.21 | Complete | Heath Thomas | SITAG | COMPLETE | PP | Systems Integration Testing (SIT) |  |
| 1358 | 1.4.1.4.6 | **SIT Operational Overarching Test Readiness Reports** |  | 33d? | 2024-08-05 A | 2024-09-18 |  | 41% | 19.49d? | 2024-08-05 | 2024-09-18 | 151d | 2025-01-07 | 2025-03-03 |  | -0 | N/A | SIT |  | 6.0 |  | Steve Evans | SITAG |  | N/A | Systems Integration Testing (SIT) |  |
| 1359 | 1.4.1.4.6.1 | **SI SIT Operational Theme 3 (Batch 1) Overarching Test Readiness Report** |  | 31d? | 2024-12-18 A | 2025-01-29 A |  | 100% |  | 2024-12-23 | 2025-01-29 |  |  |  |  |  | SI Test | SIT | -135.67 | 6.17 |  | Steve Evans | SITAG |  |  |  |  |
| 1360 | 1.4.1.4.6.1.1 | Develop Overarching SIT Operational Theme 3 (Batch 1) Overarching Test Readiness Report |  | 20d | 2024-12-18 A | 2025-01-14 A | 418FF | 100% |  | 2024-12-18 | 2025-01-14 |  |  |  | finish no earlier than 2025-01-14 |  |  | SIT |  | 6.17 | Complete | Steve Evans | SITAG | COMPLETE |  |  |  |
| 1361 | 1.4.1.4.6.1.2 | SRO review |  | 5d | 2025-01-08 A | 2025-01-14 A | 1360FF | 100% |  | 2025-01-08 | 2025-01-14 |  |  |  | finish no earlier than 2025-01-13 |  |  | SIT |  | 6.17 | Complete | Steve Evans | SITAG | COMPLETE |  |  |  |
| 1362 | 1.4.1.4.6.1.3 | SITWG Paper day | milestone | 0d | 2025-01-14 A | 2025-01-14 A | 1361 | 100% |  | 2025-01-14 | 2025-01-14 |  |  |  | finish no earlier than 2025-01-14 |  |  | SIT |  | 6.17 | Complete | Steve Evans | SITAG | COMPLETE |  |  |  |
| 1363 | 1.4.1.4.6.1.4 | SITWG review the Operational Theme 3 (Batch 1) Overarching Test Readiness Report | milestone | 0d | 2025-01-21 A | 2025-01-21 A | 1362FS+5d | 100% |  | 2025-01-21 | 2025-01-21 |  |  |  | finish no earlier than 2025-01-21 |  |  | SIT |  | 6.17 | Complete | Steve Evans | SITAG | COMPLETE |  |  |  |
| 1364 | 1.4.1.4.6.1.5 | Update Operational Theme 3 (Batch 1) Overarching Test Readiness Report following SRO / SITWG feedback |  | 1d | 2025-01-22 A | 2025-01-22 A | 1363 | 100% |  | 2025-01-22 | 2025-01-22 |  |  |  | start no earlier than 2025-01-22 |  |  | SIT |  | 6.17 | Complete | Steve Evans | SITAG | COMPLETE |  |  |  |
| 1365 | 1.4.1.4.6.1.6 | SITAG paper day | milestone | 0d | 2025-01-22 A | 2025-01-22 A | 1364 | 100% |  | 2025-01-22 | 2025-01-22 |  |  |  | finish no earlier than 2025-01-22 |  |  | SIT |  | 6.17 | Complete | Steve Evans | SITAG | COMPLETE |  |  |  |
| 1366 | 1.4.1.4.6.1.7 | FTIG recommendation | milestone | 0d | 2025-01-24 A | 2025-01-24 A | 1364FS+2d | 100% |  | 2025-01-24 | 2025-01-24 | 0d |  |  |  |  |  | SIT |  | 6.17 | Complete |  |  | COMPLETE |  |  |  |
| 1367 | 1.4.1.4.6.1.8 | Republish Operational Theme 3 (Batch 1) Overarching Test Readiness Report with latest data and evidence |  | 1d? | 2025-01-27 A | 2025-01-27 A | 1365FS+2d | 100% |  | 2025-01-27 | 2025-01-27 |  |  |  |  |  |  | SIT |  | 6.17 | Complete |  |  | COMPLETE |  |  |  |
| 1368 | 1.4.1.4.6.1.9 | SITAG approve Theme 3 (Batch 1) Test Readiness Report | milestone | 0d | 2025-01-29 A | 2025-01-29 A | 1365FS+5d, 1243, 1367 | 100% |  | 2025-01-29 | 2025-01-29 |  |  |  | finish no earlier than 2025-01-29 |  | SI Test | SIT |  | 6.17 | Complete | Steve Evans | SITAG | COMPLETE |  |  | T3-TE-0192 |

Notes:
- 1351: 29/01/25 - Added baseline date.
- 1352: 29/01/25 - Added baseline date.
- 1360: 29/01/25 - SITAG approved an updated governance timeframes for the NF and Ops Overarching Test Readiness Report, this activity has been rebaselined to reflect this.
- 1361: 29/01/25 - SITAG approved updated governance timeframes for the NF and Ops Overarching Test Readiness Report, this activity has been rebaselined to reflect this.
- 1362: 29/01/25 - SITAG approved updated governance timeframes for the NF and Ops Overarching Test Readiness Report, this activity has been rebaselined to reflect this.
- 1363: 29/01/25 - SITAG approved updated governance timeframes for the NF and Ops Overarching Test Readiness Report, this activity has been rebaselined to reflect this.
- 1364: 29/01/25 - SITAG approved an updated governance approach for the NF and Ops Overarching Test Readiness Report, this activity has been rebaselined to reflect this.
- 1365: 29/01/25 - SITAG approved an updated governance approach for the NF and Ops Overarching Test Readiness Report, this activity has been rebaselined to reflect this.
- 1366: 29/01/25 - SITAG approved an updated governance approach for the NF and Ops Overarching Test Readiness Report, this activity has been rebaselined to reflect this.
- 1367: 29/01/25 - SITAG approved an updated governance approach for the NF and Ops Overarching Test Readiness Report, this activity has been rebaselined to reflect this.
- 1368: 29/01/25 - SITAG approved the creation of a milestone ID for this activity in January.

| ID | WBS | Task | Type | Duration | Start | Finish | Predecessors | Complete | Remaining | Actual start | Actual finish | Baseline start | Baseline finish | Baseline duration | Total slack | Free slack | Constraint | Responsible | Text9 | Task Status | Update Version | MHHS Resource Name | Text29 | Sched Status | RAG | Milestone ID |
| --- | --- | --- | --- | --- | --- | --- | --- | --- | --- | --- | --- | --- | --- | --- | --- | --- | --- | --- | --- | --- | --- | --- | --- | --- | --- | --- |
| 1369 | 1.4.1.4.6.2 | **SI SIT Operational Theme 1, 2 and 3 (Batch 2) Overarching Test Readiness Report** |  | 45d | 2025-01-27 A | 2025-03-28 |  | 3% | 43.82d |  |  | 2025-01-27 | 2025-03-28 |  | 714d |  |  | SI Test | SIT | -135.67 | 6.17 | Steve Evans | SITAG |  |  |  |
| 1370 | 1.4.1.4.6.2.1 | Develop Overarching SIT Operational Theme 1, 2 and 3 (Batch 2) Overarching Test Readiness Report |  | 20d | 2025-01-27 A | 2025-02-21 | 401FS+25d | 5% | 19d |  |  | 2025-01-27 | 2025-02-21 |  | 734d | 0d | start no earlier than 2025-01-20 |  | SIT |  | 6.17 | Steve Evans | SITAG | Green | GREEN |  |
| 1371 | 1.4.1.4.6.2.2 | SRO review |  | 5d | 2025-02-24 | 2025-02-28 | 1370 |  |  |  |  | 2025-02-24 | 2025-02-28 |  | 734d |  |  |  | SIT | 26.33 | 6.17 | Steve Evans | SITAG | Green | GREEN |  |
| 1372 | 1.4.1.4.6.2.3 | SITWG Paper day | milestone | 0d | 2025-02-27 | 2025-02-27 |  |  |  |  |  | 2025-02-27 | 2025-02-27 |  | 735d | 0d | finish no earlier than 2025-02-27 |  | SIT | 29.71 | 6.17 | Steve Evans | SITAG | Green | GREEN |  |
| 1373 | 1.4.1.4.6.2.4 | SITWG review the Operational Theme 1, 2 and 3 (Batch 2) Overarching Test Readiness Report | milestone | 0d | 2025-03-06 | 2025-03-06 | 1372SS+5d |  |  |  |  | 2025-03-06 | 2025-03-06 |  | 25d | 0d |  |  | SIT | 36.71 | 6.17 | Steve Evans | SITAG | Green | GREEN |  |
| 1374 | 1.4.1.4.6.2.5 | Update Operational Theme 1, 2 and 3 (Batch 2) Overarching Test Readiness Report following SRO feedback |  | 13d | 2025-03-07 | 2025-03-25 | 1373 |  |  |  |  | 2025-03-07 | 2025-03-25 |  | 717d | 1d | start no earlier than 2025-03-07 |  | SIT | 37.33 | 6.17 | Steve Evans | SITAG | Green | GREEN |  |
| 1375 | 1.4.1.4.6.2.6 | FTIG recommendation | milestone | 0d | 2025-03-21 | 2025-03-21 | 1373FS+11d |  |  |  |  | 2025-03-21 | 2025-03-21 | 0d | 25d | 5d |  |  | SIT | 51.71 | 6.17 |  |  | Green | GREEN |  |
| 1376 | 1.4.1.4.6.2.7 | eSITAG paper day | milestone | 0d | 2025-03-26 | 2025-03-26 | 1374 |  |  |  |  | 2025-03-26 | 2025-03-26 |  | 716d |  | finish no earlier than 2025-03-26 |  | SIT | 56.71 | 6.17 | Steve Evans | SITAG | Green | GREEN |  |
| 1377 | 1.4.1.4.6.2.8 | eSITAG approve Operational Theme 1, 2 and 3 (Batch 2) Overarching Test Readiness Report | milestone | 0d | 2025-03-28 | 2025-03-28 | 1149, 1150, 1375 |  |  |  |  | 2025-03-28 | 2025-03-28 |  | 20d | 0d |  | SI Test | SIT | 58.71 | 6.17 | Steve Evans | SITAG | Green | GREEN | T3-TE-0193 |
| 1378 | 1.4.1.4.6.3 | **SIT Operational Execution Model** |  | 43d | 2024-08-05 A | 2024-10-02 |  | 63% | 15.97d |  |  | 2024-08-05 | 2024-10-02 | 0d |  |  |  | SI Test | SIT | -134.67 | 6.15 | Steve Evans | SITAG |  |  |  |
| 1379 | 1.4.1.4.6.3.1 | **Theme 3 (Batch 1)** |  | 27d | 2024-08-05 | 2024-09-10 |  | 100% |  | 2024-12-16 | 2025-01-21 | 2024-08-05 | 2024-09-10 | 0d |  |  |  | SI Test | SIT | -134.67 | 6.15 | Steve Evans | SITAG |  |  |  |
| 1380 | 1.4.1.4.6.3.1.1 | Develop execution model Theme 3 (Batch 1) |  | 3d | 2024-12-16 A | 2024-12-18 A | 1334FF | 100% |  |  |  | 2024-12-16 | 2024-12-18 | 0d |  |  |  | SI Test | SIT |  | 6.15 | Steve Evans | SITAG | Complete | COMPLETE |  |
| 1381 | 1.4.1.4.6.3.1.2 | SRO provide feedback |  | 14d | 2024-12-19 A | 2025-01-07 A | 1380 | 100% |  |  |  | 2024-12-19 | 2025-01-07 | 0d |  |  |  | SI Test | SIT |  | 6.15 | Steve Evans | SITAG | Complete | COMPLETE |  |
| 1382 | 1.4.1.4.6.3.1.3 | Address SRO feedback on execution model |  | 2d | 2025-01-08 A | 2025-01-09 A | 1381 | 100% |  |  |  | 2025-01-08 | 2025-01-09 | 0d |  |  |  | SI Test | SIT |  | 6.15 | Steve Evans | SITAG | Complete | COMPLETE |  |
| 1383 | 1.4.1.4.6.3.1.4 | Finalise execution model |  | 3d | 2025-01-10 A | 2025-01-14 A | 1382 | 100% |  |  |  | 2025-01-10 | 2025-01-14 | 0d |  |  |  | SI Test | SIT |  | 6.15 | Steve Evans | SITAG | Complete | COMPLETE |  |
| 1384 | 1.4.1.4.6.3.1.5 | SITWG paper day | milestone | 0d | 2025-01-14 A | 2025-01-14 A | 1383 | 100% |  |  |  | 2025-01-14 | 2025-01-14 | 0d |  |  |  | SI Test | SIT |  | 6.15 | Steve Evans | SITAG | Complete | COMPLETE |  |
| 1385 | 1.4.1.4.6.3.1.6 | SITWG update on execution model | milestone | 0d | 2025-01-21 A | 2025-01-21 A | 1384FS+5d | 100% |  |  |  | 2025-01-21 | 2025-01-21 | 0d |  |  |  | SI Test | SIT |  | 6.15 | Steve Evans | SITAG | Complete | COMPLETE |  |
| 1386 | 1.4.1.4.6.3.2 | **Theme 1, 2 and 3 (Batch 2)** |  | 23d | 2024-08-05 | 2024-09-04 |  |  |  |  |  | 2024-08-05 | 2024-09-04 | 0d |  |  |  | SI Test | SIT | -134.67 | 6.15 | Steve Evans | SITAG |  |  |  |
| 1387 | 1.4.1.4.6.3.2.1 | Develop execution model Theme 1, 2 and 3 (Batch 2) |  | 3d | 2025-01-13 | 2025-01-15 | 1334 |  |  |  |  | 2025-01-13 | 2025-01-15 | 0d | 746d | 0d | start no earlier than 2025-01-13 | SI Test | SIT | -15.67 | 6.15 | Steve Evans | SITAG | Green | RED |  |
| 1388 | 1.4.1.4.6.3.2.2 | SRO provide feedback |  | 5d | 2025-01-16 | 2025-01-22 | 1387 |  |  |  |  | 2025-01-16 | 2025-01-22 | 0d | 746d | 0d |  | SI Test | SIT | -12.67 | 6.15 | Steve Evans | SITAG | Green | RED |  |
| 1389 | 1.4.1.4.6.3.2.3 | Address SRO feedback on execution model |  | 2d | 2025-01-23 | 2025-01-24 | 1388 |  |  |  |  | 2025-01-23 | 2025-01-24 | 0d | 746d | 0d |  | SI Test | SIT | -5.67 | 6.15 | Steve Evans | SITAG | Green | RED |  |
| 1390 | 1.4.1.4.6.3.2.4 | Finalise execution model |  | 3d | 2025-01-27 | 2025-01-29 | 1389 |  |  |  |  | 2025-01-27 | 2025-01-29 | 0d | 746d | 0d |  | SI Test | SIT | -1.67 | 6.15 | Steve Evans | SITAG | Green | GREEN |  |
| 1391 | 1.4.1.4.6.3.2.5 | SITWG paper day | milestone | 0d | 2025-02-05 | 2025-02-05 | 1390FS+5d |  |  |  |  | 2025-02-05 | 2025-02-05 | 0d | 746d | 0d |  | SI Test | SIT | 7.71 | 6.15 | Steve Evans | SITAG | Green | GREEN |  |
| 1392 | 1.4.1.4.6.3.2.6 | SITWG update on execution model | milestone | 0d | 2025-02-12 | 2025-02-12 | 1391FS+5d |  |  |  |  | 2025-02-12 | 2025-02-12 | 0d | 746d |  |  | SI Test | SIT | 14.71 | 6.15 | Steve Evans | SITAG | Green | GREEN |  |

Notes:
- 1370: 29/01/25 - SITAG approved an updated governance timeframes for the NF and Ops Overarching Test Readiness Report, this activity has been rebaselined to reflect this. Status is Green, while there is still PIT documentation required from PPs / to be assured by the programme, it's expected this will be recieved and completed before the deadline.
- 1371: 29/01/25 - SITAG approved an updated governance timeframes for the NF and Ops Overarching Test Readiness Report, this activity has been rebaselined to reflect this. Status is Green, while there is still PIT documentation required from PPs and to be assure
- 1372: 29/01/25 - SITAG approved an updated governance timeframes for the NF and Ops Overarching Test Readiness Report, this activity has been rebaselined to reflect this. Status is Green, while there is still PIT documentation required from PPs and to be assure
- 1373: 29/01/25 - SITAG approved an updated governance timeframes for the NF and Ops Overarching Test Readiness Report, this activity has been rebaselined to reflect this. Status is Green, while there is still PIT documentation required from PPs and to be assure
- 1374: 29/01/25 - SITAG approved an updated governance timeframes for the NF and Ops Overarching Test Readiness Report, this activity has been rebaselined to reflect this. Status is Green, while there is still PIT documentation required from PPs and to be assure
- 1375: 29/01/25 - SITAG approved an updated governance timeframes for the NF and Ops Overarching Test Readiness Report, this activity has been rebaselined to reflect this. Status is Green, while there is still PIT documentation required from PPs and to be assure
- 1376: 29/01/25 - SITAG approved an updated governance timeframes for the NF and Ops Overarching Test Readiness Report, this activity has been rebaselined to reflect this. Status is Green, while there is still PIT documentation required from PPs and to be assure
- 1377: 29/01/25 - SITAG approved the creation of a milestone ID for this activity in January.

| ID | WBS | Task | Type | Duration | Start | Finish | Predecessors | Complete | Remaining | Baseline start | Baseline finish | Baseline duration | Baseline 1 start | Baseline 1 finish | Total slack | Free slack | Constraint | Responsible | Text9 | Task Status | Update Version | Sched Status | MHHS Resource Name | RAG | Text29 | Milestone ID | Involved | MHHS Programme Phase | Tier | Programme Governance Forum responsible for decisio |
| --- | --- | --- | --- | --- | --- | --- | --- | --- | --- | --- | --- | --- | --- | --- | --- | --- | --- | --- | --- | --- | --- | --- | --- | --- | --- | --- | --- | --- | --- | --- |
| 1393 | 1.4.1.4.6.4 | **SIT Operational Theme 3 (Batch 1) progress reporting** |  | 29d? | 2024-12-19 A | 2025-01-28 |  | 7% | 26.85d? | 2024-12-19 | 2025-01-31 | 0d |  |  |  |  |  | SI Test | SIT | -94.67 | 6.14 | Overdue Start | Steve Evans | RED | SITAG |  |  |  |  |  |
| 1394 | 1.4.1.4.6.4.1 | Determine reporting methodology |  | 2d? | 2024-12-19 A | 2024-12-20 A |  | 100% |  | 2024-12-19 | 2025-01-17 | 0d |  |  |  |  |  | SI Test | SIT |  | 6.14 | Complete | Steve Evans | COMPLETE | SITAG |  |  |  |  |  |
| 1395 | 1.4.1.4.6.4.2 | Implement reporting |  | 25d | 2024-12-23 | 2025-01-24 | 1394 |  |  | 2025-01-20 | 2025-01-31 | 0d |  |  | 759d |  |  | SI Test | SIT | -36.67 | 6.14 | Green | Steve Evans | RED | SITAG |  |  |  |  |  |
| 1396 | 1.4.1.4.6.5 | SIT Operational Theme 3 (Batch 1) Testing Preparation Complete | milestone | 0d | 2025-01-31 | 2025-01-31 | 1368, 1307 |  |  | 2025-01-31 | 2025-01-31 |  |  |  | 754d |  |  | SI Test | SIT | 2.71 | 6.15 | Green | Steve Evans | GREEN | SITAG | T2-TE-0750 |  |  |  |  |
| 1397 | 1.4.1.4.6.6 | SIT Operational Theme 1, 2, 3 (Batch 2) Testing Preparation Complete | milestone | 0d | 2025-03-28 | 2025-03-28 | 419, 1208, 1214, 1334, 1377 |  |  | 2025-03-31 | 2025-04-25 | 0d | 2025-03-10 | 2025-03-10 | 21d | 1d | finish no earlier than 2024-10-04 | SI Test | SIT | 58.71 | 6.15 | Green | Roger Robar | GREEN | SITAG | T2-TE-1300 | PP,IPA | Systems Integration Testing (SIT) | T2 |  |
| 1398 | 1.4.1.4.7 | **Regression Test Preparation** |  | 2d? | 2024-11-18 A | 2024-11-19 |  | 39% | 1.22d? | 2024-11-18 | 2024-11-19 | 0d |  |  |  |  |  | SI Test | SIT | -686.67 | 6.17 |  | Roger Robar |  | SITAG |  |  |  |  |  |
| 1399 | 1.4.1.4.7.1 | **Regression Test Approach** |  | 10d | 2024-11-18 A | 2024-11-29 |  | 80% | 1.96d | 2024-11-18 | 2024-11-29 | 0d |  |  |  |  |  | SI Test | SIT | -686.67 | 6.17 |  | Roger Robar |  | SITAG |  |  |  |  |  |
| 1400 | 1.4.1.4.7.1.1 | Develop approach doc |  | 45d | 2024-11-18 A | 2025-01-17 A |  | 100% |  | 2024-11-18 | 2025-01-17 | 0d |  |  |  |  | start no earlier than 2024-09-16 | SI Test | SIT |  | 6.17 | Complete | Roger Robar | COMPLETE | SITAG |  |  |  |  |  |
| 1401 | 1.4.1.4.7.1.2 | SRO / LDP review of approach doc |  | 5d | 2025-01-20 A | 2025-01-24 A | 1400 | 100% |  | 2025-01-20 | 2025-01-24 | 0d |  |  |  |  |  | SI Test | SIT |  | 6.17 | Complete | Roger Robar | COMPLETE | SITAG |  |  |  |  |  |
| 1402 | 1.4.1.4.7.1.3 | Incorporate SRO feedback into approach doc |  | 5d | 2025-01-20 A | 2025-01-24 A | 1401FF | 100% |  | 2025-01-20 | 2025-01-24 | 0d |  |  |  |  |  | SI Test | SIT |  | 6.17 | Complete | Roger Robar | COMPLETE | SITAG |  |  |  |  |  |
| 1403 | 1.4.1.4.7.1.4 | Industry review of approach |  | 10d | 2025-01-27 A | 2025-02-07 | 1402 | 5% | 9.5d | 2025-01-27 | 2025-02-07 |  |  |  | 11d | 0d |  | SI Test | SIT |  | 6.17 | Green | Roger Robar | GREEN | SITAG |  |  |  |  |  |
| 1404 | 1.4.1.4.7.1.5 | Updates to approach doc on back of industry feedback |  | 2d | 2025-02-10 | 2025-02-11 | 1403 |  |  | 2025-02-10 | 2025-02-11 |  |  |  | 11d | 0d |  | SI Test | SIT | 12.33 | 6.17 | Green | Roger Robar | GREEN | SITAG |  |  |  |  |  |
| 1405 | 1.4.1.4.7.1.6 | eSITWG paper day | milestone | 0d | 2025-02-11 | 2025-02-11 | 1404 |  |  | 2025-02-11 | 2025-02-11 | 0d |  |  | 11d | 0d |  | SI Test | SIT | 13.71 | 6.17 | Green | Roger Robar | GREEN | SITAG |  |  |  |  |  |
| 1406 | 1.4.1.4.7.1.7 | eSITWG Recommendation | milestone | 0d | 2025-02-18 | 2025-02-18 | 1405FS+5d |  |  | 2025-02-18 | 2025-02-18 | 0d |  |  | 735d | 0d | start no earlier than 2025-01-20 | SI Test | SIT | 20.71 | 6.17 | Green | Roger Robar | GREEN | SITAG |  |  |  |  |  |
| 1407 | 1.4.1.4.7.1.8 | Incorporate eSITWG feedback into approach doc |  | 2d | 2025-02-19 | 2025-02-20 | 1406 |  |  | 2025-02-19 | 2025-02-20 | 0d |  |  | 735d | 0d |  | SI Test | SIT | 21.33 | 6.17 | Green | Roger Robar | GREEN | SITAG |  |  |  |  |  |
| 1408 | 1.4.1.4.7.1.9 | eSITAG paper day | milestone | 0d | 2025-02-20 | 2025-02-20 | 1407 |  |  | 2025-02-20 | 2025-02-20 | 0d |  |  | 735d | 1d |  | SI Test | SIT | 22.71 | 6.17 | Green | Roger Robar | GREEN | SITAG |  |  |  |  |  |
| 1409 | 1.4.1.4.7.1.10 | eSITAG (inc SRO) Approval | milestone | 0d | 2025-02-28 | 2025-02-28 | 1408FS+5d |  |  | 2025-02-28 | 2025-02-28 | 0d |  |  | 734d | 0d | finish no earlier than 2025-02-28 | SI Test | SIT | 30.71 | 6.17 | Green | Roger Robar | GREEN | SITAG |  |  |  |  |  |
| 1410 | 1.4.1.4.7.1.11 | SIT Regression Testing Approach and Plan Approval | milestone | 0d | 2025-02-28 | 2025-02-28 | 1409 |  |  | 2025-02-28 | 2025-02-28 | 0d |  |  | 734d |  |  | SI Test | SIT | 30.71 | 6.17 | Green | Roger Robar | GREEN | SITAG | T3-TE-0123 |  |  | T3 |  |
| 1411 | 1.4.1.4.7.2 | **Regression Test Suite** |  | 46d | 2025-02-12 | 2025-04-16 |  |  |  | 2025-02-12 | 2025-04-16 | 0d |  |  | 11d |  |  | SI Test | SIT | -686.67 | 6.17 |  | Roger Robar |  | SITAG |  |  |  |  |  |
| 1412 | 1.4.1.4.7.2.1 | Build Regression Test Suite |  | 13d | 2025-02-12 | 2025-02-28 | 1405 |  |  | 2025-02-12 | 2025-02-28 | 0d |  |  | 11d | 0d |  | SI Test | SIT | 14.33 | 6.17 | Green | Roger Robar | GREEN | SITAG |  |  |  |  |  |
| 1413 | 1.4.1.4.7.2.2 | SITWG paper day |  | 1d | 2025-02-27 | 2025-02-27 | 1412SS |  |  | 2025-02-27 | 2025-02-27 |  |  |  | 12d | 0d | start no earlier than 2025-02-27 |  | SIT | 29.33 | 6.17 | Green | Roger Robar | GREEN |  |  |  |  |  |  |
| 1414 | 1.4.1.4.7.2.3 | SITWG provides feedback on regression suite approach | milestone | 0d | 2025-03-06 | 2025-03-06 | 1413FS+5d |  |  | 2025-03-06 | 2025-03-06 | 0d |  |  | 12d | 1d |  |  | SIT | 36.71 | 6.17 | Green | Roger Robar | GREEN |  |  |  |  |  |  |
| 1415 | 1.4.1.4.7.2.4 | LDP walkthrough of Regression Test Suite |  | 1d | 2025-02-28 | 2025-02-28 | 1412FF |  |  | 2025-02-28 | 2025-02-28 |  |  |  | 734d |  |  | SI Test | SIT | 30.33 | 6.17 | Green | Roger Robar | GREEN | SITAG |  |  |  |  |  |
| 1416 | 1.4.1.4.7.2.5 | SRO Review of regression suite doc |  | 5d | 2025-03-03 | 2025-03-07 | 1412 |  |  | 2025-03-03 | 2025-03-07 | 0d |  |  | 11d | 0d |  | SI Test | SIT | 33.33 | 6.17 | Green | Roger Robar | GREEN | SITAG |  |  |  |  |  |
| 1417 | 1.4.1.4.7.2.6 | Incorporate SRO feedback into regression suite doc |  | 5d | 2025-03-03 | 2025-03-07 | 1416SS, 1414FF |  |  | 2025-03-03 | 2025-03-07 | 0d |  |  | 11d | 0d |  | SI Test | SIT | 33.33 | 6.17 | Green | Roger Robar | GREEN | SITAG |  |  |  |  |  |
| 1418 | 1.4.1.4.7.2.7 | Industry review of Regression Test Suite |  | 10d | 2025-03-10 | 2025-03-21 | 1417 |  |  | 2025-03-10 | 2025-03-21 |  |  |  | 11d | 0d |  | SI Test | SIT | 40.33 | 6.17 | Green | Roger Robar | GREEN | SITAG |  |  |  |  |  |
| 1419 | 1.4.1.4.7.2.8 | Incorporate Industry feedback into regression suite doc |  | 4d | 2025-03-24 | 2025-03-27 | 1418 |  |  | 2025-03-24 | 2025-03-27 |  |  |  | 11d | 0d |  | SI Test | SIT | 54.33 | 6.17 | Green | Roger Robar | GREEN | SITAG |  |  |  |  |  |
| 1420 | 1.4.1.4.7.2.9 | SITWG paper day | milestone | 0d | 2025-03-27 | 2025-03-27 | 1419 |  |  | 2025-03-27 | 2025-03-27 | 0d |  |  | 11d | 0d |  | SI Test | SIT | 57.71 | 6.17 | Green | Roger Robar | GREEN | SITAG |  |  |  |  |  |
| 1421 | 1.4.1.4.7.2.10 | SITWG endorses regression suite doc | milestone | 0d | 2025-04-03 | 2025-04-03 | 1420FS+5d |  |  | 2025-04-03 | 2025-04-03 | 0d |  |  | 11d | 0d | finish no earlier than 2025-04-03 | SI Test | SIT | 64.71 | 6.17 | Green | Roger Robar | GREEN | SITAG |  |  |  |  |  |
| 1422 | 1.4.1.4.7.2.11 | Incorporate SITWG feedback into regression suite doc |  | 1d | 2025-04-04 | 2025-04-04 | 1421 |  |  | 2025-04-04 | 2025-04-04 | 0d |  |  | 11d | 3d |  | SI Test | SIT | 65.33 | 6.17 | Green | Roger Robar | GREEN | SITAG |  |  |  |  |  |
| 1423 | 1.4.1.4.7.2.12 | eSITAG paper day | milestone | 0d | 2025-04-09 | 2025-04-09 | 1422 |  |  | 2025-04-09 | 2025-04-09 | 0d |  |  | 8d | 0d | finish no earlier than 2025-04-09 | SI Test | SIT | 70.71 | 6.17 | Green | Roger Robar | GREEN | SITAG |  |  |  |  |  |
| 1424 | 1.4.1.4.7.2.13 | eSITAG (inc SRO) Approval of regression suite doc | milestone | 0d | 2025-04-16 | 2025-04-16 | 1423FS+5d |  |  | 2025-04-16 | 2025-04-16 | 0d |  |  | 8d | 0d | finish no earlier than 2025-04-16 | SI Test | SIT | 77.71 | 6.17 | Green | Roger Robar | GREEN | SITAG |  |  |  |  |  |
| 1425 | 1.4.1.4.7.2.14 | SIT Regression Approval | milestone | 0d | 2025-04-16 | 2025-04-16 | 1424 |  |  | 2025-04-16 | 2025-04-16 | 0d |  |  | 8d |  |  | SI Test | SIT | 77.71 | 6.17 | Green | Roger Robar | GREEN | SITAG | T3-TE-0122 |  |  | T3 | SITAG |

Notes:
- 1395: 27/01/25 - Reporting dashboard still being developed and due to be cleared by SRO.
- 1396: 29/01/25 - SITAG approved the Theme 3 (Batch 1) Overarching Readiness Report, and Helix are on track with their readiness preparations, so Programme expect this milestone to be reached and testing to commence 03/02/25 as planned.
- 1398: 29/01/25 - Activity rebaselined following SITAG's approval of the updated Regression Testing plan in January.
- 1399: 29/01/25 - Activity rebaselined following SITAG's approval of the updated Regression Testing plan in January.
- 1400: 29/01/25 - Activity rebaselined following SITAG's approval of the updated Regression Testing plan in January.
- 1401: 29/01/25 - Activity rebaselined following SITAG's approval of the updated Regression Testing plan in January.
- 1402: 29/01/25 - Activity rebaselined following SITAG's approval of the updated Regression Testing plan in January.
- 1403: 29/01/25 - Activity rebaselined following SITAG's approval of the updated Regression Testing plan in January.
- 1404: 29/01/25 - Activity rebaselined following SITAG's approval of the updated Regression Testing plan in January.
- 1405: 29/01/25 - Activity rebaselined following SITAG's approval of the updated Regression Testing plan in January.
- 1406: 29/01/25 - Activity rebaselined following SITAG's approval of the updated Regression Testing plan in January.
- 1407: 29/01/25 - Activity rebaselined following SITAG's approval of the updated Regression Testing plan in January.
- 1408: 29/01/25 - Activity rebaselined following SITAG's approval of the updated Regression Testing plan in January.
- 1409: 29/01/25 - Activity rebaselined following SITAG's approval of the updated Regression Testing plan in January.
- 1410: 29/01/25 - Activity rebaselined following SITAG's approval of the updated Regression Testing plan in January.
- 1411: 29/01/25 - Activity rebaselined following SITAG's approval of the updated Regression Testing plan in January.
- 1412: 29/01/25 - Activity rebaselined following SITAG's approval of the updated Regression Testing plan in January.
- 1413: 29/01/25 - Activity rebaselined following SITAG's approval of the updated Regression Testing plan in January.
- 1414: 29/01/25 - Activity rebaselined following SITAG's approval of the updated Regression Testing plan in January.
- 1415: 29/01/25 - Activity rebaselined following SITAG's approval of the updated Regression Testing plan in January.
- 1416: 29/01/25 - Activity rebaselined following SITAG's approval of the updated Regression Testing plan in January.
- 1417: 29/01/25 - Activity rebaselined following SITAG's approval of the updated Regression Testing plan in January.
- 1418: 29/01/25 - Activity rebaselined following SITAG's approval of the updated Regression Testing plan in January.
- 1419: 29/01/25 - Activity rebaselined following SITAG's approval of the updated Regression Testing plan in January.
- 1420: 29/01/25 - Activity rebaselined following SITAG's approval of the updated Regression Testing plan in January.
- 1421: 29/01/25 - Activity rebaselined following SITAG's approval of the updated Regression Testing plan in January.
- 1422: 29/01/25 - Activity rebaselined following SITAG's approval of the updated Regression Testing plan in January.
- 1423: 29/01/25 - Activity rebaselined following SITAG's approval of the updated Regression Testing plan in January.
- 1424: 29/01/25 - Activity rebaselined following SITAG's approval of the updated Regression Testing plan in January.
- 1425: 29/01/25 - Activity rebaselined following SITAG's approval of the updated Regression Testing plan in January.

| ID | WBS | Task | Type | Duration | Start | Finish | Predecessors | Complete | Remaining | Baseline start | Baseline finish | Baseline duration | Total slack | Constraint | Responsible | Text9 | Task Status | Update Version | MHHS Resource Name | Sched Status | RAG | Milestone ID | Text29 | Tier |
| --- | --- | --- | --- | --- | --- | --- | --- | --- | --- | --- | --- | --- | --- | --- | --- | --- | --- | --- | --- | --- | --- | --- | --- | --- |
| 1426 | 1.4.1.4.7.3 | **Regression Test Data Load Window (SIT Functional and Migration) - SIT A** |  | 1d? | 2025-04-28 | 2025-04-29 |  |  |  | 2025-03-14 | 2025-03-17 | 0d |  |  | SI Test | SIT | -686.67 | 6.15 | Richard Puddephatt |  |  |  |  |  |
| 1427 | 1.4.1.4.7.3.1 | Data Load preparation activities |  | 20d | 2025-03-31 | 2025-04-25 | 1147 |  |  | 2025-03-31 | 2025-04-25 | 0d | 1d | start no earlier than 2025-03-17 | SI Test | SIT | 61.33 | 6.15 | Richard Puddephatt | Green | GREEN |  |  |  |
| 1428 | 1.4.1.4.7.3.2 | Regression Test Data Load Start | milestone | 0d | 2025-04-28 | 2025-04-28 | 1597, 1525FS+1d, 1601FS+1d, 1427, 1425 |  |  | 2025-04-28 | 2025-04-28 | 0d | 0d |  | SI Test | SIT | 89.71 | 6.15 | Richard Puddephatt | Green | GREEN | T2-TE-1000 | SITAG | T2 |
| 1429 | 1.4.1.4.7.3.3 | Regression Test Data Load Window |  | 14d | 2025-04-29 | 2025-05-16 | 1428 |  |  | 2025-04-28 | 2025-05-16 | 0d | 0d | start no earlier than 2025-04-28 | SI Test | SIT | 90.33 | 6.15 | Richard Puddephatt | Green | GREEN |  |  |  |
| 1430 | 1.4.1.4.8 | **Single Instance ADO** |  | 32d? | 2024-08-21 A | 2024-10-03 |  | 98% | 0.65d? | 2024-08-21 | 2024-10-03 | 0d | 840d |  | SI Test | SIT | -701.67 | 6.1 | Heath Thomas |  |  |  |  |  |
| 1431 | 1.4.1.4.8.1 | **Single ADO Project for all Cohorts - Implementation and Test Phase** |  | 30d? | 2024-08-21 A | 2024-10-01 A |  | 100% |  | 2024-08-21 | 2024-10-01 | 0d |  |  | SI Test | SIT | -701.67 | 6.1 | Heath Thomas |  |  |  |  |  |
| 1432 | 1.4.1.4.8.1.1 | Create test plans and suites in master project |  | 2d? | 2024-08-21 A | 2024-08-22 A |  | 100% |  | 2024-08-21 | 2024-08-22 | 0d |  | finish no earlier than 2024-08-22 | SI Test | SIT |  | 6.1 | Heath Thomas | Complete | COMPLETE |  |  |  |
| 1433 | 1.4.1.4.8.1.2 | Create area paths / iterations |  | 2d? | 2024-08-21 A | 2024-08-22 A |  | 100% |  | 2024-08-21 | 2024-08-22 | 0d |  | finish no earlier than 2024-08-22 | SI Test | SIT |  | 6.1 | Heath Thomas | Complete | COMPLETE |  |  |  |
| 1434 | 1.4.1.4.8.1.3 | Create IAM roles |  | 2d? | 2024-08-21 A | 2024-08-22 A |  | 100% |  | 2024-08-21 | 2024-08-22 | 0d |  | finish no earlier than 2024-08-22 | SI Test | SIT |  | 6.1 | Heath Thomas | Complete | COMPLETE |  |  |  |
| 1435 | 1.4.1.4.8.1.4 | Add users to roles |  | 1d? | 2024-08-23 A | 2024-08-23 A |  | 100% |  | 2024-08-23 | 2024-08-23 | 0d |  | start no earlier than 2024-08-23 | SI Test | SIT |  | 6.1 | Heath Thomas | Complete | COMPLETE |  |  |  |
| 1436 | 1.4.1.4.8.1.5 | **Testing permissions** |  | 2d? | 2024-08-27 A | 2024-08-28 A |  | 100% |  | 2024-08-27 | 2024-08-28 | 0d |  |  | SI Test | SIT |  | 6.1 | Heath Thomas | Complete | COMPLETE |  |  |  |
| 1437 | 1.4.1.4.8.1.5.1 | Adding tests |  | 2d? | 2024-08-27 A | 2024-08-28 A |  | 100% |  | 2024-08-27 | 2024-08-28 | 0d |  | finish no earlier than 2024-08-28 | SI Test | SIT |  | 6.1 | Heath Thomas | Complete | COMPLETE |  |  |  |
| 1438 | 1.4.1.4.8.1.5.2 | Deleting tests |  | 2d? | 2024-08-27 A | 2024-08-28 A |  | 100% |  | 2024-08-27 | 2024-08-28 | 0d |  | finish no earlier than 2024-08-28 | SI Test | SIT |  | 6.1 | Heath Thomas | Complete | COMPLETE |  |  |  |
| 1439 | 1.4.1.4.8.1.5.3 | Adding tests to incorrect Cohort |  | 2d? | 2024-08-27 A | 2024-08-28 A |  | 100% |  | 2024-08-27 | 2024-08-28 | 0d |  | finish no earlier than 2024-08-28 | SI Test | SIT |  | 6.1 | Heath Thomas | Complete | COMPLETE |  |  |  |
| 1440 | 1.4.1.4.8.1.5.4 | Add / delete defects |  | 2d? | 2024-08-27 A | 2024-08-28 A |  | 100% |  | 2024-08-27 | 2024-08-28 | 0d |  | finish no earlier than 2024-08-28 | SI Test | SIT |  | 6.1 | Heath Thomas | Complete | COMPLETE |  |  |  |
| 1441 | 1.4.1.4.8.1.6 | Migrate defects from cohort project to master - Option 2 |  | 3d | 2024-09-23 A | 2024-09-25 A |  | 100% |  | 2024-09-23 | 2024-09-25 | 0d |  | start no earlier than 2024-09-23 | SI Test | SIT |  | 6.1 | Heath Thomas | Complete | COMPLETE |  |  |  |
| 1442 | 1.4.1.4.8.1.7 | Testing Permissions - Evidence attachment security |  | 10d? | 2024-09-18 A | 2024-10-01 A |  | 100% |  | 2024-09-18 | 2024-10-01 | 0d |  | finish no earlier than 2024-10-01 | SI Test | SIT |  | 6.1 | Heath Thomas | Complete | COMPLETE |  |  |  |
| 1443 | 1.4.1.4.8.2 | **ADO Dashboard Updates** |  | 20d? | 2024-09-03 A | 2024-09-30 A |  | 100% |  | 2024-09-03 | 2024-09-30 | 0d |  |  | SI Test | SIT | -701.67 | 6.1 | Heath Thomas | Overdue Start |  |  |  |  |
| 1444 | 1.4.1.4.8.2.1 | Update reporting dashboards in ADO |  | 3d | 2024-09-03 A | 2024-09-05 A |  | 100% |  | 2024-09-03 | 2024-09-05 | 0d |  | start no earlier than 2024-09-03 | SI Test | SIT |  | 6.1 | Heath Thomas | Complete | COMPLETE |  |  |  |
| 1445 | 1.4.1.4.8.2.2 | Review dashboards with SI LDP leads |  | 16d | 2024-09-06 A | 2024-09-27 A |  | 100% |  | 2024-09-06 | 2024-09-27 | 0d |  | start no earlier than 2024-09-06 | SI Test | SIT |  | 6.1 | Heath Thomas | Complete | COMPLETE |  |  |  |
| 1446 | 1.4.1.4.8.2.3 | Review dashboards with SRO |  | 16d | 2024-09-09 A | 2024-09-30 A |  | 100% |  | 2024-09-09 | 2024-09-30 | 0d |  | start no earlier than 2024-09-09 | SI Test | SIT |  | 6.1 | Heath Thomas | Complete | COMPLETE |  |  |  |
| 1447 | 1.4.1.4.8.2.4 | Update dashboards following review |  | 2d | 2024-09-12 A | 2024-09-13 A |  | 100% |  | 2024-09-12 | 2024-09-13 | 0d |  | start no earlier than 2024-09-12 | SI Test | SIT |  | 6.1 | Heath Thomas | Complete | COMPLETE |  |  |  |
| 1448 | 1.4.1.4.8.2.5 | Document changes to dashboard creation process |  | 4d | 2024-09-16 A | 2024-09-19 A |  | 100% |  | 2024-09-16 | 2024-09-19 | 0d |  | start no earlier than 2024-09-16 | SI Test | SIT |  | 6.1 | Heath Thomas | Complete | COMPLETE |  |  |  |
| 1449 | 1.4.1.4.8.2.6 | Update SIT Dashboards for Sprints 4.1 & 4.2 across all Cohorts |  | 1d? | 2024-09-03 A | 2024-09-03 A |  | 100% |  | 2024-09-03 | 2024-09-03 | 0d |  | start no earlier than 2024-09-03 | SI Test | SIT |  | 6.1 | Heath Thomas | Complete | COMPLETE |  |  |  |

| ID | WBS | Task | Duration | Start | Finish | Complete | Remaining | Baseline start | Baseline finish | Baseline duration | Total slack | Constraint | Responsible | Text9 | Task Status | Update Version | Sched Status | MHHS Resource Name | RAG |
| --- | --- | --- | --- | --- | --- | --- | --- | --- | --- | --- | --- | --- | --- | --- | --- | --- | --- | --- | --- |
| 1450 | 1.4.1.4.8.3 | **Reporting Changes - PowerBI & QIP** | 23d? | 2024-08-23 A | 2024-09-24 | 70% | 6.9d? | 2024-08-23 | 2024-09-24 | 0d | 847d |  | SI Test | SIT | -701.67 | 6.1 | Overdue Start | Heath Thomas |  |
| 1451 | 1.4.1.4.8.3.1 | Design, Create and ETL ADO Entities into PowerBI Data Model | 1d? | 2024-08-23 A | 2024-08-23 A | 100% |  | 2024-08-23 | 2024-08-23 | 0d |  | start no earlier than 2024-08-23 | SI Test | SIT |  | 6.1 | Complete | Heath Thomas | COMPLETE |
| 1452 | 1.4.1.4.8.3.2 | Determine Relationships between ADO Entities & Attributes | 1d? | 2024-08-27 A | 2024-08-27 A | 100% |  | 2024-08-27 | 2024-08-27 | 0d |  | start no earlier than 2024-08-27 | SI Test | SIT |  | 6.1 | Complete | Heath Thomas | COMPLETE |
| 1453 | 1.4.1.4.8.3.3 | Create Relevant Dax Measures | 1d? | 2024-08-28 A | 2024-08-28 A | 100% |  | 2024-08-28 | 2024-08-28 | 0d |  | start no earlier than 2024-08-28 | SI Test | SIT |  | 6.1 | Complete | Heath Thomas | COMPLETE |
| 1454 | 1.4.1.4.8.3.4 | Design & Build Visualisations (Graphs) | 1d? | 2024-08-29 A | 2024-08-29 A | 100% |  | 2024-08-29 | 2024-08-29 | 0d |  | start no earlier than 2024-08-29 | SI Test | SIT |  | 6.1 | Complete | Heath Thomas | COMPLETE |
| 1455 | 1.4.1.4.8.3.5 | Implement Filters | 1d? | 2024-09-23 A | 2024-09-23 A | 100% |  | 2024-09-23 | 2024-09-23 | 0d |  | start no earlier than 2024-09-23 | SI Test | SIT |  | 6.1 | Complete | Heath Thomas | COMPLETE |
| 1456 | 1.4.1.4.8.3.6 | Check Data Quality & Integrity | 1d? | 2024-09-24 A | 2024-09-24 A | 100% |  | 2024-09-24 | 2024-09-24 | 0d |  | start no earlier than 2024-09-24 | SI Test | SIT |  | 6.1 | Complete | Heath Thomas | COMPLETE |
| 1457 | 1.4.1.4.8.3.7 | Performance Optimisation | 1d? | 2024-09-24 A | 2024-09-24 A | 100% |  | 2024-09-24 | 2024-09-24 | 0d |  | start no earlier than 2024-09-24 | SI Test | SIT |  | 6.1 | Complete | Heath Thomas | COMPLETE |
| 1458 | 1.4.1.4.8.3.8 | Publish (QIP) | 1d? | 2024-09-04 | 2024-09-04 |  |  | 2024-09-04 | 2024-09-04 | 0d | 861d | start no earlier than 2024-09-04 | SI Test | SIT | -146.67 | 6.1 | Overdue Start | Heath Thomas | RED |
| 1459 | 1.4.1.4.8.3.9 | Review & UAT | 1d? | 2024-09-05 | 2024-09-05 |  |  | 2024-09-05 | 2024-09-05 | 0d | 860d | start no earlier than 2024-09-05 | SI Test | SIT | -145.67 | 6.1 | Overdue Start | Heath Thomas | RED |
| 1460 | 1.4.1.4.8.3.10 | QIP Training Material & User Guides | 1d? | 2024-09-10 | 2024-09-10 |  |  | 2024-09-10 | 2024-09-10 | 0d | 857d | start no earlier than 2024-09-10 | SI Test | SIT | -140.67 | 6.1 | Overdue Start | Heath Thomas | RED |
| 1461 | 1.4.1.4.8.4 | **Reporting Changes - Daily Excel Extract & PDF** | 2d | 2024-09-05 A | 2024-09-06 A | 100% |  | 2024-09-05 | 2024-09-06 | 0d |  |  | SI Test | SIT | -701.67 | 6.1 | Overdue Start | Heath Thomas | RED |
| 1462 | 1.4.1.4.8.4.1 | Excel Daily Report changes (Refer to above) | 2d | 2024-09-05 A | 2024-09-06 A | 100% |  | 2024-09-05 | 2024-09-06 | 0d |  | start no earlier than 2024-09-05 | SI Test | SIT |  | 6.1 | Complete | Heath Thomas | COMPLETE |
| 1463 | 1.4.1.4.8.4.2 | PDF Daily Report changes (Refer to Above) | 2d | 2024-09-05 A | 2024-09-06 A | 100% |  | 2024-09-05 | 2024-09-06 | 0d |  | start no earlier than 2024-09-05 | SI Test | SIT |  | 6.1 | Complete | Heath Thomas | COMPLETE |
| 1464 | 1.4.1.4.8.5 | **Documentation Updates** | 23d? | 2024-09-02 A | 2024-10-02 A | 100% |  | 2024-09-02 | 2024-10-02 | 0d |  |  | SI Test | SIT | -701.67 | 6.1 | Overdue Start | Heath Thomas |  |
| 1465 | 1.4.1.4.8.5.1 | Changes to onboarding process (security) | 10d | 2024-09-02 A | 2024-09-13 A | 100% |  | 2024-09-02 | 2024-09-13 | 0d |  | start no earlier than 2024-09-02 | SI Test | SIT |  | 6.1 | Complete | Heath Thomas | COMPLETE |
| 1466 | 1.4.1.4.8.5.2 | Update the documents on loading tests into ADO? | 10d | 2024-09-02 A | 2024-09-13 A | 100% |  | 2024-09-02 | 2024-09-13 | 0d |  | start no earlier than 2024-09-02 | SI Test | SIT |  | 6.1 | Complete | Heath Thomas | COMPLETE |
| 1467 | 1.4.1.4.8.5.3 | Update ADO Training material | 10d | 2024-09-02 A | 2024-09-13 A | 100% |  | 2024-09-02 | 2024-09-13 | 0d |  | start no earlier than 2024-09-02 | SI Test | SIT |  | 6.1 | Complete | Heath Thomas | COMPLETE |
| 1468 | 1.4.1.4.8.5.4 | Update ADO User Guide | 10d | 2024-09-02 A | 2024-09-13 A | 100% |  | 2024-09-02 | 2024-09-13 | 0d |  | start no earlier than 2024-09-02 | SI Test | SIT |  | 6.1 | Complete | Heath Thomas | COMPLETE |
| 1469 | 1.4.1.4.8.5.5 | Update ADO Configuration document | 10d | 2024-09-02 A | 2024-09-13 A | 100% |  | 2024-09-02 | 2024-09-13 | 0d |  | start no earlier than 2024-09-02 | SI Test | SIT |  | 6.1 | Complete | Heath Thomas | COMPLETE |
| 1470 | 1.4.1.4.8.5.6 | Update ADO Training Material and User Guide following SRO review | 1d? | 2024-10-02 A | 2024-10-02 A | 100% |  | 2024-10-02 | 2024-10-02 | 0d |  | start no earlier than 2024-10-02 | SI Test | SIT |  | 6.1 | Complete | Heath Thomas | COMPLETE |
| 1471 | 1.4.1.4.8.6 | **ADO Changes - Review Stage** | 19d? | 2024-09-09 A | 2024-10-03 A | 100% |  | 2024-09-09 | 2024-10-03 | 0d |  |  | SI Test | SIT | -701.67 | 6.1 | Overdue Start | Heath Thomas |  |
| 1472 | 1.4.1.4.8.6.1 | Review implementation with SI LDP leads | 1d? | 2024-09-27 A | 2024-09-27 A | 100% |  | 2024-09-27 | 2024-09-27 | 0d |  | start no earlier than 2024-09-27 | SI Test | SIT |  | 6.1 | Complete | Heath Thomas | COMPLETE |
| 1473 | 1.4.1.4.8.6.2 | Review implementation with SRO | 1d? | 2024-09-30 A | 2024-09-30 A | 100% |  | 2024-09-30 | 2024-09-30 | 0d |  | start no earlier than 2024-09-30 | SI Test | SIT |  | 6.1 | Complete | Heath Thomas | COMPLETE |
| 1474 | 1.4.1.4.8.6.3 | LDP Review - ADO User Guide, Training Materials | 5d | 2024-09-09 A | 2024-09-13 A | 100% |  | 2024-09-09 | 2024-09-13 | 0d |  | start no earlier than 2024-09-09 | SI Test | SIT |  | 6.1 | Complete | Heath Thomas | COMPLETE |
| 1475 | 1.4.1.4.8.6.4 | SRO Review - ADO User Guide, Training Materials | 1d? | 2024-09-30 A | 2024-09-30 A | 100% |  | 2024-09-30 | 2024-09-30 | 0d |  | start no earlier than 2024-09-30 | SI Test | SIT |  | 6.1 | Complete | Heath Thomas | COMPLETE |
| 1476 | 1.4.1.4.8.6.5 | LDP Review - Config doc | 1d? | 2024-09-30 A | 2024-09-30 A | 100% |  | 2024-09-30 | 2024-09-30 | 0d |  | start no earlier than 2024-09-30 | SI Test | SIT |  | 6.1 | Complete | Heath Thomas | COMPLETE |
| 1477 | 1.4.1.4.8.6.6 | SRO Review - Config doc | 1d? | 2024-09-30 A | 2024-09-30 A | 100% |  | 2024-09-30 | 2024-09-30 | 0d |  | start no earlier than 2024-09-30 | SI Test | SIT |  | 6.1 | Complete | Heath Thomas | COMPLETE |
| 1478 | 1.4.1.4.8.6.7 | SRO Sign-off of all changes | 1d? | 2024-10-03 A | 2024-10-03 A | 100% |  | 2024-10-03 | 2024-10-03 | 0d |  | start no earlier than 2024-10-03 | SI Test | SIT |  | 6.1 | Complete | Heath Thomas | COMPLETE |

Notes:
- 1458: 28/01/25 - This is on hold and being assessed as whether this is needed. If deemed as required, then the activity will be updated and resumed.
- 1459: 28/01/25 - This is on hold and being assessed as whether this is needed. If deemed as required, then the activity will be updated and resumed.
- 1460: 28/01/25 - This is on hold and being assessed as whether this is needed. If deemed as required, then the activity will be updated and resumed.

| ID | WBS | Task | Type | Duration | Start | Finish | Predecessors | Complete | Remaining | Baseline start | Baseline finish | Baseline duration | Baseline 1 start | Baseline 1 finish | Total slack | Constraint | Baseline cost | Responsible | Text9 | Task Status | Update Version | Sched Status | MHHS Resource Name | RAG | Involved | MHHS Programme Phase | Text29 | Artefact ID | Milestone ID | Tier | Future RAG |
| --- | --- | --- | --- | --- | --- | --- | --- | --- | --- | --- | --- | --- | --- | --- | --- | --- | --- | --- | --- | --- | --- | --- | --- | --- | --- | --- | --- | --- | --- | --- | --- |
| 1479 | 1.4.1.4.8.7 | **Azure DevOps Changes - Final Implementation** |  | 1d? | 2024-10-03 A | 2024-10-03 A |  | 100% |  | 2024-10-03 | 2024-10-03 | 0d |  |  |  |  |  | SI Test | SIT | -701.67 | 6.1 | Overdue Start | Heath Thomas |  |  |  |  |  |  |  |  |
| 1480 | 1.4.1.4.8.7.1 | Final task rollout |  | 1d? | 2024-10-03 A | 2024-10-03 A |  | 100% |  | 2024-10-03 | 2024-10-03 | 0d |  |  |  | start no earlier than 2024-10-03 |  | SI Test | SIT |  | 6.1 | Complete | Heath Thomas | COMPLETE |  |  |  |  |  |  |  |
| 1481 | 1.4.1.4.8.7.2 | ADO Training Drop-in Session ahead of Cycle 3 |  | 1d? | 2024-10-03 A | 2024-10-03 A |  | 100% |  | 2024-10-03 | 2024-10-03 | 0d |  |  |  | start no earlier than 2024-10-03 |  | SI Test | SIT |  | 6.1 | Complete | Heath Thomas | COMPLETE |  |  |  |  |  |  |  |
| 1482 | 1.4.2 | **SIT Execution** |  | 804d? | 2022-10-31 A | 2025-11-27 |  | 37% | 505.68d? | 2022-10-31 | 2025-11-27 | 390d | 2023-10-30 | 2025-04-25 | 540d |  | -0 | N/A | SIT |  | 5.0 |  | N/A |  | N/A | Systems Integration Testing (SIT) | SITAG |  |  |  |  |
| 1483 | 1.4.2.1 | System Integration Testing Start (M9) | milestone | 0d | 2023-10-30 A | 2023-10-30 A | 701FS+5d, 615 | 100% |  | 2023-10-30 | 2023-10-30 | 0d | 2023-10-30 | 2023-10-30 |  | must start on 2023-10-30 |  | CPT | SIT |  | 5.11 | Complete |  | COMPLETE | PMO | Systems Integration Testing (SIT) | PSG | MHHS-ART071 | T1-TE-1000 | T1 |  |
| 1484 | 1.4.2.2 | **SIT Component Integration Testing** |  | 96d | 2023-10-30 A | 2024-03-11 A |  | 100% |  | 2023-10-30 | 2024-03-11 | 95d | 2023-10-30 | 2024-03-08 |  |  |  | N/A | SIT |  | 5.0 |  | N/A |  | N/A | Systems Integration Testing (SIT) | SITAG |  |  |  | D24A - Industry Integration Test Completion Report |
| 1485 | 1.4.2.2.1 | SIT Component Integration Testing Start | milestone | 0d | 2023-10-30 A | 2023-10-30 A | 1483 | 100% |  | 2023-10-30 | 2023-10-30 | 0d | 2023-10-30 | 2023-10-30 |  |  |  | SI Test | SIT |  | 5.11 | Complete |  | COMPLETE | PP | Systems Integration Testing (SIT) |  |  |  |  |  |
| 1486 | 1.4.2.2.2 | Component Integration Testing Interval 1 Start | milestone | 0d | 2023-10-30 A | 2023-10-30 A | 701SS+1d, 622, 626, 630, 114 | 100% |  | 2023-10-30 | 2023-10-30 | 0d | 2023-10-30 | 2023-10-30 |  |  |  | SI Test | SIT |  | 5.11 | Complete |  | COMPLETE | PP | Systems Integration Testing (SIT) | SITAG | MHHS-ART071 | T3-TE-0060 | T3 |  |
| 1487 | 1.4.2.2.3 | Component Integration Testing Interval 2 Start | milestone | 0d | 2023-11-13 A | 2023-11-13 A | 728SS+5d, 622, 630, 626, 114 | 100% |  | 2023-11-13 | 2023-11-13 | 0d | 2023-11-13 | 2023-11-13 |  |  |  | SI Test | SIT |  | 5.12 | Complete |  | COMPLETE | PP | Systems Integration Testing (SIT) | SITAG |  | T3-TE-0061 | T3 |  |
| 1488 | 1.4.2.2.4 | Component Integration Testing Interval 3 Start | milestone | 0d | 2023-11-27 A | 2023-11-27 A | 760SS+5d, 622, 626, 630, 114 | 100% |  | 2023-11-27 | 2023-11-27 | 0d | 2023-11-27 | 2023-11-27 |  |  |  | SI Test | SIT |  | 5.0 | Complete |  | COMPLETE | PP | Systems Integration Testing (SIT) | SITAG |  | T3-TE-0062 | T3 |  |
| 1489 | 1.4.2.2.5 | Component Integration Testing Interval 4 Start | milestone | 0d | 2023-12-11 A | 2023-12-11 A | 792SS+5d, 622, 626, 630, 114 | 100% |  | 2023-12-11 | 2023-12-11 | 0d | 2023-12-11 | 2023-12-11 |  |  |  | SI Test | SIT |  | 5.0 | Complete |  | COMPLETE | PP | Systems Integration Testing (SIT) | SITAG |  | T3-TE-0063 | T3 |  |
| 1490 | 1.4.2.2.6 | Component Integration Testing Interval 5 Start | milestone | 0d | 2024-01-15 A | 2024-01-15 A | 824SS+5d, 622, 626, 630, 114 | 100% |  | 2024-01-15 | 2024-01-15 | 0d | 2024-01-15 | 2024-01-15 |  |  |  | SI Test | SIT |  | 5.0 | Complete |  | COMPLETE | PP | Systems Integration Testing (SIT) | SITAG |  | T3-TE-0064 | T3 |  |
| 1491 | 1.4.2.2.7 | Component Integration Testing Interval 6 Start | milestone | 0d | 2024-01-29 A | 2024-01-29 A | 622, 626, 630, 856, 114, 668 | 100% |  | 2024-01-29 | 2024-01-29 | 0d | 2024-01-29 | 2024-01-29 |  | must start on 2024-01-29 |  | SI Test | SIT |  | 5.0 | Complete |  | COMPLETE | PP | Systems Integration Testing (SIT) | SITAG |  | T3-TE-0065 | T3 |  |
| 1492 | 1.4.2.2.8 | SIT Component Integration Testing Execution |  | 85d | 2023-10-30 A | 2024-02-23 A | 1486SS | 100% |  | 2023-10-30 | 2024-02-23 | 85d | 2023-10-30 | 2024-02-23 |  | must start on 2023-10-30 |  | SI Test | SIT |  | 5.0 | Complete |  | COMPLETE | PP | Systems Integration Testing (SIT) |  |  |  |  | D24A - Industry Integration Test Completion Report |
| 1493 | 1.4.2.2.9 | SIT Component Integration Testing End (incl. confirmation that PPs have submitted their Test Completion Reports to Programme for assurance) | milestone | 0d | 2024-02-23 A | 2024-02-23 A | 1492FF | 100% |  | 2024-02-23 | 2024-02-23 | 0d | 2024-02-23 | 2024-02-23 |  | finish no earlier than 2024-02-23 |  | SI Test | SIT |  | 5.19 | Complete |  | COMPLETE | PP | Systems Integration Testing (SIT) | SITAG | MHHS-ART074 | T3-TE-0032 | T3 |  |
| 1494 | 1.4.2.2.10 | Assurance of PPs Test Completion Reports |  | 30d | 2024-01-22 A | 2024-03-01 A | 1493FF+5d | 100% |  | 2024-01-22 | 2024-03-01 | 30d | 2024-01-22 | 2024-03-01 |  |  |  | SI Test | SIT |  | 5.19 | Complete |  | COMPLETE | PP | Systems Integration Testing (SIT) |  |  |  |  |  |
| 1495 | 1.4.2.2.11 | **SIT CI Test Completion Report** |  | 18d | 2024-02-07 A | 2024-03-01 A |  | 100% |  | 2024-02-07 | 2024-03-01 | 18d | 2024-02-07 | 2024-03-01 |  |  |  | N/A | SIT |  | 5.0 |  | N/A |  | N/A | Systems Integration Testing (SIT) |  |  |  |  |  |
| 1496 | 1.4.2.2.11.1 | Develop document |  | 13d | 2024-02-07 A | 2024-02-23 A | 1493FF | 100% |  | 2024-02-07 | 2024-02-23 | 13d | 2024-02-07 | 2024-02-23 |  |  |  | SI Test | SIT |  | 5.19 | Complete |  | COMPLETE |  | Systems Integration Testing (SIT) |  |  |  |  |  |
| 1497 | 1.4.2.2.11.2 | Review & agree document |  | 5d | 2024-02-26 A | 2024-03-01 A | 1496, 1494FF | 100% |  | 2024-02-26 | 2024-03-01 | 5d | 2024-02-26 | 2024-03-01 |  |  |  | SI Test | SIT |  | 5.19 | Complete |  | COMPLETE | PP,IPA | Systems Integration Testing (SIT) |  |  |  |  |  |
| 1498 | 1.4.2.2.12 | SIT Component Integration Testing Test Completion Report Approved | milestone | 0d | 2024-03-11 A | 2024-03-11 A | 1497FS+6d | 100% |  | 2024-03-11 | 2024-03-11 | 0d | 2024-03-08 | 2024-03-08 |  |  |  | SI Test | SIT |  | 5.18 | Complete |  | COMPLETE | PP | Systems Integration Testing (SIT) | SITAG | MHHS-ART074 | T2-TE-0600 | T2 |  |
| 1499 | 1.4.2.3 | **SIT - Minimum Viable Cohort (MVC)** |  | 735d? | 2022-10-31 A | 2025-08-22 |  | 38% | 455.6d? | 2022-10-31 | 2025-08-22 | 240d | 2024-03-11 | 2025-02-07 | 609d |  | -0 | N/A | SIT |  | 5.0 |  | N/A |  | N/A | Systems Integration Testing (SIT) | SITAG |  |  |  |  |
| 1500 | 1.4.2.3.1 | **SIT Functional Testing (MVC)** |  | 730d? | 2022-10-31 A | 2025-08-15 |  | 50% | 363.15d? | 2022-10-31 | 2025-08-15 | 225d | 2024-03-11 | 2025-01-17 | 614d |  |  | N/A | SIT |  | 5.0 |  | N/A |  | N/A | Systems Integration Testing (SIT) |  |  |  |  |  |
| 1501 | 1.4.2.3.1.1 | SIT Functional Testing Start | milestone | 0d | 2024-03-11 A | 2024-03-11 A | 1498, 984FS+5d, 863, 871, 872, 873, 880 | 100% |  | 2024-03-11 | 2024-03-11 | 0d | 2024-03-11 | 2024-03-11 |  |  |  | SI Test | SIT |  | 6.1 | Complete |  | COMPLETE | PP | Systems Integration Testing (SIT) | SITAG | MHHS-ART073 | T3-TE-0034 | T3 |  |
| 1502 | 1.4.2.3.1.2 | **SIT Functional Testing Execution (Minimum Viable Cohort)** |  | 651d? | 2022-10-31 A | 2025-04-28 |  | 78% | 143.4d? | 2022-10-31 | 2025-08-15 | 225d | 2024-03-11 | 2025-01-17 | 693d |  |  | N/A | SIT | M10 | 5.0 |  | N/A |  | N/A | Systems Integration Testing (SIT) |  |  |  |  | D24C - E2E Test Completion Report |
| 1503 | 1.4.2.3.1.2.1 | **Cycle 1 (Full Cycle)** |  | 70d | 2024-03-11 A | 2024-06-14 A |  | 100% |  | 2024-03-11 | 2024-06-14 | 90d | 2024-03-11 | 2024-07-12 |  |  |  | N/A | SIT |  | 5.0 |  | N/A |  | N/A | Systems Integration Testing (SIT) |  |  |  |  |  |
| 1504 | 1.4.2.3.1.2.1.1 | Test Execution |  | 55d | 2024-03-11 A | 2024-05-24 A | 1501SS-1d, 948 | 100% |  | 2024-03-11 | 2024-05-24 | 80d | 2024-03-11 | 2024-06-28 |  |  |  | PP | SIT |  | 5.0 | Complete |  | COMPLETE | SI Test | Systems Integration Testing (SIT) |  |  |  |  |  |
| 1505 | 1.4.2.3.1.2.1.2 | Defect resolution, assurance, review, data & environments maintenance |  | 15d | 2024-05-27 A | 2024-06-14 A | 1504 | 100% |  | 2024-05-27 | 2024-06-14 | 10d | 2024-07-01 | 2024-07-12 |  |  |  | SI Test | SIT |  | 5.0 | Complete |  | COMPLETE | PP | Systems Integration Testing (SIT) |  |  |  |  |  |

| ID | WBS | Task | Type | Duration | Start | Finish | Predecessors | Complete | Remaining | Baseline start | Baseline finish | Baseline duration | Baseline 1 start | Baseline 1 finish | Total slack | Free slack | Constraint | Responsible | Involved | Text9 | Update Version | MHHS Resource Name | MHHS Programme Phase | Sched Status | RAG | Task Status | Text29 | Tier | Milestone ID |
| --- | --- | --- | --- | --- | --- | --- | --- | --- | --- | --- | --- | --- | --- | --- | --- | --- | --- | --- | --- | --- | --- | --- | --- | --- | --- | --- | --- | --- | --- |
| 1506 | 1.4.2.3.1.2.2 | **Cycle 2 (Defect retests and targeted regression testing)** |  | 80d | 2024-06-17 A | 2024-10-04 A |  | 100% |  | 2024-06-17 | 2024-10-04 | 50d | 2024-07-15 | 2024-09-20 |  |  |  | N/A | N/A | SIT | 5.0 | N/A | Systems Integration Testing (SIT) |  |  |  |  |  |  |
| 1507 | 1.4.2.3.1.2.2.1 | Test Execution |  | 70d | 2024-06-17 A | 2024-09-20 A | 1505, 953 | 100% |  | 2024-06-17 | 2024-09-20 | 40d | 2024-07-15 | 2024-09-06 |  |  |  | PP | SI Test | SIT | 5.0 | Roger Robar | Systems Integration Testing (SIT) | Complete | COMPLETE |  |  |  |  |
| 1508 | 1.4.2.3.1.2.2.2 | Defect resolution, assurance, review, data & environments maintenance |  | 10d | 2024-09-23 A | 2024-10-04 A | 1507 | 100% |  | 2024-09-23 | 2024-10-04 | 10d | 2024-09-09 | 2024-09-20 |  |  |  | SI Test | PP | SIT | 5.0 | Roger Robar | Systems Integration Testing (SIT) | Complete | COMPLETE |  |  |  |  |
| 1509 | 1.4.2.3.1.2.3 | **SIT Functional Testing back-up progress risk-assessment** |  | 0d | 2022-10-31 | 2022-10-31 |  |  |  | 2022-10-31 | 2022-10-31 | 20d | 2024-09-23 | 2024-10-18 | 1344d |  |  | N/A | N/A | SIT | 5.31 | N/A | Systems Integration Testing (SIT) |  |  |  |  |  |  |
| 1510 | 1.4.2.3.1.2.3.1 | Back-up risk-assessment of SIT Functional progress to assess whether Qualification Execution can start early | inactive | 15d | 2024-10-07 | 2024-10-25 | 1508 |  |  | 2024-10-07 | 2024-10-25 | 15d | 2024-09-23 | 2024-10-11 | 819d | 0d |  | SI Test | Code Bodies,PP,IPA | SIT | 5.31 | Nicola Farley | Systems Integration Testing (SIT) |  | GREEN | -113.67 |  |  |  |
| 1511 | 1.4.2.3.1.2.3.2 | Back-up SITAG decision on early Qualification Testing Execution start | milestone, inactive | 0d | 2024-11-01 | 2024-11-01 | 1510FS+5d |  |  | 2024-11-01 | 2024-11-01 | 0d | 2024-10-18 | 2024-10-18 | 819d |  |  | SI Test | Code Bodies,PP,IPA | SIT | 5.31 | Nicola Farley | Systems Integration Testing (SIT) |  | GREEN | -88.29 | QAG | T3 |  |
| 1512 | 1.4.2.3.1.2.4 | **Cycle 3 (Defect retests and targeted regression testing)** |  | 105d? | 2024-10-21 A | 2025-03-14 |  | 54% | 48.64d? | 2024-10-21 | 2025-03-14 | 30d | 2024-09-23 | 2024-11-01 |  |  |  | SI Test | N/A | SIT | 5.0 | N/A | Systems Integration Testing (SIT) |  |  |  |  |  |  |
| 1513 | 1.4.2.3.1.2.4.1 | Sprint 5 |  | 10d? | 2024-10-21 A | 2024-11-01 A | 140SS-1d | 100% |  | 2024-10-21 | 2024-11-01 | 0d |  |  |  |  |  | SI Test |  | SIT | 6.0 | Roger Robar |  | Complete | COMPLETE |  |  |  |  |
| 1514 | 1.4.2.3.1.2.4.2 | Sprint 6 |  | 10d? | 2024-11-04 A | 2024-11-15 A | 1513 | 100% |  | 2024-11-04 | 2024-11-15 | 0d |  |  |  |  |  | SI Test |  | SIT | 6.0 | Roger Robar |  | Complete | COMPLETE |  |  |  |  |
| 1515 | 1.4.2.3.1.2.4.3 | Sprint 7 |  | 10d? | 2024-11-18 A | 2024-11-29 A | 1514 | 100% |  | 2024-11-18 | 2024-11-29 | 0d |  |  |  |  |  | SI Test |  | SIT | 6.0 | Roger Robar |  | Complete | COMPLETE |  |  |  |  |
| 1516 | 1.4.2.3.1.2.4.4 | Sprint 8 |  | 15d? | 2024-12-02 A | 2024-12-20 A | 1515 | 100% |  | 2024-12-02 | 2024-12-20 | 0d |  |  |  |  |  | SI Test |  | SIT | 6.0 | Roger Robar |  | Complete | COMPLETE |  |  |  |  |
| 1517 | 1.4.2.3.1.2.4.5 | Christmas downtime |  | 10d? | 2024-12-23 A | 2025-01-03 A | 1516 | 100% |  | 2024-12-23 | 2025-01-03 | 0d |  |  |  |  |  | SI Test |  | SIT | 6.0 | Roger Robar |  | Complete | COMPLETE |  |  |  |  |
| 1518 | 1.4.2.3.1.2.4.6 | Sprint 9 |  | 10d? | 2025-01-06 A | 2025-01-17 A | 1517 | 100% |  | 2025-01-06 | 2025-01-17 | 0d |  |  |  |  |  | SI Test |  | SIT | 6.0 | Roger Robar |  | Complete | COMPLETE |  |  |  |  |
| 1519 | 1.4.2.3.1.2.4.7 | Sprint 10 |  | 10d? | 2025-01-20 A | 2025-01-31 | 1518 | 80% | 2d? | 2025-01-20 | 2025-01-31 | 0d |  |  | 0d |  |  | SI Test |  | SIT | 6.0 | Roger Robar |  | Green | GREEN |  |  |  |  |
| 1520 | 1.4.2.3.1.2.4.8 | Sprint 11 |  | 10d? | 2025-02-03 | 2025-02-14 | 1519 |  |  | 2025-02-03 | 2025-02-14 | 0d |  |  | 0d |  |  | SI Test |  | SIT | 6.0 | Roger Robar |  | Green | GREEN | 5.33 |  |  |  |
| 1521 | 1.4.2.3.1.2.4.9 | Sprint 12 |  | 10d? | 2025-02-17 | 2025-02-28 | 1520 |  |  | 2025-02-17 | 2025-02-28 | 0d |  |  | 0d |  |  | SI Test |  | SIT | 6.0 | Roger Robar |  | Green | GREEN | 19.33 |  |  |  |
| 1522 | 1.4.2.3.1.2.4.10 | Sprint 13 (RTTM Gap Analysis + CR056) |  | 10d? | 2025-03-03 | 2025-03-14 | 1521 |  |  | 2025-03-03 | 2025-03-14 | 0d |  |  | 0d |  |  | SI Test |  | SIT | 6.0 | Roger Robar |  | Green | GREEN | 33.33 |  |  |  |
| 1523 | 1.4.2.3.1.2.4.11 | Sprint 14 (RTTM Gap Analysis + CR056) |  | 10d? | 2025-03-17 | 2025-03-28 | 1522 |  |  | 2025-03-17 | 2025-03-28 | 0d |  |  | 0d |  |  | SI Test |  | SIT | 6.1 | Roger Robar |  | Green | GREEN | 47.33 |  |  |  |
| 1524 | 1.4.2.3.1.2.4.12 | Sprint 15 (Contingency 1) |  | 10d? | 2025-03-31 | 2025-04-11 | 1523 |  |  | 2025-03-31 | 2025-04-11 | 0d |  |  | 0d |  |  | SI Test |  | SIT | 6.1 | Roger Robar |  | Green | GREEN | 61.33 |  |  |  |
| 1525 | 1.4.2.3.1.2.4.13 | Sprint 16 (Contingency 2) |  | 10d? | 2025-04-14 | 2025-04-25 | 1524 |  |  | 2025-04-14 | 2025-04-25 | 0d |  |  | 0d |  |  | SI Test |  | SIT | 6.1 | Roger Robar |  | Green | GREEN | 75.33 |  |  |  |
| 1526 | 1.4.2.3.1.2.4.14 | SIT Functional Cycle 3 Complete |  | 1d? | 2025-04-28 | 2025-04-28 | 1525 |  |  | 2025-04-28 | 2025-04-28 |  |  |  | 693d |  |  | SI Test |  | SIT | 6.13 | Roger Robar |  | Green | GREEN | 89.33 | SITAG | T2 | T2-TE-1150 |
| 1527 | 1.4.2.3.1.3 | **SIT Scope Traceability** |  | 38d | 2025-01-27 | 2025-03-19 |  |  |  | 2025-01-27 | 2025-03-19 |  |  |  | 721d |  |  |  |  | SIT | 6.17 | Salman Bukhari |  | Overdue Start |  | -94.67 |  |  |  |
| 1528 | 1.4.2.3.1.3.1 | Draft Scope Tracability document |  | 10d | 2025-01-27 | 2025-02-07 |  |  |  | 2025-01-27 | 2025-02-07 |  |  |  | 721d | 0d | start no earlier than 2025-01-27 |  |  | SIT | 6.17 | Salman Bukhari |  | Green | GREEN | -1.67 |  |  |  |
| 1529 | 1.4.2.3.1.3.2 | LDP review |  | 2d | 2025-02-10 | 2025-02-11 | 1528 |  |  | 2025-02-10 | 2025-02-11 |  |  |  | 721d | 0d |  |  |  | SIT | 6.17 | Salman Bukhari |  | Green | GREEN | 12.33 |  |  |  |
| 1530 | 1.4.2.3.1.3.3 | SRO review |  | 5d | 2025-02-12 | 2025-02-18 | 1529 |  |  | 2025-02-12 | 2025-02-18 |  |  |  | 721d | 0d |  |  |  | SIT | 6.17 | Salman Bukhari |  | Green | GREEN | 14.33 |  |  |  |
| 1531 | 1.4.2.3.1.3.4 | Updates to reflect SRO feedback |  | 5d | 2025-02-12 | 2025-02-18 | 1530FF |  |  | 2025-02-12 | 2025-02-18 |  |  |  | 721d | 0d |  |  |  | SIT | 6.17 | Salman Bukhari |  | Green | GREEN | 14.33 |  |  |  |
| 1532 | 1.4.2.3.1.3.5 | Industry Review |  | 10d | 2025-02-19 | 2025-03-04 | 1531 |  |  | 2025-02-19 | 2025-03-04 |  |  |  | 732d |  |  |  |  | SIT | 6.17 | Salman Bukhari |  | Green | GREEN | 21.33 |  |  |  |
| 1533 | 1.4.2.3.1.3.6 | SITWG paper day | milestone | 0d | 2025-02-27 | 2025-02-27 | 1531FS+7d |  |  | 2025-02-27 | 2025-02-27 |  |  |  | 721d | 0d |  |  |  | SIT | 6.17 | Salman Bukhari |  | Green | GREEN | 29.71 |  |  |  |
| 1534 | 1.4.2.3.1.3.7 | SITWG recommends Scope Tracability document | milestone | 0d | 2025-03-06 | 2025-03-06 | 1533FS+5d |  |  | 2025-03-06 | 2025-03-06 |  |  |  | 721d | 0d |  |  |  | SIT | 6.17 | Salman Bukhari |  | Green | GREEN | 36.71 |  |  |  |
| 1535 | 1.4.2.3.1.3.8 | Update document to reflect industry consultation views |  | 4d | 2025-03-07 | 2025-03-12 | 1534 |  |  | 2025-03-07 | 2025-03-12 |  |  |  | 721d | 0d |  |  |  | SIT | 6.17 | Salman Bukhari |  | Green | GREEN | 37.33 |  |  |  |
| 1536 | 1.4.2.3.1.3.9 | SITAG paper day | milestone | 0d | 2025-03-12 | 2025-03-12 | 1535 |  |  | 2025-03-12 | 2025-03-12 |  |  |  | 721d | 0d |  |  |  | SIT | 6.17 | Salman Bukhari |  | Green | GREEN | 42.71 |  |  |  |
| 1537 | 1.4.2.3.1.3.10 | SITAG approve SIT Scope Traceability document | milestone | 0d | 2025-03-19 | 2025-03-19 | 1536FS+5d |  |  | 2025-03-19 | 2025-03-19 |  |  |  | 721d | 0d |  |  |  | SIT | 6.17 | Salman Bukhari |  | Green | GREEN | 49.71 |  |  |  |
| 1538 | 1.4.2.3.1.3.11 | SIT Scope Traceability Approved | milestone | 0d | 2025-03-19 | 2025-03-19 | 1537 |  |  | 2025-03-19 | 2025-03-19 |  |  |  | 721d |  |  |  |  | SIT | 6.17 | Salman Bukhari |  | Green | GREEN | 49.71 |  |  |  |

Notes:
- 1510: Action: 5/12 - LC said change name from his to nicola and check dates based on new start date for non sit ldso testing
- 1511: Guidance: 13/8/24: To be removed because SIT has not made sufficient progress to allow early quaifation test start. 22/8/24: Approved at QAG on 22/8/24 to be removed
- 1528: 28/01/25 - New activity added in to reflect the work to develop and obtain SITAG approval for a scope traceability doc.
- 1529: 28/01/25 - New activity added in to reflect the work to develop and obtain SITAG approval for a scope traceability doc.
- 1530: 28/01/25 - New activity added in to reflect the work to develop and obtain SITAG approval for a scope traceability doc.
- 1531: 28/01/25 - New activity added in to reflect the work to develop and obtain SITAG approval for a scope traceability doc.
- 1532: 28/01/25 - New activity added in to reflect the work to develop and obtain SITAG approval for a scope traceability doc.
- 1533: 28/01/25 - New activity added in to reflect the work to develop and obtain SITAG approval for a scope traceability doc.
- 1534: 28/01/25 - New activity added in to reflect the work to develop and obtain SITAG approval for a scope traceability doc.
- 1535: 28/01/25 - New activity added in to reflect the work to develop and obtain SITAG approval for a scope traceability doc.
- 1536: 28/01/25 - New activity added in to reflect the work to develop and obtain SITAG approval for a scope traceability doc.
- 1537: 28/01/25 - New activity added in to reflect the work to develop and obtain SITAG approval for a scope traceability doc.
- 1538: 28/01/25 - New activity added in to reflect the work to develop and obtain SITAG approval for a scope traceability doc.

| ID | WBS | Task | Type | Duration | Start | Finish | Predecessors | Complete | Remaining | Actual start | Baseline start | Baseline finish | Baseline duration | Baseline 1 start | Baseline 1 finish | Total slack | Free slack | Constraint | Responsible | Text9 | Task Status | Update Version | Sched Status | MHHS Resource Name | RAG | Milestone ID | Text29 | Tier | Involved | MHHS Programme Phase | Artefact ID |
| --- | --- | --- | --- | --- | --- | --- | --- | --- | --- | --- | --- | --- | --- | --- | --- | --- | --- | --- | --- | --- | --- | --- | --- | --- | --- | --- | --- | --- | --- | --- | --- |
| 1539 | 1.4.2.3.1.4 | **SIT Functional Settlement Testing** |  | 230d? | 2024-06-17 | 2025-05-02 |  | 28% | 166.35d? | 2024-10-07 | 2024-06-17 | 2025-05-02 | 0d |  |  |  |  |  | SI Test | SIT | -685.67 | 6.12 | Overdue Start | Stuart Scott |  |  |  |  |  |  |  |
| 1540 | 1.4.2.3.1.4.1 | SIT-B Settlement Testing Cycle 2 |  | 70d | 2025-03-10 | 2025-06-13 | 1557FS+10d |  |  |  | 2025-03-10 | 2025-06-13 | 0d |  |  | 659d |  | start no earlier than 2024-06-17 | SI Test | SIT | 40.33 | 6.12 | Green | Stuart Scott | GREEN |  |  |  |  |  |  |
| 1541 | 1.4.2.3.1.4.2 | **SIT-B Settlement Testing Cycle 3** |  | 100d? | 2024-10-07 A | 2025-02-21 | 1357 | 79% | 21.05d? |  | 2024-10-07 | 2024-12-20 | 0d |  |  | 664d | 0d |  | SI Test | SIT | -24.67 | 6.12 | Overdue Start | Stuart Scott | GREEN |  |  |  |  |  |  |
| 1542 | 1.4.2.3.1.4.2.1 | Sprint 5 |  | 20d? | 2024-10-07 A | 2024-11-01 A |  | 100% |  |  | 2024-10-07 | 2024-11-01 | 0d |  |  |  |  |  | SI Test | SIT |  | 6.12 | Complete | Stuart Scott | COMPLETE |  |  |  |  |  |  |
| 1543 | 1.4.2.3.1.4.2.2 | Sprint 5 Review (Flexibility Window Checkpoint) | milestone | 0d | 2024-11-04 A | 2024-11-04 A | 1542SS+21d | 100% |  |  | 2024-11-04 | 2024-11-04 | 0d |  |  |  |  |  | SI Test | SIT |  | 6.12 | Complete | Stuart Scott | COMPLETE |  |  |  |  |  |  |
| 1544 | 1.4.2.3.1.4.2.3 | Sprint 6 |  | 10d? | 2024-11-04 A | 2024-11-15 A | 1542 | 100% |  |  | 2024-11-04 | 2024-11-15 | 0d |  |  |  |  |  | SI Test | SIT |  | 6.12 | Complete | Stuart Scott | COMPLETE |  |  |  |  |  |  |
| 1545 | 1.4.2.3.1.4.2.4 | Sprint 6 Review (Pre Christmas Contingency Decision Point) | milestone | 0d | 2024-11-18 A | 2024-11-18 A | 1544SS+11d | 100% |  |  | 2024-11-18 | 2024-11-18 | 0d |  |  |  |  |  | SI Test | SIT |  | 6.12 | Complete | Stuart Scott | COMPLETE |  |  |  |  |  |  |
| 1546 | 1.4.2.3.1.4.2.5 | Sprint 7 |  | 10d? | 2024-11-18 A | 2024-11-29 A | 1544 | 100% |  |  | 2024-11-18 | 2024-11-29 | 0d |  |  |  |  |  | SI Test | SIT |  | 6.12 | Complete | Stuart Scott | COMPLETE |  |  |  |  |  |  |
| 1547 | 1.4.2.3.1.4.2.6 | Sprint 7 Review (Post Christmas Contingency Decision Point) | milestone | 0d | 2024-12-02 A | 2024-12-02 A | 1546SS+11d | 100% |  |  | 2024-12-02 | 2024-12-02 | 0d |  |  |  |  |  | SI Test | SIT |  | 6.12 | Complete | Stuart Scott | COMPLETE |  |  |  |  |  |  |
| 1548 | 1.4.2.3.1.4.2.7 | Sprint 8 |  | 15d | 2024-12-02 A | 2024-12-20 A | 1546 | 100% |  |  | 2024-12-02 | 2024-12-20 | 0d |  |  |  |  |  | SI Test | SIT |  | 6.15 | Complete | Stuart Scott | COMPLETE |  |  |  |  |  |  |
| 1549 | 1.4.2.3.1.4.2.8 | Post-Christmas Stabilisation |  | 5d | 2025-01-06 A | 2025-01-10 A | 1548FS+10d | 100% |  |  | 2025-01-06 | 2025-01-10 | 0d |  |  |  |  |  | SI Test | SIT |  | 6.15 | Complete | Stuart Scott | COMPLETE |  |  |  |  |  |  |
| 1550 | 1.4.2.3.1.4.2.9 | Sprint 9 |  | 10d | 2025-01-06 A | 2025-01-17 A | 1548FS+10d | 100% |  |  | 2025-01-13 | 2025-01-17 |  |  |  |  |  |  | SI Test | SIT |  | 6.15 | Complete | Stuart Scott | COMPLETE |  |  |  |  |  |  |
| 1551 | 1.4.2.3.1.4.2.10 | Sprint 9 Review | milestone | 0d | 2025-01-20 A | 2025-01-20 A | 1550FS+1d | 100% |  |  | 2025-01-20 | 2025-01-20 |  |  |  |  |  |  | SI Test | SIT |  | 6.15 | Complete | Stuart Scott | COMPLETE |  |  |  |  |  |  |
| 1552 | 1.4.2.3.1.4.2.11 | Sprint 10 |  | 10d | 2025-01-20 A | 2025-01-31 | 1550 | 50% | 5d |  | 2025-01-20 | 2025-01-31 |  |  |  | 1d | 0d |  | SI Test | SIT |  | 6.15 | Green | Stuart Scott | GREEN |  |  |  |  |  |  |
| 1553 | 1.4.2.3.1.4.2.12 | Sprint 10 Review | milestone | 0d | 2025-02-03 | 2025-02-03 | 1552FS+1d |  |  |  | 2025-02-03 | 2025-02-03 |  |  |  | 678d |  |  | SI Test | SIT | 5.71 | 6.15 | Green | Stuart Scott | GREEN |  |  |  |  |  |  |
| 1554 | 1.4.2.3.1.4.2.13 | Sprint 11 |  | 10d | 2025-02-03 | 2025-02-14 | 1552 |  |  |  | 2025-02-03 | 2025-02-14 |  |  |  | 1d | 0d |  | SI Test | SIT | 5.33 | 6.15 | Green | Stuart Scott | GREEN |  |  |  |  |  |  |
| 1555 | 1.4.2.3.1.4.2.14 | Sprint 11 Review | milestone | 0d | 2025-02-14 | 2025-02-14 | 1554 |  |  |  | 2025-02-14 | 2025-02-14 |  |  |  | 1d | 0d |  | SI Test | SIT | 16.71 | 6.15 | Green | Stuart Scott | GREEN |  |  |  |  |  |  |
| 1556 | 1.4.2.3.1.4.2.15 | Sprint 12 |  | 5d | 2025-02-17 | 2025-02-21 | 1555 |  |  |  | 2025-02-17 | 2025-02-21 |  |  |  | 1d | 0d |  | SI Test | SIT | 19.33 | 6.15 | Green | Stuart Scott | GREEN |  |  |  |  |  |  |
| 1557 | 1.4.2.3.1.4.2.16 | End of Settlement Testing Cycle 3 | milestone | 0d | 2025-02-21 | 2025-02-21 | 1556 |  |  |  | 2025-02-21 | 2025-02-21 | 0d |  |  | 1d | 0d |  | SI Test | SIT | 23.71 | 6.15 | Green | Stuart Scott | GREEN | T3-TE-0140 | SITAG | T3 |  |  |  |
| 1558 | 1.4.2.3.1.4.3 | SIT-A CoS Settlement Testing |  | 20d? | 2025-05-19 | 2025-06-13 | 1429 |  |  |  | 2025-05-19 | 2025-06-13 | 0d |  |  | 0d |  |  | SI Test | SIT | 110.33 | 6.15 | Green | Stuart Scott | GREEN |  |  |  |  |  |  |
| 1559 | 1.4.2.3.1.4.4 | **SIT Functional MVC Regression Testing (code freeze)** |  | 40d? | 2025-06-16 | 2025-08-08 |  |  |  |  | 2025-06-16 | 2025-08-08 | 45d | 2024-11-04 | 2025-01-03 | 0d |  |  | PP | SIT | 84.33 | 6.15 |  | Roger Robar |  |  |  |  | SI Test | Systems Integration Testing (SIT) |  |
| 1560 | 1.4.2.3.1.4.4.1 | Regression Test Execution Start |  | 1d | 2025-06-16 | 2025-06-16 | 1429, 1558 |  |  |  | 2025-06-16 | 2025-06-16 | 0d |  |  | 658d |  |  | SI Test | SIT | 138.33 | 6.15 | Green | Roger Robar | GREEN | T2-TE-1250 | SITAG | T2 |  |  |  |
| 1561 | 1.4.2.3.1.4.4.2 | Regression Sprint 1 |  | 10d? | 2025-06-16 | 2025-06-27 | 1558, 1423 |  |  |  | 2025-06-16 | 2025-06-27 | 0d |  |  | 0d |  |  | SI Test | SIT | 138.33 | 6.14 | Green | Roger Robar | GREEN |  |  |  |  |  |  |
| 1562 | 1.4.2.3.1.4.4.3 | Regression Sprint 2 |  | 15d | 2025-06-30 | 2025-07-18 | 1561 |  |  |  | 2025-06-30 | 2025-07-18 | 0d |  |  | 0d |  |  | SI Test | SIT | 152.33 | 6.15 | Green | Roger Robar | GREEN |  |  |  |  |  |  |
| 1563 | 1.4.2.3.1.4.4.4 | Regression Sprint 3 |  | 15d | 2025-07-21 | 2025-08-08 | 1562 |  |  |  | 2025-07-21 | 2025-08-08 | 0d |  |  | 0d |  |  | SI Test | SIT | 173.33 | 6.15 | Green | Roger Robar | GREEN |  |  |  |  |  |  |
| 1564 | 1.4.2.3.1.4.5 | SIT Functional Testing End (Minimum Viable Cohort) (incl. confirmation that PPs have submitted their Test Completion Reports to Programme for assurance) | milestone | 0d | 2025-08-08 | 2025-08-08 | 1563 |  |  |  | 2025-08-08 | 2025-08-08 | 0d | 2025-01-03 | 2025-01-03 | 0d |  | start no earlier than 2025-03-14 | SI Test | SIT | 191.71 | 6.1 | Green | Roger Robar | GREEN | T3-TE-0046 | SITAG | T3 | PP | Systems Integration Testing (SIT) | MHHS-ART072 |
| 1565 | 1.4.2.3.1.4.6 | Assurance of PPs Test Completion Reports |  | 25d | 2025-07-14 | 2025-08-15 | 1564FF+5d |  |  |  | 2025-07-14 | 2025-08-15 | 30d | 2024-12-02 | 2025-01-10 | 0d |  |  | SI Test | SIT | 166.33 | 6.1 | Green | Roger Robar | GREEN |  |  |  | PP | Systems Integration Testing (SIT) |  |

| ID | WBS | Task | Type | Duration | Start | Finish | Predecessors | Complete | Remaining | Actual start | Actual finish | Baseline start | Baseline finish | Baseline duration | Baseline 1 start | Baseline 1 finish | Total slack | Free slack | Constraint | Baseline cost | Responsible | Involved | Text9 | Update Version | MHHS Resource Name | MHHS Programme Phase | Task Status | Sched Status | RAG | Artefact ID | Milestone ID | Text29 | Tier |
| --- | --- | --- | --- | --- | --- | --- | --- | --- | --- | --- | --- | --- | --- | --- | --- | --- | --- | --- | --- | --- | --- | --- | --- | --- | --- | --- | --- | --- | --- | --- | --- | --- | --- |
| 1566 | 1.4.2.3.1.4.7 | **SIT Functional Test Completion Report (Minimum Viable Cohort)** |  | 20d | 2025-07-21 | 2025-08-15 |  |  |  |  |  | 2025-07-21 | 2025-08-15 | 20d | 2024-12-16 | 2025-01-10 | 0d |  |  |  | N/A | N/A | SIT | 6.1 | N/A | Systems Integration Testing (SIT) |  |  |  |  |  |  |  |
| 1567 | 1.4.2.3.1.4.7.1 | Develop document |  | 15d | 2025-07-21 | 2025-08-08 | 1564FF |  |  |  |  | 2025-07-21 | 2025-08-08 | 15d | 2024-12-16 | 2025-01-03 | 0d |  |  |  | SI Test |  | SIT | 6.1 | Roger Robar | Systems Integration Testing (SIT) | 173.33 | Green | GREEN |  |  |  |  |
| 1568 | 1.4.2.3.1.4.7.2 | Review & agree document |  | 5d | 2025-08-11 | 2025-08-15 | 1567, 1565FF |  |  |  |  | 2025-08-11 | 2025-08-15 | 5d | 2025-01-06 | 2025-01-10 | 0d |  |  |  | SI Test | PP,IPA | SIT | 6.1 | Roger Robar | Systems Integration Testing (SIT) | 194.33 | Green | GREEN |  |  |  |  |
| 1569 | 1.4.2.3.1.4.7.3 | SIT Functional Testing Test Completion Report (Minimum Viable Cohort) Approved | milestone | 0d | 2025-08-15 | 2025-08-15 | 1568FF |  |  |  |  | 2025-08-15 | 2025-08-15 | 0d | 2025-01-17 | 2025-01-17 | 0d |  |  |  | SI Test | PP | SIT | 6.1 | Roger Robar | Systems Integration Testing (SIT) | 198.71 | Green | GREEN | MHHS-ART072 | T2-TE-0850 | SITAG | T2 |
| 1570 | 1.4.2.3.2 | **Helix E2E Settlement Testing** |  | 86d? | 2025-02-07 | 2025-06-06 |  |  |  |  |  | 2025-01-06 | 2025-04-04 | 0d |  |  | 664d |  |  |  | Helix |  | SIT | 6.0 | Helix |  | -689.67 | Overdue Start |  |  |  |  |  |
| 1571 | 1.4.2.3.2.1 | Programme agreement into Settlement Testing |  | 1d? | 2025-02-07 | 2025-02-07 |  |  |  |  |  | 2025-02-07 | 2025-02-07 |  |  |  | 749d |  | start no earlier than 2025-02-07 |  | Helix |  | SIT | 6.15 | Helix |  | 9.33 | Green | GREEN |  |  |  |  |
| 1572 | 1.4.2.3.2.2 | Helix E2E Settlement Testing Execution |  | 65d | 2025-03-10 | 2025-06-06 | 1541FS+10d |  |  |  |  | 2025-01-06 | 2025-04-04 | 0d |  |  | 664d | 0d |  |  | Helix |  | SIT | 6.0 | Helix |  | 40.33 | Red | RED |  |  |  |  |
| 1573 | 1.4.2.3.2.3 | Helix E2E Settlement Testing Execution Complete | milestone | 0d | 2025-06-06 | 2025-06-06 | 1572 |  |  |  |  | 2025-04-04 | 2025-04-04 | 0d |  |  | 664d |  |  |  | Helix |  | SIT | 6.0 | Helix |  | 128.71 | Red | RED |  |  |  |  |
| 1574 | 1.4.2.3.2.4 | MHHSP Helix E2E Testing Assurance |  | 65d | 2025-03-10 | 2025-06-06 | 1541FS+10d |  |  |  |  | 2025-01-06 | 2025-04-04 | 0d |  |  | 664d | 0d |  |  | Helix |  | SIT | 6.0 | Helix |  | 40.33 | Red | RED |  |  |  |  |
| 1575 | 1.4.2.3.2.5 | MHHSP Helix E2E Testing Assurance Complete | milestone | 0d | 2025-06-06 | 2025-06-06 | 1574 |  |  |  |  | 2025-04-04 | 2025-04-04 | 0d |  |  | 664d |  |  |  | Helix |  | SIT | 6.0 | Helix |  | 128.71 | Red | RED |  |  |  |  |
| 1576 | 1.4.2.3.3 | **SIT Migration Testing (MVC)** |  | 380d? | 2024-03-11 A | 2025-08-22 |  | 62% | 145.09d? |  |  | 2024-03-11 | 2025-08-22 | 155d | 2024-06-10 | 2024-10-18 | 609d |  |  | -0 | SI Test | N/A | SIT | 6.0 | Helix | Systems Integration Testing (SIT) |  | Overdue | GREEN |  |  | SITAG |  |
| 1577 | 1.4.2.3.3.1 | SIT Migration Testing Start | milestone | 0d? | 2024-03-11 A | 2024-03-11 A |  | 100% |  |  |  | 2024-03-11 | 2024-03-11 | 0d |  |  |  |  | start no earlier than 2024-03-11 |  | SI Test |  | SIT | 6.0 | Helix |  |  | Complete | COMPLETE |  |  |  |  |
| 1578 | 1.4.2.3.3.2 | **SIT Migration Testing Execution (Minimum Viable Cohort)** |  | 380d? | 2024-03-11 A | 2025-08-22 |  | 62% | 145.09d? |  |  | 2024-03-11 | 2025-08-22 | 0d |  |  | 609d |  |  |  | SI Test |  | SIT | 6.0 | Ankur Pande |  | -685.67 | Overdue Start |  |  |  | SITAG |  |
| 1579 | 1.4.2.3.3.2.1 | **Cycle 1 (Full Cycle)** |  | 70d? | 2024-03-11 A | 2024-06-14 A |  | 100% |  |  |  | 2024-03-11 | 2024-06-14 | 0d |  |  |  |  |  |  | SI Test |  | SIT | 6.0 | Ankur Pande |  | -685.67 | Overdue Start |  |  |  |  |  |
| 1580 | 1.4.2.3.3.2.1.1 | Test Execution |  | 55d? | 2024-03-11 A | 2024-05-24 A |  | 100% |  |  |  | 2024-03-11 | 2024-05-24 | 0d |  |  |  |  | start no earlier than 2024-03-11 |  | SI Test |  | SIT | 6.0 | Ankur Pande |  |  | Complete | COMPLETE |  |  |  |  |
| 1581 | 1.4.2.3.3.2.1.2 | Defect resolution, assurance, review, data& environments maintenance |  | 15d? | 2024-05-27 A | 2024-06-14 A |  | 100% |  |  |  | 2024-05-27 | 2024-06-14 | 0d |  |  |  |  | finish no earlier than 2024-06-14 |  | SI Test |  | SIT | 6.0 | Ankur Pande |  |  | Complete | COMPLETE |  |  |  |  |
| 1582 | 1.4.2.3.3.2.2 | **Cycle 2 (Defect retests and targeted regression testing)** |  | 80d? | 2024-03-11 | 2024-06-28 |  | 100% |  | 2024-06-17 | 2024-10-04 | 2024-03-11 | 2024-06-28 | 0d |  |  |  |  |  |  | SI Test |  | SIT | 6.0 | Ankur Pande |  | -685.67 | Overdue Start |  |  |  |  |  |
| 1583 | 1.4.2.3.3.2.2.1 | Test Execution |  | 70d? | 2024-06-17 A | 2024-09-20 A | 1581 | 100% |  |  |  | 2024-06-17 | 2024-09-20 | 0d |  |  |  |  | start no earlier than 2024-06-17 |  | SI Test |  | SIT | 6.0 | Ankur Pande |  |  | Complete | COMPLETE |  |  |  |  |
| 1584 | 1.4.2.3.3.2.2.2 | Defect resolution, assurance, review, data & environments maintenance |  | 10d? | 2024-09-23 A | 2024-10-04 A | 1583 | 100% |  |  |  | 2024-09-23 | 2024-10-04 | 0d |  |  |  |  | finish no earlier than 2024-10-04 |  | SI Test |  | SIT | 6.0 | Ankur Pande |  |  | Complete | COMPLETE |  |  |  |  |
| 1585 | 1.4.2.3.3.2.3 | **SIT Migration Testing back-up progress risk-assessment** |  | 70d? | 2024-06-17 | 2024-09-20 |  | 100% |  | 2024-10-07 | 2024-11-01 | 2024-06-17 | 2024-09-20 | 0d |  |  |  |  |  |  | SI Test |  | SIT | 6.0 | Ankur Pande |  | -685.67 | Overdue Start |  |  |  |  |  |
| 1586 | 1.4.2.3.3.2.3.1 | Back-up risk-assessment of SIT Migration progress to assess whether Qualification Execution can start early |  | 15d? | 2024-10-07 A | 2024-10-25 A | 1584 | 100% |  |  |  | 2024-10-07 | 2024-10-25 | 0d |  |  |  |  | finish no earlier than 2024-10-04 |  | SI Test |  | SIT | 6.0 | Ankur Pande |  |  | Complete | COMPLETE |  |  |  |  |
| 1587 | 1.4.2.3.3.2.3.2 | Back-up SITAG decision on early Qualification Testing Execution start | milestone | 0d? | 2024-11-01 A | 2024-11-01 A | 1586FS+5d | 100% |  |  |  | 2024-11-01 | 2024-11-01 | 0d |  |  |  |  |  |  | SI Test |  | SIT | 6.0 | Ankur Pande |  |  | Complete | COMPLETE |  |  |  |  |
| 1588 | 1.4.2.3.3.2.4 | **Cycle 3 (Defect retests and targeted regression testing)** |  | 135d? | 2024-10-21 A | 2025-04-25 |  | 54% | 62d? |  |  | 2024-10-21 | 2025-04-25 | 0d |  |  | 694d |  |  |  | SI Test |  | SIT | 6.0 | Ankur Pande |  | -685.67 | Overdue Start |  |  |  |  |  |
| 1589 | 1.4.2.3.3.2.4.1 | Sprint 5 |  | 10d | 2024-10-21 A | 2024-11-01 A | 140FS-1d | 100% |  |  |  | 2024-10-21 | 2024-11-01 | 0d |  |  |  |  | start no earlier than 2024-10-21 |  | SI Test |  | SIT | 6.0 | Ankur Pande |  |  | Complete | COMPLETE |  |  |  |  |
| 1590 | 1.4.2.3.3.2.4.2 | Sprint 6 |  | 10d | 2024-11-04 A | 2024-11-15 A | 1589 | 100% |  |  |  | 2024-11-04 | 2024-11-15 | 0d |  |  |  |  | start no earlier than 2024-11-04 |  | SI Test |  | SIT | 6.0 | Ankur Pande |  |  | Complete | COMPLETE |  |  |  |  |
| 1591 | 1.4.2.3.3.2.4.3 | Sprint 7 |  | 10d | 2024-11-18 A | 2024-11-29 A | 1590 | 100% |  |  |  | 2024-11-18 | 2024-11-29 | 0d |  |  |  |  |  |  | SI Test |  | SIT | 6.0 | Ankur Pande |  |  | Complete | COMPLETE |  |  |  |  |
| 1592 | 1.4.2.3.3.2.4.4 | Sprint 8 |  | 15d | 2024-12-02 A | 2024-12-20 A | 1591 | 100% |  |  |  | 2024-12-02 | 2024-12-20 | 0d |  |  |  |  | finish no earlier than 2024-11-15 |  | SI Test |  | SIT | 6.0 | Ankur Pande |  |  | Complete | COMPLETE |  |  |  |  |
| 1593 | 1.4.2.3.3.2.4.5 | Christmas downtime |  | 10d | 2024-12-23 A | 2025-01-03 A | 1592 | 100% |  |  |  | 2024-12-23 | 2025-01-03 | 0d |  |  |  |  | finish no earlier than 2024-11-29 |  | SI Test |  | SIT | 6.0 | Ankur Pande |  |  | Complete | COMPLETE |  |  |  |  |
| 1594 | 1.4.2.3.3.2.4.6 | Sprint 9 |  | 10d | 2025-01-06 A | 2025-01-17 A | 1593 | 100% |  |  |  | 2025-01-06 | 2025-01-17 | 0d |  |  |  |  | finish no earlier than 2024-12-20 |  | SI Test |  | SIT | 6.0 | Ankur Pande |  |  | Complete | COMPLETE |  |  |  |  |
| 1595 | 1.4.2.3.3.2.4.7 | Sprint 10 |  | 10d | 2025-01-20 A | 2025-01-31 | 1594 | 80% | 2d |  |  | 2025-01-20 | 2025-01-31 | 0d |  |  | 0d |  | finish no earlier than 2025-01-03 |  | SI Test |  | SIT | 6.0 | Ankur Pande |  |  | Green | GREEN |  |  |  |  |
| 1596 | 1.4.2.3.3.2.4.8 | Sprint 11 |  | 10d | 2025-02-03 | 2025-02-14 | 1595 |  |  |  |  | 2025-02-03 | 2025-02-14 | 0d |  |  | 0d |  | finish no earlier than 2025-01-17 |  | SI Test |  | SIT | 6.0 | Ankur Pande |  | 5.33 | Green | GREEN |  |  |  |  |
| 1597 | 1.4.2.3.3.2.4.9 | Sprint 12 |  | 10d | 2025-02-17 | 2025-02-28 | 1596 |  |  |  |  | 2025-02-17 | 2025-02-28 | 0d |  |  | 0d |  | finish no earlier than 2025-01-31 |  | SI Test |  | SIT | 6.0 | Ankur Pande |  | 19.33 | Green | GREEN |  |  |  |  |
| 1598 | 1.4.2.3.3.2.4.10 | Sprint 13 |  | 10d | 2025-03-03 | 2025-03-14 | 1597 |  |  |  |  | 2025-03-03 | 2025-03-14 | 0d |  |  | 0d |  |  |  | SI Test |  | SIT | 6.1 | Ankur Pande |  | 33.33 | Green | GREEN |  |  |  |  |
| 1599 | 1.4.2.3.3.2.4.11 | Sprint 14 (RTTM Gap Analysis + CR056) |  | 10d? | 2025-03-17 | 2025-03-28 | 1598 |  |  |  |  | 2025-03-17 | 2025-03-28 | 0d |  |  | 0d |  |  |  | SI Test |  | SIT | 6.1 | Ankur Pande |  | 47.33 | Green | GREEN |  |  |  |  |
| 1600 | 1.4.2.3.3.2.4.12 | Sprint 15 (Contingency 1) |  | 10d? | 2025-03-31 | 2025-04-11 | 1599 |  |  |  |  | 2025-03-31 | 2025-04-11 | 0d |  |  | 0d |  |  |  | SI Test |  | SIT | 6.1 | Ankur Pande |  | 61.33 | Green | GREEN |  |  |  |  |
| 1601 | 1.4.2.3.3.2.4.13 | Sprint 16 (Contingency 2) |  | 10d? | 2025-04-14 | 2025-04-25 | 1600 |  |  |  |  | 2025-04-14 | 2025-04-25 | 0d |  |  | 0d |  |  |  | SI Test |  | SIT | 6.1 | Ankur Pande |  | 75.33 | Green | GREEN |  |  |  |  |
| 1602 | 1.4.2.3.3.2.4.14 | SIT Migration Cycle 3 Complete | milestone | 0d | 2025-04-25 | 2025-04-25 | 1601 |  |  |  |  | 2025-04-25 | 2025-04-25 |  |  |  | 694d |  |  |  | SI Test |  | SIT | 6.1 | Ankur Pande |  | 86.71 | Green | GREEN |  | T2-TE-1200 | SITAG | T2 |

| ID | WBS | Task | Type | Duration | Start | Finish | Predecessors | Baseline start | Baseline finish | Baseline duration | Baseline 1 start | Baseline 1 finish | Total slack | Free slack | Constraint | Responsible | Text9 | Task Status | Update Version | Sched Status | MHHS Resource Name | RAG | Involved | Artefact ID | MHHS Programme Phase | Text29 | Tier | Future RAG | Milestone ID | Guidance |
| --- | --- | --- | --- | --- | --- | --- | --- | --- | --- | --- | --- | --- | --- | --- | --- | --- | --- | --- | --- | --- | --- | --- | --- | --- | --- | --- | --- | --- | --- | --- |
| 1603 | 1.4.2.3.3.2.5 | **SIT Migration MVC Regression Testing (code freeze)** |  | 35d? | 2025-06-16 | 2025-08-01 |  | 2025-06-16 | 2025-08-01 | 0d |  |  | 609d |  |  | SI Test | SIT | -685.67 | 6.0 | Overdue Start | Roger Robar |  |  |  |  |  |  |  |  |  |
| 1604 | 1.4.2.3.3.2.5.1 | Regression Sprint 1 |  | 10d? | 2025-06-16 | 2025-06-27 | 1558 | 2025-06-16 | 2025-06-27 | 0d |  |  | 609d | 0d |  | SI Test | SIT | 138.33 | 6.0 | Green | Roger Robar | GREEN |  |  |  |  |  |  |  |  |
| 1605 | 1.4.2.3.3.2.5.2 | Regression Sprint 2 |  | 10d? | 2025-06-30 | 2025-07-11 | 1604 | 2025-06-30 | 2025-07-11 | 0d |  |  | 609d | 0d |  | SI Test | SIT | 152.33 | 6.0 | Green | Roger Robar | GREEN |  |  |  |  |  |  |  |  |
| 1606 | 1.4.2.3.3.2.5.3 | Regression Sprint 3 |  | 15d? | 2025-07-14 | 2025-08-01 | 1605 | 2025-07-14 | 2025-08-01 | 0d |  |  | 609d | 0d |  | SI Test | SIT | 166.33 | 6.0 | Green | Roger Robar | GREEN |  |  |  |  |  |  |  |  |
| 1607 | 1.4.2.3.3.2.5.4 | SIT Migration Testing End (Minimum Viable Cohort) (incl. confirmation that PPs have submitted their Test Completion Reports to Programme for assurance) | milestone | 0d | 2025-08-01 | 2025-08-01 | 1606 | 2025-08-01 | 2025-08-01 | 0d |  |  | 609d | 0d | start no earlier than 2025-06-20 | SI Test | SIT | 184.71 | 6.0 | Green | Roger Robar | GREEN |  |  |  |  |  |  |  |  |
| 1608 | 1.4.2.3.3.2.6 | **SIT Migration Test Completion Report (Minimum Viable Cohort)** |  | 25d | 2025-07-14 | 2025-08-15 | 1088, 991, 995, 1002, 1008, 1014 | 2025-07-14 | 2025-08-15 | 0d | 2024-06-10 | 2024-06-10 | 609d |  |  | SI Test | SIT |  | 6.1 | Complete |  |  | PP | MHHS-ART076 | Systems Integration Testing (SIT) | SITAG | T3 |  |  |  |
| 1609 | 1.4.2.3.3.2.6.1 | Develop document |  | 15d | 2025-07-14 | 2025-08-01 | 1607FF | 2025-07-14 | 2025-08-01 | 85d | 2024-06-10 | 2024-10-04 | 609d | 0d |  | SI Test | SIT | 166.33 | 6.1 | Green | Roger Robar | GREEN | PP |  | Systems Integration Testing (SIT) |  |  | D24E - Migration Test Completion Report |  |  |
| 1610 | 1.4.2.3.3.2.6.2 | Review & agree document |  | 5d | 2025-08-04 | 2025-08-08 | 1609 | 2025-08-04 | 2025-08-08 | 10d | 2024-10-21 | 2024-11-01 | 609d | 0d |  | SI Test | SIT | 187.33 | 6.1 | Green | Roger Robar | GREEN | PP |  | Systems Integration Testing (SIT) |  |  |  |  |  |
| 1611 | 1.4.2.3.3.2.6.3 | SIT Migration Testing Test Completion Report (Minimum Viable Cohort) Approved | milestone | 0d | 2025-08-15 | 2025-08-15 | 1610FS+5d | 2025-08-15 | 2025-08-15 | 45d |  |  | 609d | 0d |  | SI Test | SIT | 198.71 | 6.1 | Green |  | GREEN |  |  |  | SITAG | T2 |  | T2-TE-0800 |  |
| 1612 | 1.4.2.3.3.2.7 | SIT Migration Testing End (Minimum Viable Cohort) (incl. confirmation that PPs have submitted their Test Completion Reports to Programme for assurance) | milestone | 0d | 2025-08-15 | 2025-08-15 | 1609FF, 1611 | 2025-08-15 | 2025-08-15 | 0d | 2024-10-04 | 2024-10-04 | 609d | 0d | start no earlier than 2025-03-14 | SI Test | SIT | 198.71 | 6.1 | Green | Roger Robar | GREEN | PP | MHHS-ART076 | Systems Integration Testing (SIT) | SITAG | T3 |  | T3-TE-0043 |  |
| 1613 | 1.4.2.3.3.2.8 | Assurance of PPs Test Completion Reports |  | 30d | 2025-07-14 | 2025-08-22 | 1612FF+5d | 2025-07-14 | 2025-08-22 | 30d | 2024-09-02 | 2024-10-11 | 609d |  |  | SI Test | SIT | 166.33 | 6.1 | Green | Roger Robar | GREEN | PP |  | Systems Integration Testing (SIT) |  |  |  |  |  |
| 1614 | 1.4.2.3.4 | **SIT Non-Functional Testing (all SIT PPs)** |  | 69d? | 2025-03-03 | 2025-06-05 |  | 2025-02-28 | 2025-07-10 | 100d | 2024-09-02 | 2025-01-17 | 1d |  |  | N/A | SIT |  | 6.1 |  | N/A |  | N/A |  | Systems Integration Testing (SIT) | SITAG |  |  |  |  |
| 1615 | 1.4.2.3.4.1 | Theme 1 (Helix and DIP Volume Testing) Start | milestone | 0d? | 2025-03-03 | 2025-03-03 | 1146, 1161FS+1d | 2025-03-03 | 2025-03-03 | 0d |  |  | 1d | 0d | finish no earlier than 2025-01-13 | SIT Participant | SIT | 33.71 | 6.15 | Green | Roger Robar | GREEN |  |  |  | SITAG | T3 |  | T3-TE-0124 |  |
| 1616 | 1.4.2.3.4.2 | Theme 1 (Helix and DIP Volume Testing) Execution |  | 15d? | 2025-03-03 | 2025-03-21 | 1615FS-1d | 2025-03-03 | 2025-03-21 | 0d |  |  | 1d | 0d | start no earlier than 2025-01-13 |  | SIT | 33.33 | 6.15 | Green | Roger Robar | GREEN |  |  |  |  |  |  |  |  |
| 1617 | 1.4.2.3.4.3 | Theme 2 SIT Non-Functional Testing Start | milestone | 0d | 2025-03-28 | 2025-03-28 | 1188, 1507, 1095, 1099, 1106, 1112, 1118, 1148, 1557, 1170FS+1d | 2025-03-31 | 2025-03-31 | 0d | 2024-09-02 | 2024-09-02 | 95d | 0d |  | SI Test | SIT | 58.71 | 6.15 | Green | Roger Robar | GREEN | PP | MHHS-ART079 | Systems Integration Testing (SIT) | SITAG | T3 |  | T3-TE-0040 | 12/8/24: needs to be 7/10/24 |
| 1618 | 1.4.2.3.4.4 | Theme 2 SIT Non-Functional Testing Execution |  | 40d | 2025-03-28 | 2025-05-22 | 1617SS-1d | 2025-05-01 | 2025-06-25 | 90d | 2024-09-02 | 2025-01-03 | 56d | 0d |  | SI Test | SIT | 58.33 | 6.15 | Green | Roger Robar | GREEN | PP |  | Systems Integration Testing (SIT) |  |  | D24D - NF Test Completion Report |  |  |
| 1619 | 1.4.2.3.4.5 | Theme 3 SIT Non-Functional Testing Start |  | 1d? | 2025-03-28 | 2025-03-28 | 1148, 1170 | 2025-05-02 | 2025-05-02 | 0d |  |  | 56d | 0d |  |  | SIT | 58.33 | 6.15 | Green | Roger Robar | GREEN |  |  |  |  |  |  |  |  |
| 1620 | 1.4.2.3.4.6 | Theme 3 SIT Non-Functional Testing Execution |  | 40d? | 2025-03-28 | 2025-05-22 | 1619SS | 2025-05-02 | 2025-06-26 | 0d |  |  | 56d | 0d |  |  | SIT | 58.33 | 6.15 | Green | Roger Robar | GREEN |  |  |  |  |  |  |  |  |
| 1621 | 1.4.2.3.4.7 | SIT Non-Functional Testing End (all SIT PPs) (incl. confirmation that PPs have submitted their Test Completion Reports to Programme for assurance) | milestone | 0d | 2025-05-23 | 2025-05-23 | 1618FF, 1620FF | 2025-05-23 | 2025-05-23 | 0d | 2025-01-03 | 2025-01-03 | 56d | 0d | start no earlier than 2025-05-23 | SI Test | SIT | 114.33 | 6.15 | Green | Roger Robar | GREEN | PP | MHHS-ART079 | Systems Integration Testing (SIT) | SITAG | T3 |  | T3-TE-0047 |  |
| 1622 | 1.4.2.3.4.8 | Assurance of PPs Test Completion Reports |  | 20d | 2025-05-02 | 2025-05-29 | 1621FF+5d | 2025-05-05 | 2025-05-30 | 30d | 2024-12-02 | 2025-01-10 | 56d | 0d |  | SI Test | SIT | 93.33 | 6.15 | Green | Roger Robar | GREEN | PP |  | Systems Integration Testing (SIT) |  |  |  |  |  |
| 1623 | 1.4.2.3.4.9 | **SIT Non-Functional Testing Test Completion Report (all SIT PPs)** |  | 20d | 2025-05-02 | 2025-05-29 |  | 2025-05-02 | 2025-05-29 | 20d | 2024-12-16 | 2025-01-10 | 56d |  |  | N/A | SIT |  | 6.15 |  | N/A |  | N/A |  | Systems Integration Testing (SIT) |  |  |  |  |  |
| 1624 | 1.4.2.3.4.9.1 | Develop document |  | 15d | 2025-05-02 | 2025-05-23 | 1621FF | 2025-05-05 | 2025-05-23 | 15d | 2024-12-16 | 2025-01-03 | 56d | 0d |  | SI Test | SIT | 93.33 | 6.15 | Green | Roger Robar | GREEN |  |  | Systems Integration Testing (SIT) |  |  |  |  |  |
| 1625 | 1.4.2.3.4.9.2 | Review & agree document |  | 5d | 2025-05-23 | 2025-05-29 | 1624, 1622FF | 2025-05-26 | 2025-05-30 | 5d | 2025-01-06 | 2025-01-10 | 56d | 0d |  | SI Test | SIT | 114.33 | 6.15 | Green | Roger Robar | GREEN | PP,IPA |  | Systems Integration Testing (SIT) |  |  |  |  |  |
| 1626 | 1.4.2.3.4.10 | SIT Non-Functional Testing Test Completion Report (all SIT PPs) Approved | milestone | 0d | 2025-06-05 | 2025-06-05 | 1625FF+5d | 2025-06-06 | 2025-06-06 | 0d | 2025-01-17 | 2025-01-17 | 56d |  |  | SI Test | SIT | 127.71 | 6.15 | Green | Roger Robar | GREEN | PP | MHHS-ART079 | Systems Integration Testing (SIT) | SITAG | T2 |  | T2-TE-0900 |  |

| ID | WBS | Task | Type | Duration | Start | Finish | Predecessors | Baseline start | Baseline finish | Baseline duration | Baseline 1 start | Baseline 1 finish | Total slack | Free slack | Constraint | Baseline cost | Responsible | Involved | Text9 | Update Version | MHHS Resource Name | MHHS Programme Phase | Text29 | Task Status | Sched Status | RAG | Milestone ID | Tier | Artefact ID | Future RAG |
| --- | --- | --- | --- | --- | --- | --- | --- | --- | --- | --- | --- | --- | --- | --- | --- | --- | --- | --- | --- | --- | --- | --- | --- | --- | --- | --- | --- | --- | --- | --- |
| 1627 | 1.4.2.3.5 | **SIT Operational Testing (all SIT PPs)** |  | 125d? | 2025-02-03 | 2025-07-25 |  | 2025-02-03 | 2025-06-06 | 90d | 2024-10-07 | 2025-02-07 | 20d |  |  |  | N/A | N/A | SIT | 5.0 | N/A | Systems Integration Testing (SIT) | SITAG |  |  |  |  |  |  |  |
| 1628 | 1.4.2.3.5.1 | **Non-SIT B Testing** |  | 25d? | 2025-02-03 | 2025-03-07 |  | 2025-02-03 | 2025-03-07 | 0d |  |  | 110d |  |  |  |  |  | SIT |  |  |  | SITAG | -686.67 | Overdue Start |  |  |  |  |  |
| 1629 | 1.4.2.3.5.1.1 | SIT Operational Testing Start (Theme 3 - Batch 1 (Service Management)) | milestone | 0d? | 2025-02-03 | 2025-02-03 | 1334, 1275, 1276 | 2025-02-03 | 2025-02-03 | 0d |  |  | 110d | 0d | start no earlier than 2025-02-03 |  | SI Test |  | SIT | 6.0 |  |  | SITAG | 5.33 | Green | GREEN | T3-TE-0121 | T3 |  |  |
| 1630 | 1.4.2.3.5.1.2 | SIT Operational Testing Execution Window (Theme 3 - Batch 1 (Service Management)) |  | 25d? | 2025-02-03 | 2025-03-07 | 1629 | 2025-02-03 | 2025-03-07 | 0d |  |  | 110d | 90d | start no earlier than 2025-01-06 |  |  |  | SIT | 6.0 |  |  |  | 5.33 | Green | GREEN |  |  |  |  |
| 1631 | 1.4.2.3.5.2 | **SIT B Testing** |  | 70d? | 2025-03-31 | 2025-07-04 |  | 2025-02-07 | 2025-05-16 | 0d |  |  | 20d |  |  |  |  |  | SIT | 6.15 |  |  |  | -686.67 | Overdue Start |  |  |  |  |  |
| 1632 | 1.4.2.3.5.2.1 | SIT Operational Testing Start (SIT B) | milestone | 0d | 2025-03-31 | 2025-03-31 | 1397, 1197, 1201, 1208, 1214, 1334, 1149, 1150, 1377FS+1d | 2025-03-31 | 2025-03-31 | 0d | 2024-10-07 | 2024-10-07 | 20d | 0d |  |  | SI Test | PP | SIT | 6.15 | Roger Robar | Systems Integration Testing (SIT) | SITAG | 61.71 | Green | GREEN | T3-TE-0042 | T3 | MHHS-ART073 MHHS-ART143 |  |
| 1633 | 1.4.2.3.5.2.2 | SIT Operational Testing Execution Theme 3 Batch 2 |  | 25d? | 2025-03-31 | 2025-05-02 | 1632FS-1d, 1320 | 2025-03-31 | 2025-05-02 | 0d |  |  | 20d | 0d |  |  | SI Test |  | SIT | 6.15 |  |  |  | 61.33 | Green | GREEN |  |  |  |  |
| 1634 | 1.4.2.3.5.2.3 | SIT Operational Testing Execution Theme 1 |  | 25d? | 2025-05-05 | 2025-06-06 | 1633 | 2025-05-05 | 2025-06-06 | 0d |  |  | 20d | 0d |  |  | SI Test |  | SIT | 6.15 |  |  |  | 96.33 | Green | GREEN |  |  |  |  |
| 1635 | 1.4.2.3.5.2.4 | SIT Operational Testing Execution Theme 2 |  | 20d? | 2025-06-09 | 2025-07-04 | 1634 | 2025-06-09 | 2025-07-04 | 0d |  |  | 20d | 0d |  |  | SI Test |  | SIT | 6.15 |  |  |  | 131.33 | Green | GREEN |  |  |  |  |
| 1636 | 1.4.2.3.5.3 | SIT Operational Testing End (all SIT PPs) (incl. confirmation that PPs have submitted their Test Completion Reports to Programme for assurance) | milestone | 0d | 2025-07-11 | 2025-07-11 | 1635FS+5d, 1630 | 2025-07-11 | 2025-07-11 | 0d | 2025-01-24 | 2025-01-24 | 20d | 0d |  |  | SI Test | PP | SIT | 6.15 | Roger Robar | Systems Integration Testing (SIT) | SITAG | 163.71 | Green | GREEN | T3-TE-0050 | T3 | MHHS-ART081 |  |
| 1637 | 1.4.2.3.5.4 | Assurance of PPs Test Completion Reports |  | 30d | 2025-06-09 | 2025-07-18 | 1636FF+5d | 2025-06-09 | 2025-07-18 | 30d | 2024-12-23 | 2025-01-31 | 20d | 0d |  |  | SI Test | PP | SIT | 6.15 | Roger Robar | Systems Integration Testing (SIT) |  | 131.33 | Green | GREEN |  |  |  |  |
| 1638 | 1.4.2.3.5.5 | **SIT Operational Testing Test Completion Report (all SIT PPs)** |  | 20d | 2025-06-23 | 2025-07-18 |  | 2025-06-23 | 2025-07-18 | 20d | 2025-01-06 | 2025-01-31 | 20d |  |  |  | N/A | N/A | SIT | 6.15 | N/A | Systems Integration Testing (SIT) |  |  |  |  |  |  |  |  |
| 1639 | 1.4.2.3.5.5.1 | Develop document |  | 15d | 2025-06-23 | 2025-07-11 | 1636FF | 2025-06-23 | 2025-07-11 | 15d | 2025-01-06 | 2025-01-24 | 20d | 0d |  |  | SI Test |  | SIT | 6.15 | Roger Robar | Systems Integration Testing (SIT) |  | 145.33 | Green | GREEN |  |  |  |  |
| 1640 | 1.4.2.3.5.5.2 | Review & agree document |  | 5d | 2025-07-14 | 2025-07-18 | 1639, 1637FF | 2025-07-14 | 2025-07-18 | 5d | 2025-01-27 | 2025-01-31 | 20d | 0d |  |  | SI Test | PP,IPA | SIT | 6.15 | Roger Robar | Systems Integration Testing (SIT) |  | 166.33 | Green | GREEN |  |  |  |  |
| 1641 | 1.4.2.3.5.6 | SIT Operational Testing Test Completion Report (all SIT PPs) Approved | milestone | 0d | 2025-07-25 | 2025-07-25 | 1640FF+5d | 2025-07-25 | 2025-07-25 | 0d | 2025-02-07 | 2025-02-07 | 20d |  |  |  | SI Test | PP | SIT | 6.15 | Roger Robar | Systems Integration Testing (SIT) | SITAG | 177.71 | Green | GREEN | T2-TE-0950 | T2 | MHHS-ART081 |  |
| 1642 | 1.4.2.3.6 | **SIT MVC Test Exit Report** |  | 20d | 2025-07-21 | 2025-08-15 |  | 2025-07-14 | 2025-08-08 | 20d | 2025-01-06 | 2025-01-31 | 614d |  |  |  | N/A | N/A | SIT | 6.0 | N/A | Systems Integration Testing (SIT) |  |  |  |  |  |  |  |  |
| 1643 | 1.4.2.3.6.1 | Develop document |  | 15d | 2025-07-21 | 2025-08-08 | 1567FF | 2025-07-14 | 2025-08-01 | 15d | 2025-01-06 | 2025-01-24 | 614d | 0d |  |  | SI Test |  | SIT | 6.0 | Roger Robar | Systems Integration Testing (SIT) |  | 173.33 | yellow | RED |  |  |  |  |
| 1644 | 1.4.2.3.6.2 | Review & agree document |  | 5d | 2025-08-11 | 2025-08-15 | 1643 | 2025-08-04 | 2025-08-08 | 5d | 2025-01-27 | 2025-01-31 | 614d |  |  |  | SI Test | PP,IPA | SIT | 6.0 | Roger Robar | Systems Integration Testing (SIT) |  | 194.33 | yellow | RED |  |  |  |  |
| 1645 | 1.4.2.3.7 | SIT Minimum Viable Cohort Complete (SIT Minimum Viable Cohort Test Exit Report Approved) | milestone | 0d | 2025-08-22 | 2025-08-22 | 1498, 1569FS+5d, 1626, 1641 | 2025-08-22 | 2025-08-22 | 0d | 2025-02-07 | 2025-02-07 | 0d |  |  |  | CPT | PP,IPA | SIT | 6.0 | Roger Robar | Systems Integration Testing (SIT) | PSG | 205.71 | Green | GREEN | T1-TE-2000 | T1 | MHHS-ART081 |  |
| 1646 | 1.4.2.4 | **SIT (non-MVC)** |  | 119d? | 2025-06-16 | 2025-11-27 |  | 2025-05-05 | 2025-11-27 | 295d | 2024-03-11 | 2025-04-25 | 0d |  |  | -0 | N/A | N/A | SIT | 6.0 | N/A | Systems Integration Testing (SIT) |  | M10,M11 |  |  |  |  |  | D24D - NF Test Completion Report |
| 1647 | 1.4.2.4.1 | **SIT Functional Testing (non-MVC)** |  | 110d? | 2025-06-16 | 2025-11-14 |  | 2025-06-16 | 2025-11-14 | 295d | 2024-03-11 | 2025-04-25 | 0d |  |  |  | N/A | N/A | SIT | 6.0 | N/A | Systems Integration Testing (SIT) |  |  |  |  |  |  |  |  |
| 1648 | 1.4.2.4.1.1 | **SIT Functional Testing Execution (non-MVC)** |  | 95d? | 2025-06-16 | 2025-10-24 |  | 2025-06-16 | 2025-10-24 | 280d | 2024-03-11 | 2025-04-04 | 0d |  |  |  | N/A | N/A | SIT | 6.0 | N/A | Systems Integration Testing (SIT) |  | M10 |  |  |  |  |  | D24C - E2E Test Completion Report |
| 1649 | 1.4.2.4.1.1.1 | Test Execution (Cycle 3 Completion and Regression Testing) |  | 95d? | 2025-06-16 | 2025-10-24 | 1558 | 2025-06-16 | 2025-10-24 | 0d |  |  | 0d |  |  |  |  |  | SIT | 6.0 |  |  |  | 138.33 | Green | GREEN |  |  |  |  |
| 1650 | 1.4.2.4.1.1.2 | SIT Functional Testing End (non-MVC) (incl. confirmation that PPs have submitted their Test Completion Reports to Programme for assurance) | milestone | 0d | 2025-10-24 | 2025-10-24 | 1649FF | 2025-10-24 | 2025-10-24 | 0d | 2025-04-04 | 2025-04-04 | 0d |  |  |  | SI Test | PP | SIT | 6.0 | Roger Robar | Systems Integration Testing (SIT) | SITAG | 268.71 | Green | GREEN | T3-TE-0052 | T3 | MHHS-ART072 |  |
| 1651 | 1.4.2.4.1.2 | Assurance of PPs Test Completion Reports |  | 5d | 2025-11-03 | 2025-11-07 | 1650FS+5d | 2025-11-03 | 2025-11-07 | 5d | 2025-04-14 | 2025-04-18 | 0d |  |  |  | SI Test | PP | SIT | 6.0 | Roger Robar | Systems Integration Testing (SIT) |  | 278.33 | Green | GREEN |  |  |  |  |

Notes:
- 1629: 29/01/25 - SITAG approved the Theme 3 (Batch 1) Overarching Readiness Report, and Helix are on track with their readiness preparations, so Programme expect this milestone to be reached and testing to commence 03/02/25 as planned.

| ID | WBS | Task | Type | Duration | Start | Finish | Predecessors | Complete | Remaining | Baseline start | Baseline finish | Baseline duration | Baseline 1 start | Baseline 1 finish | Total slack | Free slack | Constraint | Baseline cost | Responsible | Involved | Text9 | Update Version | MHHS Resource Name | MHHS Programme Phase | Task Status | Sched Status | RAG | Artefact ID | Milestone ID | Text29 | Tier | Future RAG |
| --- | --- | --- | --- | --- | --- | --- | --- | --- | --- | --- | --- | --- | --- | --- | --- | --- | --- | --- | --- | --- | --- | --- | --- | --- | --- | --- | --- | --- | --- | --- | --- | --- |
| 1652 | 1.4.2.4.1.3 | **SIT Functional Testing Test Completion Report (non-MVC)** |  | 25d | 2025-10-06 | 2025-11-07 |  |  |  | 2025-10-06 | 2025-11-07 | 25d | 2025-03-17 | 2025-04-18 | 0d |  |  |  | N/A | N/A | SIT | 6.0 | N/A | Systems Integration Testing (SIT) |  |  |  |  |  |  |  |  |
| 1653 | 1.4.2.4.1.3.1 | Develop document |  | 15d | 2025-10-06 | 2025-10-24 | 1650FF |  |  | 2025-10-06 | 2025-10-24 | 15d | 2025-03-17 | 2025-04-04 | 5d |  |  |  | SI Test |  | SIT | 6.0 | Roger Robar | Systems Integration Testing (SIT) | 250.33 | Green | GREEN |  |  |  |  |  |
| 1654 | 1.4.2.4.1.3.2 | Review & agree document |  | 5d | 2025-11-03 | 2025-11-07 | 1653, 1651FF |  |  | 2025-11-03 | 2025-11-07 | 5d | 2025-04-14 | 2025-04-18 | 0d |  |  |  | SI Test | PP,IPA | SIT | 6.0 | Roger Robar | Systems Integration Testing (SIT) | 278.33 | Green | GREEN |  |  |  |  |  |
| 1655 | 1.4.2.4.1.4 | SIT Functional Testing Test Completion Report (non-MVC) Approved | milestone | 0d | 2025-11-14 | 2025-11-14 | 1654FF+5d |  |  | 2025-11-14 | 2025-11-14 | 0d | 2025-04-25 | 2025-04-25 | 0d |  |  |  | SI Test | PP | SIT | 6.0 | Roger Robar | Systems Integration Testing (SIT) | 289.71 | Green | GREEN | MHHS-ART072 | T3-TE-0055 | SITAG | T3 |  |
| 1656 | 1.4.2.4.2 | **SIT Migration Testing (non-MVC)** |  | 110d | 2025-06-16 | 2025-11-14 |  |  |  | 2025-05-05 | 2025-10-08 | 230d | 2024-06-10 | 2025-04-25 | 0d |  |  |  | N/A | N/A | SIT | 6.0 | N/A | Systems Integration Testing (SIT) |  |  |  |  |  |  |  |  |
| 1657 | 1.4.2.4.2.1 | Test Execution (Cycle 3 Completion and Regression Testing) |  | 95d | 2025-06-16 | 2025-10-24 | 1558 |  |  | 2025-06-16 | 2025-10-24 | 215d | 2024-06-10 | 2025-04-04 | 0d |  |  |  | SI Test | PP | SIT | 6.0 | Roger Robar | Systems Integration Testing (SIT) | 138.33 | Green | GREEN |  |  |  |  | D24E - Migration Test Completion Report |
| 1658 | 1.4.2.4.2.2 | SIT Migration Testing End (non-MVC) (incl. confirmation that PPs have submitted their Test Completion Reports to Programme for assurance) | milestone | 0d | 2025-10-24 | 2025-10-24 | 1657FF |  |  | 2025-10-24 | 2025-10-24 | 0d | 2025-04-04 | 2025-04-04 | 0d |  |  |  | SI Test | PP | SIT | 6.0 | Roger Robar | Systems Integration Testing (SIT) | 268.71 | Green | GREEN | MHHS-ART076 | T3-TE-0051 | SITAG | T3 |  |
| 1659 | 1.4.2.4.2.3 | Assurance of PPs Test Completion Reports |  | 5d | 2025-11-03 | 2025-11-07 | 1658FS+5d |  |  | 2025-11-03 | 2025-11-07 | 5d | 2025-04-14 | 2025-04-18 | 0d |  |  |  | SI Test | PP | SIT | 6.0 | Roger Robar | Systems Integration Testing (SIT) | 278.33 | Green | GREEN |  |  |  |  |  |
| 1660 | 1.4.2.4.2.4 | **SIT Migration Testing Test Completion Report (non-MVC)** |  | 25d | 2025-10-06 | 2025-11-07 |  |  |  | 2025-10-06 | 2025-11-07 | 25d | 2025-03-17 | 2025-04-18 | 0d |  |  |  | N/A | N/A | SIT | 6.0 | N/A | Systems Integration Testing (SIT) |  |  |  |  |  |  |  |  |
| 1661 | 1.4.2.4.2.4.1 | Develop document |  | 15d | 2025-10-06 | 2025-10-24 | 1658FF |  |  | 2025-10-06 | 2025-10-24 | 15d | 2025-03-17 | 2025-04-04 | 5d |  |  |  | SI Test |  | SIT | 6.0 | Roger Robar | Systems Integration Testing (SIT) | 250.33 | Green | GREEN |  |  |  |  |  |
| 1662 | 1.4.2.4.2.4.2 | Review & agree document |  | 5d | 2025-11-03 | 2025-11-07 | 1661, 1659FF |  |  | 2025-11-03 | 2025-11-07 | 5d | 2025-04-14 | 2025-04-18 | 0d |  |  |  | SI Test | PP,IPA | SIT | 6.0 | Roger Robar | Systems Integration Testing (SIT) | 278.33 | Green | GREEN |  |  |  |  |  |
| 1663 | 1.4.2.4.2.5 | SIT Migration Testing Test Completion Report (non-MVC Approved) | milestone | 0d | 2025-11-14 | 2025-11-14 | 1662FF+5d |  |  | 2025-11-14 | 2025-11-14 | 0d | 2025-04-25 | 2025-04-25 | 0d |  |  |  | SI Test | PP | SIT | 6.0 | Roger Robar | Systems Integration Testing (SIT) | 289.71 | Green | GREEN | MHHS-ART076 | T3-TE-0056 | SITAG | T3 |  |
| 1664 | 1.4.2.4.3 | **SIT non-MVC Test Exit Report** |  | 20d | 2025-10-27 | 2025-11-21 |  |  |  | 2025-10-27 | 2025-11-21 | 20d | 2025-03-17 | 2025-04-11 | 0d |  |  |  | N/A | N/A | SIT | 6.0 | N/A | Systems Integration Testing (SIT) |  |  |  |  |  |  |  |  |
| 1665 | 1.4.2.4.3.1 | Develop document |  | 15d | 2025-10-27 | 2025-11-14 | 1655FF, 1663FF |  |  | 2025-10-27 | 2025-11-14 | 15d | 2025-03-17 | 2025-04-04 | 0d |  |  |  | SI Test |  | SIT | 6.0 | Roger Robar | Systems Integration Testing (SIT) | 271.33 | Green | GREEN |  |  |  |  |  |
| 1666 | 1.4.2.4.3.2 | Review & agree document |  | 5d | 2025-11-17 | 2025-11-21 | 1665 |  |  | 2025-11-17 | 2025-11-21 | 5d | 2025-04-07 | 2025-04-11 | 0d |  |  |  | SI Test | PP,IPA | SIT | 6.0 | Roger Robar | Systems Integration Testing (SIT) | 292.33 | Green | GREEN |  |  |  |  |  |
| 1667 | 1.4.2.4.4 | SIT non-MVC Complete | milestone | 0d | 2025-11-27 | 2025-11-27 | 1666FS+4d, 1655, 1663 |  |  | 2025-11-27 | 2025-11-27 | 0d | 2025-04-21 | 2025-04-21 | 0d |  |  |  | SI Test | PP | SIT | 6.0 | Roger Robar | Systems Integration Testing (SIT) | 302.71 | Green | GREEN | MHHS-ART081 | T3-TE-0059 | SITAG | T3 |  |
| 1668 | 1.4.3 | **UIT Environment Preparation** |  | 680d? | 2022-10-31 A | 2025-06-06 |  | 51% | 330.94d? | 2022-10-31 | 2025-07-04 | 680d | 2022-10-31 | 2025-06-06 | 664d |  |  | -0 | N/A | N/A | SIT | 6.0 | N/A | Systems Integration Testing (SIT) |  |  |  |  |  | SITAG |  |  |
| 1669 | 1.4.3.1 | **Test Artefact Development** |  | 556d? | 2023-03-01 A | 2025-04-16 |  | 51% | 270.06d? | 2023-03-01 | 2024-07-18 | 361d | 2023-03-01 | 2023-08-04 | 701d |  |  | -0 | N/A | N/A | SIT | 6.0 | N/A | Systems Integration Testing (SIT) |  |  |  |  |  | SITAG |  |  |
| 1670 | 1.4.3.1.1 | **E2E Sandbox Guidance** |  | 539d? | 2023-03-01 A | 2025-03-24 |  | 71% | 158.53d? | 2023-03-01 | 2024-07-18 | 361d | 2023-03-01 | 2023-08-04 | 718d |  |  | -0 | N/A | N/A | SIT | 6.0 | N/A | Systems Integration Testing (SIT) |  |  |  |  |  |  |  |  |
| 1671 | 1.4.3.1.1.1 | Develop document |  | 83d | 2023-03-01 A | 2023-06-23 A |  | 100% |  | 2023-03-01 | 2023-06-23 | 83d | 2023-03-01 | 2023-06-23 |  |  | start no earlier than 2023-03-01 |  | SI Test |  | SIT | 6.0 | Stuart Scott | Systems Integration Testing (SIT) |  | Complete | COMPLETE |  |  |  |  |  |
| 1672 | 1.4.3.1.1.2 | Artefact review (via SITAG) and updates |  | 25d | 2023-06-26 A | 2023-07-28 A | 1671 | 100% |  | 2023-06-26 | 2023-07-28 | 25d | 2023-06-26 | 2023-07-28 |  |  |  |  | SI Test | PP,IPA | SIT | 6.0 | Stuart Scott | Systems Integration Testing (SIT) |  | Complete | COMPLETE |  |  |  |  |  |
| 1673 | 1.4.3.1.1.3 | E2E Sandbox Guidance approved | milestone | 0d | 2024-07-18 A | 2024-07-18 A | 1672FF+5d | 100% |  | 2024-07-18 | 2024-07-18 | 0d | 2023-08-04 | 2023-08-04 |  |  | start no earlier than 2024-07-18 |  | SI Test | PP | SIT | 6.0 | Stuart Scott | Systems Integration Testing (SIT) |  | Complete | COMPLETE | MHHS-ART154 | T3-TE-0067 | QAG | T3 |  |
| 1674 | 1.4.3.1.1.4 | Update E2E Sandbox guidance to reflect CR55 |  | 29d | 2025-01-13 | 2025-02-20 |  |  |  | 2025-01-13 | 2025-02-20 | 0d |  |  | 718d | 0d | start no earlier than 2025-01-13 |  | SI Test |  | SIT | 6.1 | Stuart Scott |  | -15.67 | Green | GREEN |  |  |  |  |  |
| 1675 | 1.4.3.1.1.5 | Internal SI review |  | 5d | 2025-02-21 | 2025-02-27 | 1674 |  |  | 2025-02-21 | 2025-02-27 | 0d |  |  | 718d | 0d |  |  | SI Test |  | SIT | 6.1 | Stuart Scott |  | 23.33 | Green | GREEN |  |  |  |  |  |
| 1676 | 1.4.3.1.1.6 | SRO / Code Bodies review |  | 5d | 2025-02-28 | 2025-03-06 | 1675 |  |  | 2025-02-28 | 2025-03-06 | 0d |  |  | 718d | 0d |  |  | SI Test |  | SIT | 6.1 | Stuart Scott |  | 30.33 | Green | GREEN |  |  |  |  |  |
| 1677 | 1.4.3.1.1.7 | Submit version to QWG |  | 3d | 2025-03-07 | 2025-03-11 | 1676 |  |  | 2025-03-07 | 2025-03-11 | 0d |  |  | 718d | 0d |  |  | SI Test |  | SIT | 6.1 | Stuart Scott |  | 37.33 | Green | GREEN |  |  |  |  |  |
| 1678 | 1.4.3.1.1.8 | Artefact Approval (via QWG) | milestone | 0d | 2025-03-11 | 2025-03-11 | 1677 |  |  | 2025-03-11 | 2025-03-11 | 0d |  |  | 718d | 0d |  |  | SI Test |  | SIT | 6.1 | Stuart Scott |  | 41.71 | Green | GREEN |  |  |  |  |  |
| 1679 | 1.4.3.1.1.9 | Final Document updates post QWG review |  | 1d | 2025-03-13 | 2025-03-13 | 1678FS+1d |  |  | 2025-03-13 | 2025-03-13 | 0d |  |  | 718d | 0d |  |  | SI Test |  | SIT | 6.1 | Stuart Scott |  | 43.33 | Green | GREEN |  |  |  |  |  |
| 1680 | 1.4.3.1.1.10 | Submit final version to QAG |  | 1d? | 2025-03-17 | 2025-03-17 | 1679FS+1d |  |  | 2025-03-17 | 2025-03-17 | 0d |  |  | 718d | 0d |  |  | SI Test |  | SIT | 6.1 | Stuart Scott |  | 47.33 | Green | GREEN |  |  |  |  |  |
| 1681 | 1.4.3.1.1.11 | E2E Sandbox guidance update approved |  | 1d? | 2025-03-24 | 2025-03-24 | 1680FS+4d |  |  | 2025-03-24 | 2025-03-24 | 0d |  |  | 718d |  |  |  | SI Test |  | SIT | 6.1 | Stuart Scott |  | 54.33 | Green | GREEN |  |  |  |  |  |

| ID | WBS | Task | Type | Duration | Start | Finish | Predecessors | Complete | Remaining | Baseline start | Baseline finish | Baseline duration | Baseline 1 start | Baseline 1 finish | Total slack | Free slack | Constraint | Baseline cost | Responsible | Involved | Text9 | Update Version | MHHS Resource Name | MHHS Programme Phase | Text29 | Task Status | Sched Status | RAG | Milestone ID | Tier | Artefact ID |
| --- | --- | --- | --- | --- | --- | --- | --- | --- | --- | --- | --- | --- | --- | --- | --- | --- | --- | --- | --- | --- | --- | --- | --- | --- | --- | --- | --- | --- | --- | --- | --- |
| 1682 | 1.4.3.1.2 | **E2E Sandbox Test Data Approach & Plan** |  | 68d | 2025-01-13 | 2025-04-16 |  |  |  | 2023-12-05 | 2024-05-09 | 93d | 2023-03-29 | 2023-08-04 | 701d |  |  |  | SI Test | N/A | SIT | 6.1 | Stuart Scott | Systems Integration Testing (SIT) | SITAG |  |  |  |  |  |  |
| 1683 | 1.4.3.1.2.1 | Develop document |  | 27d | 2025-01-13 | 2025-02-18 | 1671SS+199d |  |  | 2025-01-13 | 2025-02-18 | 68d | 2023-03-29 | 2023-06-30 | 701d | 0d | start no earlier than 2025-01-13 |  | SI Test |  | SIT | 5.0 | Stuart Scott | Systems Integration Testing (SIT) |  | -15.67 | Green | GREEN |  |  |  |
| 1684 | 1.4.3.1.2.2 | Internal SI review and updates |  | 5d | 2025-02-19 | 2025-02-25 | 1683 |  |  | 2025-02-19 | 2025-02-25 | 0d |  |  | 701d | 0d |  |  | SI Test |  | SIT | 6.1 | Stuart Scott |  |  | 21.33 | Green | GREEN |  |  |  |
| 1685 | 1.4.3.1.2.3 | SRO / Code Bodies review |  | 5d | 2025-02-26 | 2025-03-04 | 1684 |  |  | 2025-02-26 | 2025-03-04 | 0d |  |  | 701d | 0d |  |  | SI Test |  | SIT | 6.1 | Stuart Scott |  |  | 28.33 | Green | GREEN |  |  |  |
| 1686 | 1.4.3.1.2.4 | Submit proposed version to QWG | milestone | 0d | 2025-03-04 | 2025-03-04 | 1685 |  |  | 2025-03-04 | 2025-03-04 | 0d |  |  | 701d | 0d |  |  | SI Test |  | SIT | 6.1 | Stuart Scott |  |  | 34.71 | Green | GREEN |  |  |  |
| 1687 | 1.4.3.1.2.5 | Discuss document at QWG | milestone | 0d | 2025-03-11 | 2025-03-11 | 1686FS+5d |  |  | 2025-03-11 | 2025-03-11 | 0d |  |  | 701d | 0d |  |  | SI Test |  | SIT | 6.1 | Stuart Scott |  |  | 41.71 | Green | GREEN |  |  |  |
| 1688 | 1.4.3.1.2.6 | Final updates prior to consultation |  | 4d | 2025-03-12 | 2025-03-17 | 1687 |  |  | 2025-03-12 | 2025-03-17 | 0d |  |  | 701d | 0d |  |  | SI Test |  | SIT | 6.1 | Stuart Scott |  |  | 42.33 | Green | GREEN |  |  |  |
| 1689 | 1.4.3.1.2.7 | Industry Consultation for E2E Sandbox Test Data Approach and Plan document |  | 10d | 2025-03-18 | 2025-03-31 | 1688 |  |  | 2025-03-18 | 2025-03-31 | 0d |  |  | 701d | 0d |  |  | SI Test |  | SIT | 6.1 | Stuart Scott |  |  | 48.33 | Green | GREEN |  |  |  |
| 1690 | 1.4.3.1.2.8 | Document updates post Industry Consultation |  | 3d | 2025-04-01 | 2025-04-03 | 1689 |  |  | 2025-04-01 | 2025-04-03 | 0d |  |  | 701d | 0d | finish no earlier than 2024-04-22 |  | SI Test |  | SIT | 6.1 | Stuart Scott |  |  | 62.33 | Green | GREEN |  |  |  |
| 1691 | 1.4.3.1.2.9 | Submit Proposed Version to QWG |  | 3d | 2025-04-04 | 2025-04-08 | 1690 |  |  | 2025-04-04 | 2025-04-08 | 0d |  |  | 701d | 0d |  |  | SI Test |  | SIT | 6.1 | Stuart Scott |  |  | 65.33 | Green | GREEN |  |  |  |
| 1692 | 1.4.3.1.2.10 | Artefact Approval (via QWG) | milestone | 0d | 2025-04-08 | 2025-04-08 | 1691 |  |  | 2025-04-08 | 2025-04-08 | 0d |  |  | 701d | 0d |  |  | SI Test |  | SIT | 6.1 | Stuart Scott |  |  | 69.71 | Green | GREEN |  |  |  |
| 1693 | 1.4.3.1.2.11 | Final Document updates post QWG review | milestone | 0d | 2025-04-09 | 2025-04-09 | 1692FS+1d |  |  | 2025-04-09 | 2025-04-09 | 0d |  |  | 701d | 0d | start no earlier than 2024-05-01 |  | SI Test |  | SIT | 6.1 | Stuart Scott |  |  | 70.71 | Green | GREEN |  |  |  |
| 1694 | 1.4.3.1.2.12 | Submit final version to QAG | milestone | 0d | 2025-04-10 | 2025-04-10 | 1693FS+1d |  |  | 2025-04-10 | 2025-04-10 | 0d |  |  | 701d | 0d | start no earlier than 2024-05-02 |  | SI Test |  | SIT | 6.1 | Stuart Scott |  |  | 71.71 | Green | GREEN |  |  |  |
| 1695 | 1.4.3.1.2.13 | E2E Sandbox Test Data Approach and Plan | milestone | 0d | 2025-04-16 | 2025-04-16 | 1694FS+4d |  |  | 2025-04-16 | 2025-04-16 | 0d |  |  | 701d |  | start no earlier than 2024-05-09 |  | SI Test |  | SIT | 6.1 | Stuart Scott |  | SITAG | 77.71 | Green | GREEN | T3-QU-0124 | T3 |  |
| 1696 | 1.4.3.2 | **UIT Stub Specification and Delivery** |  | 260d | 2023-12-04 A | 2024-11-29 A |  | 100% |  | 2023-12-04 | 2024-10-18 | 190d | 2023-10-27 | 2024-08-23 |  |  |  | -0 | N/A | N/A | SIT | 5.0 | N/A | Systems Integration Testing (SIT) |  |  |  |  |  |  |  |
| 1697 | 1.4.3.2.1 | **Qualification Test Stubs** |  | 260d | 2023-12-04 A | 2024-11-29 A |  | 100% |  | 2023-12-04 | 2024-10-18 | 190d | 2023-10-27 | 2024-08-23 |  |  |  | -0 | N/A | N/A | SIT | 5.16 | N/A | Systems Integration Testing (SIT) |  |  |  |  |  |  |  |
| 1698 | 1.4.3.2.1.1 | Specify |  | 44d | 2023-12-04 A | 2024-02-01 A | 542FS+13d | 100% |  | 2023-12-04 | 2024-02-01 | 44d | 2023-10-27 | 2023-12-29 |  |  |  |  | SI DevOps | Qualification,SRO | SIT | 5.0 | Lewis Hall | Systems Integration Testing (SIT) |  |  | Complete | COMPLETE |  |  |  |
| 1699 | 1.4.3.2.1.2 | Build & Test |  | 141d | 2024-02-02 A | 2024-08-16 A | 1698 | 100% |  | 2024-02-02 | 2024-08-16 | 141d | 2023-12-29 | 2024-05-24 |  |  |  |  | SI DevOps | Qualification,SRO | SIT | 5.23 | Lewis Hall | Systems Integration Testing (SIT) |  |  | Complete | COMPLETE |  |  |  |
| 1700 | 1.4.3.2.1.3 | Prepare for release |  | 75d | 2024-08-19 A | 2024-11-29 A | 1699 | 100% |  | 2024-08-19 | 2024-11-29 | 5d | 2024-07-29 | 2024-08-23 |  |  |  |  | SI DevOps | Qualification,SRO | SIT | 5.0 | Lewis Hall | Systems Integration Testing (SIT) |  |  | Complete | COMPLETE |  |  |  |
| 1701 | 1.4.3.2.1.4 | Non-SIT LDSO Test Harness Released | milestone | 0d | 2024-11-29 A | 2024-11-29 A | 1700 | 100% |  | 2024-11-29 | 2024-11-29 | 0d | 2024-08-23 | 2024-08-23 |  |  |  |  | SI DevOps | Qualification,SRO | SIT | 5.27 | Lewis Hall | Systems Integration Testing (SIT) | QAG |  | Complete | COMPLETE | T3-TE-0035 | T3 | MHHS-ART080 |
| 1702 | 1.4.3.3 | **Environments (UIT)** |  | 680d | 2022-10-31 A | 2025-06-06 |  | 50% | 337.96d | 2022-10-31 | 2025-07-04 | 680d | 2022-10-31 | 2025-06-06 | 664d |  |  | -0 | N/A | N/A | SIT | 5.0 | N/A | Systems Integration Testing (SIT) |  |  |  |  |  |  |  |
| 1703 | 1.4.3.3.1 | **Central Party (Avanade) Environments (UIT)** |  | 488d | 2022-11-16 A | 2024-09-27 A |  | 100% |  | 2022-11-16 | 2024-09-27 | 493d | 2022-11-16 | 2024-10-04 |  |  |  | -0 | N/A | N/A | SIT | 5.28 | N/A | Systems Integration Testing (SIT) |  |  |  |  |  |  |  |
| 1704 | 1.4.3.3.1.1 | Central Party (Avandae) environment preparation (incl. security certificates and security compliance) |  | 447d | 2022-11-16 A | 2024-08-01 A | 538 | 100% |  | 2022-11-16 | 2024-08-01 | 463d | 2022-11-16 | 2024-08-23 |  |  |  |  | PP | SI Test | SIT | 5.28 | Heath Thomas | Systems Integration Testing (SIT) |  |  | Complete | COMPLETE |  |  |  |
| 1705 | 1.4.3.3.1.2 | Submit self-declaration of environment preparation complete (incl. security certificates and security compliance) to Programme for assurance |  | 447d | 2022-11-16 A | 2024-08-01 A | 1704SS | 100% |  | 2022-11-16 | 2024-08-01 | 463d | 2022-11-16 | 2024-08-23 |  |  |  |  | PP | SI Test | SIT | 5.28 | Heath Thomas | Systems Integration Testing (SIT) |  |  | Complete | COMPLETE |  |  |  |
| 1706 | 1.4.3.3.1.3 | Central Party (Avanade) UIT environment connectivity proving |  | 25d | 2024-08-26 A | 2024-09-27 A | 1718 | 100% |  | 2024-08-26 | 2024-09-27 | 25d | 2024-08-27 | 2024-09-20 |  |  |  |  | PP | SI Test | SIT | 5.28 | Heath Thomas | Systems Integration Testing (SIT) |  |  | Complete | COMPLETE |  |  |  |
| 1707 | 1.4.3.3.1.4 | Deployment of MHHS solution code to UIT environments |  | 2d | 2024-07-29 A | 2024-07-30 A |  | 100% |  | 2024-07-29 | 2024-07-30 | 10d | 2024-09-09 | 2024-09-20 |  |  | start no earlier than 2024-07-29 |  | PP | SI Test | SIT | 5.28 | Heath Thomas | Systems Integration Testing (SIT) |  |  | Complete | COMPLETE |  |  |  |
| 1708 | 1.4.3.3.1.5 | Central Party (Avanade) UIT environment Regression Testing |  | 1d | 2024-07-31 A | 2024-07-31 A | 1707 | 100% |  | 2024-07-31 | 2024-07-31 | 10d | 2024-09-23 | 2024-10-04 |  |  |  |  | PP | SI Test | SIT | 5.28 | Heath Thomas | Systems Integration Testing (SIT) |  |  | Complete | COMPLETE |  |  |  |

| ID | WBS | Task | Type | Duration | Start | Finish | Predecessors | Complete | Remaining | Baseline start | Baseline finish | Baseline duration | Baseline 1 start | Baseline 1 finish | Total slack | Free slack | Constraint | Baseline cost | Responsible | Involved | Text9 | Update Version | MHHS Resource Name | MHHS Programme Phase | Task Status | Sched Status | RAG | Milestone ID | Text29 | Tier |
| --- | --- | --- | --- | --- | --- | --- | --- | --- | --- | --- | --- | --- | --- | --- | --- | --- | --- | --- | --- | --- | --- | --- | --- | --- | --- | --- | --- | --- | --- | --- |
| 1709 | 1.4.3.3.2 | **E2E Sandbox Participants (UIT)** |  | 680d | 2022-10-31 | 2025-06-06 |  |  |  | 2022-10-31 | 2025-06-06 | 680d | 2022-10-31 | 2025-06-06 | 0d |  |  |  | N/A | N/A | SIT | 5.0 | Heath Thomas | Systems Integration Testing (SIT) |  |  |  |  |  |  |
| 1710 | 1.4.3.3.2.1 | E2E Sandbox Participants environment preparation (incl. security certificates and security compliance) |  | 660d | 2022-10-31 | 2025-05-09 |  |  |  | 2022-10-31 | 2025-05-09 | 660d | 2022-10-31 | 2025-05-09 | 0d |  | must finish on 2025-05-09 |  | PP | SI Test | SIT | 5.0 | Heath Thomas | Systems Integration Testing (SIT) | -820.67 | Overdue Start | GREEN |  |  |  |
| 1711 | 1.4.3.3.2.2 | Submit self-declaration of environment preparation complete (incl. security certificates and security compliance) to Programme for assurance |  | 660d | 2022-10-31 | 2025-05-09 |  |  |  | 2022-10-31 | 2025-05-09 | 660d | 2022-10-31 | 2025-05-09 | 664d | 0d |  |  | PP | SI Test | SIT | 5.0 | Heath Thomas | Systems Integration Testing (SIT) | -820.67 | Overdue Start | GREEN |  |  |  |
| 1712 | 1.4.3.3.2.3 | E2E Sandbox Participants UIT environment connectivity proving |  | 20d | 2025-05-12 | 2025-06-06 | 1711 |  |  | 2025-05-12 | 2025-06-06 | 20d | 2025-05-12 | 2025-06-06 | 664d | 0d |  |  | PP | SI Test | SIT | 5.0 | Heath Thomas | Systems Integration Testing (SIT) | 103.33 | Green | GREEN |  |  |  |
| 1713 | 1.4.3.3.2.4 | Deployment of MHHS solution code to UIT environments |  | 10d | 2025-05-26 | 2025-06-06 | 1712FF |  |  | 2025-05-26 | 2025-06-06 | 10d | 2025-05-26 | 2025-06-06 | 664d |  |  |  | PP | SI Test | SIT | 5.0 | Heath Thomas | Systems Integration Testing (SIT) | 117.33 | Green | GREEN |  |  |  |
| 1714 | 1.4.3.3.2.5 | Coordinate E2E Sandbox Participants' UIT environment preparation (for E2E Sandbox Testing Start) |  | 463d | 2022-10-31 | 2024-08-07 | 1710SS |  |  | 2022-10-31 | 2024-08-07 | 463d | 2022-10-31 | 2024-08-07 | 881d |  |  |  | SI Test | PP | SIT | 5.0 | Heath Thomas | Systems Integration Testing (SIT) | -820.67 | Overdue Start | RED |  |  |  |
| 1715 | 1.4.3.3.3 | **SI Environments (UIT)** |  | 489d | 2022-11-16 A | 2024-09-30 |  | 99% | 6.77d | 2022-11-16 | 2025-07-04 | 680d | 2022-10-31 | 2025-06-06 | 843d |  |  |  | N/A | N/A | SIT | 5.0 | Heath Thomas | Systems Integration Testing (SIT) |  |  |  |  |  |  |
| 1716 | 1.4.3.3.3.1 | Coordinate Central Parties' UIT environment preparation |  | 447d | 2022-11-16 A | 2024-08-01 A | 1704SS | 100% |  | 2022-11-16 | 2024-08-01 | 463d | 2022-11-16 | 2024-08-23 |  |  |  |  | SI Test | PP | SIT | 5.0 | Heath Thomas | Systems Integration Testing (SIT) |  | Complete | COMPLETE |  |  |  |
| 1717 | 1.4.3.3.3.2 | Assure Central Parties' self-declaration of environment preparation complete (incl. security certificates and security compliance) |  | 463d | 2022-11-16 A | 2024-08-23 | 1705SS | 97% | 12d | 2022-11-16 | 2024-08-23 | 463d | 2022-11-16 | 2024-08-23 | 869d |  |  |  | SI Test | PP | SIT | 5.0 | Heath Thomas | Systems Integration Testing (SIT) |  | Overdue | RED |  |  |  |
| 1718 | 1.4.3.3.3.3 | Central Parties' UIT environments ready to start connectivity proving (incl. certificates and security compliance) | milestone | 0d | 2024-08-23 A | 2024-08-23 A | 1701 | 100% |  | 2024-08-23 | 2024-08-23 | 0d | 2024-08-23 | 2024-08-23 |  |  |  |  | SI Test | PP | SIT | 5.0 | Heath Thomas | Systems Integration Testing (SIT) |  | Complete | COMPLETE | T3-TE-0044 | QAG | T3 |
| 1719 | 1.4.3.3.3.4 | Coordinate Central Parties' UIT environment connectivity proving |  | 26d | 2024-08-26 A | 2024-09-30 A | 1706SS | 100% |  | 2024-08-26 | 2024-09-30 | 19d | 2025-05-12 | 2025-06-05 |  |  |  |  | SI Test | PP | SIT | 5.0 | Heath Thomas | Systems Integration Testing (SIT) |  | Complete | COMPLETE |  |  |  |
| 1720 | 1.4.3.3.3.5 | Coordinate deployment of MHHS solution code to Central Parties' UIT environments |  | 2d | 2024-07-29 A | 2024-07-30 A | 1707SS | 100% |  | 2024-07-29 | 2024-07-30 | 10d | 2025-05-26 | 2025-06-06 |  |  |  |  | SI Test | PP | SIT | 5.0 | Heath Thomas | Systems Integration Testing (SIT) |  | Complete | COMPLETE |  |  |  |
| 1721 | 1.4.3.3.3.6 | Coordinate Central Parties' UIT environment Regression Testing |  | 1d | 2024-07-31 | 2024-07-31 | 1720 |  |  | 2024-07-31 | 2024-07-31 | 10d | 2024-09-23 | 2024-10-04 | 886d |  |  |  | SI Test | PP | SIT | 5.0 | Heath Thomas | Systems Integration Testing (SIT) | -181.67 | Overdue Start | RED |  |  |  |
| 1722 | 1.4.3.4 | **Test Data** |  | 30d | 2024-08-26 | 2024-10-04 |  |  |  | 2024-08-26 | 2024-10-04 | 30d | 2024-08-26 | 2024-10-04 | 819d |  |  | -0 | N/A | N/A | SIT | 5.0 | N/A | Systems Integration Testing (SIT) |  |  |  |  |  |  |
| 1723 | 1.4.3.4.1 | **Central Parties (for E2E Sandbox & Qualification)** |  | 30d | 2024-08-26 | 2024-10-04 |  |  |  | 2024-08-26 | 2024-10-04 | 30d | 2024-08-26 | 2024-10-04 | 819d |  |  |  | N/A | N/A | SIT | 5.0 | N/A | Systems Integration Testing (SIT) |  |  |  |  |  |  |
| 1724 | 1.4.3.4.1.1 | Central Parties' UIT environment test data loading & verification (& data cleansing, if required) |  | 30d | 2024-08-26 | 2024-10-04 |  |  |  | 2024-08-26 | 2024-10-04 | 30d | 2024-08-26 | 2024-10-04 | 819d | 0d | start no earlier than 2024-08-26 |  | PP | SI Test | SIT | 5.0 | Richard Puddephatt | Systems Integration Testing (SIT) | -155.67 | Overdue Start | RED |  |  |  |
| 1725 | 1.4.3.4.1.2 | Submit self-declaration to Programme to confirm loading & verification of test data |  | 30d | 2024-08-26 | 2024-10-04 | 1724SS |  |  | 2024-08-26 | 2024-10-04 | 30d | 2024-08-26 | 2024-10-04 | 819d | 0d |  |  | PP | SI Test | SIT | 5.0 | Richard Puddephatt | Systems Integration Testing (SIT) | -155.67 | Overdue Start | RED |  |  |  |
| 1726 | 1.4.3.4.2 | **E2E Sandbox Participants** |  | 30d | 2024-08-26 | 2024-10-04 |  |  |  | 2024-08-26 | 2024-10-04 | 30d | 2024-08-26 | 2024-10-04 | 839d |  |  | -0 | N/A | N/A | SIT | 5.0 | Richard Puddephatt | Systems Integration Testing (SIT) |  |  |  |  |  |  |
| 1727 | 1.4.3.4.2.1 | UIT environment test data loading and verification (and data cleansing, if required) (for E2E Sandbox Testing Start) |  | 30d | 2024-08-26 | 2024-10-04 | 1724FF |  |  | 2024-08-26 | 2024-10-04 | 30d | 2024-08-26 | 2024-10-04 | 839d | 0d |  |  | PP | SI Test | SIT | 5.0 | Richard Puddephatt | Systems Integration Testing (SIT) | -155.67 | Overdue Start | RED |  |  |  |
| 1728 | 1.4.3.4.3 | **SI Test Data** |  | 30d | 2024-08-26 | 2024-10-04 |  |  |  | 2024-08-26 | 2024-10-04 | 30d | 2024-08-26 | 2024-10-04 | 839d |  |  |  | N/A | N/A | SIT | 5.0 | Richard Puddephatt | Systems Integration Testing (SIT) |  |  |  |  |  |  |
| 1729 | 1.4.3.4.3.1 | Coordinate Central Parties' UIT environment test data loading and verification (and data cleansing, if required) |  | 30d | 2024-08-26 | 2024-10-04 | 1724SS |  |  | 2024-08-26 | 2024-10-04 | 30d | 2024-08-26 | 2024-10-04 | 839d |  |  |  | SI Test | PP | SIT | 5.0 | Richard Puddephatt | Systems Integration Testing (SIT) | -155.67 | Overdue Start | RED |  |  |  |
| 1730 | 1.4.3.4.3.2 | Assure evidence of Central Parties' UIT environment test data load and verification |  | 30d | 2024-08-26 | 2024-10-04 | 1725SS |  |  | 2024-08-26 | 2024-10-04 | 30d | 2024-08-26 | 2024-10-04 | 839d |  |  |  | SI Test | PP | SIT | 5.0 | Richard Puddephatt | Systems Integration Testing (SIT) | -155.67 | Overdue Start | RED |  |  |  |
| 1731 | 1.4.3.4.3.3 | Coordinate E2E Sandbox Participants' UIT environment test data loading and verification (and data cleansing, if required) (for E2E Sandbox Testing Start) |  | 30d | 2024-08-26 | 2024-10-04 | 1727SS |  |  | 2024-08-26 | 2024-10-04 | 30d | 2024-08-26 | 2024-10-04 | 839d |  |  |  | SI Test | PP | SIT | 5.0 | Richard Puddephatt | Systems Integration Testing (SIT) | -155.67 | Overdue Start | RED |  |  |  |
| 1732 | 1.4.3.5 | **Other Preparation** |  | 496d | 2022-10-31 A | 2024-09-23 |  | 59% | 201.3d | 2022-10-31 | 2024-09-23 | 484d | 2022-11-16 | 2024-09-23 | 848d |  |  |  | N/A | N/A | SIT | 5.0 | N/A | Systems Integration Testing (SIT) |  |  |  |  |  |  |
| 1733 | 1.4.3.5.1 | **SI Other Preparation** |  | 66d | 2022-10-31 | 2023-01-30 |  |  |  | 2022-10-31 | 2023-01-30 | 66d | 2024-05-02 | 2024-08-01 | 1278d |  |  |  | N/A | N/A | SIT | 5.0 | N/A | Systems Integration Testing (SIT) |  |  |  |  |  |  |
| 1734 | 1.4.3.5.1.1 | Onboarding of UIT E2E Sandbox Participants to Test Management Tool for E2E Sandbox Testing Start (onboarding of participants will be ongoing hereafter) |  | 66d | 2022-10-31 | 2023-01-30 |  |  |  | 2022-10-31 | 2023-01-30 | 66d | 2024-05-02 | 2024-08-01 | 1278d | 393d |  |  | SI Test | PP | SIT | 5.0 | Stuart Scott | Systems Integration Testing (SIT) | -820.67 | Overdue Start | RED |  |  |  |

Notes:
- 1722: 28/01/25 - Programme is working on updating these dates over the coming weeks.
- 1723: 28/01/25 - Programme is working on updating these dates over the coming weeks.
- 1724: 28/01/25 - Programme is working on updating these dates over the coming weeks.
- 1725: 28/01/25 - Programme is working on updating these dates over the coming weeks.
- 1726: 28/01/25 - Programme is working on updating these dates over the coming weeks.
- 1727: 28/01/25 - Programme is working on updating these dates over the coming weeks.
- 1728: 28/01/25 - Programme is working on updating these dates over the coming weeks.
- 1729: 28/01/25 - Programme is working on updating these dates over the coming weeks.
- 1730: 28/01/25 - Programme is working on updating these dates over the coming weeks.
- 1731: 28/01/25 - Programme is working on updating these dates over the coming weeks.
- 1732: 28/01/25 - Programme is working on updating these dates over the coming weeks.
- 1733: 28/01/25 - Programme is working on updating these dates over the coming weeks.
- 1734: 28/01/25 - Programme is working on updating these dates over the coming weeks.

| ID | WBS | Task | Type | Duration | Start | Finish | Predecessors | Complete | Remaining | Baseline start | Baseline finish | Baseline duration | Baseline 1 start | Baseline 1 finish | Total slack | Free slack | Constraint | Baseline cost | Responsible | Involved | Text9 | Update Version | MHHS Resource Name | MHHS Programme Phase | Task Status | Sched Status | RAG | Artefact ID | Milestone ID | Text29 | Tier | Future RAG |
| --- | --- | --- | --- | --- | --- | --- | --- | --- | --- | --- | --- | --- | --- | --- | --- | --- | --- | --- | --- | --- | --- | --- | --- | --- | --- | --- | --- | --- | --- | --- | --- | --- |
| 1735 | 1.4.3.5.2 | **Other Preparation (for Central Parties & E2E Sandbox Participants)** |  | 484d | 2022-11-16 A | 2024-09-23 |  | 67% | 161.92d | 2022-11-16 | 2024-09-23 | 484d | 2022-11-16 | 2024-09-23 | 848d |  |  |  | N/A | N/A | SIT | 5.0 | N/A | Systems Integration Testing (SIT) |  |  |  |  |  |  |  |  |
| 1736 | 1.4.3.5.2.1 | Test Management Tool onboarding for E2E Sandbox Testing Start (onboarding will be ongoing hereafter) |  | 66d | 2024-05-02 | 2024-08-01 | 1734SS |  |  | 2024-05-02 | 2024-08-01 | 66d | 2024-05-02 | 2024-08-01 | 885d |  | start no earlier than 2024-05-02 |  | PP | SI Test | SIT | 5.0 | Stuart Scott | Systems Integration Testing (SIT) | -271.67 | Overdue Start | RED |  |  |  |  |  |
| 1737 | 1.4.3.5.2.2 | Other Preparation (incl. test execution planning) |  | 484d | 2022-11-16 A | 2024-09-23 | 1704SS, 1710SS | 76% | 118d | 2022-11-16 | 2024-09-23 | 484d | 2022-11-16 | 2024-09-23 | 848d |  |  |  | PP | SI Test | SIT | 5.0 | Stuart Scott | Systems Integration Testing (SIT) |  | Overdue | RED |  |  |  |  |  |
| 1738 | 1.4.3.6 | **UIT E2E Sandbox Test Readiness Report** |  | 114d | 2024-08-26 | 2025-01-31 |  |  |  | 2024-08-26 | 2025-01-31 | 114d | 2024-08-26 | 2024-10-25 | 750d |  |  | -0 | N/A | N/A | SIT | 5.0 | N/A | Systems Integration Testing (SIT) |  |  |  |  |  |  |  |  |
| 1739 | 1.4.3.6.1 | **Central Parties E2E Sandbox Test Readiness Report** |  | 30d | 2024-08-26 | 2024-10-04 |  |  |  | 2024-08-26 | 2024-10-04 | 30d | 2024-08-26 | 2024-10-04 | 819d |  |  |  | N/A | N/A | SIT | 5.0 | N/A | Systems Integration Testing (SIT) |  |  |  |  |  |  |  |  |
| 1740 | 1.4.3.6.1.1 | Develop draft Test Readiness Report and submit to Programme for assurance |  | 20d | 2024-08-26 | 2024-09-20 | 1725FF-10d |  |  | 2024-08-26 | 2024-09-20 | 20d | 2024-08-26 | 2024-09-20 | 819d | 0d |  |  | PP | SI Test | SIT | 5.0 | Stuart Scott | Systems Integration Testing (SIT) | -155.67 | Overdue Start | RED |  |  |  |  |  |
| 1741 | 1.4.3.6.1.2 | Finalise Test Readiness Report and submit to Programme for assurance |  | 10d | 2024-09-23 | 2024-10-04 | 1725FF |  |  | 2024-09-23 | 2024-10-04 | 10d | 2024-09-23 | 2024-10-04 | 819d | 0d |  |  | PP | SI Test | SIT | 5.0 | Stuart Scott | Systems Integration Testing (SIT) | -127.67 | Overdue Start | RED |  |  |  |  |  |
| 1742 | 1.4.3.6.2 | **SI E2E Sandbox Test Readiness Report** |  | 40d | 2024-08-26 | 2024-10-18 |  |  |  | 2024-08-26 | 2024-10-18 | 40d | 2024-08-26 | 2024-10-18 | 819d |  |  |  | N/A | N/A | SIT | 5.0 | N/A | Systems Integration Testing (SIT) |  |  |  |  |  |  |  |  |
| 1743 | 1.4.3.6.2.1 | Assure Central Parties' E2E Sandbox Test Readiness Reports |  | 35d | 2024-08-26 | 2024-10-11 | 1740SS, 1741FF+5d |  |  | 2024-08-26 | 2024-10-11 | 35d | 2024-08-26 | 2024-10-11 | 819d | 0d |  |  | SI Test | PP | SIT | 5.0 | Stuart Scott | Systems Integration Testing (SIT) | -155.67 | Overdue Start | RED |  |  |  |  |  |
| 1744 | 1.4.3.6.2.2 | Develop Overarching E2E Sandbox Test Readiness Report |  | 20d | 2024-09-16 | 2024-10-11 | 1743FF |  |  | 2024-09-16 | 2024-10-11 | 20d | 2024-09-16 | 2024-10-11 | 819d | 0d |  |  | SI Test |  | SIT | 5.0 | Stuart Scott | Systems Integration Testing (SIT) | -134.67 | Overdue Start | RED |  |  |  |  |  |
| 1745 | 1.4.3.6.2.3 | Artefact review (via SITAG) and updates |  | 5d | 2024-10-14 | 2024-10-18 | 1744 |  |  | 2024-10-14 | 2024-10-18 | 5d | 2024-10-14 | 2024-10-18 | 819d | 69d |  |  | SI Test | PP,IPA | SIT | 5.0 | Stuart Scott | Systems Integration Testing (SIT) | -106.67 | Overdue Start | RED |  |  |  |  |  |
| 1746 | 1.4.3.6.3 | UIT E2E Sandbox Preparation Complete | milestone | 0d | 2025-01-31 | 2025-01-31 | 1745FS+5d |  |  | 2025-01-31 | 2025-01-31 | 0d | 2024-10-25 | 2024-10-25 | 750d | 131d | start no earlier than 2025-01-31 |  | SI Test | PP | SIT | 5.28 | Stuart Scott | Systems Integration Testing (SIT) | 2.33 | Green | GREEN | MHHS-ART154 MHHS-ART147 | T3-TE-0048 | QAG | T3 |  |
| 1747 | 1.4.4 | **Sandbox Testing Execution (UIT)** |  | 260d | 2025-09-01 | 2026-08-28 |  |  |  | 2025-02-07 | 2026-04-24 | 316d | 2024-11-04 | 2026-01-19 | 344d |  |  | -0 | N/A | N/A | SIT | 6.15 | N/A | Systems Integration Testing (SIT) |  |  |  |  |  |  |  |  |
| 1748 | 1.4.4.1 | Sandbox Testing Start (UIT) | milestone | 0d | 2025-09-01 | 2025-09-01 | 1645, 2176FS+5d, 1746 |  |  | 2025-09-01 | 2025-09-01 | 0d | 2024-11-04 | 2024-11-04 | 603d | 0d | start no earlier than 2025-02-10 |  | SI Test | PP | SIT | 6.15 | Stuart Scott | Systems Integration Testing (SIT) | 215.71 | Green | GREEN | MHHS-ART018 MHHS-ART154 MHHS-ART147 | T3-TE-0049 | QAG | T3 |  |
| 1749 | 1.4.4.2 | Sandbox Testing Execution (UIT) |  | 260d | 2025-09-01 | 2026-08-28 | 1748SS-1d |  |  | 2025-09-01 | 2026-08-28 | 316d | 2024-11-04 | 2026-01-19 | 344d | 0d | start no earlier than 2024-11-04 |  | PP | SI Test | SIT | 6.15 | Stuart Scott | Systems Integration Testing (SIT) | 215.33 | Green | GREEN |  |  |  |  |  |
| 1750 | 1.4.4.3 | Sandbox Testing End (UIT) | milestone | 0d | 2026-08-28 | 2026-08-28 | 1749 |  |  | 2026-08-28 | 2026-08-28 |  |  |  | 344d |  |  |  |  |  |  | 6.15 |  |  | 576.71 | Green | GREEN |  | T3-TE-XXXX |  |  |  |
| 1751 | 1.4.5 | **SIT PPs Early Sandbox Testing Execution (SIT-A)** |  | 56d | 2025-08-08 | 2025-10-24 |  |  |  | 2025-02-07 | 2026-04-24 | 316d | 2024-11-04 | 2026-01-19 | 564d |  |  | -0 | N/A | N/A | SIT | 6.15 | N/A | Systems Integration Testing (SIT) |  |  |  |  |  |  |  |  |
| 1752 | 1.4.5.1 | SIT PPs E2E Sandbox Testing Start | milestone | 0d | 2025-08-08 | 2025-08-08 | 1746FS+5d, 1563 |  |  | 2025-08-08 | 2025-08-08 | 0d | 2024-11-04 | 2024-11-04 | 619d | 0d | start no earlier than 2025-02-10 |  | SI Test | PP | SIT | 6.15 | Stuart Scott | Systems Integration Testing (SIT) | 191.71 | Green | GREEN | MHHS-ART018 MHHS-ART154 MHHS-ART147 | T3-TE-0049 | QAG | T3 |  |
| 1753 | 1.4.5.2 | SIT PPs E2E Sandbox Testing Execution |  | 56d | 2025-08-08 | 2025-10-24 | 1752SS-1d |  |  | 2025-02-07 | 2026-04-24 | 316d | 2024-11-04 | 2026-01-19 | 564d |  | start no earlier than 2024-11-04 |  | PP | SI Test | SIT | 6.15 | Stuart Scott | Systems Integration Testing (SIT) | 191.33 | Green | GREEN |  |  |  |  |  |
| 1754 | 1.4.6 | **System Integration Testing - Tier 1 Milestones** |  | 214d? | 2025-02-28 | 2025-12-24 |  |  |  | 2025-02-28 | 2025-12-24 | 0d |  |  | 149d |  |  |  |  |  | SIT | 6.15 |  |  | -685.67 | Overdue Start |  |  |  | SITAG |  |  |
| 1755 | 1.4.6.1 | M10 Checkpoint |  | 1d? | 2025-02-28 | 2025-02-28 | 1756FS-149d |  |  | 2025-02-28 | 2025-02-28 | 0d |  |  | 734d |  |  |  | SI Test |  | SIT | 6.1 |  |  | 30.33 | Green | GREEN |  | T3-MI-0040 | SITAG | T3 |  |
| 1756 | 1.4.6.2 | Central systems ready for migrating MPANs (M10) | milestone | 0d | 2025-09-24 | 2025-09-24 | 1645FS+20d, 2849, 2604FS+2d, 2601, 2616, 2583, 2587 |  |  | 2025-09-24 | 2025-09-24 | 0d | 2025-03-07 | 2025-03-07 | 0d |  |  |  | CPT | CPT | SIT | 6.1 | CPT | Migration | 238.71 | Green | GREEN |  | T1-MI-1000 | PSG | T1 | Central systems ready for migrating MPANs |
| 1757 | 1.4.6.3 | Central systems ready for migrating MPANs (M10*) - Late Exit | milestone | 0d | 2025-12-24 | 2025-12-24 | 1756FS+65d |  |  | 2025-12-24 | 2025-12-24 | 0d | 2025-06-06 | 2025-06-06 | 521d |  |  |  | CPT | CPT | SIT | 6.1 | CPT | Migration | 329.71 | Green | GREEN |  | T2-MI-1500 | PSG | T1 | Central systems ready for migrating MPANs |
| 1758 | 1.4.7 | **External Programme Dependency Management** |  | 174d | 2022-10-31 A | 2023-06-30 A |  | 100% |  | 2022-10-31 | 2023-06-30 | 174d | 2022-10-31 | 2023-06-30 |  |  |  |  | N/A | N/A | SIT | 5.0 | N/A | Systems Integration Testing (SIT) |  |  |  |  |  |  |  |  |
| 1759 | 1.4.7.1 | **BSC CP1558** |  | 173d | 2022-10-31 A | 2023-06-29 A |  | 100% |  | 2022-10-31 | 2023-06-29 | 173d | 2022-10-31 | 2023-06-29 |  |  |  |  | N/A | N/A | SIT | 5.0 | N/A | Systems Integration Testing (SIT) |  |  |  |  |  |  |  |  |
| 1760 | 1.4.7.1.1 | Monitor progress to implementation date |  | 173d | 2022-10-31 A | 2023-06-28 A |  | 100% |  | 2022-10-31 | 2023-06-28 | 173d | 2022-10-31 | 2023-06-28 |  |  |  |  | CPT | Code Bodies | SIT | 5.0 | Andrew Margan | Systems Integration Testing (SIT) |  | Complete | COMPLETE |  |  |  |  |  |
| 1761 | 1.4.7.1.2 | BSC CP1558 Implementation Date | milestone | 0d | 2023-06-29 A | 2023-06-29 A | 1760 | 100% |  | 2023-06-29 | 2023-06-29 | 0d | 2023-06-29 | 2023-06-29 |  |  | must start on 2023-06-29 |  | Code Bodies |  | SIT | 5.0 | Andrew Margan | Systems Integration Testing (SIT) |  | Complete | COMPLETE |  |  |  |  |  |

Notes:
- 1735: 28/01/25 - Programme is working on updating these dates over the coming weeks.
- 1736: 28/01/25 - Programme is working on updating these dates over the coming weeks.
- 1737: 28/01/25 - Programme is working on updating these dates over the coming weeks.
- 1738: 28/01/25 - Programme is working on updating these dates over the coming weeks.
- 1739: 28/01/25 - Programme is working on updating these dates over the coming weeks.
- 1740: 28/01/25 - Programme is working on updating these dates over the coming weeks.
- 1741: 28/01/25 - Programme is working on updating these dates over the coming weeks.
- 1742: 28/01/25 - Programme is working on updating these dates over the coming weeks.
- 1743: 28/01/25 - Programme is working on updating these dates over the coming weeks.
- 1744: 28/01/25 - Programme is working on updating these dates over the coming weeks.
- 1745: 28/01/25 - Programme is working on updating these dates over the coming weeks.
- 1746: 28/01/25 - Programme is working on updating these dates over the coming weeks.
- 1747: 28/01/25 - Programme is working on updating these dates over the coming weeks.
- 1748: 28/01/25 - Programme is working on updating these dates over the coming weeks.
- 1749: 28/01/25 - Programme is working on updating these dates over the coming weeks.
- 1750: 28/01/25 - Programme is working on updating these dates over the coming weeks.
- 1751: 28/01/25 - Programme is working on updating these dates over the coming weeks.
- 1752: 28/01/25 - Programme is working on updating these dates over the coming weeks.
- 1753: 28/01/25 - Programme is working on updating these dates over the coming weeks.

| ID | WBS | Task | Type | Duration | Start | Finish | Predecessors | Complete | Remaining | Baseline start | Baseline finish | Baseline duration | Baseline 1 start | Baseline 1 finish | Total slack | Constraint | Baseline cost | Responsible | Involved | Text9 | Update Version | MHHS Resource Name | MHHS Programme Phase | Sched Status | RAG | Text29 | Task Status | Milestone ID | Tier |
| --- | --- | --- | --- | --- | --- | --- | --- | --- | --- | --- | --- | --- | --- | --- | --- | --- | --- | --- | --- | --- | --- | --- | --- | --- | --- | --- | --- | --- | --- |
| 1762 | 1.4.7.2 | **REC CP R0032** |  | 174d | 2022-10-31 A | 2023-06-30 A |  | 100% |  | 2022-10-31 | 2023-06-30 | 174d | 2022-10-31 | 2023-06-30 |  |  |  | N/A | N/A | SIT | 5.0 | N/A | Systems Integration Testing (SIT) |  |  |  |  |  |  |
| 1763 | 1.4.7.2.1 | Monitor progress to implementation date |  | 174d | 2022-10-31 A | 2023-06-29 A |  | 100% |  | 2022-10-31 | 2023-06-29 | 174d | 2022-10-31 | 2023-06-29 |  |  |  | CPT | Code Bodies | SIT | 5.0 | Andrew Margan | Systems Integration Testing (SIT) | Complete | COMPLETE |  |  |  |  |
| 1764 | 1.4.7.2.2 | REC CP R0032 Implementation Date | milestone | 0d | 2023-06-30 A | 2023-06-30 A | 1763 | 100% |  | 2023-06-30 | 2023-06-30 | 0d | 2023-06-30 | 2023-06-30 |  | must start on 2023-06-30 |  | Code Bodies |  | SIT | 5.0 | Andrew Margan | Systems Integration Testing (SIT) | Complete | COMPLETE |  |  |  |  |
| 1765 | 1.4.7.3 | **REC CP R0044** |  | 173d | 2022-10-31 A | 2023-06-29 A |  | 100% |  | 2022-10-31 | 2023-06-29 | 173d | 2022-10-31 | 2023-06-29 |  |  |  | N/A | N/A | SIT | 5.0 | N/A | Systems Integration Testing (SIT) |  |  |  |  |  |  |
| 1766 | 1.4.7.3.1 | Monitor progress to implementation date |  | 173d | 2022-10-31 A | 2023-06-28 A |  | 100% |  | 2022-10-31 | 2023-06-28 | 173d | 2022-10-31 | 2023-06-28 |  |  |  | CPT | Code Bodies | SIT | 5.0 | Andrew Margan | Systems Integration Testing (SIT) | Complete | COMPLETE |  |  |  |  |
| 1767 | 1.4.7.3.2 | REC CP R0044 Implementation Date | milestone | 0d | 2023-06-29 A | 2023-06-29 A | 1766 | 100% |  | 2023-06-29 | 2023-06-29 | 0d | 2023-06-29 | 2023-06-29 |  | must start on 2023-06-29 |  | Code Bodies |  | SIT | 5.0 | Andrew Margan | Systems Integration Testing (SIT) | Complete | COMPLETE |  |  |  |  |
| 1768 | 1.5 | **NON SIT LDSO QUALIFICATION** |  | 489d? | 2023-11-07 A | 2025-09-19 |  | 70% | 146.73d? | 2023-11-07 | 2025-08-22 | 343d | 2024-01-29 | 2024-07-05 | 589d |  | -0 | N/A | N/A | Non-SIT LDSO Qualification |  | N/A | Systems Integration Testing (SIT) |  |  | QAG |  |  |  |
| 1769 | 1.5.1 | **Approach Planning** |  | 208d | 2023-11-07 A | 2024-08-22 A |  | 100% |  | 2023-11-07 | 2024-08-22 | 208d |  |  |  |  | -0 | N/A | N/A | Non-SIT LDSO Qualification | 5.24 | N/A |  |  |  |  | -386.67 |  |  |
| 1770 | 1.5.1.1 | Develop Draft Testing Approach & Plan |  | 61d | 2023-11-07 A | 2024-01-30 A |  | 100% |  | 2023-11-07 | 2024-01-30 | 61d |  |  |  | start no earlier than 2023-11-07 |  | Non-SIT LDSO | Non-SIT LDSO | Non-SIT LDSO Qualification | 5.24 | Ben Wickins |  | Complete | COMPLETE |  |  |  |  |
| 1771 | 1.5.1.2 | Draft Testing Approach & Plan Issued to LDSO for Review |  | 1d | 2024-01-31 A | 2024-01-31 A | 1770 | 100% |  | 2024-01-31 | 2024-01-31 | 1d |  |  |  |  |  | Non-SIT LDSO | Non-SIT LDSO | Non-SIT LDSO Qualification | 5.24 | Ben Wickins |  | Complete | COMPLETE |  |  |  |  |
| 1772 | 1.5.1.3 | LDSO Review Complete |  | 10d | 2024-02-01 A | 2024-02-14 A | 1771 | 100% |  | 2024-02-01 | 2024-02-14 | 10d |  |  |  |  |  | LDSOs | Non-SIT LDSO | Non-SIT LDSO Qualification | 5.24 | Ben Wickins |  | Complete | COMPLETE |  |  |  |  |
| 1773 | 1.5.1.4 | Update Following LDSO Review |  | 14d | 2024-02-15 A | 2024-03-05 A | 1772 | 100% |  | 2024-02-15 | 2024-03-05 | 14d |  |  |  |  |  | Non-SIT LDSO | Non-SIT LDSO, Code Bodies | Non-SIT LDSO Qualification | 5.24 | Ben Wickins |  | Complete | COMPLETE |  |  |  |  |
| 1774 | 1.5.1.5 | QWG Review of Approach & Plan |  | 1d | 2024-03-12 A | 2024-03-12 A | 1773FS+4d | 100% |  | 2024-03-12 | 2024-03-12 | 1d |  |  |  |  |  | Non-SIT LDSO, PP | Non-SIT LDSO, Code Bodies | Non-SIT LDSO Qualification | 5.24 | Ben Wickins |  | Complete | COMPLETE |  |  |  |  |
| 1775 | 1.5.1.6 | QAG Approval for Approach & Plan | milestone | 0d | 2024-03-21 A | 2024-03-21 A | 1774FS+7d | 100% |  | 2024-03-21 | 2024-03-21 | 0d |  |  |  |  |  | Code Bodies | Non-SIT LDSO,Code Bodies | Non-SIT LDSO Qualification | 5.24 | Ben Wickins |  | Complete | COMPLETE |  |  |  |  |
| 1776 | 1.5.1.7 | Confirmation of Participants for Non-SIT LDSO Qualification Testing | milestone | 0d | 2024-03-21 A | 2024-03-21 A | 1775 | 100% |  | 2024-03-21 | 2024-03-21 | 0d | 2024-01-29 | 2024-01-29 |  |  |  | Non-SIT LDSO | SI Test, PP, IPA | Non-SIT LDSO Qualification | 5.24 | Ben Wickins | Systems Integration Testing (SIT) | Complete | COMPLETE | QAG (Non-SIT LDSO) |  | T3-QU-0011 | T3 |
| 1777 | 1.5.1.8 | Update to Annex 1 for internal review (NF, Not Operational) |  | 15d | 2024-03-18 A | 2024-04-05 A | 1092 | 100% |  | 2024-03-18 | 2024-04-05 | 15d |  |  |  |  |  | Non-SIT LDSO | PP, Code Bodies | Non-SIT LDSO Qualification | 5.24 | Ben Wickins |  | Complete | COMPLETE |  |  |  |  |
| 1778 | 1.5.1.9 | Non-Functional, Operational & Migration Approaches Socialised with Code Bodies & LDSO & Feedback Actioned |  | 86d | 2024-04-08 A | 2024-08-05 A | 1777 | 100% |  | 2024-04-08 | 2024-08-05 | 86d |  |  |  |  |  | Non-SIT LDSO | PP, Code Bodies | Non-SIT LDSO Qualification | 5.27 | Ben Wickins |  | Complete | COMPLETE |  |  |  |  |
| 1779 | 1.5.1.10 | QWG Review Operational, Non-Functional & Migration Annexes of Approach & Plan |  | 1d | 2024-08-13 A | 2024-08-13 A | 1778FS+5d | 100% |  | 2024-08-13 | 2024-08-13 | 1d |  |  |  |  |  | Non-SIT LDSO, PP | Non-SIT LDSO, PP, Code Bodies | Non-SIT LDSO Qualification | 5.27 | Ben Wickins |  | Complete | COMPLETE |  |  |  |  |
| 1780 | 1.5.1.11 | Update Following QWG Review |  | 6d | 2024-08-14 A | 2024-08-21 A | 1779 | 100% |  | 2024-08-14 | 2024-08-21 | 6d |  |  |  |  |  | Non-SIT LDSO, PP | Non-SIT LDSO, Code Bodies | Non-SIT LDSO Qualification | 5.27 | Ben Wickins |  | Complete | COMPLETE |  |  |  |  |
| 1781 | 1.5.1.12 | QAG Approval for Operational, Non-Functional & Migration Annexes of Approach & Plan | milestone | 0d | 2024-08-22 A | 2024-08-22 A | 1780FS+1d, 1776, 1095 | 100% |  | 2024-08-22 | 2024-08-22 | 0d |  |  |  |  |  | Code Bodies | Non-SIT LDSO, Code Bodies | Non-SIT LDSO Qualification | 5.29 | Ben Wickins |  | Complete | COMPLETE | QAG (Non-SIT LDSO) |  | T3-QU-0110 | T3 |
| 1782 | 1.5.2 | **Functional Test Cases & Scenarios** |  | 58d | 2024-01-30 A | 2024-04-18 A |  | 100% |  | 2024-01-30 | 2024-04-18 | 58d |  |  |  |  | -0 | N/A | N/A | Non-SIT LDSO Qualification | 5.24 | N/A |  |  |  |  | -385.67 |  |  |
| 1783 | 1.5.2.1 | **Functional Test Cases & Scenarios Batch 1** |  | 8d | 2024-01-30 A | 2024-02-08 A |  | 100% |  | 2024-01-30 | 2024-02-08 | 8d |  |  |  |  | -0 | N/A | N/A | Non-SIT LDSO Qualification | 5.24 | N/A |  |  |  |  |  |  |  |
| 1784 | 1.5.2.1.1 | Walkthrough Test Cases & Scenarios Batch 1 with Code Bodies |  | 1d | 2024-01-30 A | 2024-01-30 A | 1770SS+60d | 100% |  | 2024-01-30 | 2024-01-30 | 1d |  |  |  |  |  | Non-SIT LDSO | Non-SIT LDSO, Code Bodies | Non-SIT LDSO Qualification | 5.24 | Ben Wickins |  | Complete | COMPLETE |  |  |  |  |
| 1785 | 1.5.2.1.2 | Walkthrough Test Cases & Scenarios Batch 1 with LDSO |  | 1d | 2024-02-01 A | 2024-02-01 A | 1784 | 100% |  | 2024-02-01 | 2024-02-01 | 1d |  |  |  |  |  | LDSO, Non-SIT LDSO | LDSO, Non-SIT LDSO | Non-SIT LDSO Qualification | 5.24 | Ben Wickins |  | Complete | COMPLETE |  |  |  |  |
| 1786 | 1.5.2.1.3 | Action Feedback on Test Cases & Scenarios Batch 1 |  | 5d | 2024-02-02 A | 2024-02-08 A | 1785 | 100% |  | 2024-02-02 | 2024-02-08 | 5d |  |  |  |  |  | Non-SIT LDSO | Non-SIT LDSO, LDSO , Code Bodies | Non-SIT LDSO Qualification | 5.24 | Ben Wickins |  | Complete | COMPLETE |  |  |  |  |

Notes:
- 1777: Guidance: 26/3: Linked to the development of SIT non functional plan
- 1781: Guidance: 18/7/24: Date change from 18/7/24 to 22/8/24 approved at QAG on 18/7/24

| ID | WBS | Task | Type | Duration | Start | Finish | Predecessors | Complete | Baseline start | Baseline finish | Baseline duration | Baseline 1 start | Baseline 1 finish | Constraint | Baseline cost | Responsible | Involved | Text9 | Update Version | MHHS Resource Name | Sched Status | RAG | Milestone ID | Text29 | Tier | MHHS Programme Phase |
| --- | --- | --- | --- | --- | --- | --- | --- | --- | --- | --- | --- | --- | --- | --- | --- | --- | --- | --- | --- | --- | --- | --- | --- | --- | --- | --- |
| 1787 | 1.5.2.2 | **Functional Test Cases & Scenarios Batch 2** |  | 14d | 2024-02-20 A | 2024-03-08 A |  | 100% | 2024-02-20 | 2024-03-08 | 14d |  |  |  | -0 | N/A | N/A | Non-SIT LDSO Qualification | 5.24 | N/A |  |  |  |  |  |  |
| 1788 | 1.5.2.2.1 | Walkthrough Test Cases & Scenarios Batch 2 with Code Bodies |  | 1d | 2024-02-20 A | 2024-02-20 A | 1770SS+75d | 100% | 2024-02-20 | 2024-02-20 | 1d |  |  |  |  | Non-SIT LDSO | Non-SIT LDSO, Code Bodies | Non-SIT LDSO Qualification | 5.24 | Ben Wickins | Complete | COMPLETE |  |  |  |  |
| 1789 | 1.5.2.2.2 | Walkthrough Test Cases & Scenarios Batch 2 with LDSO |  | 1d | 2024-03-01 A | 2024-03-01 A | 1788FS+7d | 100% | 2024-03-01 | 2024-03-01 | 1d |  |  |  |  | LDSO, Non-SIT LDSO | LDSO, Non-SIT LDSO | Non-SIT LDSO Qualification | 5.24 | Ben Wickins | Complete | COMPLETE |  |  |  |  |
| 1790 | 1.5.2.2.3 | Action Feedback on Test Cases & Scenarios Batch 2 |  | 5d | 2024-03-04 A | 2024-03-08 A | 1789 | 100% | 2024-03-04 | 2024-03-08 | 5d |  |  |  |  | Non-SIT LDSO | Non-SIT LDSO, LDSO , Code Bodies | Non-SIT LDSO Qualification | 5.24 | Ben Wickins | Complete | COMPLETE |  |  |  |  |
| 1791 | 1.5.2.3 | **Functional Test Cases & Scenarios Batch 3** |  | 13d | 2024-03-20 A | 2024-04-05 A |  | 100% | 2024-03-20 | 2024-04-05 | 13d |  |  |  | -0 | N/A | N/A | Non-SIT LDSO Qualification | 5.24 | N/A |  |  |  |  |  |  |
| 1792 | 1.5.2.3.1 | Walkthrough Test Cases & Scenarios Batch 3 with Code Bodies |  | 1d | 2024-03-20 A | 2024-03-20 A | 1770SS+96d | 100% | 2024-03-20 | 2024-03-20 | 1d |  |  |  |  | Non-SIT LDSO | Non-SIT LDSO, Code Bodies | Non-SIT LDSO Qualification | 5.24 | Ben Wickins | Complete | COMPLETE |  |  |  |  |
| 1793 | 1.5.2.3.2 | Walkthrough Test Cases & Scenarios Batch 3 with LDSO |  | 1d | 2024-03-28 A | 2024-03-28 A | 1792FS+5d | 100% | 2024-03-28 | 2024-03-28 | 1d |  |  |  |  | LDSO, Non-SIT LDSO | LDSO, Non-SIT LDSO | Non-SIT LDSO Qualification | 5.24 | Ben Wickins | Complete | COMPLETE |  |  |  |  |
| 1794 | 1.5.2.3.3 | Action Feedback on Test Cases & Scenarios Batch 3 |  | 6d | 2024-03-29 A | 2024-04-05 A | 1793 | 100% | 2024-03-29 | 2024-04-05 | 6d |  |  |  |  | Non-SIT LDSO | Non-SIT LDSO, LDSO , Code Bodies | Non-SIT LDSO Qualification | 5.24 | Ben Wickins | Complete | COMPLETE |  |  |  |  |
| 1795 | 1.5.2.4 | Test Cases & Scenarios Batch 1-3 Discussion at QWG |  | 1d | 2024-04-09 A | 2024-04-09 A | 1786, 1790, 1794FS+1d | 100% | 2024-04-09 | 2024-04-09 | 1d |  |  |  |  | Non-SIT LDSO, PP | Non-SIT LDSO, Code Bodies | Non-SIT LDSO Qualification | 5.24 | Ben Wickins | Complete | COMPLETE |  |  |  |  |
| 1796 | 1.5.2.5 | Action QWG Feedback on Test Cases & Scenarios Batch 1-3 |  | 2d | 2024-04-10 A | 2024-04-11 A | 1795 | 100% | 2024-04-10 | 2024-04-11 | 2d |  |  |  |  | Non-SIT LDSO | Non-SIT LDSO, Code Bodies | Non-SIT LDSO Qualification | 5.24 | Ben Wickins | Complete | COMPLETE |  |  |  |  |
| 1797 | 1.5.2.6 | Batch 1-3 Non-SIT LDSO QT Functional Test Scenarios and Test Cases approved | milestone | 0d | 2024-04-18 A | 2024-04-18 A | 1796FS+5d | 100% | 2024-04-18 | 2024-04-18 | 0d |  |  |  |  | Code Bodies | Non-SIT LDSO, Code Bodies | Non-SIT LDSO Qualification | 5.24 | Ben Wickins | Complete | COMPLETE | T3-QU-0069 | QAG (Non-SIT LDSO) | T3 |  |
| 1798 | 1.5.3 | **Test Execution Schedule** |  | 161d | 2024-04-19 A | 2024-11-29 A |  | 100% | 2024-04-19 | 2024-11-29 | 90d | 2024-01-29 | 2024-04-26 |  | -0 | N/A | N/A | Non-SIT LDSO Qualification | 5.24 | N/A |  |  |  |  |  | Systems Integration Testing (SIT) |
| 1799 | 1.5.3.1 | Draft Test Delivery Schedule for Functional and Operational Testing |  | 20d | 2024-04-19 A | 2024-05-16 A | 1797 | 100% | 2024-04-19 | 2024-05-16 | 20d | 2024-01-29 | 2024-03-22 |  |  | Non-SIT LDSO | SI Test, PP, Non-SIT LDSO | Non-SIT LDSO Qualification | 5.24 | Ben Wickins | Complete | COMPLETE |  |  |  | Systems Integration Testing (SIT) |
| 1800 | 1.5.3.2 | Socialise Test Delivery Schedule with Code Bodies & LDSO for Review & Action Feedback |  | 37d | 2024-05-17 A | 2024-07-08 A | 1799 | 100% | 2024-05-17 | 2024-07-08 | 37d |  |  |  |  | Non-SIT LDSO | LDSO, Code Bodies, Non-SIT LDSO | Non-SIT LDSO Qualification | 5.24 | Ben Wickins | Complete | COMPLETE |  |  |  |  |
| 1801 | 1.5.3.3 | Agree Test Execution Timetable Format at QWG, Including Anonymisation Requirements |  | 1d | 2024-07-09 A | 2024-07-09 A | 1800 | 100% | 2024-07-09 | 2024-07-09 | 1d | 2024-03-25 | 2024-04-19 |  |  | Non-SIT LDSO, PP | Non-SIT LDSO, Code Bodies | Non-SIT LDSO Qualification | 5.24 | Ben Wickins | Complete | COMPLETE |  |  |  | Systems Integration Testing (SIT) |
| 1802 | 1.5.3.4 | Action QWG Feedback |  | 3d | 2024-07-10 A | 2024-07-12 A | 1801 | 100% | 2024-07-10 | 2024-07-12 | 3d |  |  |  |  | Non-SIT LDSO, PP | Non-SIT LDSO, Code Bodies | Non-SIT LDSO Qualification | 5.24 | Ben Wickins | Complete | COMPLETE |  |  |  |  |
| 1803 | 1.5.3.5 | Agree Test Execution Timetable Format at QAG, Including Anonymisation Requirements | milestone | 0d | 2024-07-18 A | 2024-07-18 A | 1802FS+4d | 100% | 2024-07-18 | 2024-07-18 | 0d |  |  |  |  | Code Bodies | Non-SIT LDSO, Code Bodies | Non-SIT LDSO Qualification | 5.29 | Ben Wickins | Complete | COMPLETE | T3-QU-0111 | QAG (Non-SIT LDSO) | T3 |  |
| 1804 | 1.5.3.6 | Qualification Testing for Non-SIT LDSOs (Functional, Migration, NFT, Operational) Test Execution Schedule Complete | milestone | 0d | 2024-11-29 A | 2024-11-29 A | 1781 | 100% | 2024-11-29 | 2024-11-29 | 0d | 2024-04-26 | 2024-04-26 | finish no earlier than 2024-11-29 |  | Non-SIT LDSO | Non-SIT LDSO, Code Bodies, PP | Non-SIT LDSO Qualification | 5.29 | Ben Wickins | Complete | COMPLETE | T3-QU-0008 | QAG (Non-SIT LDSO) | T3 | Systems Integration Testing (SIT) |
| 1805 | 1.5.4 | **Functional, Non-Functional, Operational & Migration Test Scenarios & Cases** |  | 110d | 2024-03-22 A | 2024-08-22 A |  | 100% | 2024-03-22 | 2024-08-22 | 110d |  |  |  | -0 | N/A | N/A | Non-SIT LDSO Qualification | 5.24 | N/A |  |  |  |  |  |  |
| 1806 | 1.5.4.1 | Test Scenarios & Cases - Functional - Drafted, Reviewed |  | 14d | 2024-04-01 A | 2024-04-18 A | 1775 | 100% | 2024-04-01 | 2024-04-18 | 14d |  |  |  |  | Non-SIT LDSO | Non-SIT LDSO, LDSO, Code Bodies | Non-SIT LDSO Qualification | 5.24 | Ben Wickins | Complete | COMPLETE |  |  |  |  |
| 1807 | 1.5.4.2 | Test Scenarios & Cases- Functional - Approved at QAG | milestone | 0d | 2024-04-18 A | 2024-04-18 A | 1806 | 100% | 2024-04-18 | 2024-04-18 | 0d |  |  |  |  | Non-SIT LDSO | Non-SIT LDSO, LDSO, Code Bodies | Non-SIT LDSO Qualification | 5.24 | Ben Wickins | Complete | COMPLETE | T3-QU-0070 | QAG (Non-SIT LDSO) | T3 |  |
| 1808 | 1.5.4.3 | Test Scenarios & Cases - Non-Functional - Drafted, Reviewed |  | 110d | 2024-03-22 A | 2024-08-22 A | 1775, 1112FF | 100% | 2024-03-22 | 2024-08-22 | 110d |  |  |  |  | Non-SIT LDSO | Non-SIT LDSO, LDSO, Code Bodies | Non-SIT LDSO Qualification | 5.24 | Ben Wickins | Complete | COMPLETE |  |  |  |  |
| 1809 | 1.5.4.4 | Test Scenarios & Cases - Non-Functional - Approved at QAG | milestone | 0d | 2024-08-22 A | 2024-08-22 A | 1808 | 100% | 2024-08-22 | 2024-08-22 | 0d |  |  |  |  | Non-SIT LDSO | Non-SIT LDSO, LDSO, Code Bodies | Non-SIT LDSO Qualification | 5.29 | Ben Wickins | Complete | COMPLETE | T3-QU-0071 | QAG (Non-SIT LDSO) | T3 |  |
| 1810 | 1.5.4.5 | Test Scenarios & Cases - Migration - Drafted, Reviewed |  | 45d | 2024-03-22 A | 2024-05-23 A | 1775 | 100% | 2024-03-22 | 2024-05-23 | 45d |  |  |  |  | Non-SIT LDSO | Non-SIT LDSO, LDSO, Code Bodies | Non-SIT LDSO Qualification | 5.24 | Ben Wickins | Complete | COMPLETE |  |  |  |  |
| 1811 | 1.5.4.6 | Test Scenarios & Cases - Migration - Approved at QAG | milestone | 0d | 2024-05-23 A | 2024-05-23 A | 1810 | 100% | 2024-05-23 | 2024-05-23 | 0d |  |  |  |  | Non-SIT LDSO | Non-SIT LDSO, LDSO, Code Bodies | Non-SIT LDSO Qualification | 5.24 | Ben Wickins | Complete | COMPLETE | T3-QU-0072 | QAG (Non-SIT LDSO) | T3 |  |
| 1812 | 1.5.4.7 | Test Scenarios & Cases - Operational - Drafted, Reviewed |  | 59d | 2024-06-03 A | 2024-08-22 A | 1775FS+51d | 100% | 2024-06-03 | 2024-08-22 | 59d |  |  |  |  | Non-SIT LDSO | Non-SIT LDSO, LDSO, Code Bodies | Non-SIT LDSO Qualification | 5.24 | Ben Wickins | Complete | COMPLETE |  |  |  |  |
| 1813 | 1.5.4.8 | Test Scenarios & Cases - Operational - Approved at QAG | milestone | 0d | 2024-08-22 A | 2024-08-22 A | 1812, 1112FF | 100% | 2024-08-22 | 2024-08-22 | 0d |  |  |  |  | Non-SIT LDSO | Non-SIT LDSO, LDSO, Code Bodies | Non-SIT LDSO Qualification | 5.29 | Ben Wickins | Complete | COMPLETE | T3-QU-0073 | QAG (Non-SIT LDSO) | T3 |  |

Notes:
- 1804: Guidance: 18/7/24: Date change from 15/8/24 to 22/8/24 approved at QAG on 18/7/24
- 1809: Guidance: 18/7/24: Date change from 18/7/24 to 22/8/24 approved at QAG on 18/7/24
- 1813: Guidance: 18/7/24: Date change from 18/7/24 to 22/8/24 approved at QAG on 18/7/24

| ID | WBS | Task | Type | Duration | Start | Finish | Predecessors | Complete | Remaining | Baseline start | Baseline finish | Baseline duration | Total slack | Free slack | Constraint | Deadline | Baseline cost | Responsible | Involved | Text9 | Task Status | Update Version | MHHS Resource Name | Sched Status | RAG | Milestone ID | Text29 | Tier |
| --- | --- | --- | --- | --- | --- | --- | --- | --- | --- | --- | --- | --- | --- | --- | --- | --- | --- | --- | --- | --- | --- | --- | --- | --- | --- | --- | --- | --- |
| 1814 | 1.5.5 | **Test Data** |  | 345d | 2024-01-22 A | 2025-05-16 |  | 65% | 120.02d | 2024-01-22 | 2025-05-16 | 241d | 679d |  |  |  | -0 | N/A | N/A | Non-SIT LDSO Qualification | -385.67 | 5.24 | N/A |  |  |  |  |  |
| 1815 | 1.5.5.1 | Test Data Plan Drafted & Reviewed |  | 89d | 2024-01-22 A | 2024-05-23 A | 1770 | 100% |  | 2024-01-22 | 2024-05-23 | 89d |  |  |  |  |  | Code Bodies | Non-SIT LDSO, Code Bodies | Non-SIT LDSO Qualification |  | 5.24 | Ben Wickins | Complete | COMPLETE |  |  |  |
| 1816 | 1.5.5.2 | Non-SIT LDSO QT Test Data Plan Approved by QAG | milestone | 0d | 2024-05-23 A | 2024-05-23 A | 1815 | 100% |  | 2024-05-23 | 2024-05-23 | 0d |  |  |  |  |  | Code Bodies | Non-SIT LDSO, Code Bodies | Non-SIT LDSO Qualification |  | 5.24 | Ben Wickins | Complete | COMPLETE | T3-QU-0074 | QAG (Non-SIT LDSO) | T3 |
| 1817 | 1.5.5.3 | Develop Test Data Matrices |  | 10d | 2024-05-24 A | 2024-06-06 A | 1816 | 100% |  | 2024-05-24 | 2024-06-06 | 10d |  |  |  |  |  | Non-SIT LDSO | Non-SIT LDSO | Non-SIT LDSO Qualification |  | 5.24 | Ben Wickins | Complete | COMPLETE |  |  |  |
| 1818 | 1.5.5.4 | Test Data Cut |  | 17d | 2024-05-24 A | 2024-06-17 A | 1816 | 100% |  | 2024-05-24 | 2024-06-17 | 17d |  |  |  |  |  | PP, Non-SIT LDSO | PP, Non-SIT LDSO | Non-SIT LDSO Qualification |  | 5.24 | Ben Wickins | Complete | COMPLETE |  |  |  |
| 1819 | 1.5.5.5 | Test Data Cut Complete | milestone | 0d | 2024-06-17 A | 2024-06-17 A | 1818, 1817 | 100% |  | 2024-06-17 | 2024-06-17 | 0d |  |  |  |  |  | PP, Non-SIT LDSO | PP, Non-SIT LDSO | Non-SIT LDSO Qualification |  | 5.27 | Ben Wickins | Complete | COMPLETE | T3-QU-0112 | QAG (Non-SIT LDSO) | T3 |
| 1820 | 1.5.5.6 | Test Data Reviewed by the Programme |  | 39d | 2024-06-18 A | 2024-08-09 A | 1819 | 100% |  | 2024-06-18 | 2024-08-09 | 39d |  |  |  |  |  | Non-SIT LDSO | PP, Non-SIT LDSO | Non-SIT LDSO Qualification |  | 5.24 | Ben Wickins | Complete | COMPLETE |  |  |  |
| 1821 | 1.5.5.7 | Test Data Loaded |  | 85d | 2024-08-12 A | 2024-12-06 | 1820 | 90% | 8.5d | 2024-08-12 | 2024-12-06 | 17d | 679d | 0d |  |  |  | Non-SIT LDSO | PP, Non-SIT LDSO | Non-SIT LDSO Qualification |  | 5.24 | Ben Wickins | Green | RED |  |  |  |
| 1822 | 1.5.5.8 | Test Data Signed Off | milestone | 0d | 2024-12-06 | 2024-12-06 | 1821 |  |  | 2024-12-06 | 2024-12-06 | 0d | 679d | 0d |  |  |  | Non-SIT LDSO | PP, Non-SIT LDSO | Non-SIT LDSO Qualification | -53.29 | 5.25 | Ben Wickins | Green | RED | T3-QU-0113 | QAG (Non-SIT LDSO) | T3 |
| 1823 | 1.5.5.9 | Test Execution Data Support |  | 115d | 2024-12-09 | 2025-05-16 | 1822 |  |  | 2024-12-09 | 2025-05-16 | 79d | 679d |  |  |  |  | Non-SIT LDSO | Non-SIT LDSO | Non-SIT LDSO Qualification | -50.67 | 5.24 | Ben Wickins | Green | GREEN |  |  |  |
| 1824 | 1.5.6 | **Tooling** |  | 148d | 2024-01-31 A | 2024-08-23 A |  | 100% |  | 2024-01-31 | 2024-08-23 | 148d |  |  |  |  | -0 | N/A | N/A | Non-SIT LDSO Qualification | -385.67 | 5.24 | N/A |  |  |  |  |  |
| 1825 | 1.5.6.1 | Design Approach & Set-Up ADO Tool for Test & Defect Management Tool |  | 53d | 2024-01-31 A | 2024-04-12 A | 1770 | 100% |  | 2024-01-31 | 2024-04-12 | 53d |  |  |  |  |  | Non-SIT LDSO | Non-SIT LDSO, SI Test | Non-SIT LDSO Qualification |  | 5.24 | Ben Wickins | Complete | COMPLETE |  |  |  |
| 1826 | 1.5.6.2 | Develop Training Requirements & Materials Inc. Day in the Life |  | 87d | 2024-04-15 A | 2024-08-13 A | 1825 | 100% |  | 2024-04-15 | 2024-08-13 | 87d |  |  |  |  |  | Non-SIT LDSO | Non-SIT LDSO, SI Test | Non-SIT LDSO Qualification |  | 5.24 | Ben Wickins | Complete | COMPLETE |  |  |  |
| 1827 | 1.5.6.3 | ADO Launch complete |  | 1d | 2024-08-23 A | 2024-08-23 A | 1826, 1807, 1811, 1813 | 100% |  | 2024-08-23 | 2024-08-23 | 1d |  |  |  |  |  | Non-SIT LDSO | Non-SIT LDSO | Non-SIT LDSO Qualification |  | 5.24 | Ben Wickins | Complete | COMPLETE |  |  |  |
| 1828 | 1.5.7 | **Pre-Integration Testing** |  | 263d | 2024-01-31 A | 2025-01-31 |  | 83% | 43.41d | 2024-01-31 | 2024-11-29 | 174d | 754d |  |  |  | -0 | N/A | N/A | Non-SIT LDSO Qualification | -385.67 | 5.24 | N/A |  |  |  |  |  |
| 1829 | 1.5.7.1 | PIT Guidance & Templates & Approach & Plans Developed |  | 106d | 2024-02-05 A | 2024-07-01 A | 1770FS+3d | 100% |  | 2024-02-05 | 2024-07-01 | 106d |  |  |  |  |  | Non-SIT LDSO | Non-SIT LDSO, LDSO | Non-SIT LDSO Qualification |  | 5.27 | Ben Wickins | Complete | COMPLETE |  |  |  |
| 1830 | 1.5.7.2 | PIT Test Approach & Plan Deadline for Submission for Non-SIT LDSO​ QT | milestone | 0d | 2024-07-01 A | 2024-07-01 A | 1829 | 100% |  | 2024-07-01 | 2024-07-01 | 0d |  |  |  |  |  | Non-SIT LDSO | Non-SIT LDSO, LDSO | Non-SIT LDSO Qualification |  | 5.28 | Ben Wickins | Complete | COMPLETE | T3-QU-0075 | QAG (Non-SIT LDSO) | T3 |
| 1831 | 1.5.7.3 | Develop and agree PIT Test Scenarios |  | 20d | 2024-07-02 A | 2024-07-29 A | 1830 | 100% |  | 2024-07-02 | 2024-07-29 | 31d |  |  |  |  |  | Non-SIT LDSO | Non-SIT LDSO, Code Bodies, LDSO | Non-SIT LDSO Qualification |  | 5.24 | Ben Wickins | Complete | COMPLETE |  |  |  |
| 1832 | 1.5.7.4 | PIT Execution (Functional and Migration) | manual | 45d | 2024-09-30 A | 2024-11-29 | 1831 | 95% | 2.25d | 2024-09-30 | 2024-11-29 | 45d |  |  | start no earlier than 2024-09-30 |  |  | Non-SIT LDSO | Non-SIT LDSO, LDSO | Non-SIT LDSO Qualification |  | 5.24 | Ben Wickins | Green | RED |  |  |  |
| 1833 | 1.5.7.5 | PIT Execution (Non-Functional and Operational) |  | 95d | 2024-09-23 A | 2025-01-31 | 1831 | 22% | 74d | 2024-09-23 | 2025-01-31 | 0d | 754d | 0d | finish no earlier than 2025-01-31 |  |  |  |  | Non-SIT LDSO Qualification |  | 5.24 |  | Green | RED |  |  |  |
| 1834 | 1.5.7.6 | Non-SIT LDSO Participants have submitted functional PIT Test Completion Report & evidence for QT Entry​ | milestone | 0d | 2024-11-29 | 2024-11-29 | 1832 |  |  | 2024-11-29 | 2024-11-29 | 0d | 799d |  |  |  |  | Non-SIT LDSO | Non-SIT LDSO, LDSO | Non-SIT LDSO Qualification | -60.29 | 5.24 | Ben Wickins | Green | RED | T3-QU-0076 | QAG (Non-SIT LDSO) | T3 |
| 1835 | 1.5.7.7 | Non-SIT LDSO Participants have submitted non-functional PIT Test Completion Report | milestone | 0d | 2025-01-31 | 2025-01-31 | 1833 |  |  | 2025-01-31 | 2025-01-31 | 0d | 754d |  |  |  |  |  |  | Non-SIT LDSO Qualification | 2.71 | 5.24 | Ben Wickins | Green | RED |  |  |  |
| 1836 | 1.5.7.8 | **Placing Reliance - Code Body & LDSO Functional and Migration** |  | 147d | 2024-01-31 A | 2024-08-22 A |  | 100% |  | 2024-01-31 | 2024-08-22 | 147d |  |  |  |  | -0 | N/A | N/A | Non-SIT LDSO Qualification | -100.67 | 5.24 | N/A |  |  |  |  |  |
| 1837 | 1.5.7.8.1 | Placing Reliance Submitted & Reviewed |  | 21d | 2024-01-31 A | 2024-02-28 A | 1770 | 100% |  | 2024-01-31 | 2024-02-28 | 21d |  |  |  | 2024-01-05 |  | LDSO, Non-SIT LDSO | LDSO, Non-SIT LDSO | Non-SIT LDSO Qualification |  | 5.24 | Ben Wickins | Complete | COMPLETE |  |  |  |
| 1838 | 1.5.7.8.2 | Define & Agree QT Testing for Each LDSO |  | 22d | 2024-02-29 A | 2024-03-29 A | 1837 | 100% |  | 2024-02-29 | 2024-03-29 | 22d |  |  |  |  |  | Non-SIT LDSO | LDSO, Non-SIT LDSO | Non-SIT LDSO Qualification |  | 5.24 | Ben Wickins | Complete | COMPLETE |  |  |  |
| 1839 | 1.5.7.8.3 | Develop Test Scope & Reliance Submissions |  | 20d | 2024-04-01 A | 2024-04-26 A | 1838 | 100% |  | 2024-04-01 | 2024-04-26 | 20d |  |  |  |  |  | Non-SIT LDSO | LDSO, Non-SIT LDSO, Code Bodies | Non-SIT LDSO Qualification |  | 5.24 | Ben Wickins | Complete | COMPLETE |  |  |  |
| 1840 | 1.5.7.8.4 | Review and Consultation |  | 84d | 2024-04-29 A | 2024-08-22 A | 1839, 1781FF | 100% |  | 2024-04-29 | 2024-08-22 | 84d |  |  |  |  |  | Non-SIT LDSO | LDSO, Non-SIT LDSO | Non-SIT LDSO Qualification |  | 5.27 | Ben Wickins | Complete | COMPLETE |  |  |  |

Notes:
- 1821: 29/01/25 - Data load is continuing in support of test readiness assessments but additional support has been required by some LDSOs to load some data elements. LDSOs are clear that approved data is a condition of test readiness approval.
- 1822: 29/01/25 - 8/9 LDSOs have test data signed off, the other 1 have outstanding actions before they can be complete but this has not impacted testing start.
- 1832: 29/01/25 - One participant has not completed PIT Execution, hence why this is Red. This is has not delayed start of testing, the PP is forecasted to complete this on 17/02/25 and therefore start testing on same date.
- 1833: 29/01/25 - At least one PP has declared they won't complete NF and Ops PIT execution by 31/01/25. However, this will not delay QT testing because the issue delaying the PP is expiriencing is internal to them and not systemic, hence why other PPs can proceed with testing.
- 1834: 29/01/25 - One participant has not completed functional and migration PIT Execution, which is a predecessor this this, hence why this is Red. This is has not delayed start of testing, the PP is forecasted to complete this on 17/02/25 and therefore start testing on same date.
- 1835: 29/01/25 - One participant has not completed NF and Ops PIT Execution, which is a predecessor this this, hence why this is Red. This is has not delayed start of testing, the PP is forecasted to complete this on 17/02/25 and therefore start testing on the same date.

| ID | WBS | Task | Type | Duration | Start | Finish | Predecessors | Complete | Remaining | Baseline start | Baseline finish | Baseline duration | Baseline 1 start | Baseline 1 finish | Total slack | Free slack | Constraint | Deadline | Baseline cost | Responsible | Involved | Text9 | Task Status | Update Version | MHHS Resource Name | Sched Status | RAG | Milestone ID | Text29 | Tier | MHHS Programme Phase | Action |
| --- | --- | --- | --- | --- | --- | --- | --- | --- | --- | --- | --- | --- | --- | --- | --- | --- | --- | --- | --- | --- | --- | --- | --- | --- | --- | --- | --- | --- | --- | --- | --- | --- |
| 1841 | 1.5.7.9 | **Placing Reliance - Code Body & LDSO Non Functional and Operational** |  | 49d | 2024-06-17 A | 2024-08-22 A |  | 100% |  | 2024-06-17 | 2024-08-22 | 49d |  |  |  |  |  |  | -0 | N/A | N/A | Non-SIT LDSO Qualification | -100.67 | 5.25 | N/A |  |  |  |  |  |  |  |
| 1842 | 1.5.7.9.1 | Placing Reliance Submitted & Reviewed |  | 32d | 2024-06-17 A | 2024-07-30 A | 1779FF-10d | 100% |  | 2024-06-17 | 2024-07-30 | 32d |  |  |  |  |  |  |  | LDSO, Non-SIT LDSO | LDSO, Non-SIT LDSO | Non-SIT LDSO Qualification |  | 5.27 | Ben Wickins | Complete | COMPLETE |  |  |  |  |  |
| 1843 | 1.5.7.9.2 | Review and Consultation |  | 17d | 2024-07-31 A | 2024-08-22 A | 1842 | 100% |  | 2024-07-31 | 2024-08-22 | 17d |  |  |  |  |  |  |  | Non-SIT LDSO | LDSO, Non-SIT LDSO | Non-SIT LDSO Qualification |  | 5.27 | Ben Wickins | Complete | COMPLETE |  |  |  |  |  |
| 1844 | 1.5.7.9.3 | PP Test Scope Presented at QAG | milestone | 0d | 2024-08-22 A | 2024-08-22 A | 1843, 1840 | 100% |  | 2024-08-22 | 2024-08-22 | 0d |  |  |  |  |  |  |  | Non-SIT LDSO | LDSO, Non-SIT LDSO | Non-SIT LDSO Qualification |  | 5.29 | Ben Wickins | Complete | COMPLETE | T3-QU-0077 | QAG (Non-SIT LDSO) | T3 |  |  |
| 1845 | 1.5.8 | **LDSO Test Readiness Reporting** |  | 71d | 2024-04-19 A | 2024-07-26 A |  | 100% |  | 2024-04-19 | 2024-07-26 | 118d |  |  |  |  |  |  | -0 | N/A | N/A | Non-SIT LDSO Qualification |  | 5.24 | N/A |  |  |  |  |  |  |  |
| 1846 | 1.5.8.1 | Interim Test Readiness Report & Plan Developed & Reviewed |  | 71d | 2024-04-19 A | 2024-07-26 A | 1797 | 100% |  | 2024-04-19 | 2024-07-26 | 71d |  |  |  |  |  |  |  | Non-SIT LDSO, LDSO | Non-SIT LDSO, LDSO | Non-SIT LDSO Qualification |  | 5.24 | Ben Wickins | Complete | COMPLETE |  |  |  |  |  |
| 1847 | 1.5.8.2 | Test Plan Submission to MHHS Programme For Review | milestone | 0d | 2024-07-26 A | 2024-07-26 A | 1846 | 100% |  | 2024-07-26 | 2024-07-26 | 0d |  |  |  |  |  |  |  | LDSO | Non-SIT LDSO, LDSO | Non-SIT LDSO Qualification |  | 5.30 | Ben Wickins | Complete | COMPLETE | T3-QU-0114 | QAG (Non-SIT LDSO) | T3 |  |  |
| 1848 | 1.5.9 | **Test Environment** |  | 163d | 2024-04-17 A | 2024-11-29 A |  | 100% |  | 2024-04-17 | 2024-11-29 | 111d | 2024-01-29 | 2024-07-05 |  |  |  |  | -0 | N/A | N/A | Non-SIT LDSO Qualification |  | 5.24 | N/A |  |  |  |  |  | Systems Integration Testing (SIT) |  |
| 1849 | 1.5.9.1 | Define Test Harness Requirements and Sign-Off with SRO |  | 13d | 2024-04-17 A | 2024-05-03 A | 543 | 100% |  | 2024-04-17 | 2024-05-03 | 13d |  |  |  |  |  |  |  | Non-SIT LDSO | Non-SIT LDSO,SRO,Sims and Ems | Non-SIT LDSO Qualification |  | 5.24 | Ben Wickins | Complete | COMPLETE |  |  |  |  |  |
| 1850 | 1.5.9.2 | Central System (DIP Env & Helix Test Harness) Test Environment DBT |  | 163d | 2024-04-17 A | 2024-11-29 A | 543 | 100% |  | 2024-04-17 | 2024-11-29 | 92d |  |  |  |  | finish no earlier than 2024-11-29 |  |  | LDSO | Non SIT-LDSO, LDSO | Non-SIT LDSO Qualification |  | 5.24 | Ben Wickins | Complete | COMPLETE |  |  |  |  |  |
| 1851 | 1.5.9.3 | Coordinate LDSO Environment Preparation |  | 101d | 2024-07-12 A | 2024-11-29 A | 1850FF | 100% |  | 2024-07-12 | 2024-11-29 | 30d |  |  |  |  |  |  |  | Non-SIT LDSO | Non-SIT LDSO | Non-SIT LDSO Qualification |  | 5.24 | Ben Wickins | Complete | COMPLETE |  |  |  |  |  |
| 1852 | 1.5.9.4 | DIP available for Onboarding |  | 1d | 2024-08-01 A | 2024-08-01 A |  | 100% |  | 2024-08-01 | 2024-08-01 | 1d |  |  |  |  | start no earlier than 2024-08-01 |  |  | Test Env | Test Env, Non-SIT LDSO | Non-SIT LDSO Qualification |  | 5.24 | Ben Wickins | Complete | COMPLETE |  |  |  |  | 11/3: Ask Simon B for the link |
| 1853 | 1.5.9.5 | Qualification Testing for Non-SIT LDSOs Participants' environments) Ready to start DIP onboarding (incl. certificates and security compliance) | milestone | 0d | 2024-08-05 A | 2024-08-05 A | 1852FS+2d | 100% |  | 2024-08-05 | 2024-08-05 | 0d | 2024-04-26 | 2024-04-26 |  |  |  |  |  | Non-SIT LDSO | Code Bodies, PP, IPA | Non-SIT LDSO Qualification |  | 5.30 | Ben Wickins | Complete | COMPLETE | T3-QU-0009 | QAG (Non-SIT LDSO) | T3 | Systems Integration Testing (SIT) |  |
| 1854 | 1.5.9.6 | LDSO Test Environments Connection Confirmed to UIT Environment | milestone | 0d | 2024-11-29 A | 2024-11-29 A | 1853FS+32d, 1851 | 100% |  | 2024-11-29 | 2024-11-29 | 0d |  |  |  |  |  |  |  | Non-SIT LDSO | Code Bodies, PP, IPA | Non-SIT LDSO Qualification |  | 5.24 | Ben Wickins | Complete | COMPLETE | T3-QU-0078 | QAG (Non-SIT LDSO) | T3 |  |  |
| 1855 | 1.5.10 | **Test Readiness** |  | 124d | 2024-07-02 A | 2024-12-20 |  | 90% | 11.85d | 2024-07-02 | 2024-12-20 | 76d |  |  | 784d |  |  |  | -0 | N/A | N/A | Non-SIT LDSO Qualification |  | 5.24 | N/A |  |  |  |  |  |  |  |
| 1856 | 1.5.10.1 | Preparation for Interim Test Readiness Report |  | 19d | 2024-07-02 A | 2024-07-26 A | 1830 | 100% |  | 2024-07-02 | 2024-07-26 | 30d |  |  |  |  |  |  |  | LDSO | LDSO, Non-SIT LDSO | Non-SIT LDSO Qualification |  | 5.24 | Ben Wickins | Complete | COMPLETE |  |  |  |  |  |
| 1857 | 1.5.10.2 | Interim Test Readiness Report Submission to MHHS Programme for Review | milestone | 0d | 2024-07-26 A | 2024-07-26 A | 1856 | 100% |  | 2024-07-26 | 2024-07-26 | 0d |  |  |  |  |  |  |  | LDSO | Non-SIT LDSO, LDSO | Non-SIT LDSO Qualification |  | 5.25 | Ben Wickins | Complete | COMPLETE | T3-QU-0116 | QAG (Non-SIT LDSO) | T3 |  |  |
| 1858 | 1.5.10.3 | LDSO Update Readiness Report & Final Assurance by Programme |  | 99d | 2024-07-29 A | 2024-12-12 | 1857 | 95% | 4.95d | 2024-07-29 | 2024-12-12 | 25d |  |  | 10d | 0d |  |  |  | Non-SIT LDSO, LDSO | Non-SIT LDSO, LDSO | Non-SIT LDSO Qualification |  | 5.24 | Ben Wickins | Green | GREEN |  |  |  |  |  |
| 1859 | 1.5.10.4 | Final Test Readiness Report Submitted to MHHS Programme |  | 1d | 2024-12-13 | 2024-12-13 | 1858 |  |  | 2024-12-13 | 2024-12-13 | 1d |  |  | 789d |  |  |  |  | LDSO | Non-SIT LDSO, Code Bodies | Non-SIT LDSO Qualification | -46.67 | 5.24 | Ben Wickins | Green | GREEN |  |  |  |  |  |
| 1860 | 1.5.10.5 | Final Programme Assurance of LDSO Test Readiness |  | 6d | 2024-12-13 | 2024-12-20 | 1858 |  |  | 2024-12-13 | 2024-12-20 | 21d |  |  | 10d | 0d |  |  |  | Non-SIT LDSO | Non-SIT LDSO, LDSO | Non-SIT LDSO Qualification | -46.67 | 5.24 | Ben Wickins | Green | GREEN |  |  |  |  |  |
| 1861 | 1.5.10.6 | Qualification Testing for Non-SIT LDSOs (Functional, Migration, NFT, Operational) Programme Test Readiness confirmed | milestone | 0d | 2024-12-20 A | 2024-12-20 A | 1859FS+5d, 1834, 1807, 1809, 1811, 1849 | 100% |  | 2024-12-20 | 2024-12-20 | 0d | 2024-07-05 | 2024-07-05 |  |  |  |  |  | Non-SIT LDSO | SI Test, PP, Non-SIT LDSO | Non-SIT LDSO Qualification |  | 5.24 | Ben Wickins | Complete | COMPLETE | T3-QU-0007 | QAG (Non-SIT LDSO) | T3 | Systems Integration Testing (SIT) |  |
| 1862 | 1.5.10.7 | Qualification Testing for Non-SIT LDSOs (Functional, Migration, NFT, Operational) Test Readiness Confirmed (Final Test Readiness Review for LDSO) | milestone | 0d | 2024-12-20 A | 2024-12-20 | 1858, 1860 | 90% | 0d | 2024-12-20 | 2024-12-20 | 0d | 2024-07-05 | 2024-07-05 | 10d |  |  |  |  | LDSO | SI Test, PP, LDSO | Non-SIT LDSO Qualification |  | 5.24 | Ben Wickins | Green | RED | T2-QU-0550 | QAG (Non-SIT LDSO) | T2 | Systems Integration Testing (SIT) |  |
| 1863 | 1.5.11 | **Test Window** |  | 165d? | 2025-01-06 A | 2025-08-22 |  | 22% | 129.26d? | 2025-01-06 | 2025-05-16 | 59d |  |  | 609d |  |  |  | -0 | N/A | N/A | Non-SIT LDSO Qualification | -527.67 | 6.0 | N/A |  |  |  | QAG (Non-SIT LDSO) |  |  |  |
| 1864 | 1.5.11.1 | **All Non-SIT LDSOs Qualification Testing** |  | 94d | 2025-01-06 A | 2025-05-16 | 1862, 1854 | 24% | 71.36d | 2025-01-06 | 2025-05-16 | 59d |  |  | 1d |  |  |  |  | LDSO | Non-SIT LDSO,Code Bodies, LDSO | Non-SIT LDSO Qualification | 118.33 | 6.0 | Ben Wickins |  |  |  | QAG (Non-SIT LDSO) |  |  |  |
| 1865 | 1.5.11.1.1 | Non-SIT LDSO QT Test Execution Starts | milestone | 0d | 2025-01-06 A | 2025-01-06 A | 1862FS+11d | 100% |  | 2025-01-06 | 2025-01-06 | 0d |  |  |  |  | start no earlier than 2024-11-01 |  |  | Non-SIT LDSO | Non-SIT LDSO, LDSO, Code Bodies | Non-SIT LDSO Qualification |  | 6.0 | Ben Wickins | Complete | COMPLETE | T3-QU-0115 | QAG (Non-SIT LDSO) | T3 |  |  |
| 1866 | 1.5.11.1.2 | LDSO Alpha |  | 86d | 2025-01-06 A | 2025-05-05 | 1865FS-1d | 12% | 75.68d | 2025-01-06 | 2025-05-05 |  |  |  | 9d | 8d |  |  |  | LDSO |  | Non-SIT LDSO Qualification |  | 6.15 | Ben Wickins | Green | GREEN |  | QAG (Non-SIT LDSO) |  |  |  |
| 1867 | 1.5.11.1.3 | LDSO Bravo |  | 59d | 2025-01-06 A | 2025-03-27 | 1865FS-1d | 5% | 56.05d | 2025-01-06 | 2025-03-27 |  |  |  | 36d | 35d |  |  |  | LDSO |  | Non-SIT LDSO Qualification |  | 6.15 | Ben Wickins | Green | GREEN |  | QAG (Non-SIT LDSO) |  |  |  |
| 1868 | 1.5.11.1.4 | LDSO Charlie |  | 88d | 2025-01-06 A | 2025-05-07 | 1865FS-1d | 28% | 63.36d | 2025-01-06 | 2025-05-07 |  |  |  | 7d | 6d |  |  |  | LDSO |  | Non-SIT LDSO Qualification |  | 6.15 | Ben Wickins | Green | GREEN |  | QAG (Non-SIT LDSO) |  |  |  |
| 1869 | 1.5.11.1.5 | LDSO Delta |  | 83d | 2025-01-06 A | 2025-04-30 | 1865FS-1d | 15% | 70.55d | 2025-01-06 | 2025-04-30 |  |  |  | 12d | 11d |  |  |  | LDSO |  | Non-SIT LDSO Qualification |  | 6.15 | Ben Wickins | Green | GREEN |  | QAG (Non-SIT LDSO) |  |  |  |
| 1870 | 1.5.11.1.6 | LDSO Echo |  | 69d | 2025-01-06 A | 2025-04-10 | 1865FS-1d | 57% | 29.67d | 2025-01-06 | 2025-04-10 |  |  |  | 26d | 25d |  |  |  | LDSO |  | Non-SIT LDSO Qualification |  | 6.15 | Ben Wickins | Green | GREEN |  | QAG (Non-SIT LDSO) |  |  |  |
| 1871 | 1.5.11.1.7 | LDSO Foxtrot |  | 44d | 2025-01-20 | 2025-03-20 | 1865FS+9d |  |  | 2025-01-20 | 2025-03-20 |  |  |  | 41d | 40d |  |  |  | LDSO |  | Non-SIT LDSO Qualification | -8.67 | 6.15 | Ben Wickins | Green | GREEN |  | QAG (Non-SIT LDSO) |  |  |  |
| 1872 | 1.5.11.1.8 | LDSO Golf |  | 66d | 2025-01-06 A | 2025-04-07 | 1865FS-1d | 38% | 40.92d | 2025-01-06 | 2025-04-07 |  |  |  | 29d | 28d |  |  |  | LDSO |  | Non-SIT LDSO Qualification |  | 6.15 | Ben Wickins | Green | GREEN |  | QAG (Non-SIT LDSO) |  |  |  |
| 1873 | 1.5.11.1.9 | LDSO Hotel |  | 45d | 2025-01-06 A | 2025-03-07 | 1865FS-1d | 36% | 28.8d | 2025-01-06 | 2025-03-07 |  |  |  | 50d | 49d |  |  |  | LDSO |  | Non-SIT LDSO Qualification |  | 6.15 | Ben Wickins | Green | GREEN |  | QAG (Non-SIT LDSO) |  |  |  |
| 1874 | 1.5.11.1.10 | LDSO India |  | 86d | 2025-01-06 A | 2025-05-05 | 1865FS-1d | 23% | 66.22d | 2025-01-06 | 2025-05-05 |  |  |  | 9d | 8d |  |  |  | LDSO |  | Non-SIT LDSO Qualification |  | 6.15 | Ben Wickins | Green | GREEN |  | QAG (Non-SIT LDSO) |  |  |  |
| 1875 | 1.5.11.1.11 | Qualification Testing for Non-SIT LDSOs (Functional, Migration, NFT, Operational) 1 End | milestone | 0d | 2025-05-16 | 2025-05-16 | 1866, 1867, 1868, 1869, 1870, 1871, 1872, 1873, 1874 |  |  | 2025-05-16 | 2025-05-16 | 0d |  |  | 1d | 0d | start no earlier than 2025-05-16 | 2025-05-16 |  | LDSO |  | Non-SIT LDSO Qualification | 107.33 | 6.0 | Ben Wickins | Green | GREEN | T3-QU-0010 | QAG (Non-SIT LDSO) | T3 |  |  |
| 1876 | 1.5.11.2 | Potential for non-SIT LDSO QT Regression for Qualification |  | 70d? | 2025-05-19 | 2025-08-22 | 1875FS+1d |  |  | 2025-05-19 | 2025-08-22 | 0d |  |  | 609d |  |  |  |  | Non-SIT LDSO |  | Non-SIT LDSO Qualification | 110.33 | 6.12 | Ben Wickins | Green | GREEN |  | QAG (Non-SIT LDSO) |  |  |  |

Notes:
- 1844: Guidance: 18/7/24: Date change from 18/7/24 to 22/8/24 approved at QAG on 18/7/24
- 1862: 29/01/25 - Milestone RAG'd red because a predecssor activity (T3-QU-0076) is delayed due to one participant being behind schedule, but the factors behind this are internal to them, so has not delayed the start of testing for those LDSOs who were ready.

| ID | WBS | Task | Type | Duration | Start | Finish | Predecessors | Complete | Remaining | Baseline start | Baseline finish | Baseline duration | Baseline 1 start | Baseline 1 finish | Total slack | Free slack | Constraint | Baseline cost | Responsible | Involved | Text9 | Update Version | MHHS Resource Name | Text29 | Task Status | Sched Status | RAG | Milestone ID | Tier | MHHS Programme Phase |
| --- | --- | --- | --- | --- | --- | --- | --- | --- | --- | --- | --- | --- | --- | --- | --- | --- | --- | --- | --- | --- | --- | --- | --- | --- | --- | --- | --- | --- | --- | --- |
| 1877 | 1.5.12 | **Test Result Assurance** |  | 29d | 2025-04-21 | 2025-05-29 |  |  |  | 2025-04-21 | 2025-05-29 | 60d |  |  | 44d |  |  | -0 | N/A | N/A | Non-SIT LDSO Qualification | 6.0 | N/A | QAG (Non-SIT LDSO) |  |  |  |  |  |  |
| 1878 | 1.5.12.1 | LDSOs Develop & Submit Test Report (QT Test Completion Report) |  | 19d | 2025-04-21 | 2025-05-16 | 1875FF |  |  | 2025-04-21 | 2025-05-16 | 19d |  |  | 44d | 0d |  |  | LDSO | Non-SIT LDSO, LDSO | Non-SIT LDSO Qualification | 6.0 | Ben Wickins | QAG (Non-SIT LDSO) | 82.33 | Green | GREEN |  |  |  |
| 1879 | 1.5.12.2 | Test Reports Reviewed By MHHS & Code Bodies & Finalised |  | 10d | 2025-05-16 | 2025-05-29 | 1878 |  |  | 2025-05-16 | 2025-05-29 | 16d |  |  | 650d | 0d |  |  | Non-SIT LDSO | Non-SIT LDSO, Code Bodies | Non-SIT LDSO Qualification | 6.0 | Ben Wickins | QAG (Non-SIT LDSO) | 107.33 | Green | GREEN |  |  |  |
| 1880 | 1.5.12.3 | Non-SIT LDSOs submission deadline for their QT Test Completion Report to MHHS Programme | milestone | 0d | 2025-05-29 | 2025-05-29 | 1879, 1864 |  |  | 2025-05-29 | 2025-05-29 | 0d |  |  | 650d | 61d |  |  | Non-SIT LDSO | Non-SIT LDSO | Non-SIT LDSO Qualification | 6.0 | Ben Wickins | QAG (Non-SIT LDSO) | 120.71 | Green | GREEN | T3-QU-0079 | T3 |  |
| 1881 | 1.5.13 | **Non-SIT LDSO Qualification Closure** |  | 20d | 2025-08-25 | 2025-09-19 |  |  |  | 2025-05-30 | 2025-08-22 | 49d |  |  | 589d |  |  | -0 | N/A | N/A | Non-SIT LDSO Qualification | 6.0 | N/A | QAG (Non-SIT LDSO) |  |  |  |  |  |  |
| 1882 | 1.5.13.1 | Non-SIT LDSO Qualification Learned Captured |  | 15d | 2025-08-25 | 2025-09-12 | 1880, 1973 |  |  | 2025-05-30 | 2025-06-19 | 15d |  |  | 589d | 0d |  |  | Non-SIT LDSO | Non-SIT LDSO | Non-SIT LDSO Qualification | 6.0 | Ben Wickins | QAG (Non-SIT LDSO) | 208.33 | Red | RED |  |  |  |
| 1883 | 1.5.13.2 | Non-SIT LDSO Qualification Closure Down |  | 5d | 2025-09-15 | 2025-09-19 | 1882 |  |  | 2025-06-20 | 2025-06-26 | 5d |  |  | 589d |  |  |  | Non-SIT LDSO | Non-SIT LDSO | Non-SIT LDSO Qualification | 6.0 | Ben Wickins | QAG (Non-SIT LDSO) | 229.33 | Red | RED |  |  |  |
| 1884 | 1.6 | **S & A QUALIFICATION** |  | 843d? | 2023-11-07 A | 2027-01-28 |  | 57% | 358.91d? | 2023-11-07 | 2027-01-28 | 603d | 2024-01-29 | 2024-07-05 | 235d |  |  | -0 | N/A | N/A | S&A Qualification |  | N/A |  | -461.67 |  |  |  |  | Systems Integration Testing (SIT) |
| 1885 | 1.6.1 | **MHHS Qualification - Qualification Deliverables** |  | 509d | 2023-11-07 A | 2025-10-17 |  | 95% | 26.3d | 2023-11-07 | 2025-08-14 | 349d |  |  | 0d |  |  | -0 | N/A | N/A | S&A Qualification | 5.24 | N/A |  | -131.67 |  |  |  |  |  |
| 1886 | 1.6.1.1 | **BSC & REC Assessment Criteria** |  | 463d | 2023-11-07 A | 2025-08-14 A |  | 100% |  | 2023-11-07 | 2025-08-14 | 212d |  |  |  |  |  | -0 | N/A | N/A | S&A Qualification | 5.24 | N/A |  | -131.67 |  |  |  |  |  |
| 1887 | 1.6.1.1.1 | Draft BSC Assessment Criteria (Functional) |  | 21d | 2023-11-07 A | 2023-12-05 A |  | 100% |  | 2023-11-07 | 2023-12-05 | 21d |  |  |  |  | finish no earlier than 2023-12-05 |  | Code Bodies | Code Bodies | S&A Qualification | 5.24 | Laura Kennedy |  |  | Complete | COMPLETE |  |  |  |
| 1888 | 1.6.1.1.2 | BSC PAB Review |  | 1d | 2023-12-14 A | 2023-12-14 A |  | 100% |  | 2023-12-14 | 2023-12-14 | 1d |  |  |  |  | start no earlier than 2023-12-14 |  | Code Bodies | Code Bodies | S&A Qualification | 5.24 | Laura Kennedy |  |  | Complete | COMPLETE |  |  |  |
| 1889 | 1.6.1.1.3 | Update BSC Assessment Criteria (Functional, Non-Functional, Migration) |  | 30d | 2024-02-07 A | 2024-03-19 A |  | 100% |  | 2024-02-07 | 2024-03-19 | 30d |  |  |  |  | finish no earlier than 2024-03-19 |  | Code Bodies | Code Bodies | S&A Qualification | 5.24 | Laura Kennedy |  |  | Complete | COMPLETE |  |  |  |
| 1890 | 1.6.1.1.4 | REC & BSC PAB Approval |  | 3d | 2024-03-26 A | 2024-03-28 A |  | 100% |  | 2024-03-26 | 2024-03-28 | 3d |  |  |  |  | start no earlier than 2024-03-28 |  | Code Bodies | Code Bodies | S&A Qualification | 5.24 | Laura Kennedy |  |  | Complete | COMPLETE |  |  |  |
| 1891 | 1.6.1.1.5 | Update BSC Assessment Criteria (Functional, Non-Functional, Migration, Operational) |  | 20d | 2024-07-24 A | 2024-08-20 A |  | 100% |  | 2024-07-24 | 2024-08-20 | 20d |  |  |  |  |  |  | Code Bodies | Code Bodies | S&A Qualification | 5.24 | Laura Kennedy |  |  | Complete | COMPLETE |  |  |  |
| 1892 | 1.6.1.1.6 | Assessment Criteria (Functional, Non-Functional, Migration, Operational) Approved by REC PAB and BSC PAB |  | 250d | 2024-08-29 A | 2025-08-14 A | 1891FS+7d | 100% |  | 2024-08-29 | 2025-08-14 | 0d |  |  |  |  | start no earlier than 2023-09-15 |  | Code Bodies | Code Bodies | S&A Qualification | 5.25 | Laura Kennedy | QAG |  | Complete | COMPLETE | T3-QU-0080 | T3 |  |
| 1893 | 1.6.1.2 | **Qualification Approach and Plan** |  | 194d | 2023-12-04 A | 2024-08-29 A |  | 100% |  | 2023-12-04 | 2024-08-29 | 194d |  |  |  |  |  | -0 | N/A | N/A | S&A Qualification | 5.24 | N/A |  | -131.67 |  |  |  |  |  |
| 1894 | 1.6.1.2.1 | **Qualification Approach and Plan v2** |  | 84d | 2023-12-04 A | 2024-03-28 A |  | 100% |  | 2023-12-04 | 2024-03-28 | 84d |  |  |  |  |  | -0 | N/A | N/A | S&A Qualification | 5.24 | N/A |  | -131.67 |  |  |  |  |  |
| 1895 | 1.6.1.2.1.1 | Draft Qualification Approach and Plan v2 |  | 30d | 2023-12-04 A | 2024-01-12 A |  | 100% |  | 2023-12-04 | 2024-01-12 | 30d |  |  |  |  | finish no earlier than 2024-01-12 |  | Code Bodies | Code Bodies | S&A Qualification | 5.24 | Laura Kennedy |  |  | Complete | COMPLETE |  |  |  |
| 1896 | 1.6.1.2.1.2 | Internal Review (Code Bodies and MHHSP) for Qualification Approach and Plan V2 |  | 10d | 2024-01-15 A | 2024-01-26 A | 1895 | 100% |  | 2024-01-15 | 2024-01-26 | 10d |  |  |  |  | finish no earlier than 2024-01-26 |  | Code Bodies, SI Team, SRO | Code Bodies, SI Team, SRO | S&A Qualification | 5.24 | Laura Kennedy |  |  | Complete | COMPLETE |  |  |  |
| 1897 | 1.6.1.2.1.3 | Industry consultation for Qualification Approach and Plan v2 |  | 11d | 2024-01-31 A | 2024-02-14 A | 1896 | 100% |  | 2024-01-31 | 2024-02-14 | 11d |  |  |  |  | start no earlier than 2024-01-31 |  | Participants | Participants | S&A Qualification | 5.24 | Laura Kennedy |  |  | Complete | COMPLETE |  |  |  |
| 1898 | 1.6.1.2.1.4 | Update Qualification Approach and Plan v2 post industry consultation |  | 10d | 2024-02-15 A | 2024-02-28 A | 1897 | 100% |  | 2024-02-15 | 2024-02-28 | 10d |  |  |  |  |  |  | Code Bodies | Code Bodies | S&A Qualification | 5.24 | Laura Kennedy |  |  | Complete | COMPLETE |  |  |  |
| 1899 | 1.6.1.2.1.5 | QWG Endorsement of Qualification Approach and Plan v2 |  | 1d | 2024-03-12 A | 2024-03-12 A |  | 100% |  | 2024-03-12 | 2024-03-12 | 1d |  |  |  |  | start no earlier than 2024-03-12 |  | Code Bodies | Code Bodies | S&A Qualification | 5.24 | Laura Kennedy |  |  | Complete | COMPLETE |  |  |  |
| 1900 | 1.6.1.2.1.6 | QAG Approval of Qualification Approach and Plan v2 |  | 1d | 2024-03-21 A | 2024-03-21 A |  | 100% |  | 2024-03-21 | 2024-03-21 | 1d |  |  |  |  | start no earlier than 2024-03-21 |  | Code Bodies | Code Bodies | S&A Qualification | 5.24 | Laura Kennedy |  |  | Complete | COMPLETE |  |  |  |
| 1901 | 1.6.1.2.1.7 | BSC and REC PAB Approval of Qualification Approach and Plan v2 |  | 3d | 2024-03-26 A | 2024-03-28 A |  | 100% |  | 2024-03-26 | 2024-03-28 | 3d |  |  |  |  | finish no earlier than 2024-03-28 |  | Code Bodies | Code Bodies | S&A Qualification | 5.24 | Laura Kennedy |  |  | Complete | COMPLETE |  |  |  |
| 1902 | 1.6.1.2.1.8 | Functional Testing elements of Qualification Approach & Plan v2 approvement by REC PAB and BSC PAB | milestone | 0d | 2024-03-28 A | 2024-03-28 A | 1901 | 100% |  | 2024-03-28 | 2024-03-28 | 0d |  |  |  |  |  |  | Code Bodies | Code Bodies | S&A Qualification | 5.24 | Laura Kennedy | QAG |  | Complete | COMPLETE | T3-QU-0063 | T3 |  |
| 1903 | 1.6.1.2.1.9 | Migration Testing elements of Qualification Approach & Plan v2 appoved by REC PAB and BSC PAB | milestone | 0d | 2024-03-28 A | 2024-03-28 A | 1901 | 100% |  | 2024-03-28 | 2024-03-28 | 0d |  |  |  |  |  |  | Code Bodies | Code Bodies | S&A Qualification | 5.24 | Laura Kennedy | QAG |  | Complete | COMPLETE | T3-QU-0064 | T3 |  |

Notes:
- 1882: 29/01/25 - Outstanding action for Programme to update and expand this section, but waiting to see how Qualification progresses before doing this.
- 1883: 29/01/25 - Outstanding action for Programme to update and expand this section, but waiting to see how Qualification progresses before doing this.

| ID | WBS | Task | Type | Duration | Start | Finish | Predecessors | Complete | Remaining | Baseline start | Baseline finish | Baseline duration | Total slack | Constraint | Baseline cost | Responsible | Involved | Text9 | Task Status | Update Version | MHHS Resource Name | Sched Status | RAG | Milestone ID | Text29 | Tier |
| --- | --- | --- | --- | --- | --- | --- | --- | --- | --- | --- | --- | --- | --- | --- | --- | --- | --- | --- | --- | --- | --- | --- | --- | --- | --- | --- |
| 1904 | 1.6.1.2.2 | **Qualification Approach and Plan v3** |  | 84d | 2024-05-06 A | 2024-08-29 A |  | 100% |  | 2024-05-06 | 2024-08-29 | 84d |  |  | -0 | N/A | N/A | S&A Qualification | -133.67 | 5.24 | N/A |  |  |  |  |  |
| 1905 | 1.6.1.2.2.1 | Draft Qualification Approach and Plan v3 |  | 35d | 2024-05-06 A | 2024-06-21 A | 1095 | 100% |  | 2024-05-06 | 2024-06-21 | 35d |  | finish no earlier than 2024-05-17 |  | Code Bodies | Code Bodies | S&A Qualification |  | 5.27 | Laura Kennedy | Complete | COMPLETE |  |  |  |
| 1906 | 1.6.1.2.2.2 | Internal Review (Code Bodies and MHHSP) of Qualification Approach and Plan v3 |  | 10d | 2024-06-24 A | 2024-07-05 A | 1905 | 100% |  | 2024-06-24 | 2024-07-05 | 10d |  |  |  | Code Bodies, SI Team, SRO | Code Bodies, SI Team, SRO | S&A Qualification |  | 5.27 | Laura Kennedy | Complete | COMPLETE |  |  |  |
| 1907 | 1.6.1.2.2.3 | Industry consultation for Qualification Approach and Plan v3 |  | 10d | 2024-07-08 A | 2024-07-19 A | 1906 | 100% |  | 2024-07-08 | 2024-07-19 | 10d |  |  |  | Participants | Participants | S&A Qualification |  | 5.27 | Laura Kennedy | Complete | COMPLETE |  |  |  |
| 1908 | 1.6.1.2.2.4 | Update Qualification Approach and Plan v3 Post-Consultation |  | 10d | 2024-07-22 A | 2024-08-02 A | 1907 | 100% |  | 2024-07-22 | 2024-08-02 | 10d |  |  |  | Code Bodies | Code Bodies | S&A Qualification |  | 5.27 | Laura Kennedy | Complete | COMPLETE |  |  |  |
| 1909 | 1.6.1.2.2.5 | QWG Endorsement of Qualification Approach and Plan v3 |  | 1d | 2024-08-13 A | 2024-08-13 A | 1908FS+6d | 100% |  | 2024-08-13 | 2024-08-13 | 1d |  |  |  | Code Bodies | Code Bodies | S&A Qualification |  | 5.27 | Laura Kennedy | Complete | COMPLETE |  |  |  |
| 1910 | 1.6.1.2.2.6 | QAG Approval of Qualification Approach and Plan v3 | milestone | 0d | 2024-08-22 A | 2024-08-22 A | 1909FS+7d | 100% |  | 2024-08-22 | 2024-08-22 | 0d |  |  |  | Code Bodies | Code Bodies | S&A Qualification |  | 5.27 | Laura Kennedy | Complete | COMPLETE | T3-QU-0081 | QAG |  |
| 1911 | 1.6.1.2.2.7 | BSC and REC PAB Approval of Qualification Approach and Plan v3 |  | 3d | 2024-08-27 A | 2024-08-29 A | 1910FS+2d | 100% |  | 2024-08-27 | 2024-08-29 | 3d |  |  |  | Code Bodies | Code Bodies | S&A Qualification |  | 5.27 | Laura Kennedy | Complete | COMPLETE |  |  |  |
| 1912 | 1.6.1.2.2.8 | Non-Functional Testing elements of Qualification Approach and Plan v3 approved by REC PAB and BSC PAB | milestone | 0d | 2024-08-29 A | 2024-08-29 A | 1911 | 100% |  | 2024-08-29 | 2024-08-29 | 0d |  |  |  | Code Bodies | Code Bodies | S&A Qualification |  | 5.27 | Laura Kennedy | Complete | COMPLETE | T3-QU-0065 | QAG | T3 |
| 1913 | 1.6.1.3 | **Qualification Assessment Document** |  | 476d | 2023-12-22 A | 2025-10-17 |  | 87% | 60.64d | 2023-12-22 | 2025-03-07 | 316d | 0d |  | -0 | N/A | N/A | S&A Qualification | -131.67 | 5.24 | N/A |  |  |  |  |  |
| 1914 | 1.6.1.3.1 | **Qualification Assessment Document v1** |  | 70d | 2023-12-22 A | 2024-03-28 A |  | 100% |  | 2023-12-22 | 2024-03-28 | 70d |  |  | -0 | N/A | N/A | S&A Qualification | -131.67 | 5.24 | N/A |  |  |  |  |  |
| 1915 | 1.6.1.3.1.1 | Draft Qualification Assessment Document v1 |  | 30d | 2023-12-22 A | 2024-02-01 A |  | 100% |  | 2023-12-22 | 2024-02-01 | 30d |  | finish no earlier than 2024-02-01 |  | Code Bodies | Code Bodies | S&A Qualification |  | 5.24 | Laura Kennedy | Complete | COMPLETE |  |  |  |
| 1916 | 1.6.1.3.1.2 | Internal Review (Code Bodies and MHHSP) of Qualification Assessment Document v1 |  | 10d | 2024-02-01 A | 2024-02-14 A |  | 100% |  | 2024-02-01 | 2024-02-14 | 10d |  | finish no earlier than 2024-02-14 |  | Code Bodies, SI Team, SRO | Code Bodies, SI Team, SRO | S&A Qualification |  | 5.24 | Laura Kennedy | Complete | COMPLETE |  |  |  |
| 1917 | 1.6.1.3.1.3 | Industry consultation for Qualification Assessment Document v1 |  | 11d | 2024-02-16 A | 2024-03-01 A |  | 100% |  | 2024-02-16 | 2024-03-01 | 11d |  | start no earlier than 2024-02-16 |  | Participants | Participants | S&A Qualification |  | 5.24 | Laura Kennedy | Complete | COMPLETE |  |  |  |
| 1918 | 1.6.1.3.1.4 | Update Post-Consultation for Qualification Assessment Document v1 |  | 10d | 2024-03-04 A | 2024-03-15 A | 1917 | 100% |  | 2024-03-04 | 2024-03-15 | 10d |  |  |  | Code Bodies | Code Bodies | S&A Qualification |  | 5.24 | Laura Kennedy | Complete | COMPLETE |  |  |  |
| 1919 | 1.6.1.3.1.5 | BSC and REC PAB Approval of Qualification Assessment Document v1 |  | 3d | 2024-03-26 A | 2024-03-28 A |  | 100% |  | 2024-03-26 | 2024-03-28 | 3d |  | start no earlier than 2024-03-26 |  | Code Bodies | Code Bodies | S&A Qualification |  | 5.24 | Laura Kennedy | Complete | COMPLETE |  |  |  |
| 1920 | 1.6.1.3.1.6 | Qualification Assessment Document v1 approved by REC PAB and BSC PAB | milestone | 0d | 2024-03-28 A | 2024-03-28 A | 1919 | 100% |  | 2024-03-28 | 2024-03-28 | 0d |  |  |  | Code Bodies | Code Bodies | S&A Qualification |  | 5.24 | Laura Kennedy | Complete | COMPLETE | T3-QU-0066 | QAG | T3 |
| 1921 | 1.6.1.3.2 | **Qualification Assessment Document v3** |  | 110d | 2024-03-29 A | 2024-08-29 A |  | 100% |  | 2024-03-29 | 2024-08-29 | 110d |  |  | -0 | N/A | N/A | S&A Qualification | -131.67 | 5.24 | N/A |  |  |  |  |  |
| 1922 | 1.6.1.3.2.1 | Draft Qualification Assessment Document V1.1 |  | 26d | 2024-03-29 A | 2024-05-03 A | 1920 | 100% |  | 2024-03-29 | 2024-05-03 | 26d |  |  |  |  |  | S&A Qualification |  | 5.24 | Laura Kennedy | Complete | COMPLETE |  |  |  |
| 1923 | 1.6.1.3.2.2 | Industry Consultation for Qualification Assessment Document V1.1 |  | 12d | 2024-05-06 A | 2024-05-21 A | 1922 | 100% |  | 2024-05-06 | 2024-05-21 | 12d |  |  |  |  |  | S&A Qualification |  | 5.24 | Laura Kennedy | Complete | COMPLETE |  |  |  |
| 1924 | 1.6.1.3.2.3 | Draft Qualification Assessment Document v3 |  | 6d | 2024-06-14 A | 2024-06-21 A | 1211, 1923 | 100% |  | 2024-06-14 | 2024-06-21 | 6d |  |  |  | Code Bodies | Code Bodies | S&A Qualification |  | 5.24 | Laura Kennedy | Complete | COMPLETE |  |  |  |
| 1925 | 1.6.1.3.2.4 | Internal Review (Code Bodies and MHHSP) of Qualification Assessment Document v3 |  | 10d | 2024-06-24 A | 2024-07-05 A | 1924 | 100% |  | 2024-06-24 | 2024-07-05 | 10d |  |  |  | Code Bodies, SI Team, SRO | Code Bodies, SI Team, SRO | S&A Qualification |  | 5.24 | Laura Kennedy | Complete | COMPLETE |  |  |  |
| 1926 | 1.6.1.3.2.5 | Industry consultation for Qualification Assessment Document v3 |  | 10d | 2024-07-08 A | 2024-07-19 A | 1925 | 100% |  | 2024-07-08 | 2024-07-19 | 10d |  |  |  | Participants | Participants | S&A Qualification |  | 5.24 | Laura Kennedy | Complete | COMPLETE |  |  |  |
| 1927 | 1.6.1.3.2.6 | Update Post-Consultation for Qualification Assessment Document v3 |  | 10d | 2024-07-22 A | 2024-08-02 A | 1926 | 100% |  | 2024-07-22 | 2024-08-02 | 10d |  |  |  | Code Bodies | Code Bodies | S&A Qualification |  | 5.24 | Laura Kennedy | Complete | COMPLETE |  |  |  |
| 1928 | 1.6.1.3.2.7 | QWG Endorsement of Qualification Assessment Document v3 |  | 1d | 2024-08-13 A | 2024-08-13 A | 1927FS+6d | 100% |  | 2024-08-13 | 2024-08-13 | 1d |  |  |  | Code Bodies | Code Bodies | S&A Qualification |  | 5.24 | Laura Kennedy | Complete | COMPLETE |  |  |  |
| 1929 | 1.6.1.3.2.8 | QAG Endorsement of Qualification Assessment Document v3 |  | 1d | 2024-08-22 A | 2024-08-22 A | 1928FS+6d | 100% |  | 2024-08-22 | 2024-08-22 | 1d |  |  |  | Code Bodies | Code Bodies | S&A Qualification |  | 5.25 | Laura Kennedy | Complete | COMPLETE | T3-QU-0083 | QAG | T3 |
| 1930 | 1.6.1.3.2.9 | BSC and REC PAB Approval of Qualification Assessment Document v3 |  | 3d | 2024-08-27 A | 2024-08-29 A | 1929FS+2d | 100% |  | 2024-08-27 | 2024-08-29 | 3d |  |  |  | Code Bodies | Code Bodies | S&A Qualification |  | 5.24 | Laura Kennedy | Complete | COMPLETE |  |  |  |
| 1931 | 1.6.1.3.2.10 | Qualification Assessment Document v3 approved by REC PAB and BSC PAB | milestone | 0d | 2024-08-29 A | 2024-08-29 A | 1930 | 100% |  | 2024-08-29 | 2024-08-29 | 0d |  |  |  | Code Bodies | Code Bodies | S&A Qualification |  | 5.24 | Laura Kennedy | Complete | COMPLETE | T3-QU-0067 | QAG | T3 |

| ID | WBS | Task | Type | Duration | Start | Finish | Predecessors | Complete | Remaining | Baseline start | Baseline finish | Baseline duration | Baseline 1 start | Baseline 1 finish | Total slack | Free slack | Constraint | Baseline cost | Responsible | Involved | Text9 | Task Status | Update Version | MHHS Resource Name | Sched Status | RAG | Milestone ID | Text29 | Tier | MHHS Programme Phase |
| --- | --- | --- | --- | --- | --- | --- | --- | --- | --- | --- | --- | --- | --- | --- | --- | --- | --- | --- | --- | --- | --- | --- | --- | --- | --- | --- | --- | --- | --- | --- |
| 1932 | 1.6.1.3.3 | **Qualification Assessment Document Portal** |  | 445d | 2024-02-05 A | 2025-10-17 |  | 77% | 104.09d | 2024-02-05 | 2025-03-07 | 285d |  |  | 0d |  |  | -0 | N/A | N/A | S&A Qualification | -131.67 | 5.24 | N/A |  |  |  |  |  |  |
| 1933 | 1.6.1.3.3.1 | Design Completion |  | 30d | 2024-02-05 A | 2024-03-15 A |  | 100% |  | 2024-02-05 | 2024-03-15 | 30d |  |  |  |  | finish no earlier than 2024-03-15 |  | QAD Portal Dev Team | QAD Portal Dev Team | S&A Qualification |  | 5.24 | Laura Kennedy | Complete | COMPLETE |  |  |  |  |
| 1934 | 1.6.1.3.3.2 | Qualification Assessment Document Portal Build |  | 30d | 2024-03-18 A | 2024-04-26 A | 1933 | 100% |  | 2024-03-18 | 2024-04-26 | 30d |  |  |  |  |  |  | QAD Portal Dev Team | QAD Portal Dev Team | S&A Qualification |  | 5.24 | Laura Kennedy | Complete | COMPLETE |  |  |  |  |
| 1935 | 1.6.1.3.3.3 | Qualification Assessment Document Internal Testing |  | 20d | 2024-04-29 A | 2024-05-24 A | 1934 | 100% |  | 2024-04-29 | 2024-05-24 | 20d |  |  |  |  |  |  | QAD Portal Dev Team. Code Bodies | QAD Portal Dev Team. Code Bodies | S&A Qualification |  | 5.24 | Laura Kennedy | Complete | COMPLETE |  |  |  |  |
| 1936 | 1.6.1.3.3.4 | Qualification Assessment Document Portal Training and Onboarding Material Creation |  | 20d | 2024-05-27 A | 2024-06-21 A | 1935 | 100% |  | 2024-05-27 | 2024-06-21 | 20d |  |  |  |  |  |  | QAD Portal Dev Team | QAD Portal Dev Team | S&A Qualification |  | 5.24 | Laura Kennedy | Complete | COMPLETE |  |  |  |  |
| 1937 | 1.6.1.3.3.5 | Qualification Assessment Document Portal Webinar (Date TBC) |  | 1d | 2024-06-18 A | 2024-06-18 A |  | 100% |  | 2024-06-18 | 2024-06-18 | 1d |  |  |  |  | start no earlier than 2024-06-18 |  | QAD Portal Dev Team | QAD Portal Dev Team | S&A Qualification |  | 5.24 | Laura Kennedy | Complete | COMPLETE |  |  |  |  |
| 1938 | 1.6.1.3.3.6 | SIT Participant QAD Application Creation in Portal |  | 10d | 2024-12-09 A | 2024-12-20 A | 1936FS+120d | 100% |  | 2024-12-09 | 2024-12-20 | 10d |  |  |  |  |  |  | Code Bodies | Code Bodies | S&A Qualification |  | 5.24 | Laura Kennedy | Complete | COMPLETE |  |  |  |  |
| 1939 | 1.6.1.3.3.7 | Non-SIT LDSO Participant QAD Application Creation in Portal |  | 10d | 2024-12-09 A | 2024-12-20 A | 1936FS+120d | 100% |  | 2024-12-09 | 2024-12-20 | 10d |  |  |  |  |  |  | Code Bodies | Code Bodies | S&A Qualification |  | 5.24 | Laura Kennedy | Complete | COMPLETE |  |  |  |  |
| 1940 | 1.6.1.3.3.8 | QT Wave 1 Participant QAD Application Creation in Portal |  | 10d | 2025-04-21 | 2025-05-02 | 1936FS+215d |  |  | 2025-04-21 | 2025-05-02 | 10d |  |  | 1d | 0d |  |  | Code Bodies | Code Bodies | S&A Qualification | 82.33 | 6.1 | Laura Kennedy | Green | GREEN |  |  |  |  |
| 1941 | 1.6.1.3.3.9 | QT Wave 2 Participant QAD Application Creation in Portal |  | 10d | 2025-05-26 | 2025-06-06 | 1936FS+240d |  |  | 2025-05-26 | 2025-06-06 | 10d |  |  | 0d |  |  |  | Code Bodies | Code Bodies | S&A Qualification | 117.33 | 6.1 | Laura Kennedy | Green | GREEN |  |  |  |  |
| 1942 | 1.6.1.3.3.10 | QT Wave 3 Participant QAD Application Creation in Portal |  | 10d | 2025-07-28 | 2025-08-08 | 1936FS+285d |  |  | 2025-07-28 | 2025-08-08 | 10d |  |  | 0d |  |  |  | Code Bodies | Code Bodies | S&A Qualification | 180.33 | 6.1 | Laura Kennedy | Green | GREEN |  |  |  |  |
| 1943 | 1.6.1.3.3.11 | QT Wave 4 Participant QAD Application Creation in Portal |  | 10d | 2025-10-06 | 2025-10-17 | 1936FS+335d |  |  | 2025-10-06 | 2025-10-17 | 10d |  |  | 0d |  |  |  | Code Bodies | Code Bodies | S&A Qualification | 250.33 | 6.1 | Laura Kennedy | Green | GREEN |  |  |  |  |
| 1944 | 1.6.1.3.3.12 | Update to Qualification Assessment Document Portal post QAD V3 |  | 10d | 2024-08-30 A | 2024-09-12 A | 1931 | 100% |  | 2024-08-30 | 2024-09-12 | 10d |  |  |  |  |  |  | QAD Portal Dev Team | QAD Portal Dev Team | S&A Qualification |  | 6.1 | Laura Kennedy | Complete | COMPLETE |  |  |  |  |
| 1945 | 1.6.1.3.3.13 | Update to Qualification Assessment Document Portal post QAD V3 Complete | milestone | 0d | 2024-09-12 A | 2024-09-12 A | 1944 | 100% |  | 2024-09-12 | 2024-09-12 | 0d |  |  |  |  |  |  | QAD Portal Dev Team | QAD Portal Dev Team | S&A Qualification |  | 6.1 | Laura Kennedy | Complete | COMPLETE | T3-QU-0084 | QAG | T3 |  |
| 1946 | 1.6.2 | **MHHS Qualification - SIT Participants** |  | 249d | 2025-01-06 A | 2025-12-18 |  | 7% | 232.55d | 2025-01-06 | 2025-12-22 | 194d | 2024-01-29 | 2024-07-05 | 0d |  |  | -0 | N/A | N/A | S&A Qualification | -133.67 | 6.11 | N/A |  |  |  |  |  | Systems Integration Testing (SIT) |
| 1947 | 1.6.2.1 | Initial QAD Submission Window opens | milestone | 0d | 2025-01-06 A | 2025-01-06 A | 1938FS+10d | 100% |  | 2025-01-06 | 2025-01-06 | 0d |  |  |  |  | start no earlier than 2025-01-06 |  | Participants | Participants | S&A Qualification |  | 6.11 | Laura Kennedy | Complete | COMPLETE |  |  |  |  |
| 1948 | 1.6.2.2 | SIT Participants submit Initial QAD |  | 30d | 2025-01-06 A | 2025-02-14 |  | 50% | 15d | 2025-01-06 | 2025-02-14 | 29d |  |  | 55d | 0d | start no earlier than 2025-01-06 |  | Participants | Participants | S&A Qualification |  | 6.11 | Laura Kennedy | Green | GREEN |  |  |  |  |
| 1949 | 1.6.2.3 | Code Bodies review Initial QAD |  | 36d | 2025-02-14 | 2025-04-04 | 1948FS-1d |  |  | 2025-02-14 | 2025-04-04 | 36d |  |  | 55d | 0d |  |  | Code Bodies | Code Bodies | S&A Qualification | 16.33 | 6.11 | Laura Kennedy | Green | GREEN |  |  |  |  |
| 1950 | 1.6.2.4 | Completion of Code Bodies review of Initial QAD | milestone | 0d | 2025-04-04 | 2025-04-04 | 1949 |  |  | 2025-04-04 | 2025-04-04 | 0d |  |  | 55d | 0d |  |  | Code Bodies | Code Bodies | S&A Qualification | 65.71 | 6.11 | Laura Kennedy | Green | GREEN |  |  |  |  |
| 1951 | 1.6.2.5 | **MHHS Qualification - SIT MVC Participants** |  | 114d | 2025-04-07 | 2025-09-11 |  |  |  | 2025-04-07 | 2025-09-11 | 64d |  |  | 0d |  |  |  | N/A | N/A | S&A Qualification | -154.67 | 6.11 | N/A |  |  |  |  |  |  |
| 1952 | 1.6.2.5.1 | Final QAD Submission Window (MVC) opens | milestone | 0d | 2025-04-07 | 2025-04-07 | 1949, 1945, 1950FS+1d |  |  | 2025-04-07 | 2025-04-07 | 0d |  |  | 55d | 0d |  |  | Participants | Participants | S&A Qualification | 68.71 | 6.11 | Laura Kennedy | Green | GREEN |  |  |  |  |
| 1953 | 1.6.2.5.2 | SIT MVC Participants submit Final QAD (exc Test Reports) |  | 25d | 2025-04-07 | 2025-05-09 | 1952FS-1d |  |  | 2025-04-07 | 2025-05-09 | 26d |  |  | 55d | 0d |  |  | Participants | Participants | S&A Qualification | 68.33 | 6.11 | Laura Kennedy | Green | GREEN |  |  |  |  |
| 1954 | 1.6.2.5.3 | Completion of Code Bodies review of Final QAD (MVC) |  | 20d | 2025-05-12 | 2025-06-06 | 1953 |  |  | 2025-05-12 | 2025-06-06 | 19d |  |  | 55d |  |  |  | Code Bodies | Code Bodies | S&A Qualification | 103.33 | 6.11 | Laura Kennedy | Green | GREEN |  |  |  |  |
| 1955 | 1.6.2.5.4 | QAD Sign Off Deadline (MVC) + Test Reports | milestone | 0d | 2025-08-22 | 2025-08-22 | 1645, 1954, 1636 |  |  | 2025-08-22 | 2025-08-22 | 1d |  |  | 0d |  | start no earlier than 2025-07-11 |  | Participants | Participants | S&A Qualification | 205.71 | 6.11 | Laura Kennedy | Green | GREEN |  |  |  |  |
| 1956 | 1.6.2.5.5 | REC Code Manager / BSC PAB Approval of Qualification (MVC) | milestone | 0d | 2025-09-11 | 2025-09-11 | 1955FS+14d |  |  | 2025-09-11 | 2025-09-11 | 0d |  |  | 0d |  |  |  | Code Bodies | Code Bodies | S&A Qualification | 225.71 | 6.11 | Laura Kennedy | Green | GREEN | T3-QU-0085 | QAG | T3 |  |

| ID | WBS | Task | Type | Duration | Start | Finish | Predecessors | Complete | Remaining | Baseline start | Baseline finish | Baseline duration | Total slack | Free slack | Constraint | Baseline cost | Responsible | Involved | Text9 | Task Status | Update Version | MHHS Resource Name | Sched Status | RAG | Milestone ID | Text29 | Tier |
| --- | --- | --- | --- | --- | --- | --- | --- | --- | --- | --- | --- | --- | --- | --- | --- | --- | --- | --- | --- | --- | --- | --- | --- | --- | --- | --- | --- |
| 1957 | 1.6.2.6 | **MHHS Qualification - SIT Non-MVC Participants** |  | 154d | 2025-05-19 | 2025-12-18 |  |  |  | 2025-05-19 | 2025-12-22 | 129d | 0d |  |  |  | N/A | N/A | S&A Qualification | -154.67 | 6.11 | N/A |  |  |  |  |  |
| 1958 | 1.6.2.6.1 | Final QAD Submission Window (Non-MVC) opens | milestone | 0d | 2025-05-19 | 2025-05-19 | 1950FS+31d |  |  | 2025-05-19 | 2025-05-19 | 0d | 109d | 0d |  |  | Participants | Participants | S&A Qualification | 110.71 | 6.11 | Laura Kennedy | Green | GREEN |  |  |  |
| 1959 | 1.6.2.6.2 | SIT Non-MVC Participants submit Final QAD |  | 90d | 2025-05-19 | 2025-09-19 | 1958SS-1d |  |  | 2025-05-19 | 2025-09-19 | 86d | 20d | 0d |  |  | Participants | Participants | S&A Qualification | 110.33 | 6.11 | Laura Kennedy | Green | GREEN |  |  |  |
| 1960 | 1.6.2.6.3 | Completion of Code Bodies review of Final QAD (Non-MVC) |  | 25d | 2025-09-22 | 2025-10-24 | 1959 |  |  | 2025-09-22 | 2025-10-24 | 19d | 20d |  |  |  | Code Bodies | Code Bodies | S&A Qualification | 236.33 | 6.11 | Laura Kennedy | Green | GREEN |  |  |  |
| 1961 | 1.6.2.6.4 | QAD Sign Off Deadline (Non-MVC) |  | 1d | 2025-11-28 | 2025-11-28 | 1960FS+4d, 1667 |  |  | 2025-11-28 | 2025-11-28 | 1d | 0d |  |  |  | Participants | Participants | S&A Qualification | 303.33 | 6.11 | Laura Kennedy | Green | GREEN |  |  |  |
| 1962 | 1.6.2.6.5 | REC Code Manager / BSC PAB Approval of Qualification (Non-MVC) | milestone | 0d | 2025-12-18 | 2025-12-18 | 1961FS+14d |  |  | 2025-12-22 | 2025-12-22 | 0d | 0d |  |  |  | Code Bodies | Code Bodies | S&A Qualification | 323.71 | 6.11 | Laura Kennedy | Green | GREEN | T3-QU-0086 | QAG | T3 |
| 1963 | 1.6.3 | **MHHS Qualification - Non-SIT LDSO** |  | 178d | 2025-01-06 A | 2025-09-10 |  | 14% | 153.73d | 2025-01-06 | 2025-09-11 | 115d | 4d |  |  | -0 | N/A | N/A | S&A Qualification | -133.67 | 6.11 | N/A |  |  |  |  |  |
| 1964 | 1.6.3.1 | Initial QAD Submission window opens | milestone | 0d | 2025-01-06 A | 2025-01-06 A | 1939FS+11d | 100% |  | 2025-01-06 | 2025-01-06 | 0d |  |  |  |  | Participants | Participants | S&A Qualification |  | 6.11 | Laura Kennedy | Complete | COMPLETE |  |  |  |
| 1965 | 1.6.3.2 | Non-SIT LDSO Participants submit initial QAD |  | 30d | 2025-01-06 A | 2025-02-14 |  | 50% | 15d | 2025-01-06 | 2025-02-14 | 29d | 53d | 0d | start no earlier than 2025-01-06 |  | Participants | Participants | S&A Qualification |  | 6.11 | Laura Kennedy | Green | GREEN |  |  |  |
| 1966 | 1.6.3.3 | Non-SIT LDSO QT Participants have submitted their initial QAD | milestone | 0d | 2025-02-14 | 2025-02-14 | 1965 |  |  | 2025-02-14 | 2025-02-14 | 0d | 53d | 0d |  |  | Participants | Participants | S&A Qualification | 16.71 | 6.11 | Laura Kennedy | Green | GREEN | T3-QU-0087 | QAG | T3 |
| 1967 | 1.6.3.4 | Code Bodies review of Non-SIT LDSO participants Initial QAD |  | 35d | 2025-02-17 | 2025-04-04 | 1966 |  |  | 2025-02-17 | 2025-04-04 | 36d | 53d | 0d |  |  | Code Bodies | Code Bodies | S&A Qualification | 19.33 | 6.11 | Laura Kennedy | Green | GREEN |  |  |  |
| 1968 | 1.6.3.5 | Completion of Code Bodies review of Initial QAD | milestone | 0d | 2025-04-04 | 2025-04-04 | 1967 |  |  | 2025-04-04 | 2025-04-04 | 0d | 53d | 0d |  |  | Code Bodies | Code Bodies | S&A Qualification | 65.71 | 6.11 | Laura Kennedy | Green | GREEN |  |  |  |
| 1969 | 1.6.3.6 | Final QAD Submission window opens | milestone | 0d | 2025-04-07 | 2025-04-07 | 1968FS+1d |  |  | 2025-04-07 | 2025-04-07 | 0d | 53d | 9d |  |  | Participants | Participants | S&A Qualification | 68.71 | 6.11 | Laura Kennedy | Green | GREEN |  |  |  |
| 1970 | 1.6.3.7 | Non-SIT LDSO Participants submit Final QAD |  | 25d | 2025-04-21 | 2025-05-23 | 1878SS, 1969SS |  |  | 2025-04-21 | 2025-05-23 | 26d | 44d | 0d |  |  | Participants | Participants | S&A Qualification | 82.33 | 6.11 | Laura Kennedy | Green | GREEN |  |  |  |
| 1971 | 1.6.3.8 | Non-SIT LDSO QT Participants have submitted their final QAD | milestone | 0d | 2025-05-23 | 2025-05-23 | 1970 |  |  | 2025-05-23 | 2025-05-23 | 0d | 44d | 0d |  |  | Participants | Participants | S&A Qualification | 114.71 | 6.11 | Laura Kennedy | Green | GREEN | T3-QU-0088 | QAG | T3 |
| 1972 | 1.6.3.9 | Completion of Code Bodies review of the Final QAD |  | 20d | 2025-05-26 | 2025-06-20 | 1971 |  |  | 2025-05-26 | 2025-06-20 | 19d | 44d | 40d |  |  | Code Bodies | Code Bodies | S&A Qualification | 117.33 | 6.11 | Laura Kennedy | Green | GREEN |  |  |  |
| 1973 | 1.6.3.10 | QAD Sign Off Deadline (Non-SIT LDSOs) | milestone | 0d | 2025-08-22 | 2025-08-22 | 1972FS+5d, 1645, 1875 |  |  | 2025-08-22 | 2025-08-22 | 1d | 4d | 0d |  |  | Participants | Participants | S&A Qualification | 205.71 | 6.11 | Laura Kennedy | Green | GREEN |  |  |  |
| 1974 | 1.6.3.11 | BSC PAB & REC Manager approval of Qualification for Non-SIT LDSOs | milestone | 0d | 2025-09-10 | 2025-09-10 | 1973FS+13d |  |  | 2025-09-11 | 2025-09-11 | 0d | 4d | 0d |  |  | Non-SIT LDSO | Non-SIT LDSO | S&A Qualification | 224.71 | 6.12 | Ben Wickins | Green | GREEN | T2-QU-0500 | QAG (Non-SIT LDSO) | T2 |
| 1975 | 1.6.4 | **MHHS Qualification - Qualification Waves** |  | 814d? | 2023-12-18 A | 2027-01-28 |  | 55% | 369.84d? | 2023-12-18 | 2027-01-28 | 574d | 235d |  |  | -0 | N/A | N/A | S&A Qualification | -131.67 | 5.24 | N/A |  |  |  |  |  |
| 1976 | 1.6.4.1 | **Qualification Wave Prep** |  | 539d? | 2023-12-18 A | 2026-01-08 |  | 88% | 63.69d? | 2023-12-18 | 2025-12-26 | 424d | 510d |  |  | -0 | N/A | N/A | S&A Qualification | -131.67 | 5.24 | N/A |  |  |  |  |  |
| 1977 | 1.6.4.1.1 | **Non-SIT Supplier and Agent Test Approach and Plan** |  | 119d | 2023-12-18 A | 2024-05-30 A |  | 100% |  | 2023-12-18 | 2024-05-30 | 118d |  |  |  | -0 | N/A | N/A | S&A Qualification | -133.67 | 5.24 | N/A |  |  |  |  |  |
| 1978 | 1.6.4.1.1.1 | Draft Non-SIT S&A Test Approach and Plan |  | 50d | 2023-12-18 A | 2024-02-23 A |  | 100% |  | 2023-12-18 | 2024-02-23 | 50d |  |  | finish no earlier than 2024-02-23 |  | Non-SIT S&A QT Test Team | Non-SIT S&A QT Test Team | S&A Qualification |  | 5.24 | Laura Kennedy | Complete | COMPLETE |  |  |  |
| 1979 | 1.6.4.1.1.2 | Internal Review of Non-SIT S&A Test Approach and Plan (Code Bodies and MHHSP) |  | 10d | 2024-02-26 A | 2024-03-08 A | 1978 | 100% |  | 2024-02-26 | 2024-03-08 | 10d |  |  |  |  | Code Bodies, SI Team, SRO | Code Bodies, SI Team, SRO | S&A Qualification |  | 5.24 | Laura Kennedy | Complete | COMPLETE |  |  |  |
| 1980 | 1.6.4.1.1.3 | Issue Non-SIT S&A Test Approach and Plan for Consultation |  | 15d | 2024-03-18 A | 2024-04-05 A | 1979 | 100% |  | 2024-03-18 | 2024-04-05 | 15d |  |  | start no earlier than 2024-03-18 |  | Participants | Participants | S&A Qualification |  | 5.24 | Laura Kennedy | Complete | COMPLETE |  |  |  |
| 1981 | 1.6.4.1.1.4 | Update Non-SIT S&A Test Approach and Plan Post-Consultation |  | 10d | 2024-04-08 A | 2024-04-19 A | 1980 | 100% |  | 2024-04-08 | 2024-04-19 | 10d |  |  |  |  | Non-SIT S&A QT Test Team | Non-SIT S&A QT Test Team | S&A Qualification |  | 5.24 | Laura Kennedy | Complete | COMPLETE |  |  |  |
| 1982 | 1.6.4.1.1.5 | QWG Endorsement of Non-SIT S&A Test Approach and Plan |  | 1d | 2024-05-14 A | 2024-05-14 A |  | 100% |  | 2024-05-14 | 2024-05-14 | 1d |  |  | finish no earlier than 2024-05-14 |  | Non-SIT S&A QT Test Team | Non-SIT S&A QT Test Team | S&A Qualification |  | 5.24 | Laura Kennedy | Complete | COMPLETE |  |  |  |
| 1983 | 1.6.4.1.1.6 | QAG Approval of Non-SIT S&A Test Approach and Plan | milestone | 0d | 2024-05-23 A | 2024-05-23 A | 1982FS+7d | 100% |  | 2024-05-23 | 2024-05-23 | 0d |  |  |  |  | Non-SIT S&A QT Test Team | Non-SIT S&A QT Test Team | S&A Qualification |  | 5.25 | Laura Kennedy | Complete | COMPLETE | T3-QU-0089 | QAG | T3 |
| 1984 | 1.6.4.1.1.7 | BSC & REC PAB Approval of Non-SIT S&A Test Approach and Plan | milestone | 0d | 2024-05-30 A | 2024-05-30 A | 1983FS+5d | 100% |  | 2024-05-30 | 2024-05-30 | 0d |  |  |  |  | Code Bodies | Code Bodies | S&A Qualification |  | 5.25 | Laura Kennedy | Complete | COMPLETE | T3-QU-0090 | QAG | T3 |

| ID | WBS | Task | Type | Duration | Start | Finish | Predecessors | Complete | Remaining | Baseline start | Baseline finish | Baseline duration | Total slack | Free slack | Constraint | Baseline cost | Responsible | Involved | Text9 | Task Status | Update Version | MHHS Resource Name | Sched Status | RAG | Milestone ID | Text29 | Tier |
| --- | --- | --- | --- | --- | --- | --- | --- | --- | --- | --- | --- | --- | --- | --- | --- | --- | --- | --- | --- | --- | --- | --- | --- | --- | --- | --- | --- |
| 1985 | 1.6.4.1.2 | **QT Test Data Approach and Plan** |  | 64d | 2024-04-19 A | 2024-07-18 A |  | 100% |  | 2024-04-19 | 2024-07-18 | 64d |  |  |  | -0 | N/A | N/A | S&A Qualification | -133.67 | 5.24 | N/A |  |  |  |  |  |
| 1986 | 1.6.4.1.2.1 | QT Test Data Approach agreed as part of the Non-SIT Supplier and Agent Test Approach and Plan | milestone | 0d | 2024-04-19 A | 2024-04-19 A | 1981 | 100% |  | 2024-04-19 | 2024-04-19 | 0d |  |  |  |  | Non-SIT S&A QT Test Team, Participants | Non-SIT S&A QT Test Team, Participants | S&A Qualification |  | 5.24 | Laura Kennedy | Complete | COMPLETE |  |  |  |
| 1987 | 1.6.4.1.2.2 | Draft Test Data Approach and Plan for QT |  | 10d | 2024-05-06 A | 2024-05-17 A | 1986 | 100% |  | 2024-05-06 | 2024-05-17 | 10d |  |  |  |  | Non-SIT S&A QT Test Team | Non-SIT S&A QT Test Team | S&A Qualification |  | 5.24 | Laura Kennedy | Complete | COMPLETE |  |  |  |
| 1988 | 1.6.4.1.2.3 | Internal Review (Code Bodies and MHHSP) of QT Test Data Approach and Plan |  | 15d | 2024-05-20 A | 2024-06-07 A | 1987 | 100% |  | 2024-05-20 | 2024-06-07 | 10d |  |  |  |  | Code Bodies, SI Team, SRO | Code Bodies, SI Team, SRO | S&A Qualification |  | 5.24 | Laura Kennedy | Complete | COMPLETE |  |  |  |
| 1989 | 1.6.4.1.2.4 | Issue QT Test Data Approach and Plan for Industry Consultation |  | 10d | 2024-06-10 A | 2024-06-21 A | 1988 | 100% |  | 2024-06-10 | 2024-06-21 | 10d |  |  |  |  | Participants | Participants | S&A Qualification |  | 5.24 | Laura Kennedy | Complete | COMPLETE |  |  |  |
| 1990 | 1.6.4.1.2.5 | Update QT Test Approach and Plan Post Industry Consultation |  | 5d | 2024-06-24 A | 2024-06-28 A | 1989 | 100% |  | 2024-06-24 | 2024-06-28 | 10d |  |  |  |  | Non-SIT S&A QT Team | Non-SIT S&A QT Team | S&A Qualification |  | 5.24 | Laura Kennedy | Complete | COMPLETE |  |  |  |
| 1991 | 1.6.4.1.2.6 | QWG Endorsement of Test Data Approach and Plan |  | 1d | 2024-07-09 A | 2024-07-09 A | 1990FS+6d | 100% |  | 2024-07-09 | 2024-07-09 | 1d |  |  |  |  | Non-SIT S&A QT Test Team | Non-SIT S&A QT Test Team | S&A Qualification |  | 5.24 | Laura Kennedy | Complete | COMPLETE |  |  |  |
| 1992 | 1.6.4.1.2.7 | QAG Approval of QT Test Data Approach and Plan | milestone | 0d | 2024-07-18 A | 2024-07-18 A | 1991FS+7d | 100% |  | 2024-07-18 | 2024-07-18 | 0d |  |  |  |  | Non-SIT S&A QT Test Team | Non-SIT S&A QT Test Team | S&A Qualification |  | 5.29 | Laura Kennedy | Complete | COMPLETE | T3-QU-0091 | QAG | T3 |
| 1993 | 1.6.4.1.3 | **QT Functional Test Scenarios and Test Cases** |  | 59d | 2024-03-04 A | 2024-05-23 A |  | 100% |  | 2024-03-04 | 2024-05-23 | 59d |  |  |  | -0 | N/A | N/A | S&A Qualification | -133.67 | 5.24 | N/A |  |  |  |  |  |
| 1994 | 1.6.4.1.3.1 | Draft Test Scenarios and Test Case list - Batch 1 |  | 10d | 2024-03-04 A | 2024-03-15 A |  | 100% |  | 2024-03-04 | 2024-03-15 | 10d |  |  | finish no earlier than 2024-03-15 |  | Non-SIT S&A QT Test Team, Code Bodies | Non-SIT S&A QT Test Team, Code Bodies | S&A Qualification |  | 5.24 | Laura Kennedy | Complete | COMPLETE |  |  |  |
| 1995 | 1.6.4.1.3.2 | Issue Batch 1 for Consultation |  | 15d | 2024-03-18 A | 2024-04-05 A | 1994 | 100% |  | 2024-03-18 | 2024-04-05 | 15d |  |  | start no earlier than 2024-03-18 |  | Participants | Participants | S&A Qualification |  | 5.24 | Laura Kennedy | Complete | COMPLETE |  |  |  |
| 1996 | 1.6.4.1.3.3 | Gap analysis against QT Requirements |  | 8d | 2024-03-18 A | 2024-03-27 A | 1994 | 100% |  | 2024-03-18 | 2024-03-27 | 8d |  |  |  |  | Non-SIT S&A QT Test Team | Non-SIT S&A QT Test Team | S&A Qualification |  | 5.24 | Laura Kennedy | Complete | COMPLETE |  |  |  |
| 1997 | 1.6.4.1.3.4 | Update Test Scenarios and Test Case list - Batch 2 |  | 6d | 2024-03-28 A | 2024-04-04 A | 1996 | 100% |  | 2024-03-28 | 2024-04-04 | 6d |  |  |  |  | Non-SIT S&A QT Test Team, Code Bodies | Non-SIT S&A QT Test Team, Code Bodies | S&A Qualification |  | 5.24 | Laura Kennedy | Complete | COMPLETE |  |  |  |
| 1998 | 1.6.4.1.3.5 | Issue Batch 2 for consultation |  | 10d | 2024-04-05 A | 2024-04-18 A | 1997 | 100% |  | 2024-04-05 | 2024-04-18 | 10d |  |  |  |  | Participants | Participants | S&A Qualification |  | 5.24 | Laura Kennedy | Complete | COMPLETE |  |  |  |
| 1999 | 1.6.4.1.3.6 | Update Batch 2 post consultation |  | 10d | 2024-04-19 A | 2024-05-02 A | 1998 | 100% |  | 2024-04-19 | 2024-05-02 | 10d |  |  |  |  | Non-SIT S&A QT Test Team, Code Bodies | Non-SIT S&A QT Test Team, Code Bodies | S&A Qualification |  | 5.24 | Laura Kennedy | Complete | COMPLETE |  |  |  |
| 2000 | 1.6.4.1.3.7 | QWG Endorsement of Batch 1 and 2 |  | 1d | 2024-05-14 A | 2024-05-14 A |  | 100% |  | 2024-05-14 | 2024-05-14 | 1d |  |  | finish no earlier than 2024-05-14 |  | Non-SIT S&A QT Test Team | Non-SIT S&A QT Test Team, Code Bodies, Participants | S&A Qualification |  | 5.24 | Laura Kennedy | Complete | COMPLETE |  |  |  |
| 2001 | 1.6.4.1.3.8 | QAG Approval of QT Functional Test Scenarios and Test Cases Batches 1 and 2 | milestone | 0d | 2024-05-23 A | 2024-05-23 A | 2000FS+7d | 100% |  | 2024-05-23 | 2024-05-23 | 0d |  |  |  |  | Non-SIT S&A QT Test Team | Non-SIT S&A QT Test Team, Code Bodies, Participants | S&A Qualification |  | 5.25 | Laura Kennedy | Complete | COMPLETE | T3-QU-0092 | QAG | T3 |
| 2002 | 1.6.4.1.4 | **QT Migration Test Scenarios and Test Cases** |  | 54d | 2024-05-06 A | 2024-07-18 A |  | 100% |  | 2024-05-06 | 2024-07-18 | 54d |  |  |  |  | N/A | N/A | S&A Qualification |  | 5.25 | N/A |  |  |  |  |  |
| 2003 | 1.6.4.1.4.1 | Draft Test Scenarios and Test Case list - Batch 1 |  | 20d | 2024-05-06 A | 2024-05-31 A | 1014FS+12d | 100% |  | 2024-05-06 | 2024-05-31 | 20d |  |  |  |  | Non-SIT S&A QT Test Team, Code Bodies | Non-SIT S&A QT Test Team, Code Bodies | S&A Qualification |  | 5.25 | Laura Kennedy | Complete | COMPLETE |  |  |  |
| 2004 | 1.6.4.1.4.2 | Issue Batch 1 for Consultation |  | 10d | 2024-06-03 A | 2024-06-14 A | 2003 | 100% |  | 2024-06-03 | 2024-06-14 | 10d |  |  |  |  | Participants | Participants | S&A Qualification |  | 5.25 | Laura Kennedy | Complete | COMPLETE |  |  |  |
| 2005 | 1.6.4.1.4.3 | Update Batch 1 Post Consultation |  | 10d | 2024-06-17 A | 2024-06-28 A | 2004 | 100% |  | 2024-06-17 | 2024-06-28 | 10d |  |  |  |  | Non-SIT S&A QT Test Team | Non-SIT S&A QT Test Team | S&A Qualification |  | 5.25 | Laura Kennedy | Complete | COMPLETE |  |  |  |
| 2006 | 1.6.4.1.4.4 | QWG Endorsement of Batch 1 | milestone | 0d | 2024-07-09 A | 2024-07-09 A | 2005FS+7d | 100% |  | 2024-07-09 | 2024-07-09 | 0d |  |  |  |  | Non-SIT S&A QT Test Team | Non-SIT S&A QT Test Team, Code Bodies, Participants | S&A Qualification |  | 5.25 | Laura Kennedy | Complete | COMPLETE |  |  |  |
| 2007 | 1.6.4.1.4.5 | QAG Approval of QT Migration Test Scenarios and Test Cases Batches 1 | milestone | 0d | 2024-07-18 A | 2024-07-18 A | 2006FS+7d | 100% |  | 2024-07-18 | 2024-07-18 | 0d |  |  |  |  | Non-SIT S&A QT Test Team | Non-SIT S&A QT Test Team, Code Bodies, Participants | S&A Qualification |  | 5.29 | Laura Kennedy | Complete | COMPLETE | T3-QU-0119 | QAG | T3 |
| 2008 | 1.6.4.1.5 | **QT Functional (inc NF and Operational) Test Scenarios and Test Cases** |  | 77d | 2024-11-05 A | 2025-02-20 |  | 99% | 0d | 2024-11-04 | 2024-12-27 | 0d | 722d |  |  |  | Non-SIT S&A QT Test Team |  | S&A Qualification | -721.67 |  | Laura Kennedy |  |  |  |  |  |
| 2009 | 1.6.4.1.5.1 | Draft Test Scenarios and Test Case list - Batch 3 |  | 20d | 2024-11-05 A | 2024-12-02 A | 901FS-1d | 100% |  | 2024-11-05 | 2024-12-02 | 0d |  |  |  |  | Non-SIT S&A QT Test Team |  | S&A Qualification |  | 6.11 | Laura Kennedy | Complete | COMPLETE |  |  |  |
| 2010 | 1.6.4.1.5.2 | Issue Batch 3 for Consultation |  | 10d | 2024-12-03 A | 2024-12-16 A | 2009 | 100% |  | 2024-12-03 | 2024-12-16 | 0d |  |  |  |  | Non-SIT S&A QT Test Team |  | S&A Qualification |  | 6.11 | Laura Kennedy | Complete | COMPLETE |  |  |  |
| 2011 | 1.6.4.1.5.3 | Update Batch 3 Post Consultation |  | 20d | 2024-12-17 A | 2025-01-13 A | 2010 | 100% |  | 2024-12-17 | 2025-01-13 | 0d |  |  |  |  | Non-SIT S&A QT Test Team |  | S&A Qualification |  | 6.11 | Laura Kennedy | Complete | COMPLETE |  |  |  |
| 2012 | 1.6.4.1.5.4 | QWG Endorsement of Batch 3 | milestone | 0d | 2025-02-11 | 2025-02-11 | 2011FS+21d |  |  | 2025-02-11 | 2025-02-11 | 0d | 722d | 0d |  |  | Non-SIT S&A QT Test Team |  | S&A Qualification | 13.71 | 6.11 | Laura Kennedy | Green | GREEN |  |  |  |
| 2013 | 1.6.4.1.5.5 | QAG Approval of QT Functional Test Scenarios and Test Cases Batches 3 | milestone | 0d | 2025-02-20 | 2025-02-20 | 2012FS+6d |  |  | 2025-02-20 | 2025-02-20 | 0d | 722d | 0d | start no earlier than 2025-02-20 |  | Non-SIT S&A QT Test Team |  | S&A Qualification | 22.33 | 6.11 | Laura Kennedy | Green | GREEN | T3-QU-0123 | QAG | T3 |

Notes:
- 2013: 28/01/25 - QAG approval will now take place in February on 20/02/25, origional aim was January QAG but delayed because of SIT Functional RTTM which has been adding adding additional test cases, delaying drafting of test scenarios and test case list.

| ID | WBS | Task | Duration | Start | Finish | Predecessors | Complete | Remaining | Baseline start | Baseline finish | Baseline duration | Total slack | Free slack | Constraint | Responsible | Text9 | Task Status | Update Version | MHHS Resource Name | Sched Status | RAG |
| --- | --- | --- | --- | --- | --- | --- | --- | --- | --- | --- | --- | --- | --- | --- | --- | --- | --- | --- | --- | --- | --- |
| 2014 | 1.6.4.1.6 | **Qualification Testing Framework (Test Stubs and Supporting UI)** | 509d? | 2024-01-29 A | 2026-01-08 |  | 86% | 70.42d? | 2024-01-29 | 2026-01-08 | 0d | 510d |  |  | Non-SIT S&A QT Test Team | S&A Qualification | -742.67 | 6.12 | Laura Kennedy |  |  |
| 2015 | 1.6.4.1.6.1 | Proof of Concept for QTF Completion | 45d | 2024-01-29 A | 2024-03-29 A |  | 100% |  | 2024-01-29 | 2024-03-29 | 0d |  |  | finish no earlier than 2024-03-29 | Non-SIT S&A QT Test Team | S&A Qualification |  | 6.12 | Laura Kennedy | Complete | COMPLETE |
| 2016 | 1.6.4.1.6.2 | Discovery and Mobilisation | 25d | 2024-04-01 A | 2024-05-03 A | 2015 | 100% |  | 2024-04-01 | 2024-05-03 | 0d |  |  | finish no earlier than 2024-05-03 | Non-SIT S&A QT Test Team | S&A Qualification |  | 6.12 | Laura Kennedy | Complete | COMPLETE |
| 2017 | 1.6.4.1.6.3 | **Agile DBT of Qualification Testing Framework** | 83d | 2024-04-24 A | 2024-08-16 A |  | 100% |  | 2024-04-24 | 2024-08-16 | 0d |  |  |  | Non-SIT S&A QT Test Team | S&A Qualification | -742.67 | 6.12 | Laura Kennedy |  |  |
| 2018 | 1.6.4.1.6.3.1 | **User Interface (UI)** | 48d | 2024-04-24 A | 2024-06-28 A |  | 100% |  | 2024-04-24 | 2024-06-28 | 0d |  |  |  | Non-SIT S&A QT Test Team | S&A Qualification | -742.67 | 6.12 | Laura Kennedy |  |  |
| 2019 | 1.6.4.1.6.3.1.1 | UI Wireframe | 48d | 2024-04-24 A | 2024-06-28 A |  | 100% |  | 2024-04-24 | 2024-06-28 | 0d |  |  | finish no earlier than 2024-06-28 | Non-SIT S&A QT Test Team | S&A Qualification |  | 6.12 | Laura Kennedy | Complete | COMPLETE |
| 2020 | 1.6.4.1.6.3.1.2 | UI Standards | 35d | 2024-05-13 A | 2024-06-28 A | 2019FS+13d | 100% |  | 2024-05-13 | 2024-06-28 | 0d |  |  | finish no earlier than 2024-06-28 | Non-SIT S&A QT Test Team | S&A Qualification |  | 6.12 | Laura Kennedy | Complete | COMPLETE |
| 2021 | 1.6.4.1.6.3.1.3 | Elexon Branding Sylesheet | 2d | 2024-05-17 A | 2024-05-20 A | 2020FS+10d | 100% |  | 2024-05-17 | 2024-05-20 | 0d |  |  | finish no earlier than 2024-05-20 | Non-SIT S&A QT Test Team | S&A Qualification |  | 6.12 | Laura Kennedy | Complete | COMPLETE |
| 2022 | 1.6.4.1.6.3.1.4 | Elexon Branding QTF Logo | 2d | 2024-05-31 A | 2024-06-03 A | 2021FS+20d | 100% |  | 2024-05-31 | 2024-06-03 | 0d |  |  | finish no earlier than 2024-06-03 | Non-SIT S&A QT Test Team | S&A Qualification |  | 6.12 | Laura Kennedy | Complete | COMPLETE |
| 2023 | 1.6.4.1.6.3.2 | **Design, Build, Test** | 70d | 2024-05-13 A | 2024-08-16 A |  | 100% |  | 2024-05-13 | 2024-08-16 | 0d |  |  |  | Non-SIT S&A QT Test Team | S&A Qualification | -742.67 | 6.12 | Laura Kennedy |  |  |
| 2024 | 1.6.4.1.6.3.2.1 | Core UI Screens | 60d | 2024-05-13 A | 2024-08-02 A | 2020SS | 100% |  | 2024-05-13 | 2024-08-02 | 0d |  |  | finish no earlier than 2024-08-02 | Non-SIT S&A QT Test Team | S&A Qualification |  | 6.12 | Laura Kennedy | Complete | COMPLETE |
| 2025 | 1.6.4.1.6.3.2.2 | Tooling (Trigger Files / Template Generators) | 70d | 2024-05-13 A | 2024-08-16 A | 2019SS+13d | 100% |  | 2024-05-13 | 2024-08-16 | 0d |  |  | finish no earlier than 2024-08-16 | Non-SIT S&A QT Test Team | S&A Qualification |  | 6.12 | Laura Kennedy | Complete | COMPLETE |
| 2026 | 1.6.4.1.6.3.2.3 | Database Schema | 50d | 2024-05-13 A | 2024-07-19 A | 2019SS+13d | 100% |  | 2024-05-13 | 2024-07-19 | 0d |  |  | finish no earlier than 2024-07-19 | Non-SIT S&A QT Test Team | S&A Qualification |  | 6.12 | Laura Kennedy | Complete | COMPLETE |
| 2027 | 1.6.4.1.6.3.2.4 | Core API's | 60d | 2024-05-13 A | 2024-08-02 A | 2019SS+13d | 100% |  | 2024-05-13 | 2024-08-02 | 0d |  |  | finish no earlier than 2024-08-02 | Non-SIT S&A QT Test Team | S&A Qualification |  | 6.12 | Laura Kennedy | Complete | COMPLETE |
| 2028 | 1.6.4.1.6.4 | QTF Test Cases DBT Refinement, Execution and Results Validation, Defect Management, Error Handling | 77d | 2024-11-05 A | 2025-02-20 | 2013FF, 2007FF, 2009SS | 80% | 15.4d | 2024-11-05 | 2025-02-20 | 0d | 722d | 0d |  | Non-SIT S&A QT Test Team | S&A Qualification |  | 6.12 | Laura Kennedy | Green | GREEN |
| 2029 | 1.6.4.1.6.5 | **Environments** | 339d | 2024-04-15 A | 2025-07-31 |  | 98% | 7.06d | 2024-04-15 | 2025-07-31 | 0d | 625d |  |  | Non-SIT S&A QT Test Team | S&A Qualification | -742.67 | 6.12 | Laura Kennedy |  |  |
| 2030 | 1.6.4.1.6.5.1 | **Azure Devops** | 173d | 2024-04-15 A | 2024-12-11 A |  | 100% |  | 2024-04-15 | 2024-12-11 | 0d |  |  |  | Non-SIT S&A QT Test Team | S&A Qualification | -742.67 | 6.12 | Laura Kennedy |  |  |
| 2031 | 1.6.4.1.6.5.1.1 | **QFT ADO Development Instance** | 15d | 2024-04-15 A | 2024-05-03 A |  | 100% |  | 2024-04-15 | 2024-05-03 | 0d |  |  |  | Non-SIT S&A QT Test Team | S&A Qualification | -742.67 | 6.12 | Laura Kennedy |  |  |
| 2032 | 1.6.4.1.6.5.1.1.1 | Elexon Instance Setup for QTF Build | 5d | 2024-04-15 A | 2024-04-19 A | 2016SS+10d | 100% |  | 2024-04-15 | 2024-04-19 | 0d |  |  | finish no earlier than 2024-04-19 | Non-SIT S&A QT Test Team | S&A Qualification |  | 6.12 | Laura Kennedy | Complete | COMPLETE |
| 2033 | 1.6.4.1.6.5.1.1.2 | Configuration and User Access | 10d | 2024-04-22 A | 2024-05-03 A | 2032 | 100% |  | 2024-04-22 | 2024-05-03 | 0d |  |  | finish no earlier than 2024-05-03 | Non-SIT S&A QT Test Team | S&A Qualification |  | 6.12 | Laura Kennedy | Complete | COMPLETE |
| 2034 | 1.6.4.1.6.5.1.2 | **MHHSP ADO Instance** | 102d | 2024-07-23 A | 2024-12-11 A |  | 100% |  | 2024-07-23 | 2024-12-11 | 0d |  |  |  | Non-SIT S&A QT Test Team | S&A Qualification | -742.67 | 6.12 | Laura Kennedy |  |  |
| 2035 | 1.6.4.1.6.5.1.2.1 | MHHSP Instance Setup for QTF Production | 29d | 2024-07-23 A | 2024-08-30 A | 2041SS+41d | 100% |  | 2024-07-23 | 2024-08-30 | 0d |  |  | finish no earlier than 2024-08-30 | Non-SIT S&A QT Test Team | S&A Qualification |  | 6.12 | Laura Kennedy | Complete | COMPLETE |
| 2036 | 1.6.4.1.6.5.1.2.2 | Configuration and User Access | 73d | 2024-09-02 A | 2024-12-11 A | 2035 | 100% |  | 2024-09-02 | 2024-12-11 | 0d |  |  | finish no earlier than 2024-09-27 | Non-SIT S&A QT Test Team | S&A Qualification |  | 6.12 | Laura Kennedy | Complete | COMPLETE |
| 2037 | 1.6.4.1.6.5.2 | **Temporary Development Environment** | 35d | 2024-04-15 A | 2024-05-31 A |  | 100% |  | 2024-04-15 | 2024-05-31 | 0d |  |  |  | Non-SIT S&A QT Test Team | S&A Qualification | -742.67 | 6.12 | Laura Kennedy |  |  |
| 2038 | 1.6.4.1.6.5.2.1 | Design | 15d | 2024-04-15 A | 2024-05-03 A | 2016SS+10d | 100% |  | 2024-04-15 | 2024-05-03 | 0d |  |  | finish no earlier than 2024-05-03 | Non-SIT S&A QT Test Team | S&A Qualification |  | 6.12 | Laura Kennedy | Complete | COMPLETE |
| 2039 | 1.6.4.1.6.5.2.2 | Build and Deployment | 20d | 2024-05-06 A | 2024-05-31 A | 2033, 2038 | 100% |  | 2024-05-06 | 2024-05-31 | 0d |  |  | finish no earlier than 2024-05-31 | Non-SIT S&A QT Test Team | S&A Qualification |  | 6.12 | Laura Kennedy | Complete | COMPLETE |

| ID | WBS | Task | Duration | Start | Finish | Predecessors | Complete | Baseline start | Baseline finish | Baseline duration | Total slack | Free slack | Constraint | Responsible | Text9 | Task Status | Update Version | MHHS Resource Name | Sched Status | RAG |
| --- | --- | --- | --- | --- | --- | --- | --- | --- | --- | --- | --- | --- | --- | --- | --- | --- | --- | --- | --- | --- |
| 2040 | 1.6.4.1.6.5.3 | **Dev, Test & Prod Environment Requirements + Design** | 135d | 2024-05-27 A | 2024-11-29 A |  | 100% | 2024-05-27 | 2024-11-29 | 0d |  |  |  | Non-SIT S&A QT Test Team | S&A Qualification | -742.67 | 6.12 | Laura Kennedy |  |  |
| 2041 | 1.6.4.1.6.5.3.1 | Design (including Security Review) | 135d | 2024-05-27 A | 2024-11-29 A | 2016FS+15d | 100% | 2024-05-27 | 2024-11-29 | 0d |  |  | finish no earlier than 2024-08-30 | Non-SIT S&A QT Test Team | S&A Qualification |  | 6.12 | Laura Kennedy | Complete | COMPLETE |
| 2042 | 1.6.4.1.6.5.3.2 | Hub Development Dev/Test | 20d | 2024-06-10 A | 2024-07-05 A | 2041SS+10d | 100% | 2024-06-10 | 2024-07-05 | 0d |  |  |  | Non-SIT S&A QT Test Team | S&A Qualification |  | 6.12 | Laura Kennedy | Complete | COMPLETE |
| 2043 | 1.6.4.1.6.5.3.3 | Hub Deployment | 20d | 2024-06-10 A | 2024-07-05 A | 2041FS+10d, 2042 | 100% | 2024-06-10 | 2024-07-05 | 0d |  |  | finish no earlier than 2024-07-05 | Non-SIT S&A QT Test Team | S&A Qualification |  | 6.12 | Laura Kennedy | Complete | COMPLETE |
| 2044 | 1.6.4.1.6.5.3.4 | Development Envn. Deployment | 53.8d | 2024-07-08 A | 2024-09-19 A | 2043 | 100% | 2024-07-08 | 2024-09-19 | 0d |  |  | finish no earlier than 2024-08-30 | Non-SIT S&A QT Test Team | S&A Qualification |  | 6.12 | Laura Kennedy | Complete | COMPLETE |
| 2045 | 1.6.4.1.6.5.3.5 | Test Envn. Deployment | 10d | 2024-09-19 A | 2024-10-03 A | 2044 | 100% | 2024-09-19 | 2024-10-03 | 0d |  |  | finish no earlier than 2024-09-13 | Non-SIT S&A QT Test Team | S&A Qualification |  | 6.12 | Laura Kennedy | Complete | COMPLETE |
| 2046 | 1.6.4.1.6.5.3.6 | Production Envn. Deployment | 25d | 2024-10-03 A | 2024-11-07 A | 2045 | 100% | 2024-10-03 | 2024-11-07 | 0d |  |  | finish no earlier than 2024-10-18 | Non-SIT S&A QT Test Team | S&A Qualification |  | 6.12 | Laura Kennedy | Complete | COMPLETE |
| 2047 | 1.6.4.1.6.5.4 | **QTF Deployment into Production** | 19d | 2025-02-20 | 2025-03-18 |  |  | 2025-02-03 | 2025-04-25 | 0d | 722d |  |  | Non-SIT S&A QT Test Team | S&A Qualification | -742.67 | 6.15 | Laura Kennedy |  |  |
| 2048 | 1.6.4.1.6.5.4.1 | App Deployment | 5d | 2025-02-20 | 2025-02-26 | 2028, 2046 |  | 2025-02-20 | 2025-02-26 | 0d | 722d | 0d | start no earlier than 2025-02-03 | Non-SIT S&A QT Test Team | S&A Qualification | 22.33 | 6.15 | Laura Kennedy | Green | GREEN |
| 2049 | 1.6.4.1.6.5.4.2 | Smoke Test | 2d | 2025-02-27 | 2025-02-28 | 2048 |  | 2025-02-27 | 2025-02-28 | 0d | 722d | 0d | finish no earlier than 2025-02-04 | Non-SIT S&A QT Test Team | S&A Qualification | 29.33 | 6.15 | Laura Kennedy | Green | GREEN |
| 2050 | 1.6.4.1.6.5.4.3 | PEN Test | 2d | 2025-03-03 | 2025-03-04 | 2049 |  | 2025-03-03 | 2025-03-04 | 0d | 722d | 0d | finish no earlier than 2025-02-06 | Non-SIT S&A QT Test Team | S&A Qualification | 33.33 | 6.15 | Laura Kennedy | Green | GREEN |
| 2051 | 1.6.4.1.6.5.4.4 | Regression Test | 10d | 2025-03-05 | 2025-03-18 | 2050 |  | 2025-03-05 | 2025-03-18 | 0d | 722d |  | finish no earlier than 2025-02-20 | Non-SIT S&A QT Test Team | S&A Qualification | 35.33 | 6.15 | Laura Kennedy | Green | GREEN |
| 2052 | 1.6.4.1.6.5.5 | **DIP Onboarding (UIT)** | 101d | 2024-07-26 A | 2024-12-13 A |  | 100% | 2024-07-26 | 2024-11-29 | 0d |  |  |  | Non-SIT S&A QT Test Team | S&A Qualification | -742.67 | 6.15 | Laura Kennedy |  |  |
| 2053 | 1.6.4.1.6.5.5.1 | DIP Simulator | 15d | 2024-07-26 A | 2024-08-15 A |  | 100% | 2024-07-26 | 2024-08-15 | 0d |  |  | finish no earlier than 2024-08-15 | Non-SIT S&A QT Test Team | S&A Qualification |  | 6.15 | Laura Kennedy | Complete | COMPLETE |
| 2054 | 1.6.4.1.6.5.5.2 | DIP (UIT) Instance available for Onboarding | 1d | 2024-08-05 A | 2024-08-05 A |  | 100% | 2024-08-05 | 2024-08-05 | 0d |  |  | start no earlier than 2024-08-05 | Non-SIT S&A QT Test Team | S&A Qualification |  | 6.15 | Laura Kennedy | Complete | COMPLETE |
| 2055 | 1.6.4.1.6.5.5.3 | DIP (UIT) Portal | 1d | 2024-09-03 A | 2024-09-03 A | 2054 | 100% | 2024-09-03 | 2024-09-03 | 0d |  |  | start no earlier than 2024-09-03 | Non-SIT S&A QT Test Team | S&A Qualification |  | 6.15 | Laura Kennedy | Complete | COMPLETE |
| 2056 | 1.6.4.1.6.5.5.4 | DIP (UIT) Onboarding for Development (incl. certificates and security compliance) | 39d | 2024-08-06 A | 2024-09-27 A | 2054 | 100% | 2024-08-06 | 2024-09-27 | 0d |  |  | finish no earlier than 2024-09-27 | Non-SIT S&A QT Test Team | S&A Qualification |  | 6.15 | Laura Kennedy | Complete | COMPLETE |
| 2057 | 1.6.4.1.6.5.5.5 | DIP (UIT) Onboarding for Development Connection Confirmed | 1d | 2024-09-30 A | 2024-09-30 A | 2056 | 100% | 2024-09-30 | 2024-09-30 | 0d |  |  | start no earlier than 2024-09-30 | Non-SIT S&A QT Test Team | S&A Qualification |  | 6.15 | Laura Kennedy | Complete | COMPLETE |
| 2058 | 1.6.4.1.6.5.5.6 | DIP (UIT) Onboarding for Test (incl. certificates and security compliance) | 5d | 2024-10-01 A | 2024-10-07 A | 2057 | 100% | 2024-10-01 | 2024-10-07 | 0d |  |  | finish no earlier than 2024-10-07 | Non-SIT S&A QT Test Team | S&A Qualification |  | 6.15 | Laura Kennedy | Complete | COMPLETE |
| 2059 | 1.6.4.1.6.5.5.7 | DIP (UIT) Onboarding for Test Connection Confirmed | 1d | 2024-10-08 A | 2024-10-08 A | 2058 | 100% | 2024-10-08 | 2024-10-08 | 0d |  |  | start no earlier than 2024-10-08 | Non-SIT S&A QT Test Team | S&A Qualification |  | 6.15 | Laura Kennedy | Complete | COMPLETE |
| 2060 | 1.6.4.1.6.5.5.8 | DIP (UIT) Onboarding for Prod (incl. certificates and security compliance) | 5d | 2024-10-09 A | 2024-10-15 A | 2059 | 100% | 2024-10-09 | 2024-10-15 | 0d |  |  | finish no earlier than 2024-10-15 | Non-SIT S&A QT Test Team | S&A Qualification |  | 6.15 | Laura Kennedy | Complete | COMPLETE |
| 2061 | 1.6.4.1.6.5.5.9 | DIP (UIT) Onboarding for Prod Connection Confirmed | 1d | 2024-10-16 A | 2024-10-16 A | 2060 | 100% | 2024-10-16 | 2024-10-16 | 0d |  |  | start no earlier than 2024-10-16 | Non-SIT S&A QT Test Team | S&A Qualification |  | 6.15 | Laura Kennedy | Complete | COMPLETE |
| 2062 | 1.6.4.1.6.5.5.10 | DIP UIT Test Stubs | 32d | 2024-10-31 A | 2024-12-13 A | 2057, 2059, 2061 | 100% | 2024-10-17 | 2024-11-29 | 0d |  |  | start no earlier than 2024-10-31 | Non-SIT S&A QT Test Team | S&A Qualification |  | 6.15 | Laura Kennedy | Complete | COMPLETE |
| 2063 | 1.6.4.1.6.5.6 | **DTN Onboarding** | 115d | 2024-05-20 A | 2024-10-25 A |  | 100% | 2024-05-20 | 2024-10-25 | 0d |  |  |  | Non-SIT S&A QT Test Team | S&A Qualification | -742.67 | 6.15 | Laura Kennedy |  |  |
| 2064 | 1.6.4.1.6.5.6.1 | DTN Request Raised for Onboarding | 25d | 2024-05-20 A | 2024-06-21 A |  | 100% | 2024-05-20 | 2024-06-21 | 0d |  |  | start no earlier than 2024-05-20 | Non-SIT S&A QT Test Team | S&A Qualification |  | 6.15 | Laura Kennedy | Complete | COMPLETE |
| 2065 | 1.6.4.1.6.5.6.2 | Setup, configuration of New Host and Test Flags | 5d | 2024-06-24 A | 2024-06-28 A | 2064 | 100% | 2024-06-24 | 2024-06-28 | 0d |  |  | start no earlier than 2024-06-24 | Non-SIT S&A QT Test Team | S&A Qualification |  | 6.15 | Laura Kennedy | Complete | COMPLETE |
| 2066 | 1.6.4.1.6.5.6.3 | New VPN Connection (Test) | 30d | 2024-08-05 A | 2024-09-13 A | 2065 | 100% | 2024-08-05 | 2024-09-13 | 0d |  |  | start no earlier than 2024-08-05 | Non-SIT S&A QT Test Team | S&A Qualification |  | 6.15 | Laura Kennedy | Complete | COMPLETE |
| 2067 | 1.6.4.1.6.5.6.4 | New VPN Connection (Prod) | 30d | 2024-09-16 A | 2024-10-25 A | 2066 | 100% | 2024-09-16 | 2024-10-25 | 0d |  |  | finish no earlier than 2024-10-25 | Non-SIT S&A QT Test Team | S&A Qualification |  | 6.15 | Laura Kennedy | Complete | COMPLETE |
| 2068 | 1.6.4.1.6.5.6.5 | DTN Test Stubs | 10d | 2024-09-16 A | 2024-09-27 A | 2066 | 100% | 2024-09-16 | 2024-09-27 | 0d |  |  | start no earlier than 2024-09-16 | Non-SIT S&A QT Test Team | S&A Qualification |  | 6.15 | Laura Kennedy | Complete | COMPLETE |

| ID | WBS | Task | Duration | Start | Finish | Predecessors | Complete | Remaining | Actual finish | Baseline start | Baseline finish | Baseline duration | Constraint | Responsible | Text9 | Task Status | Update Version | MHHS Resource Name | Sched Status | RAG |
| --- | --- | --- | --- | --- | --- | --- | --- | --- | --- | --- | --- | --- | --- | --- | --- | --- | --- | --- | --- | --- |
| 2069 | 1.6.4.1.6.5.7 | **Generate Tooling** | 334d | 2024-04-22 A | 2025-07-31 |  | 100% |  | 2024-09-24 | 2024-04-22 | 2025-07-31 | 0d |  | Non-SIT S&A QT Test Team | S&A Qualification | -742.67 | 6.15 | Laura Kennedy |  |  |
| 2070 | 1.6.4.1.6.5.7.1 | MPAN Core Generator | 25d | 2024-04-22 A | 2024-05-24 A |  | 100% |  |  | 2024-04-22 | 2024-05-24 | 0d | finish no earlier than 2024-05-24 | Non-SIT S&A QT Test Team | S&A Qualification |  | 6.15 | Laura Kennedy | Complete | COMPLETE |
| 2071 | 1.6.4.1.6.5.7.2 | MPAN File Generator | 55d | 2024-05-27 A | 2024-08-09 A | 2070 | 100% |  |  | 2024-05-27 | 2024-08-09 | 0d | finish no earlier than 2024-08-09 | Non-SIT S&A QT Test Team | S&A Qualification |  | 6.15 | Laura Kennedy | Complete | COMPLETE |
| 2072 | 1.6.4.1.6.5.7.3 | MPAN Template Loader | 32d | 2024-08-12 A | 2024-09-24 A | 2071 | 100% |  |  | 2024-08-12 | 2024-09-24 | 0d | finish no earlier than 2024-09-24 | Non-SIT S&A QT Test Team | S&A Qualification |  | 6.15 | Laura Kennedy | Complete | COMPLETE |
| 2073 | 1.6.4.1.6.5.7.4 | ADO Extract (QTC) From SIT | 30d | 2024-05-06 A | 2024-06-14 A |  | 100% |  |  | 2024-05-06 | 2024-06-14 | 0d | finish no earlier than 2024-06-14 | Non-SIT S&A QT Test Team | S&A Qualification |  | 6.15 | Laura Kennedy | Complete | COMPLETE |
| 2074 | 1.6.4.1.6.5.7.5 | Populate QT ADO | 40d | 2024-06-17 A | 2024-08-09 A | 2073 | 100% |  |  | 2024-06-17 | 2024-08-09 | 0d | finish no earlier than 2024-08-09 | Non-SIT S&A QT Test Team | S&A Qualification |  | 6.15 | Laura Kennedy | Complete | COMPLETE |
| 2075 | 1.6.4.1.6.5.7.6 | Create QTC Spreadsheets | 20d | 2024-06-03 A | 2024-06-28 A | 2073 | 100% |  |  | 2024-06-03 | 2024-06-28 | 0d | finish no earlier than 2024-06-28 | Non-SIT S&A QT Test Team | S&A Qualification |  | 6.15 | Laura Kennedy | Complete | COMPLETE |
| 2076 | 1.6.4.1.6.5.7.7 | Upload QTC Spreadsheets to QTF | 20d | 2024-07-01 A | 2024-07-26 A | 2075 | 100% |  |  | 2024-07-01 | 2024-07-26 | 0d | finish no earlier than 2024-07-26 | Non-SIT S&A QT Test Team | S&A Qualification |  | 6.15 | Laura Kennedy | Complete | COMPLETE |
| 2077 | 1.6.4.1.6.5.7.8 | Create QTC Set / Master QTC Loader | 40d | 2024-07-22 A | 2024-09-13 A | 2076 | 100% |  |  | 2024-07-22 | 2024-09-13 | 0d | finish no earlier than 2024-09-13 | Non-SIT S&A QT Test Team | S&A Qualification |  | 6.15 | Laura Kennedy | Complete | COMPLETE |
| 2078 | 1.6.4.1.6.5.8 | **Test Data** | 15d | 2024-06-10 A | 2024-06-28 A |  | 100% |  |  | 2024-06-10 | 2024-06-28 | 0d |  | Non-SIT S&A QT Test Team | S&A Qualification | -742.67 | 6.12 | Laura Kennedy |  |  |
| 2079 | 1.6.4.1.6.5.8.1 | Sample MPAN Data + Attributes from Suppliers | 15d | 2024-06-10 A | 2024-06-28 A |  | 100% |  |  | 2024-06-10 | 2024-06-28 | 0d | finish no earlier than 2024-06-28 | Non-SIT S&A QT Test Team | S&A Qualification |  | 6.12 | Laura Kennedy | Complete | COMPLETE |
| 2080 | 1.6.4.1.6.6 | **MPANs, DIP Messages, Settlement, Consumption, Reference** | 423d? | 2024-05-27 A | 2026-01-07 |  | 69% | 129.24d? |  | 2024-05-27 | 2026-01-07 | 0d |  | Non-SIT S&A QT Test Team | S&A Qualification | -742.67 | 6.12 | Laura Kennedy |  |  |
| 2081 | 1.6.4.1.6.6.1 | Create MPAN Data | 55d | 2024-05-27 A | 2024-08-09 A | 2070 | 100% |  |  | 2024-05-27 | 2024-08-09 | 0d | finish no earlier than 2024-08-09 | Non-SIT S&A QT Test Team | S&A Qualification |  | 6.12 | Laura Kennedy | Complete | COMPLETE |
| 2082 | 1.6.4.1.6.6.2 | Create message templates (DIP, CSS, DTN) | 40d | 2024-06-03 A | 2024-07-26 A |  | 100% |  |  | 2024-06-03 | 2024-07-26 | 0d | finish no earlier than 2024-07-26 | Non-SIT S&A QT Test Team | S&A Qualification |  | 6.12 | Laura Kennedy | Complete | COMPLETE |
| 2083 | 1.6.4.1.6.6.3 | Create Consumption Data Templates | 20d | 2024-09-16 A | 2024-10-11 A |  | 100% |  |  | 2024-09-16 | 2024-10-11 | 0d | finish no earlier than 2024-10-11 | Non-SIT S&A QT Test Team | S&A Qualification |  | 6.12 | Laura Kennedy | Complete | COMPLETE |
| 2084 | 1.6.4.1.6.6.4 | Load Consumption Data | 25d | 2024-11-11 A | 2024-12-13 A | 2083FS+20d | 100% |  |  | 2024-11-11 | 2024-12-06 | 0d |  | Non-SIT S&A QT Test Team | S&A Qualification |  | 6.12 | Laura Kennedy | Complete | COMPLETE |
| 2085 | 1.6.4.1.6.6.5 | Create Load Shape and Load Shape Total Templates | 20d | 2024-09-16 A | 2024-10-11 A |  | 100% |  |  | 2024-09-16 | 2024-10-11 | 0d | finish no earlier than 2024-10-11 | Non-SIT S&A QT Test Team | S&A Qualification |  | 6.12 | Laura Kennedy | Complete | COMPLETE |
| 2086 | 1.6.4.1.6.6.6 | Load Shape and Load Shape Total Data | 25d | 2024-11-11 A | 2024-12-13 A | 2085FS+20d | 100% |  |  | 2024-11-11 | 2024-12-06 | 0d |  | Non-SIT S&A QT Test Team | S&A Qualification |  | 6.12 | Laura Kennedy | Complete | COMPLETE |
| 2087 | 1.6.4.1.6.6.7 | Create Settlement Report Templates | 20d | 2024-09-16 A | 2024-10-11 A |  | 100% |  |  | 2024-09-16 | 2024-10-11 | 0d | finish no earlier than 2024-10-11 | Non-SIT S&A QT Test Team | S&A Qualification |  | 6.12 | Laura Kennedy | Complete | COMPLETE |
| 2088 | 1.6.4.1.6.6.8 | Load Settlement Report Data | 25d | 2024-11-11 A | 2024-12-13 A | 2087FS+20d | 100% |  |  | 2024-11-11 | 2024-12-06 | 0d |  | Non-SIT S&A QT Test Team | S&A Qualification |  | 6.12 | Laura Kennedy | Complete | COMPLETE |
| 2089 | 1.6.4.1.6.6.9 | Market Domain Data (MDD) For Legacy Systems | 25d | 2024-07-29 A | 2024-08-30 A |  | 100% |  |  | 2024-07-29 | 2024-08-30 | 0d | finish no earlier than 2024-08-30 | Non-SIT S&A QT Test Team | S&A Qualification |  | 6.12 | Laura Kennedy | Complete | COMPLETE |
| 2090 | 1.6.4.1.6.6.10 | **Industry Standing Data (ISD)** | 71d? | 2024-07-26 A | 2024-11-01 A |  | 100% |  |  | 2024-07-26 | 2024-11-01 | 0d |  | Non-SIT S&A QT Test Team | S&A Qualification | -742.67 | 6.12 | Laura Kennedy |  |  |
| 2091 | 1.6.4.1.6.6.10.1 | Dependant on Receiving ISD Agreed Source Data from Helix | 1d | 2024-07-26 A | 2024-07-26 A |  | 100% |  |  | 2024-07-26 | 2024-07-26 | 0d | start no earlier than 2024-07-26 | Non-SIT S&A QT Test Team | S&A Qualification |  | 6.12 | Laura Kennedy | Complete | COMPLETE |
| 2092 | 1.6.4.1.6.6.10.2 | Helix Dev Environment migration | 6d | 2024-07-29 A | 2024-08-05 A | 2091 | 100% |  |  | 2024-07-29 | 2024-08-05 | 0d | finish no earlier than 2024-08-05 | Non-SIT S&A QT Test Team | S&A Qualification |  | 6.12 | Laura Kennedy | Complete | COMPLETE |
| 2093 | 1.6.4.1.6.6.10.3 | STGi (UK) migration | 5d | 2024-09-09 A | 2024-09-13 A | 2091 | 100% |  |  | 2024-09-09 | 2024-09-13 | 0d | finish no earlier than 2024-09-13 | Non-SIT S&A QT Test Team | S&A Qualification |  | 6.12 | Laura Kennedy | Complete | COMPLETE |
| 2094 | 1.6.4.1.6.6.10.4 | Maintenance window between cycle 2 and 3 | 1d | 2024-09-20 A | 2024-09-20 A | 2091 | 100% |  |  | 2024-09-20 | 2024-09-20 | 0d | finish no earlier than 2024-09-20 | Non-SIT S&A QT Test Team | S&A Qualification |  | 6.12 | Laura Kennedy | Complete | COMPLETE |
| 2095 | 1.6.4.1.6.6.10.5 | First View of Migrated ISD Data | 5d | 2024-09-23 A | 2024-09-27 A | 2094 | 100% |  |  | 2024-09-23 | 2024-09-27 | 0d | finish no earlier than 2024-09-27 | Non-SIT S&A QT Test Team | S&A Qualification |  | 6.12 | Laura Kennedy | Complete | COMPLETE |
| 2096 | 1.6.4.1.6.6.10.6 | Second View of Migrated ISD Data (HXT1 (SIT B) migration) | 5d | 2024-09-23 A | 2024-09-27 A | 2094 | 100% |  |  | 2024-09-23 | 2024-09-27 | 0d | finish no earlier than 2024-09-27 | Non-SIT S&A QT Test Team | S&A Qualification |  | 6.12 | Laura Kennedy | Complete | COMPLETE |
| 2097 | 1.6.4.1.6.6.10.7 | Final Cycle 3 Migrated ISD Data | 5d | 2024-10-07 A | 2024-10-11 A | 2095 | 100% |  |  | 2024-10-07 | 2024-10-11 | 0d | finish no earlier than 2024-10-11 | Non-SIT S&A QT Test Team | S&A Qualification |  | 6.12 | Laura Kennedy | Complete | COMPLETE |
| 2098 | 1.6.4.1.6.6.10.8 | Create ISD Template inc. DIP ID | 35d? | 2024-09-16 A | 2024-11-01 A | 2094 | 100% |  |  | 2024-09-16 | 2024-11-01 | 0d | finish no earlier than 2024-11-01 | Non-SIT S&A QT Test Team | S&A Qualification |  | 6.12 | Laura Kennedy | Complete | COMPLETE |
| 2099 | 1.6.4.1.6.6.10.9 | Publish Qualification ISD | 10d? | 2024-10-14 A | 2024-10-25 A | 2097, 2094 | 100% |  |  | 2024-10-14 | 2024-10-25 | 0d | finish no earlier than 2024-10-25 | Non-SIT S&A QT Test Team | S&A Qualification |  | 6.12 | Laura Kennedy | Complete | COMPLETE |

| ID | WBS | Task | Duration | Start | Finish | Predecessors | Complete | Actual finish | Baseline start | Baseline finish | Baseline duration | Total slack | Free slack | Constraint | Responsible | Text9 | Task Status | Update Version | MHHS Resource Name | Sched Status | RAG |
| --- | --- | --- | --- | --- | --- | --- | --- | --- | --- | --- | --- | --- | --- | --- | --- | --- | --- | --- | --- | --- | --- |
| 2100 | 1.6.4.1.6.6.11 | **BETA Testing 1 - Test Data** | 27d | 2024-11-01 A | 2024-12-09 |  | 100% | 2025-01-22 | 2024-11-01 | 2024-11-15 | 0d |  |  |  | Non-SIT S&A QT Test Team | S&A Qualification | -169.67 | 6.12 | Laura Kennedy |  |  |
| 2101 | 1.6.4.1.6.6.11.1 | Provide Example MPAN File | 3d | 2024-11-01 A | 2024-11-05 A | 2144SS | 100% |  | 2024-11-01 | 2024-11-05 | 0d |  |  | finish no earlier than 2024-11-05 | Non-SIT S&A QT Test Team | S&A Qualification |  | 6.12 | Laura Kennedy | Complete | COMPLETE |
| 2102 | 1.6.4.1.6.6.11.2 | Load Example MPAN File | 6d | 2024-11-06 A | 2024-11-13 A | 2101 | 100% |  | 2024-11-06 | 2024-11-13 | 0d |  |  | finish no earlier than 2024-11-13 | Non-SIT S&A QT Test Team | S&A Qualification |  | 6.12 | Laura Kennedy | Complete | COMPLETE |
| 2103 | 1.6.4.1.6.6.11.3 | Industry Standing Data (ISD) | 6d | 2024-11-06 A | 2024-11-13 A | 2144SS+3d | 100% |  | 2024-11-06 | 2024-11-13 | 0d |  |  | finish no earlier than 2024-11-13 | Non-SIT S&A QT Test Team | S&A Qualification |  | 6.12 | Laura Kennedy | Complete | COMPLETE |
| 2104 | 1.6.4.1.6.6.11.4 | Market Domain Data (MDD) | 6d | 2024-11-06 A | 2024-11-13 A | 2144SS+3d | 100% |  | 2024-11-06 | 2024-11-13 | 0d |  |  | finish no earlier than 2024-11-13 | Non-SIT S&A QT Test Team | S&A Qualification |  | 6.12 | Laura Kennedy | Complete | COMPLETE |
| 2105 | 1.6.4.1.6.6.11.5 | Load ISD / MDD Data | 1d | 2024-12-06 A | 2024-12-06 A | 2103FS+16d, 2104FS+11d | 100% |  | 2024-11-14 | 2024-11-14 | 0d |  |  | start no earlier than 2024-11-14 | Non-SIT S&A QT Test Team | S&A Qualification |  | 6.12 | Laura Kennedy | Complete | COMPLETE |
| 2106 | 1.6.4.1.6.6.11.6 | Create QTC sets and Test MPANs via QTF | 1d | 2024-12-06 A | 2024-12-06 A | 2102FS+16d | 100% |  | 2024-11-14 | 2024-11-14 | 0d |  |  | start no earlier than 2024-11-14 | Non-SIT S&A QT Test Team | S&A Qualification |  | 6.12 | Laura Kennedy | Complete | COMPLETE |
| 2107 | 1.6.4.1.6.6.11.7 | Create QTC sets in ADO via QTF | 1d | 2024-12-06 A | 2024-12-06 A | 2106SS | 100% |  | 2024-11-14 | 2024-11-14 | 0d |  |  | start no earlier than 2024-11-14 | Non-SIT S&A QT Test Team | S&A Qualification |  | 6.12 | Laura Kennedy | Complete | COMPLETE |
| 2108 | 1.6.4.1.6.6.11.8 | Provide Test MPANs (Suppliers only) allocated to specfic QTC's | 1d | 2024-12-06 A | 2024-12-06 A | 2105SS | 100% |  | 2024-11-14 | 2024-11-14 | 0d |  |  | start no earlier than 2024-11-14 | Non-SIT S&A QT Test Team | S&A Qualification |  | 6.12 | Laura Kennedy | Complete | COMPLETE |
| 2109 | 1.6.4.1.6.6.11.9 | Load Test MPANs | 1d | 2024-12-09 A | 2024-12-09 A | 2108 | 100% |  | 2024-11-15 | 2024-11-15 | 0d |  |  | start no earlier than 2024-11-15 | Non-SIT S&A QT Test Team | S&A Qualification |  | 6.12 | Laura Kennedy | Complete | COMPLETE |
| 2110 | 1.6.4.1.6.6.11.10 | **BETA Testing 2 - Test Data** | 11d | 2025-01-08 A | 2025-01-22 A |  | 100% |  | 2025-01-08 | 2025-01-22 | 0d |  |  |  | Non-SIT S&A QT Test Team | S&A Qualification | -169.67 | 6.15 | Laura Kennedy | green |  |
| 2111 | 1.6.4.1.6.6.11.10.1 | Provide Example MPAN File | 3d | 2025-01-08 A | 2025-01-10 A | 2145SS | 100% |  | 2025-01-08 | 2025-01-10 | 0d |  |  | start no earlier than 2025-01-08 | Non-SIT S&A QT Test Team | S&A Qualification |  | 6.15 | Laura Kennedy | Complete | COMPLETE |
| 2112 | 1.6.4.1.6.6.11.10.2 | Load Example MPAN File | 6d | 2025-01-13 A | 2025-01-20 A | 2111 | 100% |  | 2025-01-13 | 2025-01-20 | 0d |  |  | start no earlier than 2025-01-13 | Non-SIT S&A QT Test Team | S&A Qualification |  | 6.15 | Laura Kennedy | Complete | COMPLETE |
| 2113 | 1.6.4.1.6.6.11.10.3 | Industry Standing Data (ISD) | 6d | 2025-01-08 A | 2025-01-15 A | 2099, 2145SS | 100% |  | 2025-01-08 | 2025-01-15 | 0d |  |  | start no earlier than 2025-01-08 | Non-SIT S&A QT Test Team | S&A Qualification |  | 6.15 | Laura Kennedy | Complete | COMPLETE |
| 2114 | 1.6.4.1.6.6.11.10.4 | Market Domain Data (MDD) | 6d | 2025-01-08 A | 2025-01-15 A | 2083, 2145SS | 100% |  | 2025-01-08 | 2025-01-15 | 0d |  |  | start no earlier than 2025-01-08 | Non-SIT S&A QT Test Team | S&A Qualification |  | 6.15 | Laura Kennedy | Complete | COMPLETE |
| 2115 | 1.6.4.1.6.6.11.10.5 | Load ISD / MDD Data | 1d | 2025-01-16 A | 2025-01-16 A | 2113, 2114, 2145SS | 100% |  | 2025-01-16 | 2025-01-16 | 0d |  |  | start no earlier than 2025-01-16 | Non-SIT S&A QT Test Team | S&A Qualification |  | 6.15 | Laura Kennedy | Complete | COMPLETE |
| 2116 | 1.6.4.1.6.6.11.10.6 | Create QTC sets and Test MPANs via QTF | 1d | 2025-01-21 A | 2025-01-21 A | 2112 | 100% |  | 2025-01-21 | 2025-01-21 | 0d |  |  | start no earlier than 2025-01-21 | Non-SIT S&A QT Test Team | S&A Qualification |  | 6.15 | Laura Kennedy | Complete | COMPLETE |
| 2117 | 1.6.4.1.6.6.11.10.7 | Create QTC sets in ADO via QTF | 1d | 2025-01-21 A | 2025-01-21 A | 2116SS | 100% |  | 2025-01-21 | 2025-01-21 | 0d |  |  | start no earlier than 2025-01-21 | Non-SIT S&A QT Test Team | S&A Qualification |  | 6.15 | Laura Kennedy | Complete | COMPLETE |
| 2118 | 1.6.4.1.6.6.11.10.8 | Provide Test MPANs (Suppliers only) allocated to specfic QTC's | 1d | 2025-01-21 A | 2025-01-21 A | 2116SS | 100% |  | 2025-01-21 | 2025-01-21 | 0d |  |  | start no earlier than 2025-01-21 | Non-SIT S&A QT Test Team | S&A Qualification |  | 6.15 | Laura Kennedy | Complete | COMPLETE |
| 2119 | 1.6.4.1.6.6.11.10.9 | Load Test MPANs | 1d | 2025-01-22 A | 2025-01-22 A | 2118 | 100% |  | 2025-01-22 | 2025-01-22 | 0d |  |  | start no earlier than 2025-01-22 | Non-SIT S&A QT Test Team | S&A Qualification |  | 6.15 | Laura Kennedy | Complete | COMPLETE |
| 2120 | 1.6.4.1.6.6.12 | **Wave 1 Test Data** | 46d | 2025-05-12 | 2025-07-15 | 2106SS |  |  | 2025-05-12 | 2025-07-15 | 0d |  |  |  | Non-SIT S&A QT Test Team | S&A Qualification | -168.67 | 6.12 | Laura Kennedy |  |  |
| 2121 | 1.6.4.1.6.6.12.1 | Test Data Request + Templates Completed | 16d | 2025-04-21 | 2025-05-12 | 2105SS |  |  | 2025-04-21 | 2025-05-12 | 0d | 653d | 6d | finish no earlier than 2025-05-12 | Non-SIT S&A QT Test Team | S&A Qualification | 82.33 | 6.12 | Laura Kennedy | Green | GREEN |
| 2122 | 1.6.4.1.6.6.12.2 | Test Data Generated | 10d | 2025-05-21 | 2025-06-03 | 2108, 2121 |  |  | 2025-05-21 | 2025-06-03 | 0d | 647d | 0d | finish no earlier than 2025-06-03 | Non-SIT S&A QT Test Team | S&A Qualification | 112.33 | 6.12 | Laura Kennedy | Green | GREEN |
| 2123 | 1.6.4.1.6.6.12.3 | Test Data Loaded into QP Systems | 20d | 2025-06-04 | 2025-07-01 | 2122 |  |  | 2025-06-04 | 2025-07-01 | 0d | 647d |  | finish no earlier than 2025-06-17 | Non-SIT S&A QT Test Team | S&A Qualification | 126.33 | 6.12 | Laura Kennedy | Green | GREEN |
| 2124 | 1.6.4.1.6.6.12.4 | Test Data Loaded into QTF + ADO | 19d | 2025-06-04 | 2025-06-30 | 2122 |  |  | 2025-06-04 | 2025-06-30 | 0d | 648d |  | finish no earlier than 2025-06-17 | Non-SIT S&A QT Test Team | S&A Qualification | 126.33 | 6.12 | Laura Kennedy | Green | GREEN |

| ID | WBS | Task | Type | Duration | Start | Finish | Predecessors | Complete | Remaining | Baseline start | Baseline finish | Baseline duration | Total slack | Free slack | Constraint | Baseline cost | Responsible | Text9 | Task Status | Update Version | MHHS Resource Name | Sched Status | RAG | Milestone ID | Tier | Involved | Text29 |
| --- | --- | --- | --- | --- | --- | --- | --- | --- | --- | --- | --- | --- | --- | --- | --- | --- | --- | --- | --- | --- | --- | --- | --- | --- | --- | --- | --- |
| 2125 | 1.6.4.1.6.6.13 | **Wave 2 Test Data** |  | 42d | 2025-07-07 | 2025-09-03 |  |  |  | 2025-07-07 | 2025-09-03 | 0d |  |  |  |  | Non-SIT S&A QT Test Team | S&A Qualification | -168.67 | 6.12 | Laura Kennedy |  |  |  |  |  |  |
| 2126 | 1.6.4.1.6.6.13.1 | Test Data Request + Templates Completed |  | 16d | 2025-06-16 | 2025-07-07 |  |  |  | 2025-06-16 | 2025-07-07 | 0d | 617d | 6d | finish no earlier than 2025-07-07 |  | Non-SIT S&A QT Test Team | S&A Qualification | 138.33 | 6.12 | Laura Kennedy | Green | GREEN |  |  |  |  |
| 2127 | 1.6.4.1.6.6.13.2 | Test Data Generated |  | 10d | 2025-07-16 | 2025-07-29 | 2126 |  |  | 2025-07-16 | 2025-07-29 | 0d | 611d | 0d | finish no earlier than 2025-07-29 |  | Non-SIT S&A QT Test Team | S&A Qualification | 168.33 | 6.12 | Laura Kennedy | Green | GREEN |  |  |  |  |
| 2128 | 1.6.4.1.6.6.13.3 | Test Data Loaded into QP Systems |  | 16d | 2025-07-30 | 2025-08-20 | 2127 |  |  | 2025-07-30 | 2025-08-20 | 0d | 611d |  | finish no earlier than 2025-08-12 |  | Non-SIT S&A QT Test Team | S&A Qualification | 182.33 | 6.12 | Laura Kennedy | Green | GREEN |  |  |  |  |
| 2129 | 1.6.4.1.6.6.13.4 | Test Data Loaded into QTF + ADO |  | 16d | 2025-07-30 | 2025-08-20 | 2127 |  |  | 2025-07-30 | 2025-08-20 | 0d | 611d |  | finish no earlier than 2025-08-12 |  | Non-SIT S&A QT Test Team | S&A Qualification | 182.33 | 6.12 | Laura Kennedy | Green | GREEN |  |  |  |  |
| 2130 | 1.6.4.1.6.6.14 | **Wave 3 Test Data** |  | 45d | 2025-09-08 | 2025-11-10 |  |  |  | 2025-09-08 | 2025-11-10 | 0d |  |  |  |  | Non-SIT S&A QT Test Team | S&A Qualification | -168.67 | 6.12 | Laura Kennedy |  |  |  |  |  |  |
| 2131 | 1.6.4.1.6.6.14.1 | Test Data Request + Templates Completed |  | 15d | 2025-08-19 | 2025-09-08 |  |  |  | 2025-08-19 | 2025-09-08 | 0d | 568d | 5d | finish no earlier than 2025-09-08 |  | Non-SIT S&A QT Test Team | S&A Qualification | 202.33 | 6.12 | Laura Kennedy | Green | GREEN |  |  |  |  |
| 2132 | 1.6.4.1.6.6.14.2 | Test Data Generated |  | 10d | 2025-09-16 | 2025-09-29 | 2131 |  |  | 2025-09-16 | 2025-09-29 | 0d | 563d | 0d | finish no earlier than 2025-09-29 |  | Non-SIT S&A QT Test Team | S&A Qualification | 230.33 | 6.12 | Laura Kennedy | Green | GREEN |  |  |  |  |
| 2133 | 1.6.4.1.6.6.14.3 | Test Data Loaded into QP Systems |  | 20d | 2025-09-30 | 2025-10-27 | 2132 |  |  | 2025-09-30 | 2025-10-27 | 0d | 563d |  | finish no earlier than 2025-10-13 |  | Non-SIT S&A QT Test Team | S&A Qualification | 244.33 | 6.12 | Laura Kennedy | Green | GREEN |  |  |  |  |
| 2134 | 1.6.4.1.6.6.14.4 | Test Data Loaded into QTF + ADO |  | 20d | 2025-09-30 | 2025-10-27 | 2132 |  |  | 2025-09-30 | 2025-10-27 | 0d | 563d |  | finish no earlier than 2025-10-13 |  | Non-SIT S&A QT Test Team | S&A Qualification | 244.33 | 6.12 | Laura Kennedy | Green | GREEN |  |  |  |  |
| 2135 | 1.6.4.1.6.6.15 | **Wave 4 Test Data** |  | 45d | 2025-11-06 | 2026-01-08 |  |  |  | 2025-11-06 | 2026-01-08 | 0d |  |  |  |  | Non-SIT S&A QT Test Team | S&A Qualification | -168.67 | 6.12 | Laura Kennedy |  |  |  |  |  |  |
| 2136 | 1.6.4.1.6.6.15.1 | Test Data Request + Templates Completed |  | 15d | 2025-10-17 | 2025-11-06 |  |  |  | 2025-10-17 | 2025-11-06 | 0d | 525d | 5d | finish no earlier than 2025-11-06 |  | Non-SIT S&A QT Test Team | S&A Qualification | 261.33 | 6.12 | Laura Kennedy | Green | GREEN |  |  |  |  |
| 2137 | 1.6.4.1.6.6.15.2 | Test Data Generated |  | 10d | 2025-11-14 | 2025-11-27 | 2136 |  |  | 2025-11-14 | 2025-11-27 | 0d | 520d | 0d | finish no earlier than 2025-11-27 |  | Non-SIT S&A QT Test Team | S&A Qualification | 289.33 | 6.12 | Laura Kennedy | Green | GREEN |  |  |  |  |
| 2138 | 1.6.4.1.6.6.15.3 | Test Data Loaded into QP Systems |  | 20d | 2025-11-28 | 2025-12-25 | 2137 |  |  | 2025-11-28 | 2025-12-25 | 0d | 520d |  | finish no earlier than 2025-12-11 |  | Non-SIT S&A QT Test Team | S&A Qualification | 303.33 | 6.12 | Laura Kennedy | Green | GREEN |  |  |  |  |
| 2139 | 1.6.4.1.6.6.15.4 | Test Data Loaded into QTF + ADO |  | 20d | 2025-11-28 | 2025-12-25 | 2137 |  |  | 2025-11-28 | 2025-12-25 | 0d | 520d |  | finish no earlier than 2025-12-11 |  | Non-SIT S&A QT Test Team | S&A Qualification | 303.33 | 6.12 | Laura Kennedy | Green | GREEN |  |  |  |  |
| 2140 | 1.6.4.1.6.6.16 | **Governance** |  | 195d | 2024-07-01 A | 2025-03-28 |  | 89% | 21.96d | 2024-07-01 | 2024-12-20 | 0d | 714d |  |  |  | Non-SIT S&A QT Test Team | S&A Qualification | -168.67 | 6.12 | Laura Kennedy |  |  |  |  |  |  |
| 2141 | 1.6.4.1.6.6.16.1 | Onboarding Strategy and Develop Training Requirements & Materials Inc. Day in the Life |  | 120d | 2024-07-01 A | 2024-12-13 A | 2019 | 100% |  | 2024-07-01 | 2024-11-29 | 0d |  |  | finish no earlier than 2024-12-13 |  | Non-SIT S&A QT Test Team | S&A Qualification |  | 6.12 | Laura Kennedy | Complete | COMPLETE |  |  |  |  |
| 2142 | 1.6.4.1.6.6.16.2 | Design Approach & Set-Up ADO Tool for Test & Defect Management Tool |  | 20d | 2024-07-01 A | 2024-07-26 A | 2141SS | 100% |  | 2024-07-01 | 2024-07-26 | 0d |  |  |  |  | Non-SIT S&A QT Test Team | S&A Qualification |  | 6.12 | Laura Kennedy | Complete | COMPLETE |  |  |  |  |
| 2143 | 1.6.4.1.6.6.16.3 | Knowledge Transfer, Training, Demonstrations, Documentation, Governance |  | 78d | 2024-08-30 A | 2024-12-17 A | 2141SS+44d | 100% |  | 2024-08-30 | 2024-12-17 | 0d |  |  |  |  | Non-SIT S&A QT Test Team | S&A Qualification |  | 6.12 | Laura Kennedy | Complete | COMPLETE |  |  |  |  |
| 2144 | 1.6.4.1.6.6.16.4 | BETA Testing |  | 33d | 2024-11-01 A | 2024-12-17 A |  | 100% |  | 2024-11-01 | 2024-12-20 | 0d |  |  | finish no earlier than 2024-12-17 |  | Non-SIT S&A QT Test Team | S&A Qualification |  | 6.12 | Laura Kennedy | Complete | COMPLETE |  |  |  |  |
| 2145 | 1.6.4.1.6.6.16.5 | BETA Testing 2 |  | 58d | 2025-01-08 A | 2025-03-28 | 2144 | 40% | 34.8d | 2025-01-08 | 2025-03-28 | 0d | 714d | 0d | start no earlier than 2025-01-08 |  | Non-SIT S&A QT Test Team | S&A Qualification |  | 6.13 | Laura Kennedy | Green | GREEN |  |  |  |  |
| 2146 | 1.6.4.1.6.6.17 | Qualification Testing Framework Readiness Confirmed | milestone | 0d | 2025-03-28 | 2025-03-28 | 2145 |  |  | 2025-03-28 | 2025-03-28 | 0d | 714d |  | start no earlier than 2025-03-28 |  | Non-SIT S&A QT Test Team | S&A Qualification | 58.71 | 6.12 | Laura Kennedy | Green | GREEN |  |  |  |  |
| 2147 | 1.6.4.1.6.6.18 | Qualification Testing Wave Readiness Confirmed | milestone | 0d | 2025-08-21 | 2025-08-21 | 2175FS-2d |  |  | 2025-08-21 | 2025-08-21 | 0d | 611d |  | finish no earlier than 2025-05-30 |  |  | S&A Qualification | 204.33 | 6.13 |  | Green | GREEN | T2-QU-1100 | T2 |  |  |
| 2148 | 1.6.4.1.7 | **Wave Allocation** |  | 129d | 2024-01-02 A | 2024-06-28 A |  | 100% |  | 2024-01-02 | 2024-06-28 | 128d |  |  |  | -0 | N/A | S&A Qualification | -133.67 | 5.24 | N/A |  |  |  |  | N/A |  |
| 2149 | 1.6.4.1.7.1 | Draft Pre-Qualification Submission (PQS) document |  | 20d | 2024-01-02 A | 2024-01-29 A |  | 100% |  | 2024-01-02 | 2024-01-29 | 20d |  |  | finish no earlier than 2024-01-26 |  | Code Bodies | S&A Qualification |  | 5.24 | Laura Kennedy | Complete | COMPLETE |  |  | Code Bodies |  |
| 2150 | 1.6.4.1.7.2 | Publish PQS document |  | 1d | 2024-01-31 A | 2024-01-31 A |  | 100% |  | 2024-01-31 | 2024-01-31 | 1d |  |  | start no earlier than 2024-01-31 |  | Code Bodies | S&A Qualification |  | 5.24 | Laura Kennedy | Complete | COMPLETE |  |  | Code Bodies |  |
| 2151 | 1.6.4.1.7.3 | PQS Submission window |  | 60d | 2024-02-05 A | 2024-04-26 A |  | 100% |  | 2024-02-05 | 2024-04-26 | 60d |  |  | start no earlier than 2024-02-05 |  | Participants | S&A Qualification |  | 5.24 | Laura Kennedy | Complete | COMPLETE |  |  | Participants |  |
| 2152 | 1.6.4.1.7.4 | Pre-Qualification Submission and PIT Test Plan Deadline for Submission​ | milestone | 0d | 2024-04-26 A | 2024-04-26 A | 2151 | 100% |  | 2024-04-26 | 2024-04-26 | 0d |  |  |  |  | Participants | S&A Qualification |  | 5.25 | Laura Kennedy | Complete | COMPLETE | T3-QU-0118 | T3 | Participants | QAG |
| 2153 | 1.6.4.1.7.5 | PQS Review by Code Bodies |  | 25d | 2024-04-29 A | 2024-05-31 A | 2151, 2152 | 100% |  | 2024-04-29 | 2024-05-31 | 25d |  |  |  |  | Code Bodies | S&A Qualification |  | 5.24 | Laura Kennedy | Complete | COMPLETE |  |  | Code Bodies |  |
| 2154 | 1.6.4.1.7.6 | Draft Wave Allocations |  | 15d | 2024-06-03 A | 2024-06-21 A | 2153 | 100% |  | 2024-06-03 | 2024-06-21 | 15d |  |  |  |  | Code Bodies | S&A Qualification |  | 5.24 | Laura Kennedy | Complete | COMPLETE |  |  | Code Bodies |  |
| 2155 | 1.6.4.1.7.7 | Confirmation of participant Qualification Wave allocation | milestone | 0d | 2024-06-28 A | 2024-06-28 A | 2154FS+5d | 100% |  | 2024-06-28 | 2024-06-28 | 0d |  |  |  |  | Code Bodies | S&A Qualification |  | 5.28 | Laura Kennedy | Complete | COMPLETE | T3-QU-0012 | T3 | Code Bodies | QAG |

| ID | WBS | Task | Type | Duration | Start | Finish | Predecessors | Baseline start | Baseline finish | Baseline duration | Total slack | Free slack | Constraint | Baseline cost | Responsible | Involved | Text9 | Task Status | Update Version | MHHS Resource Name | Sched Status | RAG | Milestone ID | Text29 | Tier |
| --- | --- | --- | --- | --- | --- | --- | --- | --- | --- | --- | --- | --- | --- | --- | --- | --- | --- | --- | --- | --- | --- | --- | --- | --- | --- |
| 2156 | 1.6.4.2 | **Qualification Wave 1** |  | 248d | 2025-05-05 | 2026-04-15 |  | 2025-03-24 | 2026-04-10 | 229d | 0d |  |  | -0 | N/A | N/A | S&A Qualification | -133.67 | 6.13 | N/A |  |  |  |  |  |
| 2157 | 1.6.4.2.1 | **Qualification Wave 1 QAD Prep** |  | 80d | 2025-05-05 | 2025-08-22 |  | 2025-03-24 | 2025-07-11 | 80d | 1d |  |  | -0 | N/A | N/A | S&A Qualification | -152.67 | 6.13 | N/A |  |  |  |  |  |
| 2158 | 1.6.4.2.1.1 | Initial QAD Submission window opens | milestone | 0d | 2025-05-05 | 2025-05-05 | 2155, 1940FS+1d | 2025-05-05 | 2025-05-05 | 0d | 1d | 0d | start no earlier than 2025-03-24 |  | Participants | Participants | S&A Qualification | 96.71 | 6.13 | Laura Kennedy | Green | GREEN |  |  |  |
| 2159 | 1.6.4.2.1.2 | Qualification Wave 1 Participants Submit Initial QAD |  | 50d | 2025-05-05 | 2025-07-11 | 2158FS-1d | 2025-05-05 | 2025-07-11 | 50d | 1d | 0d |  |  | Participants | Participants | S&A Qualification | 96.33 | 6.13 | Laura Kennedy | Green | GREEN |  |  |  |
| 2160 | 1.6.4.2.1.3 | Qualification Wave 1 Participants have submitted their initial QAD | milestone | 0d | 2025-07-14 | 2025-07-14 | 2159FS+1d | 2025-07-14 | 2025-07-14 | 0d | 1d | 0d |  |  | Participants | Participants | S&A Qualification | 166.71 | 6.13 | Laura Kennedy | Green | GREEN | T3-QU-0094 | QAG | T3 |
| 2161 | 1.6.4.2.1.4 | Code Bodies review of Wave 1 Participants Initial QAD |  | 30d | 2025-07-14 | 2025-08-22 | 2159FS-1d, 2160FS-1d | 2025-07-14 | 2025-08-22 | 30d | 1d | 0d |  |  | Code Bodies | Code Bodies | S&A Qualification | 166.33 | 6.13 | Laura Kennedy | Green | GREEN |  |  |  |
| 2162 | 1.6.4.2.1.5 | Completion of Code Bodies review of Initial QAD | milestone | 0d | 2025-08-22 | 2025-08-22 | 2161 | 2025-08-22 | 2025-08-22 | 0d | 1d | 0d |  |  | Code Bodies | Code Bodies | S&A Qualification | 205.71 | 6.13 | Laura Kennedy | Green | GREEN |  |  |  |
| 2163 | 1.6.4.2.2 | **Qualification Wave 1 Test Prep** |  | 60d | 2025-05-26 | 2025-08-15 |  | 2025-04-14 | 2025-07-04 | 60d | 6d |  |  | -0 | N/A | N/A | S&A Qualification | -555.67 | 6.13 | N/A |  |  |  |  |  |
| 2164 | 1.6.4.2.2.1 | Confirmation from Qualification Wave 1 Participants that DIP onboarding has commenced | milestone | 0d | 2025-05-26 | 2025-05-26 |  | 2025-05-26 | 2025-05-26 | 0d | 26d | 0d | start no earlier than 2025-05-26 |  | Participants | Participants | S&A Qualification | 117.33 | 6.13 | Laura Kennedy | Green | GREEN | T3-QU-0017 | QAG | T3 |
| 2165 | 1.6.4.2.2.2 | Qualification Wave 1 Participants DIP Onboarding Window |  | 35d | 2025-05-26 | 2025-07-11 | 2164 | 2025-05-26 | 2025-07-11 | 35d | 26d | 0d |  |  | Participants | Participants | S&A Qualification | 117.33 | 6.13 | Laura Kennedy | Green | GREEN |  |  |  |
| 2166 | 1.6.4.2.2.3 | Confirmation from Qualification Wave 1 Participants that DIP onboarding has completed | milestone | 0d | 2025-07-11 | 2025-07-11 | 2165 | 2025-07-11 | 2025-07-11 | 0d | 26d | 25d |  |  | Participants | Participants | S&A Qualification | 163.71 | 6.13 | Laura Kennedy | Green | GREEN | T3-TE-0017 | QAG | T3 |
| 2167 | 1.6.4.2.2.4 | Qualification Wave 1 Participants' to provide status of PIT completion and submit QT Test Plan | milestone | 0d | 2025-06-13 | 2025-06-13 |  | 2025-06-16 | 2025-06-16 | 0d | 32d | 0d | start no earlier than 2025-06-13 |  | Participants | Participants | S&A Qualification | 135.33 | 6.13 | Laura Kennedy | Green | GREEN | T3-QU-0095 | QAG | T3 |
| 2168 | 1.6.4.2.2.5 | Review of Participants' PIT Status and QT Test Plan |  | 15d | 2025-06-13 | 2025-07-03 | 2167 | 2025-06-16 | 2025-07-04 | 15d | 32d | 0d |  |  | Code Bodies, Non-SIT S&A QT Test Team | Code Bodies, Non-SIT S&A QT Test Team | S&A Qualification | 135.33 | 6.13 | Laura Kennedy | Green | GREEN |  |  |  |
| 2169 | 1.6.4.2.2.6 | Qualification Test Plans for Wave 1 Participants approved | milestone | 0d | 2025-07-03 | 2025-07-03 | 2168 | 2025-07-04 | 2025-07-04 | 0d | 32d | 31d |  |  | Non-SIT S&A QT Test Team | Non-SIT S&A QT Test Team | S&A Qualification | 155.71 | 6.13 | Laura Kennedy | Green | GREEN | T3-QU-0016 | QAG | T3 |
| 2170 | 1.6.4.2.2.7 | Qualification Wave 1 Participants have submitted PIT Test Completion Report and evidence for QT Entry | milestone | 0d | 2025-07-14 | 2025-07-14 |  | 2025-07-14 | 2025-07-14 | 0d | 1d | 0d | start no earlier than 2025-07-14 |  | Participants | Participants | S&A Qualification | 166.33 | 6.13 | Laura Kennedy | Green | GREEN | T3-QU-0096 | QAG | T3 |
| 2171 | 1.6.4.2.2.8 | Review of Participants PIT Test Completion Report |  | 25d | 2025-07-14 | 2025-08-15 | 2170 | 2025-07-14 | 2025-08-15 | 25d | 1d | 0d |  |  | Code Bodies, Non-SIT S&A QT Test Team | Code Bodies, Non-SIT S&A QT Test Team | S&A Qualification | 166.33 | 6.13 | Laura Kennedy | Green | GREEN |  |  |  |
| 2172 | 1.6.4.2.2.9 | Onboarding to QTF & ADO |  | 25d | 2025-07-14 | 2025-08-15 | 2171SS | 2025-07-14 | 2025-08-15 | 25d | 6d |  |  |  | Code Bodies, Non-SIT S&A QT Test Team | Code Bodies, Non-SIT S&A QT Test Team | S&A Qualification | 166.33 | 6.13 | Laura Kennedy | Green | GREEN |  |  |  |
| 2173 | 1.6.4.2.3 | **Qualification Wave 1 QT Execution** |  | 105d | 2025-08-18 | 2026-01-09 |  | 2025-08-18 | 2026-01-09 | 100d | 1d |  |  | -0 | N/A | N/A | S&A Qualification | -152.67 | 6.13 | N/A |  |  |  |  |  |
| 2174 | 1.6.4.2.3.1 | Review Entry Criteria Evidence for each Wave 1 Participant |  | 5d | 2025-08-18 | 2025-08-22 | 2162FF, 2166, 2169, 2171 | 2025-08-18 | 2025-08-22 | 5d | 1d | 0d |  |  | Non-SIT S&A QT Test Team | Non-SIT S&A QT Test Team | S&A Qualification | 201.33 | 6.13 | Laura Kennedy | Green | GREEN |  |  |  |
| 2175 | 1.6.4.2.3.2 | Qualification Wave 1 Participant Test Readiness Confirmed | milestone | 0d | 2025-08-22 | 2025-08-22 | 2161, 2162, 2174FF | 2025-08-22 | 2025-08-22 | 0d | 1d | 0d |  |  | Non-SIT S&A QT Test Team | Non-SIT S&A QT Test Team | S&A Qualification | 205.71 | 6.13 | Laura Kennedy | Green | GREEN | T3-QU-0027 | QAG | T3 |
| 2176 | 1.6.4.2.3.3 | Qualification Wave 1 QT Execution Start | milestone | 0d | 2025-08-25 | 2025-08-25 | 2175, 2172, 1569FS+6d | 2025-08-25 | 2025-08-25 | 0d | 0d |  | start no earlier than 2025-07-14 |  | Participants | Participants | S&A Qualification | 208.71 | 6.13 | Laura Kennedy | Green | GREEN | T3-QU-0028 | QAG | T3 |
| 2177 | 1.6.4.2.3.4 | Qualification Wave 1 QT Execution Window |  | 100d | 2025-08-25 | 2026-01-09 | 2176FS-1d | 2025-08-25 | 2026-01-09 | 95d | 5d | 0d |  |  | Participants | Participants | S&A Qualification | 208.33 | 6.13 | Laura Kennedy | Green | GREEN |  |  |  |
| 2178 | 1.6.4.2.3.5 | Qualification Wave 1 QT Projected Execution End | milestone | 0d | 2026-01-09 | 2026-01-09 | 2177 | 2026-01-09 | 2026-01-09 | 0d | 5d |  |  |  | Participants | Participants | S&A Qualification | 345.71 | 6.13 | Laura Kennedy | Green | GREEN | T3-QU-0054 | QAG | T3 |
| 2179 | 1.6.4.2.4 | **Qualification Wave 1 Exit** |  | 168d | 2025-08-25 | 2026-04-15 |  | 2025-08-25 | 2026-04-15 | 149d? | 0d |  |  | -0 | N/A | N/A | S&A Qualification | -152.67 | 6.13 | N/A |  |  |  |  |  |
| 2180 | 1.6.4.2.4.1 | Final QAD Submission window opens | milestone | 0d | 2025-08-25 | 2025-08-25 | 2176 | 2025-08-25 | 2025-08-25 | 0d | 0d |  |  |  | Participants | Participants | S&A Qualification | 208.71 | 6.13 | Laura Kennedy | Green | GREEN |  |  |  |
| 2181 | 1.6.4.2.4.2 | Qualification Wave 1 Participants submit their Final QAD |  | 105d | 2025-08-25 | 2026-01-16 | 2180FS-1d | 2025-08-25 | 2026-01-16 | 100d | 0d |  |  |  | Participants | Participants | S&A Qualification | 208.33 | 6.13 | Laura Kennedy | Green | GREEN |  |  |  |
| 2182 | 1.6.4.2.4.3 | Qualification Wave 1 Participants have submitted their final QAD | milestone | 0d | 2026-01-16 | 2026-01-16 | 2181, 2178 | 2026-01-16 | 2026-01-16 | 0d | 0d |  |  |  | Participants | Participants | S&A Qualification | 352.71 | 6.13 | Laura Kennedy | Green | GREEN | T3-QU-0097 | QAG | T3 |
| 2183 | 1.6.4.2.4.4 | Completion of Code Bodies review of Final QAD |  | 35d | 2026-01-19 | 2026-03-06 | 2181, 2182 | 2026-01-19 | 2026-03-06 | 20d | 0d |  |  |  | Code Bodies | Code Bodies | S&A Qualification | 355.33 | 6.13 | Laura Kennedy | Green | GREEN |  |  |  |
| 2184 | 1.6.4.2.4.5 | QAD Sign Off deadline |  | 1d | 2026-03-20 | 2026-03-20 | 2183FS+9d | 2026-03-20 | 2026-03-20 | 1d | 0d |  |  |  | Participants | Participants | S&A Qualification | 415.33 | 6.13 | Laura Kennedy | Green | GREEN |  |  |  |
| 2185 | 1.6.4.2.4.6 | Qualification Wave 1 Participants Qualification approved by BSC PAB and REC Manager | milestone | 0d | 2026-04-15 | 2026-04-15 | 2184FS+18d | 2026-04-15 | 2026-04-15 | 0d | 0d |  |  |  | Code Bodies | Code Bodies | S&A Qualification | 441.71 | 6.13 | Laura Kennedy | Green | GREEN | T2-QU-0150 | QAG | T2 |

| ID | WBS | Task | Type | Duration | Start | Finish | Predecessors | Baseline start | Baseline finish | Baseline duration | Total slack | Free slack | Constraint | Baseline cost | Responsible | Involved | Text9 | Task Status | Update Version | MHHS Resource Name | Sched Status | RAG | Milestone ID | Text29 | Tier |
| --- | --- | --- | --- | --- | --- | --- | --- | --- | --- | --- | --- | --- | --- | --- | --- | --- | --- | --- | --- | --- | --- | --- | --- | --- | --- |
| 2186 | 1.6.4.3 | **Qualification Wave 2** |  | 254d | 2025-06-09 | 2026-05-28 |  | 2025-06-09 | 2026-05-28 | 249d | 0d |  |  | -0 | N/A | N/A | S&A Qualification | -133.67 | 6.13 | N/A |  |  |  |  |  |
| 2187 | 1.6.4.3.1 | **Qualification Wave 2 QAD Prep** |  | 95d | 2025-06-09 | 2025-10-17 |  | 2025-06-09 | 2025-10-17 | 96d | 0d |  |  | -0 | N/A | N/A | S&A Qualification | -154.67 | 6.13 | N/A |  |  |  |  |  |
| 2188 | 1.6.4.3.1.1 | Initial QAD Submission window opens | milestone | 0d | 2025-06-09 | 2025-06-09 | 1941FS+1d | 2025-06-09 | 2025-06-09 | 0d | 0d |  |  |  | Participants | Participants | S&A Qualification | 131.71 | 6.13 | Laura Kennedy | Green | GREEN |  |  |  |
| 2189 | 1.6.4.3.1.2 | Qualification Wave 2 Participants Submit Initial QAD |  | 70d | 2025-06-09 | 2025-09-12 | 2188FS-1d | 2025-06-09 | 2025-09-12 | 70d | 0d |  |  |  | Participants | Participants | S&A Qualification | 131.33 | 6.13 | Laura Kennedy | Green | GREEN |  |  |  |
| 2190 | 1.6.4.3.1.3 | Qualification Wave 2 Participants have submitted their initial QAD | milestone | 0d | 2025-09-12 | 2025-09-12 | 2189 | 2025-09-12 | 2025-09-12 | 0d | 0d |  |  |  | Participants | Participants | S&A Qualification | 226.71 | 6.13 | Laura Kennedy | Green | GREEN | T3-QU-0098 | QAG | T3 |
| 2191 | 1.6.4.3.1.4 | Code Bodies review of Wave 2 Participants' Initial QAD |  | 25d | 2025-09-15 | 2025-10-17 | 2190 | 2025-09-15 | 2025-10-17 | 26d | 0d |  |  |  | Code Bodies | Code Bodies | S&A Qualification | 229.33 | 6.13 | Laura Kennedy | Green | GREEN |  |  |  |
| 2192 | 1.6.4.3.1.5 | Completion of Code Bodies review of Initial QAD | milestone | 0d | 2025-10-17 | 2025-10-17 | 2191 | 2025-10-17 | 2025-10-17 | 0d | 0d |  |  |  | Code Bodies | Code Bodies | S&A Qualification | 261.71 | 6.13 | Laura Kennedy | Green | GREEN |  |  |  |
| 2193 | 1.6.4.3.2 | **Qualification Wave 2 Test Prep** |  | 60d | 2025-07-21 | 2025-10-10 |  | 2025-07-21 | 2025-10-10 | 60d | 6d |  |  | -0 | N/A | N/A | S&A Qualification | -555.67 | 6.13 | N/A |  |  |  |  |  |
| 2194 | 1.6.4.3.2.1 | Confirmation from Qualification Wave 2 Participants that DIP Onboarding has commenced | milestone | 0d | 2025-07-21 | 2025-07-21 |  | 2025-07-21 | 2025-07-21 | 0d | 25d | 0d | start no earlier than 2025-07-21 |  | Participants | Participants | S&A Qualification | 173.33 | 6.13 | Laura Kennedy | Green | GREEN | T3-QU-0021 | QAG | T3 |
| 2195 | 1.6.4.3.2.2 | Qualification Wave 2 Participants DIP Onboarding Window |  | 35d | 2025-07-21 | 2025-09-05 | 2194 | 2025-07-21 | 2025-09-05 | 40d | 25d | 0d |  |  | Participants | Participants | S&A Qualification | 173.33 | 6.13 | Laura Kennedy | Green | GREEN |  |  |  |
| 2196 | 1.6.4.3.2.3 | Confirmation from Qualificiation Wave 2 Participants that DIP onboarding has completed | milestone | 0d | 2025-09-05 | 2025-09-05 | 2195 | 2025-09-05 | 2025-09-05 | 0d | 25d |  |  |  | Participants | Participants | S&A Qualification | 219.71 | 6.13 | Laura Kennedy | Green | GREEN |  |  |  |
| 2197 | 1.6.4.3.2.4 | Qualification Wave 2 Participants' to provide status of PIT completion and submit QT Test Plan | milestone | 0d | 2025-08-18 | 2025-08-18 |  | 2025-08-18 | 2025-08-18 | 0d | 25d | 0d | start no earlier than 2025-08-18 |  | Participants | Participants | S&A Qualification | 201.33 | 6.13 | Laura Kennedy | Green | GREEN | T3-QU-0099 | QAG | T3 |
| 2198 | 1.6.4.3.2.5 | Review of Participants' PIT Status and QT Test Plan |  | 15d | 2025-08-18 | 2025-09-05 | 2197 | 2025-08-18 | 2025-09-05 | 15d | 25d | 0d | start no earlier than 2025-07-07 |  | Code Bodies, Non-SIT S&A QT Test Team | Code Bodies, Non-SIT S&A QT Test Team | S&A Qualification | 201.33 | 6.13 | Laura Kennedy | Green | GREEN |  |  |  |
| 2199 | 1.6.4.3.2.6 | Qualification Test Plans for Wave 2 Participants approved | milestone | 0d | 2025-09-05 | 2025-09-05 | 2198 | 2025-09-05 | 2025-09-05 | 0d | 25d |  | start no earlier than 2025-07-25 |  | Non-SIT S&A QT Test Team | Non-SIT S&A QT Test Team | S&A Qualification | 219.71 | 6.13 | Laura Kennedy | Green | GREEN | T3-QU-0020 | QAG | T3 |
| 2200 | 1.6.4.3.2.7 | Qualification Wave 2 Participants have submitted PIT Test Completion Report and evidence for QT entry | milestone | 0d | 2025-09-08 | 2025-09-08 |  | 2025-09-08 | 2025-09-08 | 0d | 0d |  | start no earlier than 2025-09-08 |  | Participants | Participants | S&A Qualification | 222.33 | 6.13 | Laura Kennedy | Green | GREEN | T3-QU-0100 | QAG | T3 |
| 2201 | 1.6.4.3.2.8 | Review of Participants' PIT Test Completion Report |  | 25d | 2025-09-08 | 2025-10-10 | 2200 | 2025-09-08 | 2025-10-10 | 25d | 0d |  |  |  | Code Bodies, Non-SIT S&A QT Test Team | Code Bodies, Non-SIT S&A QT Test Team | S&A Qualification | 222.33 | 6.13 | Laura Kennedy | Green | GREEN |  |  |  |
| 2202 | 1.6.4.3.2.9 | Onboarding to QTF & ADO |  | 25d | 2025-09-08 | 2025-10-10 | 2201SS | 2025-09-08 | 2025-10-10 | 25d | 6d |  |  |  | Code Bodies, Non-SIT S&A QT Test Team | Code Bodies, Non-SIT S&A QT Test Team | S&A Qualification | 222.33 | 6.13 | Laura Kennedy | Green | GREEN |  |  |  |
| 2203 | 1.6.4.3.3 | **Qualification Wave 2 QT Execution** |  | 100d | 2025-10-13 | 2026-02-27 |  | 2025-10-13 | 2026-02-27 | 99d | 0d |  |  | -0 | N/A | N/A | S&A Qualification | -154.67 | 6.13 | N/A |  |  |  |  |  |
| 2204 | 1.6.4.3.3.1 | Review Entry Criteria Evidence for each Wave 2 Participant |  | 5d | 2025-10-13 | 2025-10-17 | 2192FF, 2196, 2199, 2201 | 2025-10-13 | 2025-10-17 | 5d | 0d |  |  |  | Non-SIT S&A QT Test Team | Non-SIT S&A QT Test Team | S&A Qualification | 257.33 | 6.13 | Laura Kennedy | Green | GREEN |  |  |  |
| 2205 | 1.6.4.3.3.2 | Qualification Wave 2 Participant Test Readiness Confirmed | milestone | 0d | 2025-10-17 | 2025-10-17 | 2204, 2192 | 2025-10-17 | 2025-10-17 | 0d | 0d |  |  |  | Non-SIT S&A QT Test Team | Non-SIT S&A QT Test Team | S&A Qualification | 261.71 | 6.13 | Laura Kennedy | Green | GREEN | T3-QU-0033 | QAG | T3 |
| 2206 | 1.6.4.3.3.3 | Qualification Wave 2 Execution Start | milestone | 0d | 2025-10-20 | 2025-10-20 | 2205FS+1d, 2202 | 2025-10-20 | 2025-10-20 | 0d | 0d |  |  |  | Participants | Participants | S&A Qualification | 264.71 | 6.13 | Laura Kennedy | Green | GREEN | T3-QU-0034 | QAG | T3 |
| 2207 | 1.6.4.3.3.4 | Qualification Wave 2 QT Execution Window |  | 95d | 2025-10-20 | 2026-02-27 | 2206SS-1d | 2025-10-20 | 2026-02-27 | 94d | 5d | 0d |  |  | Participants | Participants | S&A Qualification | 264.33 | 6.13 | Laura Kennedy | Green | GREEN |  |  |  |
| 2208 | 1.6.4.3.3.5 | Qualfication Wave 2 QT Execution End | milestone | 0d | 2026-02-27 | 2026-02-27 | 2207 | 2026-02-27 | 2026-02-27 | 0d | 5d |  |  |  | Participants | Participants | S&A Qualification | 394.71 | 6.13 | Laura Kennedy | Green | GREEN | T3-QU-0055 | QAG | T3 |
| 2209 | 1.6.4.3.4 | **Qualification Wave 2 Exit** |  | 159d | 2025-10-20 | 2026-05-28 |  | 2025-10-20 | 2026-05-28 | 153d | 0d |  |  | -0 | N/A | N/A | S&A Qualification | -154.67 | 6.13 | N/A |  |  |  |  |  |
| 2210 | 1.6.4.3.4.1 | Final QAD Submission window opens | milestone | 0d | 2025-10-20 | 2025-10-20 | 2206 | 2025-10-20 | 2025-10-20 | 0d | 0d |  |  |  | Participants | Participants | S&A Qualification | 264.71 | 6.13 | Laura Kennedy | Green | GREEN |  |  |  |
| 2211 | 1.6.4.3.4.2 | Qualification Wave 2 Participants submit their Final QAD |  | 100d | 2025-10-20 | 2026-03-06 | 2210FS-1d | 2025-10-20 | 2026-03-06 | 99d | 0d |  |  |  | Participants | Participants | S&A Qualification | 264.33 | 6.13 | Laura Kennedy | Green | GREEN |  |  |  |
| 2212 | 1.6.4.3.4.3 | Qualification Wave 2 Participants have submitted their final QAD | milestone | 0d | 2026-03-06 | 2026-03-06 | 2211, 2208 | 2026-03-06 | 2026-03-06 | 0d | 0d |  |  |  | Participants | Participants | S&A Qualification | 401.71 | 6.13 | Laura Kennedy | Green | GREEN | T3-QU-0101 | QAG | T3 |
| 2213 | 1.6.4.3.4.4 | Completion of Code Bodies review of Final QAD |  | 26d | 2026-03-09 | 2026-04-13 | 2212 | 2026-03-09 | 2026-04-13 | 27d | 0d |  |  |  | Code Bodies | Code Bodies | S&A Qualification | 404.33 | 6.13 | Laura Kennedy | Green | GREEN |  |  |  |
| 2214 | 1.6.4.3.4.5 | QAD Sign Off deadline |  | 1d | 2026-04-20 | 2026-04-20 | 2213FS+4d | 2026-04-20 | 2026-04-20 | 1d | 0d |  |  |  | Participants | Participants | S&A Qualification | 446.33 | 6.13 | Laura Kennedy | Green | GREEN |  |  |  |
| 2215 | 1.6.4.3.4.6 | Qualification Wave 2 Participants Qualification approved by BSC PAB and REC Manager | milestone | 0d | 2026-05-28 | 2026-05-28 | 2214FS+28d | 2026-05-28 | 2026-05-28 | 0d | 0d |  |  |  | Code Bodies | Code Bodies | S&A Qualification | 484.71 | 6.13 | Laura Kennedy | Green | GREEN | T2-QU-0200 | QAG | T2 |

| ID | WBS | Task | Type | Duration | Start | Finish | Predecessors | Baseline start | Baseline finish | Baseline duration | Total slack | Free slack | Constraint | Baseline cost | Responsible | Involved | Text9 | Task Status | Update Version | MHHS Resource Name | Sched Status | RAG | Milestone ID | Text29 | Tier |
| --- | --- | --- | --- | --- | --- | --- | --- | --- | --- | --- | --- | --- | --- | --- | --- | --- | --- | --- | --- | --- | --- | --- | --- | --- | --- |
| 2216 | 1.6.4.4 | **Qualification Wave 3** |  | 254d | 2025-08-11 | 2026-07-30 |  | 2025-08-11 | 2026-07-30 | 239d | 0d |  |  | -0 | N/A | N/A | S&A Qualification | -133.67 | 6.13 | N/A |  |  |  |  |  |
| 2217 | 1.6.4.4.1 | **Qualification Wave 3 QAD Prep** |  | 95d | 2025-08-11 | 2025-12-19 |  | 2025-08-11 | 2025-12-19 | 95d | 0d |  |  | -0 | N/A | N/A | S&A Qualification | -154.67 | 6.13 | N/A |  |  |  |  |  |
| 2218 | 1.6.4.4.1.1 | Initial QAD Submission window opens | milestone | 0d | 2025-08-11 | 2025-08-11 | 1942FS+1d | 2025-08-11 | 2025-08-11 | 0d | 0d |  |  |  | Participants | Participants | S&A Qualification | 194.71 | 6.13 | Laura Kennedy | Green | GREEN |  |  |  |
| 2219 | 1.6.4.4.1.2 | Qualification Wave 3 Participants Submit Initial QAD |  | 65d | 2025-08-11 | 2025-11-07 | 2218FS-1d | 2025-08-11 | 2025-11-07 | 65d | 0d |  |  |  | Participants | Participants | S&A Qualification | 194.33 | 6.13 | Laura Kennedy | Green | GREEN |  |  |  |
| 2220 | 1.6.4.4.1.3 | Qualification Wave 3 Participants have submitted their initial QAD | milestone | 0d | 2025-11-07 | 2025-11-07 | 2219 | 2025-11-07 | 2025-11-07 | 0d | 0d |  |  |  | Participants | Participants | S&A Qualification | 282.71 | 6.13 | Laura Kennedy | Green | GREEN | T3-QU-0102 | QAG | T3 |
| 2221 | 1.6.4.4.1.4 | Code Bodies review of Wave 3 Participants' Initial QAD |  | 30d | 2025-11-10 | 2025-12-19 | 2220 | 2025-11-10 | 2025-12-19 | 30d | 0d |  |  |  | Code Bodies | Code Bodies | S&A Qualification | 285.33 | 6.13 | Laura Kennedy | Green | GREEN |  |  |  |
| 2222 | 1.6.4.4.1.5 | Completion of Code Bodies review of Initial QAD | milestone | 0d | 2025-12-19 | 2025-12-19 | 2221 | 2025-12-19 | 2025-12-19 | 0d | 0d |  |  |  | Code Bodies | Code Bodies | S&A Qualification | 324.71 | 6.13 | Laura Kennedy | Green | GREEN |  |  |  |
| 2223 | 1.6.4.4.2 | **Qualification Wave 3 Test Prep** |  | 65d | 2025-09-15 | 2025-12-12 |  | 2025-09-15 | 2025-12-12 | 65d | 30d |  |  | -0 | N/A | N/A | S&A Qualification | -555.67 | 6.13 | N/A |  |  |  |  |  |
| 2224 | 1.6.4.4.2.1 | Confirmation from Qualification Wave 3 Participants that DIP Onboarding has commenced | milestone | 0d | 2025-09-15 | 2025-09-15 |  | 2025-09-15 | 2025-09-15 | 0d | 30d | 0d | start no earlier than 2025-09-15 |  | Participants | Participants | S&A Qualification | 229.33 | 6.13 | Laura Kennedy | Green | GREEN | T3-QU-0025 | QAG | T3 |
| 2225 | 1.6.4.4.2.2 | Qualification Wave 3 Participants DIP Onboarding window |  | 35d | 2025-09-15 | 2025-10-31 | 2224 | 2025-09-15 | 2025-10-31 | 40d | 30d | 0d | start no earlier than 2025-08-04 |  | Participants | Participants | S&A Qualification | 229.33 | 6.13 | Laura Kennedy | Green | GREEN |  |  |  |
| 2226 | 1.6.4.4.2.3 | Confirmation from Qualification Wave 3 Participants that DIP onboarding has completed | milestone | 0d | 2025-10-31 | 2025-10-31 | 2225 | 2025-10-31 | 2025-10-31 | 0d | 30d |  | start no earlier than 2025-09-22 |  | Participants | Participants | S&A Qualification | 275.71 | 6.13 | Laura Kennedy | Green | GREEN |  |  |  |
| 2227 | 1.6.4.4.2.4 | Qualification Wave 3 Participants' to provide status of PIT completion and submit QT Test Plan | milestone | 0d | 2025-10-20 | 2025-10-20 |  | 2025-10-20 | 2025-10-20 | 0d | 554d | 0d | start no earlier than 2025-10-20 |  | Participants | Participants | S&A Qualification | 264.33 | 6.13 | Laura Kennedy | Green | GREEN | T3-QU-0103 | QAG | T3 |
| 2228 | 1.6.4.4.2.5 | Review of Participants' PIT Status and QT Test Plan |  | 15d | 2025-10-20 | 2025-11-07 | 2227 | 2025-10-20 | 2025-11-07 | 15d | 554d | 0d | start no earlier than 2025-09-08 |  | Code Bodies, Non-SIT S&A QT Test Team | Code Bodies, Non-SIT S&A QT Test Team | S&A Qualification | 264.33 | 6.13 | Laura Kennedy | Green | GREEN |  |  |  |
| 2229 | 1.6.4.4.2.6 | Qualification Test Plans for Wave 3 Participants approved | milestone | 0d | 2025-11-07 | 2025-11-07 | 2228 | 2025-11-07 | 2025-11-07 | 0d | 554d |  | start no earlier than 2025-09-26 |  | Non-SIT S&A QT Test Team | Non-SIT S&A QT Test Team | S&A Qualification | 282.71 | 6.13 | Laura Kennedy | Green | GREEN | T3-QU-0024 | QAG | T3 |
| 2230 | 1.6.4.4.2.7 | Qualification Wave 3 Participants have submitted PIT Test Completion Report and evidence for QT Entry | milestone | 0d | 2025-11-10 | 2025-11-10 |  | 2025-11-10 | 2025-11-10 | 0d | 0d |  | start no earlier than 2025-11-10 |  | Participants | Participants | S&A Qualification | 285.33 | 6.13 | Laura Kennedy | Green | GREEN | T3-QU-0104 | QAG | T3 |
| 2231 | 1.6.4.4.2.8 | Review of Participants' PIT Test Completion Report |  | 25d | 2025-11-10 | 2025-12-12 | 2230 | 2025-11-10 | 2025-12-12 | 30d | 0d |  | start no earlier than 2025-09-29 |  | Code Bodies, Non-SIT S&A QT Test Team | Code Bodies, Non-SIT S&A QT Test Team | S&A Qualification | 285.33 | 6.13 | Laura Kennedy | Green | GREEN |  |  |  |
| 2232 | 1.6.4.4.2.9 | Onboarding to QTF & ADO |  | 25d | 2025-11-10 | 2025-12-12 | 2231SS | 2025-11-10 | 2025-12-12 | 30d | 0d |  | finish no earlier than 2025-10-31 |  |  |  | S&A Qualification | 285.33 | 6.13 | Laura Kennedy | Green | GREEN |  |  |  |
| 2233 | 1.6.4.4.3 | **Qualification Wave 3 QT Execution** |  | 102d | 2025-11-03 | 2026-03-24 |  | 2025-11-03 | 2026-03-24 | 100d |  |  |  | -0 | N/A | N/A | S&A Qualification | -154.67 | 6.13 | N/A |  |  |  |  |  |
| 2234 | 1.6.4.4.3.1 | Review Entry Criteria Evidence for each Wave 3 Participant |  | 5d | 2025-12-15 | 2025-12-19 | 2226, 2222FF, 2232 | 2025-12-15 | 2025-12-19 | 5d | 0d |  | start no earlier than 2025-11-03 |  | Non-SIT S&A QT Test Team | Non-SIT S&A QT Test Team | S&A Qualification | 320.33 | 6.13 | Laura Kennedy | Green | GREEN |  |  |  |
| 2235 | 1.6.4.4.3.2 | Qualification Wave 3 Participant Test Readiness confirmed | milestone | 0d | 2025-12-19 | 2025-12-19 | 2226, 2234 | 2025-12-19 | 2025-12-19 | 0d | 0d |  |  |  | Non-SIT S&A QT Test Team | Non-SIT S&A QT Test Team | S&A Qualification | 324.71 | 6.13 | Laura Kennedy | Green | GREEN | T3-QU-0038 | QAG | T3 |
| 2236 | 1.6.4.4.3.3 | Qualification Wave 3 Execution Start | milestone | 0d | 2026-01-12 | 2026-01-12 | 2235FS+16d, 2232FS+1d | 2026-01-12 | 2026-01-12 | 0d | 0d |  | start no earlier than 2025-11-03 |  | Participants | Participants | S&A Qualification | 348.71 | 6.13 | Laura Kennedy | Green | GREEN | T3-QU-0039 | QAG | T3 |
| 2237 | 1.6.4.4.3.4 | Qualification Wave 3 QT Execution Window |  | 90d | 2026-01-12 | 2026-05-15 | 2234, 2236FS-1d | 2026-01-12 | 2026-05-15 | 95d | 5d | 0d |  |  | Participants | Participants | S&A Qualification | 348.33 | 6.13 | Laura Kennedy | Green | GREEN |  |  |  |
| 2238 | 1.6.4.4.3.5 | Qualification Wave 3 Projected Execution End | milestone | 0d | 2026-05-15 | 2026-05-15 | 2237 | 2026-05-15 | 2026-05-15 | 0d | 5d |  |  |  | Participants | Participants | S&A Qualification | 471.71 | 6.13 | Laura Kennedy | Green | GREEN | T3-QU-0056 | QAG | T3 |
| 2239 | 1.6.4.4.4 | **Qualification Wave 3 Exit** |  | 144d | 2026-01-12 | 2026-07-30 |  | 2026-01-12 | 2026-07-30 | 144d | 0d |  |  | -0 | N/A | N/A | S&A Qualification | -154.67 | 6.13 | N/A |  |  |  |  |  |
| 2240 | 1.6.4.4.4.1 | Final QAD Submission window opens | milestone | 0d | 2026-01-12 | 2026-01-12 | 2236 | 2026-01-12 | 2026-01-12 | 0d | 0d |  |  |  | Participants | Participants | S&A Qualification | 348.71 | 6.13 | Laura Kennedy | Green | GREEN |  |  |  |
| 2241 | 1.6.4.4.4.2 | Qualification Wave 3 Participants submit their Final QAD |  | 95d | 2026-01-12 | 2026-05-22 | 2240FS-1d | 2026-01-12 | 2026-05-22 | 100d | 0d |  |  |  | Participants | Participants | S&A Qualification | 348.33 | 6.13 | Laura Kennedy | Green | GREEN |  |  |  |
| 2242 | 1.6.4.4.4.3 | Qualification Wave 3 Participants have submitted their Final QAD | milestone | 0d | 2026-05-22 | 2026-05-22 | 2241, 2238 | 2026-05-22 | 2026-05-22 | 0d | 0d |  |  |  | Participants | Participants | S&A Qualification | 478.71 | 6.13 | Laura Kennedy | Green | GREEN | T3-QU-0105 | QAG | T3 |
| 2243 | 1.6.4.4.4.4 | Completion of Code Bodies review of Final QAD |  | 20d | 2026-05-25 | 2026-06-19 | 2242 | 2026-05-25 | 2026-06-19 | 20d | 0d |  |  |  | Code Bodies | Code Bodies | S&A Qualification | 481.33 | 6.13 | Laura Kennedy | Green | GREEN |  |  |  |
| 2244 | 1.6.4.4.4.5 | QAD Sign Off deadline |  | 1d | 2026-06-26 | 2026-06-26 | 2243FS+4d | 2026-06-26 | 2026-06-26 | 1d | 0d |  |  |  | Participants | Participants | S&A Qualification | 513.33 | 6.13 | Laura Kennedy | Green | GREEN |  |  |  |
| 2245 | 1.6.4.4.4.6 | Qualification Wave 3 Participants Qualification approved by BSC PAB and REC Manager | milestone | 0d | 2026-07-30 | 2026-07-30 | 2244FS+24d | 2026-07-30 | 2026-07-30 | 0d | 0d |  |  |  | Code Bodies | Code Bodies | S&A Qualification | 547.71 | 6.13 | Laura Kennedy | Green | GREEN | T2-QU-0250 | QAG | T2 |

| ID | WBS | Task | Type | Duration | Start | Finish | Predecessors | Baseline start | Baseline finish | Baseline duration | Total slack | Free slack | Constraint | Baseline cost | Responsible | Involved | Text9 | Task Status | Update Version | MHHS Resource Name | Sched Status | RAG | Milestone ID | Text29 | Tier |
| --- | --- | --- | --- | --- | --- | --- | --- | --- | --- | --- | --- | --- | --- | --- | --- | --- | --- | --- | --- | --- | --- | --- | --- | --- | --- |
| 2246 | 1.6.4.5 | **Qualification Wave 4** |  | 334d | 2025-10-20 | 2027-01-28 |  | 2025-10-20 | 2027-01-28 | 249d | 0d |  |  | -0 | N/A | N/A | S&A Qualification | -133.67 | 6.13 | N/A |  |  |  |  |  |
| 2247 | 1.6.4.5.1 | **Qualification Wave 4 QAD Prep** |  | 95d | 2025-10-20 | 2026-02-27 |  | 2025-10-20 | 2026-02-27 | 99d | 0d |  |  | -0 | N/A | N/A | S&A Qualification | -155.67 | 6.13 | N/A |  |  |  |  |  |
| 2248 | 1.6.4.5.1.1 | Initial QAD Submission window opens | milestone | 0d | 2025-10-20 | 2025-10-20 | 1943FS+1d | 2025-10-20 | 2025-10-20 | 0d | 0d |  |  |  | Participants | Participants | S&A Qualification | 264.71 | 6.13 | Laura Kennedy | Green | GREEN |  |  |  |
| 2249 | 1.6.4.5.1.2 | Qualification Wave 4 Participants Submit Initial QAD |  | 65d | 2025-10-20 | 2026-01-16 | 2248FS-1d | 2025-10-20 | 2026-01-16 | 70d | 0d |  |  |  | Participants | Participants | S&A Qualification | 264.33 | 6.13 | Laura Kennedy | Green | GREEN |  |  |  |
| 2250 | 1.6.4.5.1.3 | Qualification Wave 4 Participants have submitted their Initial QAD | milestone | 0d | 2026-01-16 | 2026-01-16 | 2249 | 2026-01-16 | 2026-01-16 | 0d | 0d |  |  |  | Participants | Participants | S&A Qualification | 352.71 | 6.13 | Laura Kennedy | Green | GREEN | T3-QU-0106 | QAG | T3 |
| 2251 | 1.6.4.5.1.4 | Code Bodies review of Wave 4 Participants' Initial QAD |  | 30d | 2026-01-19 | 2026-02-27 | 2250 | 2026-01-19 | 2026-02-27 | 29d | 0d |  |  |  | Code Bodies | Code Bodies | S&A Qualification | 355.33 | 6.13 | Laura Kennedy | Green | GREEN |  |  |  |
| 2252 | 1.6.4.5.1.5 | Completion of Code Bodies review of Initial QAD | milestone | 0d | 2026-02-27 | 2026-02-27 | 2251 | 2026-02-27 | 2026-02-27 | 0d | 0d |  |  |  | Code Bodies | Code Bodies | S&A Qualification | 394.71 | 6.13 | Laura Kennedy | Green | GREEN |  |  |  |
| 2253 | 1.6.4.5.2 | **Qualification Wave 4 Test Prep** |  | 75d | 2025-11-03 | 2026-02-13 |  | 2025-11-03 | 2026-02-13 | 67d | 16d |  |  | -0 | N/A | N/A | S&A Qualification | -555.67 | 6.13 | N/A |  |  |  |  |  |
| 2254 | 1.6.4.5.2.1 | Confirmation from Qualification 4 Participants that DIP Onboarding has commenced | milestone | 0d | 2025-11-03 | 2025-11-03 |  | 2025-11-03 | 2025-11-03 | 0d | 50d | 0d | start no earlier than 2025-11-03 |  | Participants | Participants | S&A Qualification | 278.33 | 6.13 | Laura Kennedy | Green | GREEN | T3-QU-0031 | QAG | T3 |
| 2255 | 1.6.4.5.2.2 | Qualification Wave 4 Participants DIP Onboarding Window |  | 35d | 2025-11-03 | 2025-12-19 | 2254 | 2025-11-03 | 2025-12-19 | 42d | 50d | 0d |  |  | Participants | Participants | S&A Qualification | 278.33 | 6.13 | Laura Kennedy | Green | GREEN |  |  |  |
| 2256 | 1.6.4.5.2.3 | Confirmation from Qualification Wave 4 Participants that DIP onboarding has completed | milestone | 0d | 2025-12-19 | 2025-12-19 | 2255 | 2025-12-19 | 2025-12-19 | 0d | 50d |  |  |  | Participants | Participants | S&A Qualification | 324.71 | 6.13 | Laura Kennedy | Green | GREEN |  |  |  |
| 2257 | 1.6.4.5.2.4 | Qualification Wave 4 Participants' to provide status of PIT completion and submit QT Test Plan | milestone | 0d | 2025-12-08 | 2025-12-08 |  | 2025-12-08 | 2025-12-08 | 0d | 16d | 0d | start no earlier than 2025-12-08 |  | Participants | Participants | S&A Qualification | 313.33 | 6.13 | Laura Kennedy | Green | GREEN | T3-QU-0107 | QAG | T3 |
| 2258 | 1.6.4.5.2.5 | Review of Participants' PIT Status and QT Test Plan |  | 25d | 2025-12-08 | 2026-01-09 | 2257 | 2025-12-08 | 2026-01-09 | 16d | 16d | 0d |  |  | Code Bodies, Non-SIT S&A QT Test Team | Code Bodies, Non-SIT S&A QT Test Team | S&A Qualification | 313.33 | 6.13 | Laura Kennedy | Green | GREEN |  |  |  |
| 2259 | 1.6.4.5.2.6 | Qualification Test Plans for Qualification Wave 4 Participants approved | milestone | 0d | 2026-01-09 | 2026-01-09 | 2258 | 2026-01-09 | 2026-01-09 | 0d | 16d | 0d |  |  | Non-SIT S&A QT Test Team | Non-SIT S&A QT Test Team | S&A Qualification | 345.71 | 6.13 | Laura Kennedy | Green | GREEN | T3-QU-0030 | QAG | T3 |
| 2260 | 1.6.4.5.2.7 | Qualification Wave 4 Participants have submitted PIT Test Completion Report and evidence for QT entry | milestone | 0d | 2026-01-09 | 2026-01-09 | 2259 | 2026-01-09 | 2026-01-09 | 0d | 16d | 0d |  |  | Participants | Participants | S&A Qualification | 345.71 | 6.13 | Laura Kennedy | Green | GREEN | T3-QU-0108 | QAG | T3 |
| 2261 | 1.6.4.5.2.8 | Review of Participants' PIT Test Completion Report |  | 25d | 2026-01-12 | 2026-02-13 | 2260 | 2026-01-12 | 2026-02-13 | 30d | 16d | 0d |  |  | Code Bodies, Non-SIT S&A QT Test Team | Code Bodies, Non-SIT S&A QT Test Team | S&A Qualification | 348.33 | 6.13 | Laura Kennedy | Green | GREEN |  |  |  |
| 2262 | 1.6.4.5.2.9 | Onboarding to QTF & ADO |  | 25d | 2026-01-12 | 2026-02-13 | 2261SS | 2026-01-12 | 2026-02-13 | 30d | 16d |  | start no earlier than 2025-11-24 |  | Code Bodies, Non-SIT S&A QT Test Team | Code Bodies, Non-SIT S&A QT Test Team | S&A Qualification | 348.33 | 6.13 | Laura Kennedy | Green | GREEN |  |  |  |
| 2263 | 1.6.4.5.3 | **Qualification Wave 4 QT Execution** |  | 100d | 2026-03-02 | 2026-07-17 |  | 2026-03-02 | 2026-07-17 | 101d | 0d |  |  | -0 | N/A | N/A | S&A Qualification | -155.67 | 6.13 | N/A |  |  |  |  |  |
| 2264 | 1.6.4.5.3.1 | Review Entry Criteria Evidence for each Wave 4 Participant |  | 5d | 2026-03-02 | 2026-03-06 | 2252FF+5d, 2256 | 2026-03-02 | 2026-03-06 | 5d | 0d |  |  |  | Non-SIT S&A QT Test Team | Non-SIT S&A QT Test Team | S&A Qualification | 397.33 | 6.13 | Laura Kennedy | Green | GREEN |  |  |  |
| 2265 | 1.6.4.5.3.2 | Qualification Wave 4 Participant Test Readiness Confirmed | milestone | 0d | 2026-03-06 | 2026-03-06 | 2256, 2264 | 2026-03-06 | 2026-03-06 | 0d | 0d |  |  |  | Non-SIT S&A QT Test Team | Non-SIT S&A QT Test Team | S&A Qualification | 401.71 | 6.13 | Laura Kennedy | Green | GREEN | T3-QU-0043 | QAG | T3 |
| 2266 | 1.6.4.5.3.3 | Qualification Wave 4 QT Execution Start | milestone | 0d | 2026-03-09 | 2026-03-09 | 2265FS+1d, 2262 | 2026-03-09 | 2026-03-09 | 0d | 0d |  | start no earlier than 2026-01-07 |  | Participants | Participants | S&A Qualification | 404.71 | 6.13 | Laura Kennedy | Green | GREEN | T3-QU-0044 | QAG | T3 |
| 2267 | 1.6.4.5.3.4 | Qualification Wave 4 QT Execution Window |  | 95d | 2026-03-09 | 2026-07-17 | 2266FS-1d, 2264 | 2026-03-09 | 2026-07-17 | 96d | 5d | 0d |  |  | Participants | Participants | S&A Qualification | 404.33 | 6.13 | Laura Kennedy | Green | GREEN |  |  |  |
| 2268 | 1.6.4.5.3.5 | Qualification Wave 4 Projected Execution End | milestone | 0d | 2026-07-17 | 2026-07-17 | 2267 | 2026-07-17 | 2026-07-17 | 0d | 5d |  |  |  | Participants | Participants | S&A Qualification | 534.71 | 6.13 | Laura Kennedy | Green | GREEN | T3-QU-0057 | QAG | T3 |
| 2269 | 1.6.4.5.4 | **Qualification Wave 4 Exit** |  | 144d | 2026-03-09 | 2026-09-24 |  | 2026-03-09 | 2026-09-24 | 150d | 0d |  |  | -0 | N/A | N/A | S&A Qualification | -155.67 | 6.13 | N/A |  |  |  |  |  |
| 2270 | 1.6.4.5.4.1 | Final QAD Submission window opens | milestone | 0d | 2026-03-09 | 2026-03-09 | 2266 | 2026-03-09 | 2026-03-09 | 0d | 0d |  |  |  | Participants | Participants | S&A Qualification | 404.71 | 6.13 | Laura Kennedy | Green | GREEN |  |  |  |
| 2271 | 1.6.4.5.4.2 | Qualification Wave 4 Participants submit their Final QAD |  | 100d | 2026-03-09 | 2026-07-24 | 2270FS-1d | 2026-03-09 | 2026-07-24 | 101d | 0d |  |  |  | Participants | Participants | S&A Qualification | 404.33 | 6.13 | Laura Kennedy | Green | GREEN |  |  |  |
| 2272 | 1.6.4.5.4.3 | Qualification Wave 4 Participants have submitted their Final QAD | milestone | 0d | 2026-07-24 | 2026-07-24 | 2271, 2268 | 2026-07-24 | 2026-07-24 | 0d | 0d |  |  |  | Participants | Participants | S&A Qualification | 541.71 | 6.13 | Laura Kennedy | Green | GREEN | T3-QU-0109 | QAG | T3 |
| 2273 | 1.6.4.5.4.4 | Completion of Code Bodies review of Final QAD |  | 20d | 2026-07-27 | 2026-08-21 | 2272 | 2026-07-27 | 2026-08-21 | 25d | 0d |  |  |  | Code Bodies | Code Bodies | S&A Qualification | 544.33 | 6.13 | Laura Kennedy | Green | GREEN |  |  |  |
| 2274 | 1.6.4.5.4.5 | QAD Sign Off deadline |  | 1d | 2026-08-28 | 2026-08-28 | 2273FS+4d | 2026-08-28 | 2026-08-28 | 1d | 0d |  |  |  | Participants | Participants | S&A Qualification | 576.33 | 6.13 | Laura Kennedy | Green | GREEN |  |  |  |
| 2275 | 1.6.4.5.4.6 | Qualification Wave 4 Participants Qualification approved by BSC PAB and REC Manager | milestone | 0d | 2026-09-24 | 2026-09-24 | 2274FS+19d | 2026-09-24 | 2026-09-24 | 0d | 0d |  |  |  | Code Bodies | Code Bodies | S&A Qualification | 603.71 | 6.13 | Laura Kennedy | Green | GREEN | T2-QU-0300 | QAG | T3 |

| ID | WBS | Task | Type | Duration | Start | Finish | Predecessors | Complete | Remaining | Baseline start | Baseline finish | Baseline duration | Baseline 1 start | Baseline 1 finish | Total slack | Free slack | Constraint | Baseline cost | Text9 | Task Status | Update Version | Sched Status | Responsible | Involved | MHHS Resource Name | MHHS Programme Phase | RAG | Milestone ID | Text29 | Tier | Artefact ID |
| --- | --- | --- | --- | --- | --- | --- | --- | --- | --- | --- | --- | --- | --- | --- | --- | --- | --- | --- | --- | --- | --- | --- | --- | --- | --- | --- | --- | --- | --- | --- | --- |
| 2276 | 1.6.4.5.5 | **Qualification Tier 1 Milestone** |  | 66d | 2026-10-28 | 2027-01-28 |  |  |  | 2026-10-28 | 2027-01-28 | 0d |  |  | 235d |  |  |  | S&A Qualification | -686.67 | 6.13 | Overdue Start |  |  |  |  |  |  |  |  |  |
| 2277 | 1.6.4.5.5.1 | All suppliers must be able to access MPANs under the new TOM (M14) | milestone | 0d | 2026-10-28 | 2026-10-28 | 2275FS+24d |  |  | 2026-10-28 | 2026-10-28 | 0d | 2026-03-16 | 2026-03-16 | 235d | 0d | start no earlier than 2026-03-12 |  | S&A Qualification | 637.71 | 6.13 | Green | CPT | CPT | CPT | Migration | GREEN | T1-MI-5000 | PSG | T1 |  |
| 2278 | 1.6.4.5.5.2 | All suppliers must be able to access MPANs under the new TOM (M14*) - Late Exit | milestone | 0d | 2027-01-28 | 2027-01-28 | 2277FS+66d |  |  | 2027-01-28 | 2027-01-28 | 0d | 2026-06-16 | 2026-06-16 | 235d |  |  |  | S&A Qualification | 729.71 | 6.13 | Green | CPT | CPT | CPT | Migration | GREEN | T1-MI-5500 | PSG | T1 |  |
| 2279 | 1.7 | **REGULATORY** |  | 823d | 2022-10-31 A | 2025-12-24 |  | 99% | 2.17d | 2022-10-31 | 2025-12-24 | 680d | 2022-10-31 | 2025-03-07 | 521d |  |  | -0 | Regulatory |  |  |  | N/A | N/A | N/A | Regulatory |  |  |  |  |  |
| 2280 | 1.7.1 | **Baseline MHHS Code Changes** |  | 475d | 2022-10-31 A | 2024-08-23 A |  | 100% |  | 2022-10-31 | 2024-08-23 | 475d | 2022-10-31 | 2024-08-23 |  |  |  | -0 | Regulatory |  | 5.0 |  | N/A | N/A | N/A | Regulatory |  |  |  |  |  |
| 2281 | 1.7.1.1 | **Preparation and planning** |  | 35d | 2022-10-31 A | 2022-12-16 A |  | 100% |  | 2022-10-31 | 2022-12-16 | 35d | 2022-10-31 | 2022-12-16 |  |  |  |  | Regulatory |  | 5.0 |  | N/A | N/A | N/A | Regulatory |  |  |  |  |  |
| 2282 | 1.7.1.1.1 | Impact assessment of Programme design on codes to determine required changes |  | 20d | 2022-10-31 A | 2022-11-25 A | 47 | 100% |  | 2022-10-31 | 2022-11-25 | 20d | 2022-10-31 | 2022-11-25 |  |  |  |  | Regulatory |  | 5.0 | Complete | Code Bodies,SRO Code Drafters | Code Drafting PM | Andrew Margan | Regulatory | COMPLETE |  |  |  |  |
| 2283 | 1.7.1.1.2 | Become 'code draft ready' |  | 35d | 2022-10-31 A | 2022-12-16 A |  | 100% |  | 2022-10-31 | 2022-12-16 | 35d | 2022-10-31 | 2022-12-16 |  |  |  |  | Regulatory |  | 5.0 | Complete | Code Bodies,SRO Code Drafters | Code Drafting PM | Andrew Margan | Regulatory | COMPLETE |  |  |  |  |
| 2284 | 1.7.1.1.3 | Soft start drafting where possible |  | 35d | 2022-10-31 A | 2022-12-16 A |  | 100% |  | 2022-10-31 | 2022-12-16 | 35d | 2022-10-31 | 2022-12-16 |  |  |  |  | Regulatory |  | 5.0 | Complete | Code Bodies,SRO Code Drafters | Code Drafting PM | Andrew Margan | Regulatory | COMPLETE |  |  |  |  |
| 2285 | 1.7.1.2 | **Code drafting** |  | 443d | 2022-12-12 A | 2024-08-21 A |  | 100% |  | 2022-12-12 | 2024-08-21 | 445d | 2022-12-12 | 2024-08-23 |  |  |  | -0 | Regulatory | M6 | 5.0 |  | N/A | N/A | N/A | Regulatory |  |  |  |  |  |
| 2286 | 1.7.1.2.1 | **Data Services (BSC driven)** |  | 118d | 2022-12-12 A | 2023-05-24 A |  | 100% |  | 2022-12-12 | 2023-05-24 | 118d | 2022-12-12 | 2023-05-24 |  |  |  |  | Regulatory | M6 | 5.0 |  | N/A | N/A | N/A | Regulatory |  |  |  |  |  |
| 2287 | 1.7.1.2.1.1 | Pre Code Drafting activities |  | 5d | 2022-12-12 A | 2022-12-16 A |  | 100% |  | 2022-12-12 | 2022-12-16 | 5d | 2022-12-12 | 2022-12-16 |  |  | start no earlier than 2022-12-12 |  | Regulatory |  | 5.0 | Complete | Code Drafting PM |  | Andrew Margan | Regulatory | COMPLETE |  |  |  |  |
| 2288 | 1.7.1.2.1.2 | Code and subsidiary document drafting takes place offline |  | 19d | 2023-01-03 A | 2023-01-27 A | 2287FS+11d | 100% |  | 2023-01-03 | 2023-01-27 | 19d | 2023-01-03 | 2023-01-27 |  |  |  |  | Regulatory |  | 5.0 | Complete | Code Bodies,SRO Design | Code Drafting PM | Andrew Margan | Regulatory | COMPLETE |  |  |  |  |
| 2289 | 1.7.1.2.1.3 | Internal review and cross-checking of drafting across code drafters |  | 11d | 2023-01-30 A | 2023-02-13 A | 2288 | 100% |  | 2023-01-30 | 2023-02-13 | 11d | 2023-01-30 | 2023-02-13 |  |  |  |  | Regulatory |  | 5.0 | Complete | Code Bodies,SRO Design | Code Drafting PM | Andrew Margan | Regulatory | COMPLETE |  |  |  |  |
| 2290 | 1.7.1.2.1.4 | External industry review via consultation |  | 20d | 2023-02-14 A | 2023-03-13 A | 2289 | 100% |  | 2023-02-14 | 2023-03-13 | 20d | 2023-02-14 | 2023-03-13 |  |  |  |  | Regulatory |  | 5.0 | Complete | PP | Code Drafting PM | Andrew Margan | Regulatory | COMPLETE |  |  |  |  |
| 2291 | 1.7.1.2.1.5 | Triage and action comments |  | 19d | 2023-03-10 A | 2023-04-05 A | 2290FS-2d | 100% |  | 2023-03-10 | 2023-04-05 | 19d | 2023-03-10 | 2023-04-05 |  |  |  |  | Regulatory |  | 5.0 | Complete | Code Bodies,SRO Design | Code Drafting PM | Andrew Margan | Regulatory | COMPLETE |  |  |  |  |
| 2292 | 1.7.1.2.1.6 | CDWG review |  | 30d | 2023-04-06 A | 2023-05-17 A | 2291 | 100% |  | 2023-04-06 | 2023-05-17 | 30d | 2023-04-06 | 2023-05-17 |  |  |  |  | Regulatory |  | 5.0 | Complete | PP | Code Drafting PM | Andrew Margan | Regulatory | COMPLETE |  |  |  |  |
| 2293 | 1.7.1.2.1.7 | CCAG review |  | 5d | 2023-05-18 A | 2023-05-24 A | 2292 | 100% |  | 2023-05-18 | 2023-05-24 | 5d | 2023-05-18 | 2023-05-24 |  |  |  |  | Regulatory |  | 5.0 | Complete | PP |  | Andrew Margan | Regulatory | COMPLETE |  |  |  |  |
| 2294 | 1.7.1.2.1.8 | Code drafting for Data Services topic area approved | milestone | 0d | 2023-05-24 A | 2023-05-24 A | 2293 | 100% |  | 2023-05-24 | 2023-05-24 | 0d | 2023-05-24 | 2023-05-24 |  |  |  |  | Regulatory |  | 5.0 | Complete | PP | Code Drafting PM | Andrew Margan | Regulatory | COMPLETE | T2-RE-0100 | CCAG | T2 | MHHS-ART060 |
| 2295 | 1.7.1.2.2 | **Metering (REC driven)** |  | 118d | 2022-12-12 A | 2023-05-24 A |  | 100% |  | 2022-12-12 | 2023-05-24 | 118d | 2022-12-12 | 2023-05-24 |  |  |  |  | Regulatory | M6 | 5.0 |  | N/A | N/A | N/A | Regulatory |  |  |  |  |  |
| 2296 | 1.7.1.2.2.1 | Pre Code Drafting activities |  | 5d | 2022-12-12 A | 2022-12-16 A | 2287SS | 100% |  | 2022-12-12 | 2022-12-16 | 5d | 2022-12-12 | 2022-12-16 |  |  |  |  | Regulatory |  | 5.0 | Complete | Code Drafting PM |  | Andrew Margan | Regulatory | COMPLETE |  |  |  |  |
| 2297 | 1.7.1.2.2.2 | Code and subsidiary document drafting takes place offline |  | 19d | 2023-01-03 A | 2023-01-27 A | 2296FS+11d | 100% |  | 2023-01-03 | 2023-01-27 | 19d | 2023-01-03 | 2023-01-27 |  |  |  |  | Regulatory |  | 5.0 | Complete | Code Bodies,SRO Design | Code Drafting PM | Andrew Margan | Regulatory | COMPLETE |  |  |  |  |
| 2298 | 1.7.1.2.2.3 | Internal review and cross-checking of drafting across code drafters |  | 11d | 2023-01-30 A | 2023-02-13 A | 2297 | 100% |  | 2023-01-30 | 2023-02-13 | 11d | 2023-01-30 | 2023-02-13 |  |  |  |  | Regulatory |  | 5.0 | Complete | Code Bodies,SRO Design | Code Drafting PM | Andrew Margan | Regulatory | COMPLETE |  |  |  |  |
| 2299 | 1.7.1.2.2.4 | External industry review via consultation |  | 20d | 2023-02-14 A | 2023-03-13 A | 2298 | 100% |  | 2023-02-14 | 2023-03-13 | 20d | 2023-02-14 | 2023-03-13 |  |  |  |  | Regulatory |  | 5.0 | Complete | PP | Code Drafting PM | Andrew Margan | Regulatory | COMPLETE |  |  |  |  |
| 2300 | 1.7.1.2.2.5 | Triage and action comments |  | 19d | 2023-03-10 A | 2023-04-05 A | 2299FS-2d | 100% |  | 2023-03-10 | 2023-04-05 | 19d | 2023-03-10 | 2023-04-05 |  |  |  |  | Regulatory |  | 5.0 | Complete | Code Bodies,SRO Design | Code Drafting PM | Andrew Margan | Regulatory | COMPLETE |  |  |  |  |
| 2301 | 1.7.1.2.2.6 | CDWG review |  | 30d | 2023-04-06 A | 2023-05-17 A | 2300 | 100% |  | 2023-04-06 | 2023-05-17 | 30d | 2023-04-06 | 2023-05-17 |  |  |  |  | Regulatory |  | 5.0 | Complete | PP | Code Drafting PM | Andrew Margan | Regulatory | COMPLETE |  |  |  |  |
| 2302 | 1.7.1.2.2.7 | CCAG review |  | 5d | 2023-05-18 A | 2023-05-24 A | 2301 | 100% |  | 2023-05-18 | 2023-05-24 | 5d | 2023-05-18 | 2023-05-24 |  |  |  |  | Regulatory |  | 5.0 | Complete | PP |  | Andrew Margan | Regulatory | COMPLETE |  |  |  |  |
| 2303 | 1.7.1.2.2.8 | Code drafting for Metering topic area approved | milestone | 0d | 2023-05-24 A | 2023-05-24 A | 2302 | 100% |  | 2023-05-24 | 2023-05-24 | 0d | 2023-05-24 | 2023-05-24 |  |  |  |  | Regulatory |  | 5.0 | Complete | PP | Code Drafting PM | Andrew Margan | Regulatory | COMPLETE | T2-RE-0150 | CCAG | T2 | MHHS-ART060 |

Notes:
- 2277: Future RAG: All suppliers must be able to accept MPANs under the new TOM (one way gate)
- 2278: Future RAG: All suppliers must be able to accept MPANs under the new TOM (one way gate)

| ID | WBS | Task | Type | Duration | Start | Finish | Predecessors | Complete | Baseline start | Baseline finish | Baseline duration | Baseline 1 start | Baseline 1 finish | Constraint | Responsible | Involved | Text9 | Task Status | Update Version | MHHS Resource Name | MHHS Programme Phase | Sched Status | RAG | Artefact ID | Milestone ID | Text29 | Tier |
| --- | --- | --- | --- | --- | --- | --- | --- | --- | --- | --- | --- | --- | --- | --- | --- | --- | --- | --- | --- | --- | --- | --- | --- | --- | --- | --- | --- |
| 2304 | 1.7.1.2.3 | **BSC Central Services (BSC driven)** |  | 156d | 2023-02-22 A | 2023-09-27 A |  | 100% | 2023-02-22 | 2023-09-27 | 156d | 2023-02-22 | 2023-09-14 |  | N/A | N/A | Regulatory | M6 | 5.0 | N/A | Regulatory |  |  |  |  |  |  |
| 2305 | 1.7.1.2.3.1 | Pre Code Drafting activities |  | 5d | 2023-02-22 A | 2023-02-28 A | 2306SS-5d | 100% | 2023-02-22 | 2023-02-28 | 5d | 2023-02-22 | 2023-02-28 |  | Code Drafting PM |  | Regulatory |  | 5.0 | Andrew Margan | Regulatory | Complete | COMPLETE |  |  |  |  |
| 2306 | 1.7.1.2.3.2 | Code Drafting (offline) |  | 80d | 2023-03-01 A | 2023-06-20 A | 2290SS | 100% | 2023-03-01 | 2023-06-20 | 80d | 2023-03-01 | 2023-06-20 | must start on 2023-03-01 | Code Bodies,SRO Design | Code Drafting PM | Regulatory |  | 5.0 | Andrew Margan | Regulatory | Complete | COMPLETE |  |  |  |  |
| 2307 | 1.7.1.2.3.3 | Internal review and cross-checking of drafting across code drafters |  | 70d | 2023-03-15 A | 2023-06-20 A | 2306SS+10d | 100% | 2023-03-15 | 2023-06-20 | 70d | 2023-03-15 | 2023-06-20 |  | Code Bodies,SRO Design | Code Drafting PM | Regulatory |  | 5.0 | Andrew Margan | Regulatory | Complete | COMPLETE |  |  |  |  |
| 2308 | 1.7.1.2.3.4 | External industry review via consultation |  | 15d | 2023-06-21 A | 2023-07-11 A | 2307 | 100% | 2023-06-21 | 2023-07-11 | 15d | 2023-06-21 | 2023-07-11 |  | PP | Code Drafting PM | Regulatory |  | 5.0 | Andrew Margan | Regulatory | Complete | COMPLETE |  |  |  |  |
| 2309 | 1.7.1.2.3.5 | Triage and action comments |  | 19d | 2023-07-10 A | 2023-08-03 A | 2308FS-2d | 100% | 2023-07-10 | 2023-08-03 | 19d | 2023-07-10 | 2023-08-03 |  | Code Bodies,SRO Design | Code Drafting PM | Regulatory |  | 5.0 | Andrew Margan | Regulatory | Complete | COMPLETE |  |  |  |  |
| 2310 | 1.7.1.2.3.6 | CDWG review |  | 28d | 2023-08-04 A | 2023-09-12 A | 2309 | 100% | 2023-08-04 | 2023-09-12 | 28d | 2023-08-04 | 2023-09-07 |  | PP | Code Drafting PM | Regulatory |  | 5.0 | Andrew Margan | Regulatory | Complete | COMPLETE |  |  |  |  |
| 2311 | 1.7.1.2.3.7 | CCAG review |  | 11d | 2023-09-13 A | 2023-09-27 A | 2310 | 100% | 2023-09-13 | 2023-09-27 | 11d | 2023-09-08 | 2023-09-14 |  | PP |  | Regulatory |  | 5.0 | Andrew Margan | Regulatory | Complete | COMPLETE |  |  |  |  |
| 2312 | 1.7.1.2.3.8 | Code drafting for BSC Central Services topic area approved | milestone | 0d | 2023-09-27 A | 2023-09-27 A | 2311 | 100% | 2023-09-27 | 2023-09-27 | 0d | 2023-09-14 | 2023-09-14 |  | PP | Code Drafting PM | Regulatory |  | 5.0 | Andrew Margan | Regulatory | Complete | COMPLETE | MHHS-ART060 | T2-RE-0200 | CCAG | T2 |
| 2313 | 1.7.1.2.4 | **Registration (BSC & REC driven)** |  | 131d | 2023-02-22 A | 2023-08-23 A |  | 100% | 2023-02-22 | 2023-08-23 | 131d | 2023-02-22 | 2023-08-23 |  | N/A | N/A | Regulatory | M6 | 5.0 | N/A | Regulatory |  |  |  |  |  |  |
| 2314 | 1.7.1.2.4.1 | Pre Code Drafting activities |  | 5d | 2023-02-22 A | 2023-02-28 A | 2315SS-5d | 100% | 2023-02-22 | 2023-02-28 | 5d | 2023-02-22 | 2023-02-28 |  | Code Drafting PM |  | Regulatory |  | 5.0 | Andrew Margan | Regulatory | Complete | COMPLETE |  |  |  |  |
| 2315 | 1.7.1.2.4.2 | Code Drafting (offline) |  | 65d | 2023-03-01 A | 2023-05-30 A | 2289, 2298 | 100% | 2023-03-01 | 2023-05-30 | 65d | 2023-03-01 | 2023-05-30 | must start on 2023-03-01 | Code Bodies,SRO Design | Code Drafting PM | Regulatory |  | 5.0 | Andrew Margan | Regulatory | Complete | COMPLETE |  |  |  |  |
| 2316 | 1.7.1.2.4.3 | Internal review and cross-checking of drafting across code drafters |  | 55d | 2023-03-15 A | 2023-05-30 A | 2315SS+10d | 100% | 2023-03-15 | 2023-05-30 | 55d | 2023-03-15 | 2023-05-30 |  | Code Bodies,SRO Design | Code Drafting PM | Regulatory |  | 5.0 | Andrew Margan | Regulatory | Complete | COMPLETE |  |  |  |  |
| 2317 | 1.7.1.2.4.4 | External industry review via consultation |  | 15d | 2023-05-31 A | 2023-06-20 A | 2316 | 100% | 2023-05-31 | 2023-06-20 | 15d | 2023-05-31 | 2023-06-20 |  | PP | Code Drafting PM | Regulatory |  | 5.0 | Andrew Margan | Regulatory | Complete | COMPLETE |  |  |  |  |
| 2318 | 1.7.1.2.4.5 | Triage and action comments |  | 19d | 2023-06-19 A | 2023-07-13 A | 2317FS-2d | 100% | 2023-06-19 | 2023-07-13 | 19d | 2023-06-19 | 2023-07-13 |  | Code Bodies,SRO Design | Code Drafting PM | Regulatory |  | 5.0 | Andrew Margan | Regulatory | Complete | COMPLETE |  |  |  |  |
| 2319 | 1.7.1.2.4.6 | CDWG review |  | 18d | 2023-07-14 A | 2023-08-08 A | 2318 | 100% | 2023-07-14 | 2023-08-08 | 18d | 2023-07-14 | 2023-08-16 |  | PP | Code Drafting PM | Regulatory |  | 5.0 | Andrew Margan | Regulatory | Complete | COMPLETE |  |  |  |  |
| 2320 | 1.7.1.2.4.7 | CCAG review |  | 11d | 2023-08-09 A | 2023-08-23 A | 2319 | 100% | 2023-08-09 | 2023-08-23 | 11d | 2023-08-17 | 2023-08-23 |  | PP |  | Regulatory |  | 5.0 | Andrew Margan | Regulatory | Complete | COMPLETE |  |  |  |  |
| 2321 | 1.7.1.2.4.8 | Code drafting for Registration topic area approved | milestone | 0d | 2023-08-23 A | 2023-08-23 A | 2320 | 100% | 2023-08-23 | 2023-08-23 | 0d | 2023-08-23 | 2023-08-23 |  | PP | Code Drafting PM | Regulatory |  | 5.0 | Andrew Margan | Regulatory | Complete | COMPLETE | MHHS-ART060 | T2-RE-0250 | CCAG | T2 |
| 2322 | 1.7.1.2.5 | **Governance and Qualification (BSC & REC driven)** |  | 130d | 2023-05-25 A | 2023-11-22 A |  | 100% | 2023-05-25 | 2023-11-22 | 130d | 2023-05-25 | 2023-11-13 |  | N/A | N/A | Regulatory | M6 | 5.0 | N/A | Regulatory |  |  |  |  |  |  |
| 2323 | 1.7.1.2.5.1 | Pre Code Drafting activities |  | 5d | 2023-05-25 A | 2023-05-31 A | 2324SS-5d | 100% | 2023-05-25 | 2023-05-31 | 5d | 2023-05-25 | 2023-05-31 |  | Code Drafting PM |  | Regulatory |  | 5.0 | Andrew Margan | Regulatory | Complete | COMPLETE |  |  |  |  |
| 2324 | 1.7.1.2.5.2 | Code Drafting (offline) |  | 55d | 2023-06-01 A | 2023-08-16 A | 2317SS+1d | 100% | 2023-06-01 | 2023-08-16 | 55d | 2023-06-01 | 2023-08-16 |  | Code Bodies,SRO Design | Code Drafting PM | Regulatory |  | 5.0 | Andrew Margan | Regulatory | Complete | COMPLETE |  |  |  |  |
| 2325 | 1.7.1.2.5.3 | Internal review and cross-checking of drafting across code drafters |  | 45d | 2023-06-15 A | 2023-08-16 A | 2324SS+10d | 100% | 2023-06-15 | 2023-08-16 | 45d | 2023-06-15 | 2023-08-16 |  | Code Bodies,SRO Design | Code Drafting PM | Regulatory |  | 5.0 | Andrew Margan | Regulatory | Complete | COMPLETE |  |  |  |  |
| 2326 | 1.7.1.2.5.4 | External industry review via consultation |  | 15d | 2023-08-18 A | 2023-09-07 A | 2325FS+1d | 100% | 2023-08-18 | 2023-09-07 | 15d | 2023-08-18 | 2023-09-07 |  | PP | Code Drafting PM | Regulatory |  | 5.0 | Andrew Margan | Regulatory | Complete | COMPLETE |  |  |  |  |
| 2327 | 1.7.1.2.5.5 | Triage and action comments |  | 19d | 2023-09-06 A | 2023-10-02 A | 2326FS-2d | 100% | 2023-09-06 | 2023-10-02 | 19d | 2023-09-06 | 2023-10-02 |  | Code Bodies,SRO Design | Code Drafting PM | Regulatory |  | 5.0 | Andrew Margan | Regulatory | Complete | COMPLETE |  |  |  |  |
| 2328 | 1.7.1.2.5.6 | CDWG review |  | 31d | 2023-10-03 A | 2023-11-14 A | 2327 | 100% | 2023-10-03 | 2023-11-14 | 31d | 2023-10-03 | 2023-11-06 |  | PP | Code Drafting PM | Regulatory |  | 5.0 | Andrew Margan | Regulatory | Complete | COMPLETE |  |  |  |  |
| 2329 | 1.7.1.2.5.7 | CCAG review |  | 6d | 2023-11-15 A | 2023-11-22 A | 2328 | 100% | 2023-11-15 | 2023-11-22 | 6d | 2023-11-07 | 2023-11-13 |  | PP |  | Regulatory |  | 5.0 | Andrew Margan | Regulatory | Complete | COMPLETE |  |  |  |  |
| 2330 | 1.7.1.2.5.8 | Code drafting for Governance and Qualification topic areas approved | milestone | 0d | 2023-11-22 A | 2023-11-22 A | 2329 | 100% | 2023-11-22 | 2023-11-22 | 0d | 2023-11-13 | 2023-11-13 |  | PP | Code Drafting PM | Regulatory |  | 5.12 | Andrew Margan | Regulatory | Complete | COMPLETE | MHHS-ART060 | T3-RE-0300 | CCAG | T2 |

| ID | WBS | Task | Type | Duration | Start | Finish | Predecessors | Complete | Baseline start | Baseline finish | Baseline duration | Baseline 1 start | Baseline 1 finish | Constraint | Baseline cost | Responsible | Involved | Text9 | Task Status | Update Version | MHHS Resource Name | MHHS Programme Phase | Sched Status | RAG | Artefact ID | Milestone ID | Text29 | Tier |
| --- | --- | --- | --- | --- | --- | --- | --- | --- | --- | --- | --- | --- | --- | --- | --- | --- | --- | --- | --- | --- | --- | --- | --- | --- | --- | --- | --- | --- |
| 2331 | 1.7.1.2.6 | **Interfaces / Data Specification (REC driven)** |  | 174d | 2023-05-25 A | 2024-01-23 A |  | 100% | 2023-05-25 | 2024-01-23 | 175d | 2023-05-25 | 2023-11-13 |  |  | N/A | N/A | Regulatory | M6 | 5.2 | N/A | Regulatory |  |  |  |  |  |  |
| 2332 | 1.7.1.2.6.1 | Pre Code Drafting activities |  | 5d | 2023-05-25 A | 2023-05-31 A | 2333SS-5d | 100% | 2023-05-25 | 2023-05-31 | 5d | 2023-05-25 | 2023-05-31 |  |  | Code Drafting PM |  | Regulatory |  | 5.0 | Andrew Margan | Regulatory | Complete | COMPLETE |  |  |  |  |
| 2333 | 1.7.1.2.6.2 | Code Drafting (offline) |  | 94d | 2023-06-01 A | 2023-10-10 A | 2317SS+1d | 100% | 2023-06-01 | 2023-10-10 | 94d | 2023-06-01 | 2023-08-16 |  |  | Code Bodies,SRO Design | Code Drafting PM | Regulatory |  | 5.2 | Andrew Margan | Regulatory | Complete | COMPLETE |  |  |  |  |
| 2334 | 1.7.1.2.6.3 | Internal review and cross-checking of drafting across code drafters |  | 84d | 2023-06-15 A | 2023-10-10 A | 2333SS+10d | 100% | 2023-06-15 | 2023-10-10 | 84d | 2023-06-15 | 2023-08-16 |  |  | Code Bodies,SRO Design | Code Drafting PM | Regulatory |  | 5.2 | Andrew Margan | Regulatory | Complete | COMPLETE |  |  |  |  |
| 2335 | 1.7.1.2.6.4 | External industry review via consultation |  | 15d | 2023-10-11 A | 2023-10-31 A | 2334 | 100% | 2023-10-11 | 2023-10-31 | 15d | 2023-08-18 | 2023-09-07 |  |  | PP | Code Drafting PM | Regulatory |  | 5.2 | Andrew Margan | Regulatory | Complete | COMPLETE |  |  |  |  |
| 2336 | 1.7.1.2.6.5 | Triage and action comments |  | 20d | 2023-10-30 A | 2023-11-24 A | 2335FS-2d | 100% | 2023-10-30 | 2023-11-24 | 20d | 2023-09-06 | 2023-10-02 |  |  | Code Bodies,SRO Design | Code Drafting PM | Regulatory |  | 5.2 | Andrew Margan | Regulatory | Complete | COMPLETE |  |  |  |  |
| 2337 | 1.7.1.2.6.6 | CDWG review |  | 37d | 2023-11-27 A | 2024-01-16 A | 2336 | 100% | 2023-11-27 | 2024-01-16 | 32d | 2023-10-03 | 2023-11-06 |  |  | PP | Code Drafting PM | Regulatory |  | 5.2 | Andrew Margan | Regulatory | Complete | COMPLETE |  |  |  |  |
| 2338 | 1.7.1.2.6.7 | CCAG review |  | 5d | 2024-01-17 A | 2024-01-23 A | 2337 | 100% | 2024-01-17 | 2024-01-23 | 11d | 2023-11-07 | 2023-11-13 |  |  | PP | Code Drafting PM | Regulatory |  | 5.2 | Andrew Margan | Regulatory | Complete | COMPLETE |  |  |  |  |
| 2339 | 1.7.1.2.6.8 | Code drafting for Interfaces / Data Specification topic areas approved | milestone | 0d | 2024-01-23 A | 2024-01-23 A | 2338 | 100% | 2024-01-23 | 2024-01-23 | 0d | 2023-11-13 | 2023-11-13 |  |  | PP | Code Drafting PM | Regulatory |  | 5.16 | Andrew Margan | Regulatory | Complete | COMPLETE | MHHS-ART060 | T3-RE-0350 | CCAG | T2 |
| 2340 | 1.7.1.2.7 | **Migration (BSC & REC driven)** |  | 130d | 2023-05-25 A | 2023-11-22 A |  | 100% | 2023-05-25 | 2023-11-22 | 130d | 2023-05-25 | 2023-11-13 |  |  | N/A | N/A | Regulatory | M6 | 5.0 | N/A | Regulatory |  |  |  |  |  |  |
| 2341 | 1.7.1.2.7.1 | Pre Code Drafting activities |  | 5d | 2023-05-25 A | 2023-05-31 A | 2342SS-5d | 100% | 2023-05-25 | 2023-05-31 | 5d | 2023-05-25 | 2023-05-31 |  |  | Code Drafting PM |  | Regulatory |  | 5.0 | Andrew Margan | Regulatory | Complete | COMPLETE |  |  |  |  |
| 2342 | 1.7.1.2.7.2 | Code Drafting (offline) |  | 55d | 2023-06-01 A | 2023-08-16 A | 2317SS+1d | 100% | 2023-06-01 | 2023-08-16 | 55d | 2023-06-01 | 2023-08-16 |  |  | Code Bodies,SRO Design | Code Drafting PM | Regulatory |  | 5.0 | Andrew Margan | Regulatory | Complete | COMPLETE |  |  |  |  |
| 2343 | 1.7.1.2.7.3 | Internal review and cross-checking of drafting across code drafters |  | 45d | 2023-06-15 A | 2023-08-16 A | 2342SS+10d | 100% | 2023-06-15 | 2023-08-16 | 45d | 2023-06-15 | 2023-08-16 |  |  | Code Bodies,SRO Design | Code Drafting PM | Regulatory |  | 5.0 | Andrew Margan | Regulatory | Complete | COMPLETE |  |  |  |  |
| 2344 | 1.7.1.2.7.4 | External industry review via consultation |  | 15d | 2023-08-18 A | 2023-09-07 A | 2343FS+1d | 100% | 2023-08-18 | 2023-09-07 | 15d | 2023-08-18 | 2023-09-07 |  |  | PP | Code Drafting PM | Regulatory |  | 5.0 | Andrew Margan | Regulatory | Complete | COMPLETE |  |  |  |  |
| 2345 | 1.7.1.2.7.5 | Triage and action comments |  | 19d | 2023-09-06 A | 2023-10-02 A | 2344FS-2d | 100% | 2023-09-06 | 2023-10-02 | 19d | 2023-09-06 | 2023-10-02 |  |  | Code Bodies,SRO Design | Code Drafting PM | Regulatory |  | 5.0 | Andrew Margan | Regulatory | Complete | COMPLETE |  |  |  |  |
| 2346 | 1.7.1.2.7.6 | CDWG review |  | 31d | 2023-10-03 A | 2023-11-14 A | 2345 | 100% | 2023-10-03 | 2023-11-14 | 31d | 2023-10-03 | 2023-11-06 |  |  | PP | Code Drafting PM | Regulatory |  | 5.0 | Andrew Margan | Regulatory | Complete | COMPLETE |  |  |  |  |
| 2347 | 1.7.1.2.7.7 | CCAG review |  | 6d | 2023-11-15 A | 2023-11-22 A | 2346 | 100% | 2023-11-15 | 2023-11-22 | 6d | 2023-11-07 | 2023-11-13 |  |  | PP | Code Drafting PM | Regulatory |  | 5.0 | Andrew Margan | Regulatory | Complete | COMPLETE |  |  |  |  |
| 2348 | 1.7.1.2.7.8 | Code drafting for Migration topic area approved | milestone | 0d | 2023-11-22 A | 2023-11-22 A | 2347 | 100% | 2023-11-22 | 2023-11-22 | 0d | 2023-11-13 | 2023-11-13 |  |  | PP | Code Drafting PM | Regulatory |  | 5.12 | Andrew Margan | Regulatory | Complete | COMPLETE | MHHS-ART060 | T3-RE-0400 | CCAG | T2 |
| 2349 | 1.7.1.2.8 | **Consequential Code Change** |  | 109d | 2023-10-11 A | 2024-03-11 A |  | 100% | 2023-10-11 | 2024-03-11 | 108d | 2023-08-18 | 2024-03-08 |  | -0 | N/A | N/A | Regulatory |  | 5.0 | N/A | Regulatory |  |  |  |  |  |  |
| 2350 | 1.7.1.2.8.1 | External industry review via consultation - drop 1 (DCUSA) |  | 15d | 2023-10-11 A | 2023-10-31 A | 2356SS | 100% | 2023-10-11 | 2023-10-31 | 15d | 2023-08-18 | 2023-09-07 |  |  | Code Bodies | PP | Regulatory |  | 5.2 | Andrew Margan | Regulatory | Complete | COMPLETE |  |  |  |  |
| 2351 | 1.7.1.2.8.2 | External industry review via consultation - drop 2 (Elexon) |  | 16d | 2024-02-19 A | 2024-03-11 A | 2366SS | 100% | 2024-02-19 | 2024-03-11 | 15d | 2023-10-16 | 2023-11-03 | start no earlier than 2024-02-19 |  | Code Bodies | PP | Regulatory |  | 5.2 | Andrew Margan | Regulatory | Complete | COMPLETE |  |  |  |  |
| 2352 | 1.7.1.2.9 | **Transition Text (all codes)** |  | 118d | 2023-08-11 A | 2024-01-23 A |  | 100% | 2023-08-11 | 2024-01-23 | 119d | 2023-08-11 | 2024-01-25 |  |  | N/A | N/A | Regulatory | M6 | 5.2 | N/A | Regulatory |  |  |  |  |  |  |
| 2353 | 1.7.1.2.9.1 | Pre Code Drafting activities |  | 8d | 2023-08-11 A | 2023-08-22 A | 2354SS-5d | 100% | 2023-08-11 | 2023-08-22 | 8d | 2023-08-11 | 2023-08-17 |  |  | Code Drafting PM |  | Regulatory |  | 5.0 | Andrew Margan | Regulatory | Complete | COMPLETE |  |  |  |  |
| 2354 | 1.7.1.2.9.2 | Code Drafting (offline) |  | 38d | 2023-08-18 A | 2023-10-10 A | 2344SS | 100% | 2023-08-18 | 2023-10-10 | 38d | 2023-08-18 | 2023-10-12 |  |  | Code Bodies,SRO Design | Code Drafting PM | Regulatory |  | 5.2 | Andrew Margan | Regulatory | Complete | COMPLETE |  |  |  |  |
| 2355 | 1.7.1.2.9.3 | Internal review and cross-checking of drafting across code drafters |  | 28d | 2023-09-01 A | 2023-10-10 A | 2354SS+10d | 100% | 2023-09-01 | 2023-10-10 | 28d | 2023-09-01 | 2023-10-12 |  |  | Code Bodies,SRO Design | Code Drafting PM | Regulatory |  | 5.2 | Andrew Margan | Regulatory | Complete | COMPLETE |  |  |  |  |
| 2356 | 1.7.1.2.9.4 | External industry review via consultation |  | 15d | 2023-10-11 A | 2023-10-31 A | 2355 | 100% | 2023-10-11 | 2023-10-31 | 15d | 2023-10-16 | 2023-11-03 |  |  | PP | Code Drafting PM | Regulatory |  | 5.2 | Andrew Margan | Regulatory | Complete | COMPLETE |  |  |  |  |
| 2357 | 1.7.1.2.9.5 | Triage and action comments |  | 20d | 2023-10-30 A | 2023-11-24 A | 2356FS-2d | 100% | 2023-10-30 | 2023-11-24 | 20d | 2023-11-02 | 2023-11-21 |  |  | Code Bodies,SRO Design | Code Drafting PM | Regulatory |  | 5.2 | Andrew Margan | Regulatory | Complete | COMPLETE |  |  |  |  |
| 2358 | 1.7.1.2.9.6 | CDWG review |  | 37d | 2023-11-27 A | 2024-01-16 A | 2357 | 100% | 2023-11-27 | 2024-01-16 | 37d | 2023-11-22 | 2024-01-17 |  |  | PP | Code Drafting PM | Regulatory |  | 5.2 | Andrew Margan | Regulatory | Complete | COMPLETE |  |  |  |  |
| 2359 | 1.7.1.2.9.7 | CCAG review |  | 5d | 2024-01-17 A | 2024-01-23 A | 2358 | 100% | 2024-01-17 | 2024-01-23 | 6d | 2024-01-18 | 2024-01-25 |  |  | PP | Code Drafting PM | Regulatory |  | 5.2 | Andrew Margan | Regulatory | Complete | COMPLETE |  |  |  |  |
| 2360 | 1.7.1.2.9.8 | Code drafting for Transition Text topic area approved | milestone | 0d | 2024-01-23 A | 2024-01-23 A | 2359 | 100% | 2024-01-23 | 2024-01-23 | 0d | 2024-01-25 | 2024-01-25 |  |  | PP | Code Drafting PM | Regulatory |  | 5.16 | Andrew Margan | Regulatory | Complete | COMPLETE | MHHS-ART060 | T3-RE-0450 | CCAG | T2 |

Notes:
- 2354: Guidance: 14/8/23 - RECCo transition drafting activity is expected to take the full 38 days, noting BSE co-drafting will be expected to take approx. 21 days

| ID | WBS | Task | Type | Duration | Start | Finish | Predecessors | Complete | Baseline start | Baseline finish | Baseline duration | Baseline 1 start | Baseline 1 finish | Baseline cost | Responsible | Involved | Text9 | Task Status | Update Version | MHHS Resource Name | MHHS Programme Phase | Sched Status | RAG | Artefact ID | Milestone ID | Text29 | Tier |
| --- | --- | --- | --- | --- | --- | --- | --- | --- | --- | --- | --- | --- | --- | --- | --- | --- | --- | --- | --- | --- | --- | --- | --- | --- | --- | --- | --- |
| 2361 | 1.7.1.2.10 | **Final Code Drafting (mop-up) (all codes)** |  | 199d | 2023-08-18 A | 2024-05-22 A |  | 100% | 2023-08-18 | 2024-05-22 | 199d | 2023-08-18 | 2024-05-13 |  | N/A | N/A | Regulatory | M6 | 5.0 | N/A | Regulatory |  |  |  |  |  |  |
| 2362 | 1.7.1.2.10.1 | Forward look and confirm remaining plan |  | 15d | 2023-08-18 A | 2023-09-07 A | 2354SS | 100% | 2023-08-18 | 2023-09-07 | 15d | 2023-08-18 | 2023-09-07 |  | Code Drafting PM |  | Regulatory |  | 5.0 | Andrew Margan | Regulatory | Complete | COMPLETE |  |  |  |  |
| 2363 | 1.7.1.2.10.2 | Identify remaining or additional areas of code (e.g. consequential change requirements) to be completed |  | 15d | 2023-08-18 A | 2023-09-07 A | 2362SS | 100% | 2023-08-18 | 2023-09-07 | 15d | 2023-08-18 | 2023-09-07 |  | Code Bodies,SRO Design | Code Drafting PM | Regulatory |  | 5.0 | Andrew Margan | Regulatory | Complete | COMPLETE |  |  |  |  |
| 2364 | 1.7.1.2.10.3 | Code Drafting (offline) Interim Consultation (1) |  | 60d | 2023-09-08 A | 2023-11-30 A | 2363 | 100% | 2023-09-08 | 2023-11-30 | 60d | 2023-09-08 | 2024-02-15 |  | Code Bodies,SRO Design | Code Drafting PM | Regulatory |  | 5.0 | Andrew Margan | Regulatory | Complete | COMPLETE |  |  |  |  |
| 2365 | 1.7.1.2.10.4 | Internal review and cross-checking of drafting across code drafters Interim Consultation (1) |  | 50d | 2023-09-22 A | 2023-11-30 A | 2364SS+10d | 100% | 2023-09-22 | 2023-11-30 | 50d | 2023-09-22 | 2024-02-15 |  | Code Bodies,SRO Design | Code Drafting PM | Regulatory |  | 5.0 | Andrew Margan | Regulatory | Complete | COMPLETE |  |  |  |  |
| 2366 | 1.7.1.2.10.5 | External industry review via consultation Interim Consultation (1) |  | 23d | 2023-12-01 A | 2024-01-02 A | 2365 | 100% | 2023-12-01 | 2024-01-02 | 23d | 2024-02-19 | 2024-03-08 |  | PP | Code Drafting PM | Regulatory |  | 5.0 | Andrew Margan | Regulatory | Complete | COMPLETE |  |  |  |  |
| 2367 | 1.7.1.2.10.6 | Code Drafting (offline) Final Consultation (2) |  | 55d | 2023-12-01 A | 2024-02-15 A | 2365 | 100% | 2023-12-01 | 2024-02-15 | 55d | 2023-09-08 | 2024-02-15 |  | Code Bodies,SRO Design | Code Drafting PM | Regulatory |  | 5.0 | Andrew Margan | Regulatory | Complete | COMPLETE |  |  |  |  |
| 2368 | 1.7.1.2.10.7 | Internal review and cross-checking of drafting across code drafters Final Consultation (2) |  | 45d | 2023-12-15 A | 2024-02-15 A | 2367SS+10d | 100% | 2023-12-15 | 2024-02-15 | 45d | 2023-09-22 | 2024-02-15 |  | Code Bodies,SRO Design | Code Drafting PM | Regulatory |  | 5.0 | Andrew Margan | Regulatory | Complete | COMPLETE |  |  |  |  |
| 2369 | 1.7.1.2.10.8 | External industry review via consultation Final Consultation (2) |  | 16d | 2024-02-19 A | 2024-03-11 A | 2368FS+1d | 100% | 2024-02-19 | 2024-03-11 | 15d | 2024-02-19 | 2024-03-08 |  | PP | Code Drafting PM | Regulatory |  | 5.0 | Andrew Margan | Regulatory | Complete | COMPLETE |  |  |  |  |
| 2370 | 1.7.1.2.10.9 | Triage and action comments |  | 18d | 2024-03-11 A | 2024-04-03 A | 2369FS-1d | 100% | 2024-03-11 | 2024-04-03 | 18d | 2024-03-07 | 2024-04-03 |  | Code Bodies,SRO Design | Code Drafting PM | Regulatory |  | 5.0 | Andrew Margan | Regulatory | Complete | COMPLETE |  |  |  |  |
| 2371 | 1.7.1.2.10.10 | CDWG review |  | 29d | 2024-04-04 A | 2024-05-14 A | 2370 | 100% | 2024-04-04 | 2024-05-14 | 31d | 2024-04-04 | 2024-05-03 |  | PP | Code Drafting PM | Regulatory |  | 5.0 | Andrew Margan | Regulatory | Complete | COMPLETE |  |  |  |  |
| 2372 | 1.7.1.2.10.11 | CCAG review |  | 6d | 2024-05-15 A | 2024-05-22 A | 2371 | 100% | 2024-05-15 | 2024-05-22 | 6d | 2024-05-06 | 2024-05-13 |  | PP | Code Drafting PM | Regulatory |  | 5.0 | Andrew Margan | Regulatory | Complete | COMPLETE |  |  |  |  |
| 2373 | 1.7.1.2.10.12 | Final code drafting (mop-up) approved | milestone | 0d | 2024-05-22 A | 2024-05-22 A | 2372 | 100% | 2024-05-22 | 2024-05-22 | 0d | 2024-05-13 | 2024-05-13 |  | PP | Code Drafting PM | Regulatory |  | 5.25 | Andrew Margan | Regulatory | Complete | COMPLETE | MHHS-ART060 | T3-RE-0500 | CCAG | T2 |
| 2374 | 1.7.1.2.11 | **Final code review, consistency check and approval** |  | 100d | 2024-04-04 A | 2024-08-21 A |  | 100% | 2024-04-04 | 2024-08-21 | 102d | 2024-05-06 | 2024-08-23 | -0 | N/A | N/A | Regulatory | M6 | 5.0 | N/A | Regulatory |  |  |  |  |  |  |
| 2375 | 1.7.1.2.11.1 | Gap analysis of final code against design artefacts (reverse process to code drafting) |  | 38d | 2024-04-04 A | 2024-05-27 A | 2371SS | 100% | 2024-04-04 | 2024-05-27 | 38d | 2024-05-06 | 2024-05-17 |  | Code Bodies,SRO Design | Code Drafting PM | Regulatory |  | 5.0 | Andrew Margan | Regulatory | Complete | COMPLETE |  |  |  |  |
| 2376 | 1.7.1.2.11.2 | Outputs of gap analysis actioned offline |  | 11d | 2024-05-28 A | 2024-06-11 A | 2375 | 100% | 2024-05-28 | 2024-06-11 | 11d | 2024-05-20 | 2024-06-07 |  | Code Bodies,SRO Design | Code Drafting PM | Regulatory |  | 5.0 | Andrew Margan | Regulatory | Complete | COMPLETE |  |  |  |  |
| 2377 | 1.7.1.2.11.3 | Final documentation collated for final consultation |  | 8d | 2024-06-12 A | 2024-06-21 A | 2376 | 100% | 2024-06-12 | 2024-06-21 | 9d | 2024-06-10 | 2024-06-13 |  | Code Drafting PM | Code Bodies,SRO Design | Regulatory |  | 5.23 | Andrew Margan | Regulatory | Complete | COMPLETE |  |  |  |  |
| 2378 | 1.7.1.2.11.4 | External industry review via consultation |  | 15d | 2024-06-24 A | 2024-07-12 A | 2377 | 100% | 2024-06-24 | 2024-07-12 | 20d | 2024-06-14 | 2024-07-04 |  | PP | Code Drafting PM | Regulatory |  | 5.0 | Andrew Margan | Regulatory | Complete | COMPLETE |  |  |  |  |
| 2379 | 1.7.1.2.11.5 | Triage and action comments |  | 10d | 2024-07-15 A | 2024-07-26 A | 2378 | 100% | 2024-07-15 | 2024-07-26 | 13d | 2024-07-03 | 2024-07-19 |  | Code Bodies,SRO Design | Code Drafting PM | Regulatory |  | 5.0 | Andrew Margan | Regulatory | Complete | COMPLETE |  |  |  |  |
| 2380 | 1.7.1.2.11.6 | Final CDWG review |  | 8d | 2024-08-02 A | 2024-08-13 A | 2379FS+4d | 100% | 2024-08-02 | 2024-08-13 | 6d | 2024-07-22 | 2024-08-16 |  | PP | Code Drafting PM | Regulatory |  | 5.0 | Andrew Margan | Regulatory | Complete | COMPLETE |  |  |  |  |
| 2381 | 1.7.1.2.11.7 | Final CCAG review |  | 6d | 2024-08-14 A | 2024-08-21 A | 2380 | 100% | 2024-08-14 | 2024-08-21 | 8d | 2024-08-19 | 2024-08-23 |  | PP | Code Drafting PM | Regulatory |  | 5.0 | Andrew Margan | Regulatory | Complete | COMPLETE |  |  |  |  |
| 2382 | 1.7.1.2.11.8 | CCAG recommend final code to PSG for baselining | milestone | 0d | 2024-08-21 A | 2024-08-21 A | 2381 | 100% | 2024-08-21 | 2024-08-21 | 0d | 2024-08-23 | 2024-08-23 |  | PP | Code Drafting PM | Regulatory |  | 5.9 | Andrew Margan | Regulatory | Complete | COMPLETE | MHHS-ART060 | T3-RE-0550 | CCAG | T2 |
| 2383 | 1.7.1.3 | Code changes baselined (M6) | milestone | 0d | 2024-08-23 A | 2024-08-23 A | 2381FS+2d, 2373, 2360, 2348, 2339, 2330, 2321, 2312, 2303, 2294 | 100% | 2024-08-23 | 2024-08-23 | 0d | 2024-08-23 | 2024-08-23 |  | CPT | PP | Regulatory |  | 5.0 | Andrew Margan | Regulatory | Complete | COMPLETE | MHHS-ART012 | T1-RE-1000 | PSG | T1 |
| 2384 | 1.7.2 | **Ofgem preparation and enactment of SCR powers** |  | 225d | 2024-02-05 A | 2024-12-13 A |  | 100% | 2024-02-05 | 2024-12-13 | 225d | 2024-01-26 | 2024-11-12 | -0 | N/A | N/A | Regulatory | M7 | 5.0 | N/A | Regulatory |  |  |  |  |  |  |
| 2385 | 1.7.2.1 | **Preparation and enactment of SCR Powers** |  | 223d | 2024-02-05 A | 2024-12-11 A |  | 100% | 2024-02-05 | 2024-12-11 | 223d | 2024-01-26 | 2024-11-11 | -0 | N/A | N/A | Regulatory |  | 5.0 | N/A | Regulatory |  |  |  |  |  |  |
| 2386 | 1.7.2.1.1 | Ofgem to keep Ofgem legal informed of process followed and nature of Code drafting to ensure that prepared for SCR go/no go decision |  | 101d | 2024-02-05 A | 2024-06-24 A | 2387SF | 100% | 2024-02-05 | 2024-06-24 | 101d | 2024-01-26 | 2024-06-14 |  | Ofgem | Code Bodies | Regulatory |  | 5.0 | Andrew Margan | Regulatory | Complete | COMPLETE |  |  |  |  |
| 2387 | 1.7.2.1.2 | OFGEM Legal to review Code Artefacts deliver policy intent and process followed and confirm that SCR powers are appropriate to use rather than SMAP - SCR go/no go |  | 14d | 2024-06-24 A | 2024-07-11 A | 2378SS | 100% | 2024-06-24 | 2024-07-11 | 15d | 2024-06-14 | 2024-07-04 |  | Ofgem | Code Bodies | Regulatory |  | 5.0 | Andrew Margan | Regulatory | Complete | COMPLETE |  |  |  |  |
| 2388 | 1.7.2.1.3 | Code Bodies to draft MOD proposal forms |  | 20d | 2024-07-12 A | 2024-08-08 A | 2387 | 100% | 2024-07-12 | 2024-08-08 | 20d | 2024-07-05 | 2024-08-01 |  | Code Bodies | Ofgem | Regulatory |  | 5.0 | Andrew Margan | Regulatory | Complete | COMPLETE |  |  |  |  |
| 2389 | 1.7.2.1.4 | Ofgem discuss and agree code mod timetable with code bodies (and MHHSP in relation to the dates for expected decisions) |  | 20d | 2024-07-12 A | 2024-08-08 A | 2387 | 100% | 2024-07-12 | 2024-08-08 | 20d | 2024-07-05 | 2024-08-01 |  | Ofgem | Code Bodies | Regulatory |  | 5.0 | Andrew Margan | Regulatory | Complete | COMPLETE |  |  |  |  |
| 2390 | 1.7.2.1.5 | Ofgem to publish each Direction to each code body specifying the timetable for each modification |  | 1d | 2024-08-28 A | 2024-08-28 A | 2389FS+13d | 100% | 2024-08-28 | 2024-08-28 | 1d | 2024-08-28 | 2024-08-28 |  | Ofgem | Code Bodies | Regulatory |  | 5.0 | Andrew Margan | Regulatory | Complete | COMPLETE |  |  |  |  |
| 2391 | 1.7.2.1.6 | Formally submit (by separate email) Modification Proposal Forms and legal texts to each code body |  | 1d | 2024-08-28 A | 2024-08-28 A | 2389FS+13d | 100% | 2024-08-28 | 2024-08-28 | 1d | 2024-08-28 | 2024-08-28 |  | Ofgem | Code Bodies | Regulatory |  | 5.0 | Andrew Margan | Regulatory | Complete | COMPLETE |  |  |  |  |
| 2392 | 1.7.2.1.7 | Each Code Body publishes and issues Modification Proposal Forms |  | 3d | 2024-08-29 A | 2024-09-02 A | 2391, 2390 | 100% | 2024-08-29 | 2024-09-02 | 3d | 2024-08-29 | 2024-09-02 |  | Code Bodies | Ofgem | Regulatory |  | 5.0 | Andrew Margan | Regulatory | Complete | COMPLETE |  |  |  |  |
| 2393 | 1.7.2.1.8 | Each Code Body sends Modification Proposal Forms to Panel to approve Mod to go to consultation |  | 10d | 2024-09-03 A | 2024-09-16 A | 2392 | 100% | 2024-09-03 | 2024-09-16 | 10d | 2024-09-03 | 2024-09-16 |  | Code Bodies | Ofgem | Regulatory |  | 5.0 | Andrew Margan | Regulatory | Complete | COMPLETE |  |  |  |  |
| 2394 | 1.7.2.1.9 | Modification Proposal approved by Panel for Consultation |  | 1d | 2024-09-17 A | 2024-09-17 A | 2393 | 100% | 2024-09-17 | 2024-09-17 | 1d | 2024-09-17 | 2024-09-17 |  | Code Bodies | Ofgem | Regulatory |  | 5.0 | Andrew Margan | Regulatory | Complete | COMPLETE |  |  |  |  |
| 2395 | 1.7.2.1.10 | Draft Modification Report issued for consultation |  | 1d | 2024-09-18 A | 2024-09-18 A | 2394 | 100% | 2024-09-18 | 2024-09-18 | 1d | 2024-09-18 | 2024-09-18 |  | Code Bodies | Ofgem | Regulatory |  | 5.0 | Andrew Margan | Regulatory | Complete | COMPLETE |  |  |  |  |
| 2396 | 1.7.2.1.11 | Consultation Close-out for representations |  | 15d | 2024-09-19 A | 2024-10-09 A | 2395 | 100% | 2024-09-19 | 2024-10-09 | 15d | 2024-09-19 | 2024-10-09 |  | Code Bodies | Ofgem | Regulatory |  | 5.0 | Andrew Margan | Regulatory | Complete | COMPLETE |  |  |  |  |
| 2397 | 1.7.2.1.12 | Each Code Body reviews consultation response and drafts Modification Report |  | 10d | 2024-10-10 A | 2024-10-23 A | 2396 | 100% | 2024-10-10 | 2024-10-23 | 10d | 2024-10-10 | 2024-10-23 |  | Code Bodies | Ofgem | Regulatory |  | 5.0 | Andrew Margan | Regulatory | Complete | COMPLETE |  |  |  |  |
| 2398 | 1.7.2.1.13 | Final Modification Report sent to Panel for decision with recommendation to approve |  | 1d | 2024-10-24 A | 2024-10-24 A | 2397 | 100% | 2024-10-24 | 2024-10-24 | 1d | 2024-10-24 | 2024-10-24 |  | Code Bodies | Ofgem | Regulatory |  | 6.11 | Andrew Margan | Regulatory | Complete | COMPLETE |  |  |  |  |
| 2399 | 1.7.2.1.14 | Modification Panel decision |  | 1d | 2024-11-07 A | 2024-11-07 A | 2398FS+9d | 100% | 2024-11-07 | 2024-11-07 | 1d | 2024-11-07 | 2024-11-07 |  | Code Bodies | Ofgem | Regulatory |  | 6.11 | Andrew Margan | Regulatory | Complete | COMPLETE |  |  |  |  |
| 2400 | 1.7.2.1.15 | Code Bodies Submit Final Modification/Change Reports |  | 1d | 2024-11-08 A | 2024-11-08 A | 2399 | 100% | 2024-11-08 | 2024-11-08 | 1d |  |  |  | Code Bodies | Ofgem | Regulatory |  | 6.11 | Andrew Margan |  | Complete | COMPLETE |  |  |  |  |
| 2401 | 1.7.2.1.16 | Ofgem Reviews Final Modification/Change Reports |  | 10d | 2024-11-11 A | 2024-11-22 A | 2400 | 100% | 2024-11-11 | 2024-11-22 | 10d |  |  |  | Ofgem | Code Bodies | Regulatory |  | 6.11 | Andrew Margan |  | Complete | COMPLETE |  |  |  |  |
| 2402 | 1.7.2.1.17 | Ofgem Drafts Decision/Direction Letters |  | 17d | 2024-11-18 A | 2024-12-10 A | 2401SS+5d | 100% | 2024-11-18 | 2024-12-10 | 17d |  |  |  | Ofgem | Code Bodies | Regulatory |  | 6.11 | Andrew Margan |  | Complete | COMPLETE |  |  |  |  |
| 2403 | 1.7.2.1.18 | Ofgem Internally Signs Off the Decision/Direction Letters and Sends Them to the Code Bodies |  | 1d | 2024-12-11 A | 2024-12-11 A | 2402 | 100% | 2024-12-11 | 2024-12-11 | 1d |  |  |  | Ofgem | Code Bodies | Regulatory |  | 6.11 | Andrew Margan |  | Complete | COMPLETE |  |  |  |  |
| 2404 | 1.7.2.2 | Ofgem decisions on M6 baselined code modification proposals (M7) | milestone | 0d | 2024-12-11 A | 2024-12-11 A | 2383, 2403 | 100% | 2024-12-11 | 2024-12-11 | 0d | 2024-11-11 | 2024-11-11 |  | CPT | PP | Regulatory |  | 6.11 | Andrew Margan | Regulatory | Complete | COMPLETE | MHHS-ART012 | T2-RE-0600 | CCAG | T2 |
| 2405 | 1.7.2.3 | Ofgem Publishes the Decisions/Directions |  | 2d | 2024-12-12 A | 2024-12-13 A | 2404 | 100% | 2024-12-12 | 2024-12-13 | 2d |  |  |  | Ofgem | Code Bodies | Regulatory |  | 6.11 | Andrew Margan |  | Complete | COMPLETE |  |  |  |  |

Notes:
- 2404: Guidance: 5/8/25 - CR no52 and going to PSG on 7/8/24. 21/8/24: Milestone name and date change approved at psg on 7/8/24

| ID | WBS | Task | Type | Duration | Start | Finish | Predecessors | Complete | Remaining | Baseline start | Baseline finish | Baseline duration | Baseline 1 start | Baseline 1 finish | Total slack | Free slack | Constraint | Baseline cost | Responsible | Involved | Text9 | Task Status | Update Version | MHHS Resource Name | MHHS Programme Phase | Sched Status | RAG | Artefact ID | Milestone ID | Text29 | Tier | Future RAG |
| --- | --- | --- | --- | --- | --- | --- | --- | --- | --- | --- | --- | --- | --- | --- | --- | --- | --- | --- | --- | --- | --- | --- | --- | --- | --- | --- | --- | --- | --- | --- | --- | --- |
| 2406 | 1.7.3 | **Deliver MHHS Code Changes** |  | 292d | 2024-11-12 A | 2025-12-24 |  | 93% | 20.86d | 2024-11-12 | 2025-12-24 | 149d | 2024-11-12 | 2025-03-07 | 521d |  |  |  | N/A | N/A | Regulatory | M8 | 6.11 | N/A | Regulatory |  |  |  |  |  |  |  |
| 2407 | 1.7.3.1 | **Releases** |  | 292d | 2024-11-12 A | 2025-12-24 |  | 93% | 20.86d | 2024-11-12 | 2025-12-24 | 149d | 2024-11-12 | 2025-03-07 | 521d |  |  |  | N/A | N/A | Regulatory |  | 6.11 | N/A | Regulatory |  |  |  |  |  |  |  |
| 2408 | 1.7.3.1.1 | Impacted codes make resourcing provisions and prepare to implement new Code via internal code body change processes |  | 78d | 2024-11-12 A | 2025-02-27 A |  | 100% |  | 2024-11-12 | 2025-02-27 | 78d | 2024-11-12 | 2025-02-27 |  |  | start no earlier than 2024-11-12 |  | Code Bodies |  | Regulatory |  | 6.11 | Andrew Margan | Regulatory | Complete | COMPLETE |  |  |  |  |  |
| 2409 | 1.7.3.1.2 | **Main Code Release** |  | 71d | 2025-09-17 | 2025-12-24 |  |  |  | 2025-09-17 | 2025-12-24 | 71d | 2025-02-28 | 2025-03-07 | 521d |  |  |  | N/A | N/A | Regulatory |  | 6.11 | N/A | Regulatory |  |  |  |  |  |  |  |
| 2410 | 1.7.3.1.2.1 | Release preparation (e.g. preparing release documentation) |  | 6d | 2025-09-17 | 2025-09-24 | 2411SF |  |  | 2025-09-17 | 2025-09-24 | 5d | 2025-02-28 | 2025-03-07 | 586d |  |  |  | Code Bodies |  | Regulatory | 231.33 | 6.11 | Andrew Margan | Regulatory | Green | GREEN |  |  |  |  |  |
| 2411 | 1.7.3.1.2.2 | Implement new code on day of code release | milestone | 0d | 2025-09-24 | 2025-09-24 | 2412SF |  |  | 2025-09-24 | 2025-09-24 | 1d | 2025-03-07 | 2025-03-07 | 586d | 0d |  |  | Code Bodies |  | Regulatory | 238.71 | 6.11 | Andrew Margan | Regulatory | Green | GREEN |  |  |  |  |  |
| 2412 | 1.7.3.1.2.3 | Code changes delivered (M8) | milestone | 0d | 2025-09-24 | 2025-09-24 | 2404, 2383, 1756SS |  |  | 2025-09-24 | 2025-09-24 | 0d | 2025-03-07 | 2025-03-07 | 521d | 0d |  |  | CPT | Code Bodies,PP | Regulatory | 238.71 | 6.11 | Andrew Margan | Regulatory | Green | GREEN | MHHS-ART060 | T2-RE-0650 | CCAG | T2 |  |
| 2413 | 1.7.3.1.2.4 | Code changes delivered (M8*) late exit | milestone | 0d | 2025-12-24 | 2025-12-24 | 2412FS+65d |  |  | 2025-12-24 | 2025-12-24 | 0d |  |  | 521d |  |  |  | CPT | Code Bodies,PP | Regulatory | 329.71 | 6.11 | Andrew Margan | Regulatory | Green | GREEN | MHHS-ART060 | T2-RE-0700 | CCAG | T2 |  |
| 2414 | 1.7.4 | **External Programme Dependency Management** |  | 38d | 2023-12-01 A | 2024-01-24 A |  | 100% |  | 2023-12-01 | 2024-01-24 | 38d | 2023-09-08 | 2024-01-24 |  |  |  |  | N/A | N/A | Regulatory |  | 5.0 | N/A | Regulatory |  |  |  |  |  |  |  |
| 2415 | 1.7.4.1 | **DCP397** |  | 38d | 2023-12-01 A | 2024-01-24 A |  | 100% |  | 2023-12-01 | 2024-01-24 | 38d | 2023-09-08 | 2024-01-24 |  |  |  |  | N/A | N/A | Regulatory |  | 5.0 | N/A | Regulatory |  |  |  |  |  |  |  |
| 2416 | 1.7.4.1.1 | Ensure DCP397 drafting included in mop-up code drafting activity (link to mop-up) |  | 20d | 2023-12-01 A | 2023-12-28 A | 2367SS, 2364SS | 100% |  | 2023-12-01 | 2023-12-28 | 20d | 2023-09-08 | 2023-10-05 |  |  |  |  | CPT | Code Bodies,SRO Design, Code Drafting PM | Regulatory |  | 5.0 | Andrew Margan | Regulatory | Complete | COMPLETE |  |  |  |  |  |
| 2417 | 1.7.4.1.2 | Implementation of DCP397 | milestone | 0d | 2024-01-24 A | 2024-01-24 A |  | 100% |  | 2024-01-24 | 2024-01-24 | 0d | 2024-01-24 | 2024-01-24 |  |  | start no earlier than 2024-01-24 |  | Code Bodies |  | Regulatory |  | 5.0 | Andrew Margan | Regulatory | Complete | COMPLETE |  |  |  |  |  |
| 2418 | 1.8 | **MIGRATION** |  | 1246d? | 2022-10-31 A | 2027-08-09 |  | 38% | 777.61d? | 2022-10-31 | 2027-08-09 | 1092d | 2022-10-31 | 2027-01-05 | 98d |  |  | -0 | N/A | N/A | Migration |  |  | N/A | Migration |  |  |  |  |  |  | 1 Oct 2024 - 31 Oct 2025 |
| 2419 | 1.8.1 | **Regulatory Governance** |  | 198d | 2024-04-01 A | 2025-01-01 |  | 47% | 105d | 2024-04-01 | 2025-01-01 | 173d |  |  | 776d |  |  | -0 | N/A | N/A | Migration |  | 5.28 | Warren Fulton |  |  |  |  |  |  |  |  |
| 2420 | 1.8.1.1 | Incentive Mods Created |  | 110d | 2024-04-01 A | 2024-08-30 |  | 85% | 17d | 2024-04-01 | 2024-08-30 | 85d |  |  | 776d | 0d | start no earlier than 2024-04-01 |  | SRO Migration | SRO Migration,Code Bodies,PP | Migration |  | 5.28 | Warren Fulton |  | Overdue | RED |  |  |  |  |  |
| 2421 | 1.8.1.2 | Incentives Implemented |  | 88d | 2024-09-02 | 2025-01-01 | 2420 |  |  | 2024-09-02 | 2025-01-01 | 88d |  |  | 776d |  | start no earlier than 2024-07-02 |  | Code Bodies | Code Bodies,SRO Migration | Migration | -148.67 | 5.28 | Warren Fulton |  | Overdue Start | GREEN |  |  |  |  |  |
| 2422 | 1.8.2 | **Migration Framework Agreed and Implemented** |  | 330d? | 2024-02-01 A | 2025-05-07 |  | 58% | 138.24d? | 2024-02-01 | 2025-01-23 | 214d |  |  | 686d |  |  | -0 | N/A | N/A | Migration |  | 5.28 | Warren Fulton |  |  |  |  |  |  |  |  |
| 2423 | 1.8.2.1 | **Consultation 1 - Schedule** |  | 70d | 2024-02-01 A | 2024-05-08 A |  | 100% |  | 2024-02-01 | 2024-05-08 | 70d |  |  |  |  |  |  | N/A | N/A | Migration |  | 5.28 | Warren Fulton |  |  |  |  |  |  |  |  |
| 2424 | 1.8.2.1.1 | Prepare Artefacts for Consultation |  | 33d | 2024-02-01 A | 2024-03-18 A |  | 100% |  | 2024-02-01 | 2024-03-18 | 33d |  |  |  |  |  |  |  |  | Migration |  | 5.28 | Warren Fulton |  | Complete | COMPLETE |  |  |  |  |  |
| 2425 | 1.8.2.1.2 | Industry Consultation |  | 16d | 2024-03-18 A | 2024-04-08 A |  | 100% |  | 2024-03-18 | 2024-04-08 | 16d |  |  |  |  |  |  |  |  | Migration |  | 5.28 | Warren Fulton |  | Complete | COMPLETE |  |  |  |  |  |
| 2426 | 1.8.2.1.3 | Triage and Action Comments |  | 10d | 2024-04-08 A | 2024-04-19 A |  | 100% |  | 2024-04-08 | 2024-04-19 | 10d |  |  |  |  |  |  |  |  | Migration |  | 5.28 | Warren Fulton |  | Complete | COMPLETE |  |  |  |  |  |
| 2427 | 1.8.2.1.4 | Industry Assurance Review |  | 6d | 2024-04-19 A | 2024-04-26 A |  | 100% |  | 2024-04-19 | 2024-04-26 | 6d |  |  |  |  |  |  |  |  | Migration |  | 5.28 | Warren Fulton |  | Complete | COMPLETE |  |  |  |  |  |
| 2428 | 1.8.2.1.5 | MWG Recommendation |  | 1d | 2024-04-26 A | 2024-04-26 A |  | 100% |  | 2024-04-26 | 2024-04-26 | 1d |  |  |  |  |  |  |  |  | Migration |  | 5.28 | Warren Fulton |  | Complete | COMPLETE |  |  |  |  |  |
| 2429 | 1.8.2.1.6 | MCAG Interim Approval Artefacts |  | 1d | 2024-05-08 A | 2024-05-08 A |  | 100% |  | 2024-05-08 | 2024-05-08 | 1d |  |  |  |  |  |  |  |  | Migration |  | 5.28 | Warren Fulton |  | Complete | COMPLETE |  |  |  |  |  |

| ID | WBS | Task | Type | Duration | Start | Finish | Predecessors | Complete | Remaining | Baseline start | Baseline finish | Baseline duration | Total slack | Free slack | Constraint | Baseline cost | Responsible | Involved | Text9 | Update Version | MHHS Resource Name | Sched Status | RAG | Milestone ID | Text29 | Tier | Task Status |
| --- | --- | --- | --- | --- | --- | --- | --- | --- | --- | --- | --- | --- | --- | --- | --- | --- | --- | --- | --- | --- | --- | --- | --- | --- | --- | --- | --- |
| 2430 | 1.8.2.2 | **Consultation 2 - Control** |  | 79d | 2024-04-08 A | 2024-07-25 A |  | 100% |  | 2024-04-08 | 2024-07-25 | 79d |  |  |  | -0 | N/A | N/A | Migration | 5.28 | Warren Fulton |  |  |  |  |  |  |
| 2431 | 1.8.2.2.1 | Prepare Artefacts for Consultation |  | 49d | 2024-04-08 A | 2024-06-13 A |  | 100% |  | 2024-04-08 | 2024-06-13 | 49d |  |  |  |  |  |  | Migration | 5.28 | Warren Fulton | Complete | COMPLETE |  |  |  |  |
| 2432 | 1.8.2.2.2 | Industry Consultation |  | 11d | 2024-06-14 A | 2024-06-28 A | 2431 | 100% |  | 2024-06-14 | 2024-06-28 | 11d |  |  |  |  |  |  | Migration | 5.28 | Warren Fulton | Complete | COMPLETE |  |  |  |  |
| 2433 | 1.8.2.2.3 | Triage and Action Comments |  | 9d | 2024-07-01 A | 2024-07-11 A | 2432 | 100% |  | 2024-07-01 | 2024-07-11 | 9d |  |  |  |  | SRO Migration | SRO Migration | Migration | 5.28 | Warren Fulton | Complete | COMPLETE |  |  |  |  |
| 2434 | 1.8.2.2.4 | Industry Assurance Review |  | 5d | 2024-07-12 A | 2024-07-18 A | 2433 | 100% |  | 2024-07-12 | 2024-07-18 | 5d |  |  |  |  | PP | PP,SRO Migration | Migration | 5.28 | Warren Fulton | Complete | COMPLETE |  |  |  |  |
| 2435 | 1.8.2.2.5 | MWG Recommendation | milestone | 0d | 2024-07-18 A | 2024-07-18 A | 2434 | 100% |  | 2024-07-18 | 2024-07-18 | 0d |  |  |  |  | PP | PP,SRO Migration | Migration | 5.28 | Warren Fulton | Complete | COMPLETE |  |  |  |  |
| 2436 | 1.8.2.2.6 | Consultation 2 - Control - MCAG Approval of Interim Artefacts | milestone | 0d | 2024-07-25 A | 2024-07-25 A | 2435FS+5d | 100% |  | 2024-07-25 | 2024-07-25 | 0d |  |  |  |  | PP | PP,SRO Migration | Migration | 5.30 | Warren Fulton | Complete | COMPLETE | T3-MI-0037 | MCAG (Migration) | T3 |  |
| 2437 | 1.8.2.3 | **Consultation 3 - Parameters** |  | 72d | 2024-11-18 A | 2025-02-25 |  | 71% | 20.96d | 2024-11-18 | 2025-02-25 | 76d | 690d |  |  | -0 | N/A | N/A | Migration | 6.14 | Warren Fulton |  |  |  |  |  |  |
| 2438 | 1.8.2.3.1 | Prepare Artefacts for Consultation |  | 24d | 2024-11-18 A | 2024-12-19 A |  | 100% |  | 2024-11-18 | 2024-12-19 | 36d |  |  |  |  | SRO Migration | SRO Migration | Migration | 6.14 | Warren Fulton | Complete | COMPLETE |  |  |  |  |
| 2439 | 1.8.2.3.2 | Industry Consultation |  | 21d | 2024-12-20 A | 2025-01-17 | 2438 | 95% | 1.05d | 2024-12-20 | 2025-01-17 | 10d | 690d | 0d |  |  | PP | PP,SRO Migration | Migration | 6.14 | Warren Fulton | Green | GREEN |  |  |  |  |
| 2440 | 1.8.2.3.3 | Triage Response |  | 10d | 2025-01-20 | 2025-01-31 | 2439 |  |  | 2025-01-20 | 2025-01-31 | 10d | 690d | 0d |  |  | SRO Migration | SRO Migration | Migration | 6.14 | Warren Fulton | Green | GREEN |  |  |  | -8.67 |
| 2441 | 1.8.2.3.4 | Industry Assurance Review |  | 7d | 2025-02-03 | 2025-02-11 | 2440 |  |  | 2025-02-03 | 2025-02-11 | 7d | 690d | 0d |  |  | PP | PP,SRO Migration | Migration | 6.14 | Warren Fulton | Green | GREEN |  |  |  | 5.33 |
| 2442 | 1.8.2.3.5 | MWG Recommendation | milestone | 0d | 2025-02-21 | 2025-02-21 | 2441FS+8d |  |  | 2025-02-21 | 2025-02-21 | 0d | 690d | 0d |  |  | PP | PP,SRO Migration | Migration | 6.14 | Warren Fulton | Green | GREEN |  |  |  | 23.71 |
| 2443 | 1.8.2.3.6 | MCAG Paper Day | milestone | 0d | 2025-02-25 | 2025-02-25 | 2442FS+2d |  |  | 2025-02-25 | 2025-02-25 | 0d | 690d | 0d |  |  |  |  | Migration | 6.14 | Warren Fulton | Green | GREEN |  |  |  | 27.71 |
| 2444 | 1.8.2.3.7 | MCAG Approval of Consultation 3 | milestone | 0d | 2025-02-25 | 2025-02-25 | 2442, 2443 |  |  | 2025-02-25 | 2025-02-25 | 0d | 690d | 0d | start no earlier than 2025-02-25 |  | PP | PP,SRO Migration | Migration | 6.17 | Warren Fulton | Green | GREEN | T3-MI-0017 | MCAG (Migration) | T3 | 27.71 |
| 2445 | 1.8.2.4 | **Consultation 4** |  | 87d? | 2025-01-07 A | 2025-05-07 |  | 1% | 86.26d? | 2025-01-07 | 2025-05-07 |  | 686d |  |  |  | SI Migration |  | Migration | 6.17 | Warren Fulton |  |  |  |  |  | -770.67 |
| 2446 | 1.8.2.4.1 | **Prepare Artefacts** |  | 87d? | 2025-01-07 A | 2025-05-07 |  | 1% | 86d? | 2025-01-07 | 2025-05-07 |  | 686d |  |  |  | SI Migration |  | Migration | 6.17 | Warren Fulton |  |  |  |  |  | -770.67 |
| 2447 | 1.8.2.4.1.1 | Test Approach |  | 20d? | 2025-01-07 A | 2025-02-03 |  | 5% | 19d? | 2025-01-07 | 2025-02-03 |  | 686d | 0d | start no earlier than 2025-01-07 |  | SI Migration |  | Migration | 6.17 | Warren Fulton | Green | GREEN |  |  |  |  |
| 2448 | 1.8.2.4.1.2 | Test Plan |  | 20d? | 2025-02-04 | 2025-03-03 | 2447 |  |  | 2025-02-04 | 2025-03-03 |  | 686d | 0d |  |  | SI Migration |  | Migration | 6.17 | Warren Fulton | Green | GREEN |  |  |  | 6.33 |
| 2449 | 1.8.2.4.1.3 | Other Framework items |  | 47d? | 2025-03-04 | 2025-05-07 | 2448 |  |  | 2025-03-04 | 2025-05-07 |  | 686d |  |  |  | SI Migration |  | Migration | 6.17 | Warren Fulton | Green | GREEN |  |  |  | 34.33 |
| 2450 | 1.8.2.4.2 | Industry Consultation |  | 10d? | 2025-03-12 | 2025-03-25 |  |  |  | 2025-03-12 | 2025-03-25 |  | 697d | 0d | start no earlier than 2025-03-12 |  | PP |  | Migration | 6.17 | Warren Fulton | Green | GREEN |  |  |  | 42.33 |
| 2451 | 1.8.2.4.3 | Triage Response |  | 10d? | 2025-03-26 | 2025-04-08 | 2450 |  |  | 2025-03-26 | 2025-04-08 |  | 697d | 0d |  |  | SI Migration |  | Migration | 6.17 | Warren Fulton | Green | GREEN |  |  |  | 56.33 |
| 2452 | 1.8.2.4.4 | Assurance and MCAG Approval |  | 10d? | 2025-04-09 | 2025-04-22 | 2451 |  |  | 2025-04-09 | 2025-04-22 |  | 697d | 0d |  |  | SI Migration |  | Migration | 6.17 | Warren Fulton | Green | GREEN |  |  |  | 70.33 |
| 2453 | 1.8.2.4.5 | MCAG Approval of Consultation 4 | milestone | 0d | 2025-04-22 | 2025-04-22 | 2452 |  |  | 2025-04-22 | 2025-04-22 |  | 697d | 0d |  |  | SI Migration |  | Migration | 6.17 | Warren Fulton | Green | GREEN | T3-MI-0041 | MCAG (Migration) | T3 | 83.71 |
| 2454 | 1.8.2.5 | Framework Baselined at MCAG | milestone | 0d | 2025-04-22 | 2025-04-22 | 2453 |  |  | 2025-04-22 | 2025-04-22 |  | 697d |  |  |  | SI Migration |  | Migration | 6.17 | Warren Fulton | Green | GREEN | T2-MI-7000 | MCAG (Migration) | T2 | 83.71 |

Notes:
- 2436: Guidance: 25/7/24: New Milestone approved at MCAG on 25/7/24
- 2444: Guidance: 25/7/24: Milestone name and date change approved at MCAG on 25/7/24. Date from 2/8/24 to 22/10/24. Name from 'Migration Processes & Procedures approved' to 'MCAG Approval of Migration Framework Artefacts (Baselined)’
- 2445: 29/01/25 - Dates for Consultation 4 included in the plan after approval by January MCAG.
- 2446: 29/01/25 - Dates for Consultation 4 included in the plan after approval by January MCAG.
- 2447: 29/01/25 - Dates for Consultation 4 included in the plan after approval by January MCAG.
- 2448: 29/01/25 - Dates for Consultation 4 included in the plan after approval by January MCAG.
- 2449: 29/01/25 - Dates for Consultation 4 included in the plan after approval by January MCAG.
- 2450: 29/01/25 - Dates for Consultation 4 included in the plan after approval by January MCAG.
- 2451: 29/01/25 - Dates for Consultation 4 included in the plan after approval by January MCAG.
- 2452: 29/01/25 - Dates for Consultation 4 included in the plan after approval by January MCAG.
- 2453: 29/01/25 - Dates for Consultation 4 included in the plan after approval by January MCAG.
- 2454: 29/01/25 - Updated timeframe for baselining of migration framework included in the plan after approval by January MCAG.

| ID | WBS | Task | Type | Duration | Start | Finish | Predecessors | Complete | Remaining | Baseline start | Baseline finish | Baseline duration | Baseline 1 start | Baseline 1 finish | Total slack | Free slack | Constraint | Baseline cost | Responsible | Involved | Text9 | Update Version | MHHS Resource Name | Sched Status | RAG | Text29 | Tier | Milestone ID | Task Status | Guidance | MHHS Programme Phase | Artefact ID |
| --- | --- | --- | --- | --- | --- | --- | --- | --- | --- | --- | --- | --- | --- | --- | --- | --- | --- | --- | --- | --- | --- | --- | --- | --- | --- | --- | --- | --- | --- | --- | --- | --- |
| 2455 | 1.8.3 | **Migration Schedule Agreed and Maintained** |  | 276d? | 2024-07-01 A | 2025-07-22 |  | 99% | 0d? | 2024-07-01 | 2026-01-30 | 207d |  |  | 633d |  |  | -0 | SI Migration | N/A | Migration | 6.17 | Warren Fulton |  |  |  |  |  |  |  |  |  |
| 2456 | 1.8.3.1 | Schedule Production |  | 125d? | 2024-07-01 A | 2024-12-20 A |  | 100% |  | 2024-11-18 | 2024-12-20 |  |  |  |  |  | start no earlier than 2024-11-18 |  | SI Migration |  | Migration | 6.14 | Warren Fulton | Complete | COMPLETE | MCAG (Migration) | T3 |  |  |  |  |  |
| 2457 | 1.8.3.2 | Schedule Production Complete | milestone | 0d | 2024-12-20 A | 2024-12-20 A | 2456 | 100% |  | 2024-12-20 | 2024-12-20 |  |  |  |  |  |  |  | SI Migration |  | Migration | 6.14 | Warren Fulton | Complete | COMPLETE | MCAG (Migration) |  | T3-MI-0042 |  |  |  |  |
| 2458 | 1.8.3.3 | Second Supplier Submission complete | milestone | 0d | 2025-06-20 | 2025-06-20 |  |  |  | 2025-06-20 | 2025-06-20 |  |  |  | 634d | 1d | finish no earlier than 2025-06-20 |  | SI Migration |  | Migration | 6.17 | Warren Fulton | Green | GREEN | MCAG (Migration) | T3 | T3-MI-0043 | 142.71 |  |  |  |
| 2459 | 1.8.3.4 | V1.0 of Migration Schedule Baseline Approved at MCAG | milestone | 0d | 2025-07-22 | 2025-07-22 | 2458FS+20d |  |  | 2025-07-22 | 2025-07-22 | 0d |  |  | 633d |  | start no earlier than 2025-07-22 |  | SI Migration | SRO Migration,PP | Migration | 6.17 | Warren Fulton | Green | GREEN | MCAG (Migration) | T2 | T2-MI-7500 | 174.33 | 25/7/24: New Milestone approved at MCAG on 25/7/24 |  |  |
| 2460 | 1.8.4 | Migration Sprint 0 schedule baselined | milestone | 0d | 2025-10-16 | 2025-10-16 |  |  |  | 2025-10-16 | 2025-10-16 |  |  |  | 570d |  | finish no earlier than 2025-10-16 |  | SI Migration |  | Migration | 6.17 | Warren Fulton | Green | GREEN | MCAG (Migration) | T2 | T2-MI-8000 | 260.71 |  |  |  |
| 2461 | 1.8.5 | **MCC Stood up** |  | 265d? | 2024-11-18 | 2025-11-21 |  |  |  | 2024-11-18 | 2025-11-21 |  |  |  |  |  |  |  | SI Migration |  | Migration | 6.17 | Warren Fulton |  |  | MCAG (Migration) |  |  | -771.67 |  |  |  |
| 2462 | 1.8.5.1 | Migration Planning Management Tool Delivery | manual | 265d | 2024-11-18 | 2025-11-21 |  |  |  | 2024-11-18 | 2025-11-21 |  |  |  |  |  |  |  | SI Migration |  | Migration | 6.17 | Warren Fulton | Green | GREEN | MCAG (Migration) |  |  | -71.67 |  |  |  |
| 2463 | 1.8.5.2 | **MCC Operational** |  | 33d | 2025-07-15 | 2025-08-29 |  |  |  | 2025-07-15 | 2025-08-29 |  |  |  | 605d |  |  |  | SI Migration |  | Migration | 6.17 | Warren Fulton | Red |  | MCAG (Migration) | T2 |  | 220.71 |  |  |  |
| 2464 | 1.8.5.2.1 | MCC Dress Rehersal 1 - complete | milestone | 0d | 2025-07-15 | 2025-07-15 |  |  |  | 2025-07-15 | 2025-07-15 |  |  |  | 638d |  | start no earlier than 2025-07-15 |  | SI Migration |  | Migration | 6.17 | Warren Fulton | Green | GREEN | MCAG (Migration) | T3 | T3-MI-0044 | 167.33 |  |  |  |
| 2465 | 1.8.5.2.2 | MCC Dress Rehersal 2 - complete | milestone | 0d | 2025-08-29 | 2025-08-29 |  |  |  | 2025-08-29 | 2025-08-29 |  |  |  | 605d | 0d | start no earlier than 2025-08-29 |  | SI Migration |  | Migration | 6.17 | Warren Fulton | Green | GREEN | MCAG (Migration) | T3 | T3-MI-0045 | 212.33 |  |  |  |
| 2466 | 1.8.5.2.3 | MCC Operational Complete | milestone | 0d | 2025-08-29 | 2025-08-29 | 2465 |  |  | 2025-08-29 | 2025-08-29 |  |  |  | 605d |  |  |  | SI Migration |  | Migration | 6.17 |  | Green | GREEN | MCAG (Migration) | T2 | T2-MI-0500 | 212.33 |  |  |  |
| 2467 | 1.8.6 | **PP's Prepared for Migration** |  | 219d | 2024-07-01 A | 2025-05-01 |  | 23% | 168.46d | 2024-07-01 | 2025-03-31 | 154d |  |  | 690d |  |  | -0 | N/A | N/A | Migration | 5.28 | Warren Fulton |  |  |  |  |  |  |  |  |  |
| 2468 | 1.8.6.1 | Prep for Envelope Webinar |  | 26d | 2024-07-01 A | 2024-08-05 A |  | 100% |  | 2024-07-01 | 2024-08-05 | 26d |  |  |  |  |  |  | SRO Migration | SRO Migration | Migration | 5.28 | Warren Fulton | Complete | COMPLETE |  |  |  |  |  |  |  |
| 2469 | 1.8.6.2 | Envelope/Submission Webinar |  | 1d | 2024-08-05 A | 2024-08-05 A | 2468FF | 100% |  | 2024-08-05 | 2024-08-05 | 1d |  |  |  |  |  |  | SRO Migration | SRO Migration,PP | Migration | 5.28 | Warren Fulton | Complete | COMPLETE |  |  |  |  |  |  |  |
| 2470 | 1.8.6.3 | Guides Creation |  | 45d | 2025-02-28 | 2025-05-01 | 2444FS+2d |  |  | 2025-01-28 | 2025-03-31 | 45d |  |  | 690d |  |  |  | SRO Migration | SRO Migration,PP | Migration | 5.28 | Warren Fulton | Red | RED |  |  |  | 30.33 |  |  |  |
| 2471 | 1.8.6.4 | Support Channels |  | 45d | 2025-02-28 | 2025-05-01 | 2444FS+2d |  |  | 2025-01-28 | 2025-03-31 | 45d |  |  | 690d |  |  |  | SRO Migration | SRO Migration,PP | Migration | 5.28 | Warren Fulton | Red | RED |  |  |  | 30.33 |  |  |  |
| 2472 | 1.8.7 | **Migration Artefact Development and Publication** |  | 773d | 2022-10-31 A | 2025-10-15 |  | 91% | 73.28d | 2022-10-31 | 2025-09-03 | 635d | 2022-10-31 | 2025-04-04 | 571d |  |  | -0 | N/A | N/A | Migration | 5.0 | Warren Fulton |  |  |  |  |  |  |  | Migration |  |
| 2473 | 1.8.7.1 | **Migration Approach** |  | 28d | 2022-10-31 A | 2022-12-07 A |  | 100% |  | 2022-10-31 | 2022-12-07 | 28d | 2022-10-31 | 2022-12-07 |  |  |  |  | N/A | N/A | Migration | 5.0 | Warren Fulton |  |  |  |  |  |  |  | Migration |  |
| 2474 | 1.8.7.1.1 | Option analysis (via MWG and PPIR) and recommendation |  | 23d | 2022-10-31 A | 2022-11-30 A |  | 100% |  | 2022-10-31 | 2022-11-30 | 23d | 2022-10-31 | 2022-11-30 |  |  |  |  | PP | SI Migration | Migration | 5.0 | John Wiggins,Matthew Breen | Complete | COMPLETE |  |  |  |  |  | Migration |  |
| 2475 | 1.8.7.1.2 | Migration Approach approved | milestone | 0d | 2022-12-07 A | 2022-12-07 A | 2474FS+5d | 100% |  | 2022-12-07 | 2022-12-07 | 0d | 2022-12-07 | 2022-12-07 |  |  |  |  | SI Migration | PP,IPA | Migration | 5.0 | John Wiggins,Matthew Breen | Complete | COMPLETE | PSG | T3 | T3-MI-0010 |  |  | Migration | MHHS-DEL770 |
| 2476 | 1.8.7.2 | **Migration Design** |  | 100d | 2022-11-14 A | 2023-03-31 A |  | 100% |  | 2022-11-14 | 2023-03-31 | 100d | 2022-11-14 | 2023-03-31 |  |  |  |  | N/A | N/A | Migration | 5.0 | N/A |  |  |  |  |  |  |  | Migration |  |
| 2477 | 1.8.7.2.1 | Review and update existing design artefacts and socialise with participants ahead of MDSG |  | 10d | 2022-11-14 A | 2022-11-25 A |  | 100% |  | 2022-11-14 | 2022-11-25 | 10d | 2022-11-14 | 2022-11-25 |  |  |  |  | SI Migration | SRO Design,CPT | Migration | 5.0 | John Wiggins,Matthew Breen | Complete | COMPLETE |  |  |  |  |  | Migration |  |
| 2478 | 1.8.7.2.2 | Develop design artefacts and supporting technical documents in line with MDSG |  | 53d | 2022-11-30 A | 2023-02-10 A | 2477FS+2d | 100% |  | 2022-11-30 | 2023-02-10 | 53d | 2022-11-30 | 2023-02-10 |  |  |  |  | SI Migration | PP,SRO Function,CPT | Migration | 5.0 | John Wiggins,Matthew Breen | Complete | COMPLETE |  |  |  |  |  | Migration |  |
| 2479 | 1.8.7.2.3 | Migration design artefacts issued for consultation | milestone | 0d | 2023-02-13 A | 2023-02-13 A | 2478FS+1d | 100% |  | 2023-02-13 | 2023-02-13 | 0d | 2023-02-13 | 2023-02-13 |  |  |  |  | SI Migration | PP,SRO Function,CPT | Migration | 5.0 | John Wiggins,Matthew Breen | Complete | COMPLETE | DAG | T3 | T3-MI-0011 |  |  | Migration |  |
| 2480 | 1.8.7.2.4 | Industry consultation |  | 5d | 2023-02-14 A | 2023-02-20 A | 2479SS | 100% |  | 2023-02-14 | 2023-02-20 | 5d | 2023-02-14 | 2023-02-20 |  |  |  |  | PP | SI Migration | Migration | 5.0 | John Wiggins,Matthew Breen | Complete | COMPLETE |  |  |  |  |  | Migration |  |
| 2481 | 1.8.7.2.5 | Review consultation feedback, address comments and update artefacts |  | 5d | 2023-02-21 A | 2023-02-27 A | 2480 | 100% |  | 2023-02-21 | 2023-02-27 | 5d | 2023-02-21 | 2023-02-27 |  |  |  |  | SI Migration | PP | Migration | 5.0 | John Wiggins,Matthew Breen | Complete | COMPLETE |  |  |  |  |  | Migration |  |
| 2482 | 1.8.7.2.6 | Internal artefact review and comms preparation |  | 3d | 2023-02-28 A | 2023-03-02 A | 2481 | 100% |  | 2023-02-28 | 2023-03-02 | 3d | 2023-02-28 | 2023-03-02 |  |  |  |  | SI Migration | SRO Function | Migration | 5.0 | John Wiggins,Matthew Breen | Complete | COMPLETE |  |  |  |  |  | Migration |  |
| 2483 | 1.8.7.2.7 | Updated Migration Design artefacts issued to PPs for assurance review | milestone | 0d | 2023-03-03 A | 2023-03-03 A | 2482FS+1d | 100% |  | 2023-03-03 | 2023-03-03 | 0d | 2023-03-03 | 2023-03-03 |  |  |  |  | SI Migration | PP | Migration | 5.0 | John Wiggins,Matthew Breen | Complete | COMPLETE | DAG | T3 | T3-MI-0013 |  |  | Migration |  |
| 2484 | 1.8.7.2.8 | Final Migration Design artefacts walkthrough with PPs | milestone | 0d | 2023-03-22 A | 2023-03-22 A | 2483FS+13d | 100% |  | 2023-03-22 | 2023-03-22 | 0d | 2023-03-22 | 2023-03-22 |  |  |  |  | SI Migration | PP | Migration | 5.0 | John Wiggins,Matthew Breen | Complete | COMPLETE |  |  |  |  |  | Migration |  |
| 2485 | 1.8.7.2.9 | Migration Design approved | milestone | 0d | 2023-03-31 A | 2023-03-31 A | 2484FS+7d | 100% |  | 2023-03-31 | 2023-03-31 | 0d | 2023-03-31 | 2023-03-31 |  |  |  |  | SI Migration | PP,SRO Function,CPT | Migration | 5.0 | John Wiggins,Matthew Breen | Complete | COMPLETE | DAG | T2 | T2-MI-0050 |  |  | Migration |  |

Notes:
- 2458: 29/01/25 - Latest Migration plan, which was approved by January MCAG, included in the plan. New Milestone ID created.
- 2459: 29/01/25 - Latest Migration plan, which was approved by January MCAG, included in the plan. New Milestone ID created.
- 2460: 29/01/25 - Latest Migration plan, which was approved by January MCAG, included in the plan. New Milestone ID created.
- 2461: 29/01/25 - Latest Migration plan, which was approved by January MCAG, included in the plan.
- 2462: 29/01/25 - Latest Migration plan, which was approved by January MCAG, included in the plan.
- 2463: 29/01/25 - Latest Migration plan, which was approved by January MCAG, included in the plan.
- 2464: 29/01/25 - Latest Migration plan, which was approved by January MCAG, included in the plan. New Milestone ID created.
- 2465: 29/01/25 - Latest Migration plan, which was approved by January MCAG, included in the plan. New Milestone ID created.
- 2466: 29/01/25 - Latest Migration plan, which was approved by January MCAG, included in the plan. New Milestone ID created.

| ID | WBS | Task | Type | Duration | Start | Finish | Predecessors | Complete | Baseline start | Baseline finish | Baseline duration | Baseline 1 start | Baseline 1 finish | Baseline cost | Responsible | Involved | Text9 | Update Version | MHHS Resource Name | MHHS Programme Phase | Sched Status | RAG | Milestone ID | Text29 | Tier | Guidance |
| --- | --- | --- | --- | --- | --- | --- | --- | --- | --- | --- | --- | --- | --- | --- | --- | --- | --- | --- | --- | --- | --- | --- | --- | --- | --- | --- |
| 2486 | 1.8.7.3 | **Transition Design** |  | 186d | 2023-03-01 A | 2023-11-15 A |  | 100% | 2023-03-01 | 2023-11-15 | 186d | 2023-03-01 | 2023-08-03 | -0 | N/A | N/A | Migration | 5.0 | N/A | Migration |  |  |  |  |  |  |
| 2487 | 1.8.7.3.1 | **Tranche 1** |  | 56d | 2023-03-01 A | 2023-05-17 A |  | 100% | 2023-03-01 | 2023-05-17 | 56d | 2023-03-01 | 2023-05-17 |  | N/A | N/A | Migration | 5.0 | N/A | Migration |  |  |  |  |  |  |
| 2488 | 1.8.7.3.1.1 | Develop design artefacts and supporting technical details with participants |  | 50d | 2023-03-01 A | 2023-05-09 A |  | 100% | 2023-03-01 | 2023-05-09 | 50d | 2023-03-01 | 2023-05-09 |  | SI Design | PP | Migration | 5.0 | Andrew Margan | Migration | Complete | COMPLETE |  |  |  |  |
| 2489 | 1.8.7.3.1.2 | Issue Material for DAG approval |  | 1d | 2023-05-10 A | 2023-05-10 A | 2488 | 100% | 2023-05-10 | 2023-05-10 | 1d | 2023-05-10 | 2023-05-10 |  | PP | SI Design | Migration | 5.0 | Andrew Margan | Migration | Complete | COMPLETE |  |  |  |  |
| 2490 | 1.8.7.3.1.3 | Tranche 1 Transition Design approved | milestone | 0d | 2023-05-17 A | 2023-05-17 A | 2489FS+5d | 100% | 2023-05-17 | 2023-05-17 | 0d | 2023-05-17 | 2023-05-17 |  | SI Design | PP | Migration | 5.0 | Andrew Margan | Migration | Complete | COMPLETE | T2-DB-0150 | DAG | T2 |  |
| 2491 | 1.8.7.3.2 | **Tranche 2** |  | 130d | 2023-05-18 A | 2023-11-15 A |  | 100% | 2023-05-18 | 2023-11-15 | 130d | 2023-05-18 | 2023-08-03 | -0 | N/A | N/A | Migration | 5.0 | N/A | Migration |  |  |  |  |  |  |
| 2492 | 1.8.7.3.2.1 | Develop Initial design artefacts and supporting technical details |  | 76d | 2023-05-18 A | 2023-08-31 A | 2490 | 100% | 2023-05-18 | 2023-08-31 | 76d | 2023-05-18 | 2023-07-26 |  | SRO | PP, CPT, SRO Design | Migration | 5.5 | Andrew Margan | Migration | Complete | COMPLETE |  |  |  |  |
| 2493 | 1.8.7.3.2.2 | Communicate Initial Design Artefacts with Industry (MTDSG) |  | 1d | 2023-09-01 A | 2023-09-01 A | 2492 | 100% | 2023-09-01 | 2023-09-01 | 1d |  |  |  | SRO | PP, CPT, SRO Design | Migration | 5.5 | Andrew Margan | Migration | Complete | COMPLETE |  |  |  |  |
| 2494 | 1.8.7.3.2.3 | Host MTDSG |  | 1d | 2023-09-11 A | 2023-09-11 A | 2493FS+5d | 100% | 2023-09-11 | 2023-09-11 | 1d |  |  |  | SRO | PP, CPT, SRO Design | Migration | 5.5 | Andrew Margan | Migration | Complete | COMPLETE |  |  |  |  |
| 2495 | 1.8.7.3.2.4 | Process MTDSG Feedback and Amend Design Artefacts |  | 4d | 2023-09-12 A | 2023-09-15 A | 2494 | 100% | 2023-09-12 | 2023-09-15 | 4d |  |  |  | SRO | PP, CPT, SRO Design | Migration | 5.5 | Andrew Margan | Migration | Complete | COMPLETE |  |  |  |  |
| 2496 | 1.8.7.3.2.5 | Communicate Amended Design Artefacts with Industry |  | 1d | 2023-09-15 A | 2023-09-15 A | 2495FF | 100% | 2023-09-15 | 2023-09-15 | 1d |  |  |  | SRO | PP, CPT, SRO Design | Migration | 5.5 | Andrew Margan | Migration | Complete | COMPLETE |  |  |  |  |
| 2497 | 1.8.7.3.2.6 | Host MTDSG |  | 1d | 2023-09-26 A | 2023-09-26 A | 2496FS+6d | 100% | 2023-09-26 | 2023-09-26 | 1d |  |  |  | SRO | PP, CPT, SRO Design | Migration | 5.5 | Andrew Margan | Migration | Complete | COMPLETE |  |  |  |  |
| 2498 | 1.8.7.3.2.7 | Make Final Amendments to Design Artefact |  | 5d | 2023-09-27 A | 2023-10-03 A | 2497 | 100% | 2023-09-27 | 2023-10-03 | 5d |  |  |  | SRO | PP, CPT, SRO Design | Migration | 5.5 | Andrew Margan | Migration | Complete | COMPLETE |  |  |  |  |
| 2499 | 1.8.7.3.2.8 | Request DAG Consultation |  | 1d | 2023-10-04 A | 2023-10-04 A | 2498 | 100% | 2023-10-04 | 2023-10-04 | 1d |  |  |  | SRO | PP, CPT, SRO Design | Migration | 5.5 | Andrew Margan | Migration | Complete | COMPLETE |  |  |  |  |
| 2500 | 1.8.7.3.2.9 | Consultation Period |  | 11d | 2023-10-04 A | 2023-10-18 A | 2499SS | 100% | 2023-10-04 | 2023-10-18 | 11d |  |  |  | SRO | PP, CPT, SRO Design | Migration | 5.5 | Andrew Margan | Migration | Complete | COMPLETE |  |  |  |  |
| 2501 | 1.8.7.3.2.10 | Action Consultation Comments |  | 5d | 2023-10-19 A | 2023-10-25 A | 2500 | 100% | 2023-10-19 | 2023-10-25 | 5d |  |  |  | SRO | PP, CPT, SRO Design | Migration | 5.5 | Andrew Margan | Migration | Complete | COMPLETE |  |  |  |  |
| 2502 | 1.8.7.3.2.11 | Post Consultation Industry Assurance |  | 5d | 2023-10-26 A | 2023-11-01 A | 2501 | 100% | 2023-10-26 | 2023-11-01 | 5d |  |  |  | SRO | PP, CPT, SRO Design | Migration | 5.5 | Andrew Margan | Migration | Complete | COMPLETE |  |  |  |  |
| 2503 | 1.8.7.3.2.12 | Request DAG Approval |  | 1d | 2023-11-01 A | 2023-11-01 A | 2502FF | 100% | 2023-11-01 | 2023-11-01 | 1d |  |  |  | SRO | PP, CPT, SRO Design | Migration | 5.5 | Andrew Margan | Migration | Complete | COMPLETE |  |  |  |  |
| 2504 | 1.8.7.3.2.13 | DAG Transition Design Approved |  | 1d | 2023-11-08 A | 2023-11-08 A | 2503FS+4d | 100% | 2023-11-08 | 2023-11-08 | 1d |  |  |  | SRO | PP, CPT, SRO Design | Migration | 5.5 | Andrew Margan | Migration | Complete | COMPLETE |  |  |  |  |
| 2505 | 1.8.7.3.2.14 | Update Transition Design Admin |  | 5d | 2023-11-09 A | 2023-11-15 A | 2504 | 100% | 2023-11-09 | 2023-11-15 | 5d |  |  |  | SRO | PP, CPT, SRO Design | Migration | 5.5 | Andrew Margan | Migration | Complete | COMPLETE |  |  |  |  |
| 2506 | 1.8.7.3.2.15 | Tranche 2 Transition Design Baselined | milestone | 0d | 2023-11-15 A | 2023-11-15 A | 2505 | 100% | 2023-11-15 | 2023-11-15 | 0d | 2023-08-03 | 2023-08-03 |  | SRO | PP, CPT, SRO Design | Migration | 5.12 | Andrew Margan | Migration | Complete | COMPLETE | T2-DB-0250 | DAG | T2 | 14/8 - Date aligns with DAG |
| 2507 | 1.8.7.4 | **Data Assessment Report** |  | 61d | 2022-12-06 A | 2023-02-28 A |  | 100% | 2022-12-06 | 2023-02-28 | 61d | 2022-12-06 | 2023-02-28 |  | N/A | N/A | Migration | 5.0 | N/A | Migration |  |  |  |  |  |  |
| 2508 | 1.8.7.4.1 | Develop document with MWG |  | 49d | 2022-12-06 A | 2023-02-10 A |  | 100% | 2022-12-06 | 2023-02-10 | 49d | 2022-12-06 | 2023-02-10 |  | SI Migration |  | Migration | 5.0 | John Wiggins,Matthew Breen | Migration | Complete | COMPLETE |  |  |  |  |
| 2509 | 1.8.7.4.2 | Artefact review (via TMAG) and updates |  | 25d | 2023-01-18 A | 2023-02-21 A | 2508FS-18d | 100% | 2023-01-18 | 2023-02-21 | 25d | 2023-01-18 | 2023-02-21 |  | PP | IPA,SI Migration | Migration | 5.0 | John Wiggins,Matthew Breen | Migration | Complete | COMPLETE |  |  |  |  |
| 2510 | 1.8.7.4.3 | Data Assessment Report approved | milestone | 0d | 2023-02-28 A | 2023-02-28 A | 2509FS+5d | 100% | 2023-02-28 | 2023-02-28 | 0d | 2023-02-28 | 2023-02-28 |  | SI Migration | PP,IPA | Migration | 5.0 | John Wiggins,Matthew Breen | Migration | Complete | COMPLETE | T3-MI-0012 | MCAG | T3 |  |

Notes:
- 2506: Action: 2/8/23 - needs to be replanned to 15//11/23. AM to raise CR as T2 milestone

| ID | WBS | Task | Type | Duration | Start | Finish | Predecessors | Complete | Remaining | Baseline start | Baseline finish | Baseline duration | Baseline 1 start | Baseline 1 finish | Total slack | Free slack | Constraint | Baseline cost | Responsible | Involved | Text9 | Update Version | MHHS Resource Name | MHHS Programme Phase | Sched Status | RAG | Milestone ID | Text29 | Tier | Task Status | Guidance |
| --- | --- | --- | --- | --- | --- | --- | --- | --- | --- | --- | --- | --- | --- | --- | --- | --- | --- | --- | --- | --- | --- | --- | --- | --- | --- | --- | --- | --- | --- | --- | --- |
| 2511 | 1.8.7.5 | **Migration, Cutover & Data Strategy (incl. Migration Entry Criteria)** |  | 102d | 2022-12-08 A | 2023-04-28 A |  | 100% |  | 2022-12-08 | 2023-04-28 | 102d | 2022-12-08 | 2023-04-28 |  |  |  |  | N/A | N/A | Migration | 5.0 | N/A | Migration |  |  |  |  |  |  |  |
| 2512 | 1.8.7.5.1 | Develop document with MWG |  | 67d | 2022-12-08 A | 2023-03-10 A | 2475 | 100% |  | 2022-12-08 | 2023-03-10 | 67d | 2022-12-08 | 2023-03-10 |  |  |  |  | SI Migration | PP | Migration | 5.0 | John Wiggins,Matthew Breen | Migration | Complete | COMPLETE |  |  |  |  |  |
| 2513 | 1.8.7.5.2 | Artefact review (via TMAG) and updates |  | 28d | 2023-03-15 A | 2023-04-21 A | 2512FS+2d | 100% |  | 2023-03-15 | 2023-04-21 | 28d | 2023-03-15 | 2023-04-21 |  |  |  |  | PP | SI Migration | Migration | 5.0 | John Wiggins,Matthew Breen | Migration | Complete | COMPLETE |  |  |  |  |  |
| 2514 | 1.8.7.5.3 | Migration, Cutover & Data Strategy approved | milestone | 0d | 2023-04-28 A | 2023-04-28 A | 2513FF+5d | 100% |  | 2023-04-28 | 2023-04-28 | 0d | 2023-04-28 | 2023-04-28 |  |  |  |  | SI Migration | PP | Migration | 5.0 | John Wiggins,Matthew Breen | Migration | Complete | COMPLETE | T3-MI-0014 | MCAG | T3 |  |  |
| 2515 | 1.8.7.6 | **Data Cleanse Plan** |  | 685d | 2023-03-02 A | 2025-10-15 |  | 84% | 112.15d | 2023-03-02 | 2025-09-03 | 547d | 2023-03-02 | 2025-04-04 | 571d |  |  | -0 | N/A | N/A | Migration | 5.0 | N/A | Migration |  |  |  |  |  |  |  |
| 2516 | 1.8.7.6.1 | Develop document with MWG |  | 50d | 2023-03-02 A | 2023-05-10 A |  | 100% |  | 2023-03-02 | 2023-05-10 | 50d | 2023-03-02 | 2023-05-10 |  |  |  |  | SI Migration | PP | Migration | 5.0 | John Wiggins,Matthew Breen | Migration | Complete | COMPLETE |  |  |  |  |  |
| 2517 | 1.8.7.6.2 | Artefact review (via TMAG) and updates |  | 20d | 2023-05-11 A | 2023-06-07 A | 2516 | 100% |  | 2023-05-11 | 2023-06-07 | 20d | 2023-05-11 | 2023-06-07 |  |  |  |  | PP | SI Migration,IPA | Migration | 5.0 | John Wiggins,Matthew Breen | Migration | Complete | COMPLETE |  |  |  |  |  |
| 2518 | 1.8.7.6.3 | Data Cleanse Plan approved | milestone | 0d | 2023-07-19 A | 2023-07-19 A | 2517FS+30d | 100% |  | 2023-07-19 | 2023-07-19 | 0d | 2023-06-14 | 2023-06-14 |  |  |  |  | SI Migration | PP | Migration | 5.0 | John Wiggins,Matthew Breen | Migration | Complete | COMPLETE | T3-MI-0020 | MCAG | T3 |  |  |
| 2519 | 1.8.7.6.4 | Monitor Programme Participant adherence to Data Cleanse Plan |  | 467d | 2023-06-15 A | 2025-03-28 | 2518 | 80% | 93.4d | 2023-06-15 | 2025-03-28 | 467d | 2023-06-15 | 2025-03-28 | 714d |  |  |  | SI Migration | PP | Migration | 5.0 | Matthew Breen | Migration | Green | GREEN |  |  |  |  |  |
| 2520 | 1.8.7.6.5 | **MTDs** |  | 115d | 2024-08-16 A | 2025-01-24 |  | 98% | 2.88d | 2024-08-16 | 2025-01-31 | 91d |  |  | 759d |  |  | -0 | N/A | N/A | Transition | 5.4 | N/A | Migration |  |  |  |  |  |  |  |
| 2521 | 1.8.7.6.5.1 | **ESME ID** |  | 90d | 2024-08-16 A | 2024-12-20 A |  | 100% |  | 2024-08-16 | 2024-12-20 | 90d |  |  |  |  |  | -0 | N/A | N/A | Transition | 5.4 | N/A | Migration |  |  |  |  |  |  |  |
| 2522 | 1.8.7.6.5.1.1 | DCC to extract ESME ID and share with LDSO | milestone | 0d | 2024-08-16 A | 2024-08-16 A | 2518FS+282d | 100% |  | 2024-08-16 | 2024-08-16 | 0d |  |  |  |  |  |  | DCC/SI |  | Transition | 5.5 | Matthew Breen | Migration | Complete | COMPLETE | T3-MI-0024 | MCAG (Transition) | T3 |  |  |
| 2523 | 1.8.7.6.5.1.2 | LDSO ‘full refresh’ between their Registration Service and the EES (ESME ID) |  | 16d | 2024-10-21 A | 2024-11-11 A | 2522FS+45d | 100% |  | 2024-10-21 | 2024-11-11 | 0d |  |  |  |  |  |  | LDSO/EES |  | Transition | 5.5 | Matthew Breen | Migration | Complete | COMPLETE | T3-MI-0025 | MCAG (Transition) | T3 |  |  |
| 2524 | 1.8.7.6.5.1.3 | Suppliers complete investigation of exceptions and resolution of exceptions |  | 1d | 2024-12-20 A | 2024-12-20 A | 2523FS+28d | 100% |  | 2024-12-20 | 2024-12-20 | 1d |  |  |  |  |  |  | Supplier |  | Transition | 5.4 | Matthew Breen | Migration | Complete | COMPLETE |  |  |  |  |  |
| 2525 | 1.8.7.6.5.1.4 | ESME ID Complete | milestone | 0d | 2024-12-20 A | 2024-12-20 A | 2524 | 100% |  | 2024-12-20 | 2024-12-20 | 0d |  |  |  |  |  |  |  |  | Transition | 5.4 | Matthew Breen | Migration | Complete | COMPLETE |  |  |  |  |  |
| 2526 | 1.8.7.6.5.2 | **Meter Location and Number of Displayed Register Digits** |  | 96d | 2024-09-13 A | 2025-01-24 |  | 96% | 4.17d | 2024-09-13 | 2025-01-31 | 91d |  |  | 759d |  |  |  | N/A | N/A | Transition | 5.4 | N/A | Migration |  |  |  |  |  |  |  |
| 2527 | 1.8.7.6.5.2.1 | MEM to extract data and share with LDSO |  | 6d | 2024-09-13 A | 2024-09-20 A | 2518FS+301d | 100% |  | 2024-09-13 | 2024-09-20 | 1d |  |  |  |  |  |  | MEM/SI |  | Transition | 5.4 | Matthew Breen | Migration | Complete | COMPLETE |  |  |  |  |  |
| 2528 | 1.8.7.6.5.2.2 | LDSO ‘full refresh’ between their Registration Service and the EES (Meter Location and Number of Displayed Register Digits) |  | 16d | 2024-10-21 A | 2024-11-15 A | 2527FS+25d | 100% |  | 2024-10-28 | 2024-11-18 | 0d |  |  |  |  |  |  | LDSO /EES |  | Transition | 5.5 | Matthew Breen | Migration | Complete | COMPLETE | T3-MI-0026 | MCAG (Transition) | T3 |  |  |
| 2529 | 1.8.7.6.5.2.3 | Suppliers complete investigation of exceptions and resolution of exceptions |  | 1d | 2025-01-24 | 2025-01-24 | 2528FS+49d |  |  | 2025-01-31 | 2025-01-31 | 1d |  |  | 759d | 0d |  |  | Supplier |  | Transition | 5.4 | Matthew Breen | Migration | Green | GREEN |  |  |  | -4.67 |  |
| 2530 | 1.8.7.6.5.2.4 | Meter Location and Number of Displayed Register Digits Complete | milestone | 0d | 2025-01-24 | 2025-01-24 | 2529 |  |  | 2025-01-31 | 2025-01-31 | 0d |  |  | 759d |  |  |  |  |  | Transition | 5.4 | Matthew Breen | Migration | Green | GREEN |  |  |  | -4.29 |  |
| 2531 | 1.8.7.6.6 | **Registration Data** |  | 289d | 2024-09-06 A | 2025-10-15 |  | 81% | 55.05d | 2024-09-06 | 2025-09-03 | 147d |  |  | 571d |  |  |  | N/A | N/A | Transition | 5.4 | N/A | Migration |  |  |  |  |  |  |  |
| 2532 | 1.8.7.6.6.1 | **Connection Type** |  | 47d | 2024-09-06 A | 2024-11-11 A |  | 100% |  | 2024-09-06 | 2024-11-11 | 16d |  |  |  |  |  |  | N/A | N/A | Transition | 5.4 | N/A | Migration |  |  |  |  |  |  |  |
| 2533 | 1.8.7.6.6.1.1 | Automated Population of Connection Type for Measurement Classes ‘B’, ‘D’, ‘F’ & ‘G’ | milestone | 0d | 2024-10-04 A | 2024-10-04 A | 2518FS+317d | 100% |  | 2024-10-04 | 2024-10-04 | 0d |  |  |  |  | start no earlier than 2024-09-13 |  | LDSO |  | Transition | 5.5 | Matthew Breen | Migration | Complete | COMPLETE | T3-MI-0027 | MCAG (Transition) | T3 |  |  |
| 2534 | 1.8.7.6.6.1.2 | BAU Population of Connection Type for Site Specific LLFCs within Measurement Classes ‘C’ & ‘E’ | milestone | 0d | 2024-10-04 A | 2024-10-04 A | 2518FS+317d | 100% |  | 2024-10-04 | 2024-10-04 | 0d |  |  |  |  |  |  | LDSO |  | Transition | 5.5 | Matthew Breen | Migration | Complete | COMPLETE | T3-MI-0028 | MCAG (Transition) | T3 |  |  |
| 2535 | 1.8.7.6.6.1.3 | Automated Population of Connection Type for Smart Meters within Measurement Class ‘A’ | milestone | 0d | 2024-10-04 A | 2024-10-04 A | 2518FS+317d | 100% |  | 2024-10-04 | 2024-10-04 | 0d |  |  |  |  |  |  | LDSO |  | Transition | 5.5 | Matthew Breen | Migration | Complete | COMPLETE | T3-MI-0029 | MCAG (Transition) | T3 |  |  |
| 2536 | 1.8.7.6.6.1.4 | Population of Connection Type for Traditional and Advanced Meters within Measurement Class ‘A’ |  | 1d | 2024-09-06 A | 2024-09-06 A | 2518FS+296d | 100% |  | 2024-09-06 | 2024-09-06 | 1d |  |  |  |  |  |  | Suppliers |  | Transition | 5.4 | Matthew Breen | Migration | Complete | COMPLETE |  |  |  |  |  |
| 2537 | 1.8.7.6.6.1.5 | Automated Population of Null Connection Type | milestone | 0d | 2024-10-04 A | 2024-10-04 A | 2518FS+317d | 100% |  | 2024-10-04 | 2024-10-04 | 0d |  |  |  |  |  |  | LDSO |  | Transition | 5.5 | Matthew Breen | Migration | Complete | COMPLETE | T3-MI-0030 | MCAG (Transition) | T3 |  |  |
| 2538 | 1.8.7.6.6.1.6 | Full MPAN refresh to ESS |  | 16d | 2024-10-21 A | 2024-11-11 A | 2518FS+327d | 100% |  | 2024-10-21 | 2024-11-11 | 1d |  |  |  |  |  |  | LDSO/EES |  | Transition | 5.4 | Matthew Breen | Migration | Complete | COMPLETE |  |  |  |  | Actually takes place on 29/9/24 which is a Sunday |
| 2539 | 1.8.7.6.6.1.7 | Connection Type Complete | milestone | 0d | 2024-11-11 A | 2024-11-11 A | 2533, 2534, 2535, 2536, 2537, 2538 | 100% |  | 2024-11-11 | 2024-11-11 | 0d |  |  |  |  |  |  |  |  | Transition | 5.4 | Matthew Breen | Migration | Complete | COMPLETE |  |  |  |  |  |

Notes:
- 2525: Action: 2/8/24: is date right as different to baseline? Why was it 23rd?

| ID | WBS | Task | Type | Duration | Start | Finish | Predecessors | Complete | Remaining | Baseline start | Baseline finish | Baseline duration | Baseline 1 start | Baseline 1 finish | Total slack | Free slack | Constraint | Baseline cost | Responsible | Involved | Text9 | Update Version | MHHS Resource Name | MHHS Programme Phase | Guidance | Task Status | Sched Status | RAG | Milestone ID | Text29 | Tier |
| --- | --- | --- | --- | --- | --- | --- | --- | --- | --- | --- | --- | --- | --- | --- | --- | --- | --- | --- | --- | --- | --- | --- | --- | --- | --- | --- | --- | --- | --- | --- | --- |
| 2540 | 1.8.7.6.6.2 | **Domestic Premises Indicator** |  | 19d | 2025-09-19 | 2025-10-15 |  |  |  | 2025-08-08 | 2025-09-03 | 17d |  |  | 571d |  |  |  | N/A | N/A | Transition | 5.4 | N/A | Migration |  |  |  |  |  |  |  |
| 2541 | 1.8.7.6.6.2.1 | The DCC to extract Domestic Premises Indicator from the CSS and provide a file to each LDSO and EES. |  | 2d | 2025-09-19 | 2025-09-22 | 1756FS-4d |  |  | 2025-09-19 | 2025-09-22 | 1d |  |  | 571d | 0d | start no earlier than 2025-08-08 |  | DCC |  | Transition | 5.4 | Matthew Breen | Migration | 27/7 - needs to end on date of M10 7/3/25 | 233.33 | Green | GREEN |  |  |  |
| 2542 | 1.8.7.6.6.2.2 | Each LDSO notifies the DCC of any exceptions |  | 1d | 2025-09-23 | 2025-09-23 | 2541 |  |  | 2025-09-23 | 2025-09-23 | 1d |  |  | 571d | 0d |  |  | LDSO |  | Transition | 5.4 | Matthew Breen | Migration | 27/7 - needs to end on date of M10 7/3/25 | 237.33 | Green | GREEN |  |  |  |
| 2543 | 1.8.7.6.6.2.3 | Each LDSO and DCC completes investigation and resolution of exceptions |  | 1d | 2025-10-15 | 2025-10-15 | 2541FS+15d, 2542FS+15d |  |  | 2025-10-15 | 2025-10-15 | 1d |  |  | 571d | 0d |  |  | LDSO / DCC |  | Transition | 5.4 | Matthew Breen | Migration | 27/7 Needs to take place approx. 1 month after M10 | 259.33 | Green | GREEN |  |  |  |
| 2544 | 1.8.7.6.6.2.4 | Domestic Premises Indicator Complete | milestone | 0d | 2025-10-15 | 2025-10-15 | 2543 |  |  | 2025-10-15 | 2025-10-15 | 0d |  |  | 571d |  |  |  |  |  | Transition | 5.4 | Matthew Breen | Migration |  | 259.71 | Green | GREEN |  |  |  |
| 2545 | 1.8.7.6.7 | **Export / Import MPANs** |  | 151d | 2024-03-22 A | 2024-10-18 A |  | 100% |  | 2024-03-22 | 2024-10-18 | 151d |  |  |  |  |  |  | N/A | N/A | Transition | 5.4 | N/A | Migration |  |  |  |  |  |  |  |
| 2546 | 1.8.7.6.7.1 | **Linking of Export / Import MPANS** |  | 151d | 2024-03-22 A | 2024-10-18 A |  | 100% |  | 2024-03-22 | 2024-10-18 | 151d |  |  |  |  |  |  | N/A | N/A | Transition | 5.4 | N/A | Migration |  |  |  |  |  |  |  |
| 2547 | 1.8.7.6.7.1.1 | LDSO utilises BAU processing (DB05s) to populate each import/export association |  | 1d | 2024-03-22 A | 2024-03-22 A | 2518FS+176d | 100% |  | 2024-03-22 | 2024-03-22 | 1d |  |  |  |  |  |  | LDSO |  | Transition | 5.4 | Matthew Breen | Migration |  |  | Complete | COMPLETE |  |  |  |
| 2548 | 1.8.7.6.7.1.2 | Each LDSO notifies the Registered Supplier of any exceptions |  | 1d | 2024-04-19 A | 2024-04-19 A | 2547FS+19d | 100% |  | 2024-04-19 | 2024-04-19 | 1d |  |  |  |  |  |  | LDSO |  | Transition | 5.4 | Matthew Breen | Migration |  |  | Complete | COMPLETE |  |  |  |
| 2549 | 1.8.7.6.7.1.3 | Each Supplier completes investigation and resolution of exceptions |  | 1d | 2024-08-23 A | 2024-08-23 A | 2548FS+89d | 100% |  | 2024-08-23 | 2024-08-23 | 1d |  |  |  |  |  |  | Supplier |  | Transition | 5.4 | Matthew Breen | Migration |  |  | Complete | COMPLETE |  |  |  |
| 2550 | 1.8.7.6.7.1.4 | Each LDSO has linked al relevant import/export MPANS | milestone | 0d | 2024-10-18 A | 2024-10-18 A | 2549FS+40d | 100% |  | 2024-10-18 | 2024-10-18 | 0d |  |  |  |  |  |  | LDSO |  | Transition | 5.5 | Matthew Breen | Migration |  |  | Complete | COMPLETE | T3-MI-0031 | MCAG (Transition) | T3 |
| 2551 | 1.8.7.6.7.1.5 | Linking of Export / Import MPANS Complete | milestone | 0d | 2024-10-18 A | 2024-10-18 A | 2550 | 100% |  | 2024-10-18 | 2024-10-18 | 0d |  |  |  |  |  |  |  |  | Transition | 5.4 | Matthew Breen | Migration |  |  | Complete | COMPLETE |  |  |  |
| 2552 | 1.8.7.6.8 | Pre-migration data cleanse complete | milestone | 0d | 2025-08-13 | 2025-08-13 |  |  |  | 2025-08-13 | 2025-08-13 | 0d | 2025-04-04 | 2025-04-04 | 617d |  | start no earlier than 2025-08-13 |  | SI Migration | PP | Transition | 5.0 | Matthew Breen | Migration |  | 196.33 | Green | GREEN | T2-MI-0450 | MCAG (Transition) | T2 |
| 2553 | 1.8.8 | **Migration Period Planning** |  | 367d | 2023-07-03 A | 2024-11-26 |  | 83% | 61.71d | 2023-07-03 | 2024-11-26 | 851d | 2023-07-03 | 2026-10-05 | 678d |  |  | -0 | N/A | N/A | Transition | 5.0 | N/A | Migration |  | M10 |  |  |  |  |  |
| 2554 | 1.8.8.1 | **Migration Implementation Plan (incl. Migration Exit Criteria)** |  | 367d | 2023-07-03 A | 2024-11-26 |  | 83% | 61.71d | 2023-07-03 | 2024-11-26 | 851d | 2023-07-03 | 2026-10-05 | 678d |  |  | -0 | N/A | N/A | Transition | 5.0 | N/A | Migration |  |  |  |  |  |  |  |
| 2555 | 1.8.8.1.1 | **Migration Threshold Volumes** |  | 101d | 2023-07-03 A | 2023-11-20 A |  | 100% |  | 2023-07-03 | 2023-11-20 | 98d | 2023-07-03 | 2023-08-31 |  |  |  | -0 | N/A | N/A | Transition | 5.0 | N/A | Migration |  |  |  |  |  |  |  |
| 2556 | 1.8.8.1.1.1 | Threshold volumes reviewed by MWG |  | 54d | 2023-07-03 A | 2023-09-14 A |  | 100% |  | 2023-07-03 | 2023-09-14 | 54d | 2023-07-03 | 2023-07-28 |  |  |  |  | SI Migration | PP | Transition | 5.6 | John Wiggins,Matthew Breen | Migration |  |  | Complete | COMPLETE |  |  |  |
| 2557 | 1.8.8.1.1.2 | Artefact review (via TMAG) and updates |  | 47d | 2023-09-15 A | 2023-11-20 A | 2556 | 100% |  | 2023-09-15 | 2023-11-20 | 44d | 2023-07-31 | 2023-08-31 |  |  |  |  | PP | SI Migration | Transition | 5.9 | John Wiggins,Matthew Breen | Migration |  |  | Complete | COMPLETE |  |  |  |
| 2558 | 1.8.8.1.1.3 | Threshold volumes approved at TMAG | milestone | 0d | 2023-11-20 A | 2023-11-20 A | 2557 | 100% |  | 2023-11-20 | 2023-11-20 | 0d | 2023-08-31 | 2023-08-31 |  |  |  |  | SI Migration | PP | Transition | 5.12 | John Wiggins,Matthew Breen | Migration |  |  | Complete | COMPLETE | T3-MI-0021 | SITAG | T3 |
| 2559 | 1.8.8.1.2 | **Define acceptance criteria for M15** |  | 78d | 2023-09-04 A | 2023-12-20 A |  | 100% |  | 2023-09-04 | 2023-12-20 | 78d | 2023-09-04 | 2023-11-30 |  |  |  | -0 | N/A | N/A | Transition | 5.0 | N/A | Migration |  |  |  |  |  |  |  |
| 2560 | 1.8.8.1.2.1 | Review acceptance criteria and reporting requirements with MWG |  | 49d | 2023-09-04 A | 2023-11-09 A |  | 100% |  | 2023-09-04 | 2023-11-09 | 40d | 2023-09-04 | 2023-10-27 |  |  | start no earlier than 2023-09-04 |  | SI Migration |  | Transition | 5.0 | John Wiggins,Matthew Breen | Migration |  |  | Complete | COMPLETE |  |  |  |
| 2561 | 1.8.8.1.2.2 | Artefact review (via TMAG) and updates |  | 29d | 2023-11-10 A | 2023-12-20 A | 2560 | 100% |  | 2023-11-10 | 2023-12-20 | 29d | 2023-10-30 | 2023-11-30 |  |  | start no earlier than 2023-10-30 |  | PP | SI Migration | Transition | 5.0 | John Wiggins,Matthew Breen | Migration |  |  | Complete | COMPLETE |  |  |  |
| 2562 | 1.8.8.1.2.3 | Acceptance criteria for M15 agreed at TMAG | milestone | 0d | 2023-12-20 A | 2023-12-20 A | 2561 | 100% |  | 2023-12-20 | 2023-12-20 | 0d | 2023-11-30 | 2023-11-30 |  |  | finish no earlier than 2023-11-30 |  | SI Migration |  | Transition | 5.14 | John Wiggins,Matthew Breen | Migration |  |  | Complete | COMPLETE | T3-MI-0022 | SITAG | T3 |
| 2563 | 1.8.8.1.3 | **M10/M11 cut-over plan** |  | 119d | 2023-12-21 A | 2024-06-04 A |  | 100% |  | 2023-12-21 | 2024-06-04 | 119d | 2024-01-01 | 2024-05-31 |  |  |  | -0 | N/A | N/A | Transition | 5.16 | N/A | Migration |  |  |  |  |  |  |  |
| 2564 | 1.8.8.1.3.1 | Draft Document |  | 84d | 2023-12-21 A | 2024-04-16 A | 2562 | 100% |  | 2023-12-21 | 2024-04-16 | 84d |  |  |  |  |  |  | SI Transition | SI Transition,PP,SRO | Transition | 5.16 | Matthew Breen | Migration |  |  | Complete | COMPLETE |  |  |  |
| 2565 | 1.8.8.1.3.2 | Share Document with SRO |  | 1d | 2024-04-17 A | 2024-04-17 A | 2564 | 100% |  | 2024-04-17 | 2024-04-17 | 1d |  |  |  |  |  |  | SI Transition | SI Transition,PP,SRO | Transition | 5.16 | Matthew Breen | Migration |  |  | Complete | COMPLETE |  |  |  |
| 2566 | 1.8.8.1.3.3 | Industry Consultation |  | 11d | 2024-04-23 A | 2024-05-07 A | 2565FS+3d | 100% |  | 2024-04-23 | 2024-05-07 | 11d |  |  |  |  |  |  | SI Transition | SI Transition,PP,SRO | Transition | 5.16 | Matthew Breen | Migration |  |  | Complete | COMPLETE |  |  |  |
| 2567 | 1.8.8.1.3.4 | Assurance Meeting |  | 1d | 2024-05-21 A | 2024-05-21 A | 2566FS+9d | 100% |  | 2024-05-21 | 2024-05-21 | 1d |  |  |  |  |  |  | SI Transition | SI Transition,PP,SRO | Transition | 5.16 | Matthew Breen | Migration |  |  | Complete | COMPLETE |  |  |  |
| 2568 | 1.8.8.1.3.5 | MCAG Approval of M10/M11 Cut-over Plan | milestone | 0d | 2024-06-04 A | 2024-06-04 A | 2567FS+10d | 100% |  | 2024-06-04 | 2024-06-04 | 0d | 2024-05-31 | 2024-05-31 |  |  |  |  | SI Transition | SI Transition,PP,SRO | Transition | 5.26 | Matthew Breen | Migration |  |  | Complete | COMPLETE | T3-MI-0023 | MCAG | T3 |

| ID | WBS | Task | Type | Duration | Start | Finish | Predecessors | Complete | Remaining | Baseline start | Baseline finish | Baseline duration | Baseline 1 start | Baseline 1 finish | Total slack | Free slack | Constraint | Baseline cost | Responsible | Involved | Text9 | Update Version | MHHS Resource Name | MHHS Programme Phase | Sched Status | RAG | Task Status | Milestone ID | Text29 | Tier | Action |
| --- | --- | --- | --- | --- | --- | --- | --- | --- | --- | --- | --- | --- | --- | --- | --- | --- | --- | --- | --- | --- | --- | --- | --- | --- | --- | --- | --- | --- | --- | --- | --- |
| 2569 | 1.8.8.1.4 | **M16 Methodology** |  | 85d | 2024-07-31 A | 2024-11-26 |  | 10% | 76.9d | 2024-07-31 | 2024-11-26 | 85d | 2023-10-02 | 2024-04-26 | 678d |  |  | -0 | N/A | N/A | Transition | 5.0 | N/A | Migration |  |  |  |  |  |  |  |
| 2570 | 1.8.8.1.4.1 | Draft Document |  | 50d | 2024-07-31 A | 2024-10-08 |  | 12% | 44d | 2024-07-31 | 2024-10-08 | 50d | 2023-10-02 | 2023-12-29 | 678d | 0d |  |  | SI Transition | SI Transition,PP,SRO | Transition | 5.26 | Matthew Breen | Migration | Overdue | RED |  |  |  |  |  |
| 2571 | 1.8.8.1.4.2 | Share Document with SRO |  | 1d | 2024-10-09 | 2024-10-09 | 2570 |  |  | 2024-10-09 | 2024-10-09 | 1d | 2024-01-01 | 2024-01-26 | 678d | 0d |  |  | SI Transition | SI Transition,PP,SRO | Transition | 5.26 | Matthew Breen | Migration | Overdue Start | RED | -111.67 |  |  |  |  |
| 2572 | 1.8.8.1.4.3 | Industry Consultation |  | 11d | 2024-10-15 | 2024-10-29 | 2571FS+3d |  |  | 2024-10-15 | 2024-10-29 | 11d | 2024-01-29 | 2024-03-29 | 678d | 0d |  |  | SI Transition | SI Transition,PP,SRO | Transition | 5.26 | Matthew Breen | Migration | Overdue Start | RED | -105.67 |  |  |  |  |
| 2573 | 1.8.8.1.4.4 | Assurance Meeting |  | 1d | 2024-11-12 | 2024-11-12 | 2572FS+9d |  |  | 2024-11-12 | 2024-11-12 | 1d | 2024-04-01 | 2024-04-26 | 678d | 0d |  |  | SI Transition | SI Transition,PP,SRO | Transition | 5.26 | Matthew Breen | Migration | Green | RED | -77.67 |  |  |  |  |
| 2574 | 1.8.8.1.4.5 | M16 methodology approved | milestone | 0d | 2024-11-26 | 2024-11-26 | 2573FS+10d |  |  | 2024-11-26 | 2024-11-26 | 0d | 2024-04-26 | 2024-04-26 | 678d |  |  |  | SI Transition | SI Transition,PP,SRO | Transition | 5.26 | Matthew Breen | Migration | Green | RED | -63.29 | T3-MI-0500 | MCAG (Transition) | T2 |  |
| 2575 | 1.8.9 | **Preparation for Cutover to Live** |  | 341d | 2024-06-28 A | 2025-10-17 |  |  | 341d | 2024-06-28 | 2025-10-22 | 201d | 2025-02-07 | 2025-04-04 | 569d |  |  | -0 | N/A | N/A | Transition | 6.11 | N/A | Migration |  |  |  |  |  |  |  |
| 2576 | 1.8.9.1 | **Central Systems Prepare for Cutover to Live** |  | 326d | 2024-06-28 A | 2025-09-26 |  |  | 326d | 2024-06-28 | 2025-09-26 | 186d | 2025-02-07 | 2025-03-07 | 584d |  |  | -0 | N/A | N/A | Transition | 6.11 | N/A | Migration |  |  | M13 |  |  |  |  |
| 2577 | 1.8.9.1.1 | DCC (Functionality available June 2024) | milestone | 0d | 2024-06-28 A | 2024-06-28 A |  | 100% |  | 2024-06-28 | 2024-06-28 | 0d |  |  |  |  | start no earlier than 2024-06-28 |  | DCC |  | Transition | 6.11 | Matthew Breen |  | Complete | COMPLETE |  |  |  |  |  |
| 2578 | 1.8.9.1.2 | **Development of Comms Approach and Declaration Guidance** |  | 79d | 2025-04-28 | 2025-08-14 |  |  |  | 2025-03-03 | 2025-06-19 | 79d |  |  | 29d |  |  |  | N/A | N/A | Transition | 6.11 | N/A |  |  |  | 95.33 |  |  |  |  |
| 2579 | 1.8.9.1.2.1 | Draft Cutover Comms Approach |  | 59d | 2025-04-28 | 2025-07-17 |  |  |  | 2025-04-28 | 2025-07-17 | 59d |  |  | 29d | 0d | start no earlier than 2025-04-28 |  | SI Transition | SI Transition | Transition | 6.11 | Matthew Breen |  | Green | GREEN | 89.33 |  |  |  |  |
| 2580 | 1.8.9.1.2.2 | Draft Cutover Comms Approach shared | milestone | 0d | 2025-07-17 | 2025-07-17 | 2579 |  |  | 2025-07-17 | 2025-07-17 | 0d |  |  | 29d | 0d |  |  | SI Transition | SI Transition | Transition | 6.11 | Matthew Breen |  | Green | GREEN | 169.71 |  |  |  |  |
| 2581 | 1.8.9.1.2.3 | Development of Implementation Group |  | 59d | 2025-04-28 | 2025-07-17 |  |  |  | 2025-04-28 | 2025-07-17 | 59d |  |  | 29d | 0d | start no earlier than 2025-04-28 |  | SI Transition | SI Transition | Transition | 6.11 | Matthew Breen |  | Green | GREEN | 89.33 |  |  |  |  |
| 2582 | 1.8.9.1.2.4 | Implementation Group Established | milestone | 0d | 2025-07-17 | 2025-07-17 | 2581 |  |  | 2025-07-17 | 2025-07-17 | 0d |  |  | 29d | 0d |  |  | SI Transition | SI Transition | Transition | 6.11 | Matthew Breen |  | Green | GREEN | 169.71 |  |  |  |  |
| 2583 | 1.8.9.1.2.5 | Finalised Cutover Comms Approach shared | milestone | 0d | 2025-08-14 | 2025-08-14 | 2580FS+20d, 2582FS+20d |  |  | 2025-08-14 | 2025-08-14 | 0d |  |  | 29d |  |  |  | SI Transition | SI Transition | Transition | 6.11 | Matthew Breen |  | Green | GREEN | 197.71 |  |  |  |  |
| 2584 | 1.8.9.1.3 | **Development of Cutover Plan requirements with Participants** |  | 94d | 2025-04-28 | 2025-09-04 |  |  |  | 2025-03-03 | 2025-08-06 | 59d |  |  | 14d |  |  |  | N/A | N/A | Transition | 6.11 | N/A |  |  |  | -605.67 |  |  |  |  |
| 2585 | 1.8.9.1.3.1 | Development of SIT Participant Cutover Plans |  | 59d | 2025-04-28 | 2025-07-17 |  |  |  | 2025-04-28 | 2025-07-17 | 59d |  |  | 14d | 0d | start no earlier than 2025-04-28 |  | SI Transition | SI Transition | Transition | 6.11 | Matthew Breen |  | Green | GREEN | 89.33 |  |  |  |  |
| 2586 | 1.8.9.1.3.2 | SIT Participant Cutover Plans Ready | milestone | 0d | 2025-07-17 | 2025-07-17 | 2585 |  |  | 2025-07-17 | 2025-07-17 | 0d |  |  | 14d | 0d |  |  | SI Transition | SI Transition | Transition | 6.11 | Matthew Breen |  | Green | GREEN | 169.71 |  |  |  |  |
| 2587 | 1.8.9.1.3.3 | Programme SIT Participant Cutover Plan Assurance |  | 35d | 2025-07-18 | 2025-09-04 | 2586 |  |  | 2025-07-18 | 2025-09-17 | 44d |  |  | 14d |  |  |  | SI Transition | SI Transition | Transition | 6.11 | Matthew Breen |  | Green | GREEN | 170.33 |  |  |  |  |
| 2588 | 1.8.9.1.4 | **M10/M11 Cutover Activities** |  | 15d | 2025-09-05 | 2025-09-26 |  |  |  | 2025-04-14 | 2025-09-26 | 15d |  |  | 7d |  |  | -0 |  |  | Transition | 6.11 |  |  |  |  | -608.67 |  |  |  |  |
| 2589 | 1.8.9.1.4.1 | Production DIP Portal (DIP Deployment) | milestone | 0d | 2025-09-05 | 2025-09-05 | 1645FS+10d |  |  | 2025-09-05 | 2025-09-05 | 0d |  |  | 7d |  |  |  | Elexon,DIP Manager | Elexon,DIP Manager, SI Transition | Transition | 6.11 | Matthew Breen |  | Green | GREEN | 219.71 |  |  |  |  |
| 2590 | 1.8.9.1.4.2 | Production Certificates (DIP Deployment) | milestone | 0d | 2025-09-05 | 2025-09-05 | 1645FS+10d |  |  | 2025-09-05 | 2025-09-05 | 0d |  |  | 7d |  |  |  | Elexon,DIP Manager | Elexon,DIP Manager, SI Transition | Transition | 6.11 | Matthew Breen |  | Green | GREEN | 219.71 |  |  |  |  |
| 2591 | 1.8.9.1.4.3 | Completion of the pre-M10 MHHS Data Cleanse | milestone | 0d | 2025-09-24 | 2025-09-24 | 1756 |  |  | 2025-09-24 | 2025-09-24 | 0d |  |  | 586d |  |  |  | PP,DCC,SI Transition | PP,DCC,SI Transition | Transition | 6.11 | Matthew Breen |  | Green | GREEN | 238.71 |  |  |  |  |
| 2592 | 1.8.9.1.4.4 | Market-wide Participant MHHS Supporting Functionality Ready - Confirmation from Code Bodies | milestone | 0d | 2025-09-15 | 2025-09-15 | 1756FS-8d |  |  | 2025-09-15 | 2025-09-15 | 0d |  |  | 594d |  |  |  | Code Bodies | Code Bodies,SI Transition | Transition | 6.11 | Matthew Breen |  | Green | GREEN | 229.33 |  |  |  |  |
| 2593 | 1.8.9.1.4.5 | Market-wide Participant MHHS Supporting Functionality Ready | milestone | 0d | 2025-09-22 | 2025-09-22 | 1756FS-3d |  |  | 2025-09-22 | 2025-09-22 | 0d |  |  | 589d |  |  |  | PP | PP,SI Transition | Transition | 6.11 | Matthew Breen |  | Green | GREEN | 236.33 |  |  |  |  |
| 2594 | 1.8.9.1.4.6 | Elexon Central Services Deployment | milestone | 0d | 2025-09-19 | 2025-09-19 | 2616 |  |  | 2025-09-19 | 2025-09-19 | 0d |  |  | 0d |  |  |  | DIP Manager,Elexon | DIP Manager,Elexon,SI Transition | Transition | 6.11 | Matthew Breen |  | Green | GREEN | 233.71 |  |  |  |  |
| 2595 | 1.8.9.1.4.7 | Service Management Go-Live | milestone | 0d | 2025-09-19 | 2025-09-19 | 2616 |  |  | 2025-09-19 | 2025-09-19 | 0d |  |  | 0d |  |  |  | Elexon | Elexon,SI Transition | Transition | 6.11 | Matthew Breen |  | Green | GREEN | 233.71 |  |  |  |  |
| 2596 | 1.8.9.1.4.8 | Data Transfer Service (DTS) New Functionality Deployment | milestone | 0d | 2025-09-19 | 2025-09-19 | 2616 |  |  | 2025-09-19 | 2025-09-19 | 0d |  |  | 0d |  |  |  | Code Bodies,Electralink | Code Bodies,SI Transition | Transition | 6.11 | Matthew Breen |  | Green | GREEN | 233.71 |  |  |  |  |
| 2597 | 1.8.9.1.4.9 | Electricity Enquiry Service (EES) Deployment | milestone | 0d | 2025-09-19 | 2025-09-19 | 2616 |  |  | 2025-09-19 | 2025-09-19 | 0d |  |  | 0d |  |  |  | Code Bodies | Code Bodies,SI Transition | Transition | 6.11 | Matthew Breen |  | Green | GREEN | 233.71 |  |  |  |  |
| 2598 | 1.8.9.1.4.10 | MPRS, UMSO Role, LDSO Role Operational | milestone | 0d | 2025-09-19 | 2025-09-19 | 2616 |  |  | 2025-09-19 | 2025-09-19 | 0d |  |  | 0d |  |  |  | PP | SI Transition,PP | Transition | 6.11 | Matthew Breen |  | Green | GREEN | 233.71 |  |  |  |  |
| 2599 | 1.8.9.1.4.11 | Population of Domestic Premises Indicator | milestone | 0d | 2025-09-19 | 2025-09-19 | 2616 |  |  | 2025-09-19 | 2025-09-19 | 0d |  |  | 0d |  |  |  | PP,DCC,SI Transition | PP,DCC,SI Transition | Transition | 6.11 | Matthew Breen |  | Green | GREEN | 233.71 |  |  |  |  |
| 2600 | 1.8.9.1.4.12 | Population of Market Segment | milestone | 0d | 2025-09-19 | 2025-09-19 | 2616 |  |  | 2025-09-19 | 2025-09-19 | 0d |  |  | 0d |  |  |  | PP,SI Transition | PP,SI Transition | Transition | 6.11 | Matthew Breen |  | Green | GREEN | 233.71 |  |  |  |  |
| 2601 | 1.8.9.1.4.13 | Early Life Support Implemented | milestone | 0d | 2025-09-19 | 2025-09-19 | 2616 |  |  | 2025-09-19 | 2025-09-19 | 0d |  |  | 3d |  |  |  | SI Transition,Elexon,Central Services | SI Transition,Elexon,Central Services | Transition | 6.11 | Matthew Breen |  | Green | GREEN | 233.71 |  |  |  |  |
| 2602 | 1.8.9.1.4.14 | MCC Tested and Ready to Operate | milestone | 0d | 2025-09-19 | 2025-09-19 |  |  |  | 2025-09-19 | 2025-09-19 | 0d |  |  | 590d | 0d | start no earlier than 2025-09-19 |  | SI Migration | SI Migration | Transition | 6.11 | Matthew Breen |  | Green | GREEN | 233.33 |  |  |  | 1/7: To link into migration/service activation |
| 2603 | 1.8.9.1.4.15 | MCC Operational | milestone | 0d | 2025-09-19 | 2025-09-19 | 2602 |  |  | 2025-09-19 | 2025-09-19 | 0d |  |  | 590d |  |  |  | SI Migration | SI Migration | Transition | 6.11 | Matthew Breen |  | Green | GREEN | 233.33 |  |  |  | 1/7: To link into migration/service activation |
| 2604 | 1.8.4.1.4 | Central Systems live and Codes designated at 00:00 | milestone | 0d | 2025-09-22 | 2025-09-22 | 2594FS+1d, 2595FS+1d, 2596FS+1d, 2597FS+1d, 2598FS+1d, 2599FS+1d, 2600FS+1d, 2577FS+1d |  |  | 2025-09-22 | 2025-09-22 | 0d |  |  | 0d |  |  |  | SI Transition | SI Transition | Transition | 6.11 | Matthew Breen |  | Green | GREEN | 236.71 | T3-MI-0034 | MCAG (Transition) | T3 |  |
| 2605 | 1.8.9.1.4.17 | SIT Participant Qualification - The final date by which participant qualification status can be confirmed for participants to be ready for the start of Migration at M11. | milestone | 0d | 2025-09-26 | 2025-09-26 | 1645FS+25d |  |  | 2025-09-26 | 2025-09-26 | 0d |  |  | 14d | 11d |  |  | PP,Code Bodies,BSC PAB | SI Transition,PP,Code Bodies,BSC PAB | Transition | 6.11 | Matthew Breen |  | Green | GREEN | 240.71 |  |  |  |  |

Notes:
- 2570: 21/01/25 - Production of this artefact has been delayed. M16 decision making process to be reviewed in Jan 2025 following CR055.
- 2571: 21/01/25 - Production of this artefact has been delayed. M16 decision making process to be reviewed in Jan 2025 following CR055.
- 2572: 21/01/25 - Production of this artefact has been delayed. M16 decision making process to be reviewed in Jan 2025 following CR055.
- 2573: 21/01/25 - Production of this artefact has been delayed. M16 decision making process to be reviewed in Jan 2025 following CR055.
- 2574: 21/01/25 - Production of this artefact has been delayed. M16 decision making process to be reviewed in Jan 2025 following CR055.
- 2604: Guidance: 25/7/24: New Milestone approved at MCAG on 25/7/24. It was initially approved at MCAG on 4/6 but didn't follow the usual process so addded to July MCAG for noting

| ID | WBS | Task | Type | Duration | Start | Finish | Predecessors | Baseline start | Baseline finish | Baseline duration | Total slack | Free slack | Constraint | Responsible | Involved | Text9 | Task Status | Update Version | MHHS Resource Name | Sched Status | RAG | Milestone ID | Text29 | Tier |
| --- | --- | --- | --- | --- | --- | --- | --- | --- | --- | --- | --- | --- | --- | --- | --- | --- | --- | --- | --- | --- | --- | --- | --- | --- |
| 2606 | 1.8.9.2 | **Cutover Governance M10** |  | 11d | 2025-09-10 | 2025-09-24 |  | 2025-07-30 | 2025-09-24 | 27d | 3d |  |  | N/A | N/A | Transition | -595.67 | 6.11 | N/A |  |  |  |  |  |
| 2607 | 1.8.9.2.1 | Confirmation that Pre-migration Data Cleanse Activities have successfully taken place | milestone | 0d | 2025-09-10 | 2025-09-10 |  | 2025-09-10 | 2025-09-10 | 0d | 5d |  | start no earlier than 2025-09-10 | PP | SI Transition,PP | Transition | 224.33 | 6.11 | Matthew Breen | Green | GREEN |  |  |  |
| 2608 | 1.8.9.2.2 | Confirmation of Helix E2E Settlement Testing Complete | milestone | 0d | 2025-09-15 | 2025-09-15 |  | 2025-09-15 | 2025-09-15 | 0d | 2d |  | start no earlier than 2025-09-15 |  |  | Transition | 229.33 | 6.11 |  | Green | GREEN |  |  |  |
| 2609 | 1.8.9.2.3 | Confirmation of assurance of Helix E2E Settlement Testing | milestone | 0d | 2025-09-15 | 2025-09-15 |  | 2025-09-15 | 2025-09-15 | 0d | 2d |  | start no earlier than 2025-09-15 |  |  | Transition | 229.33 | 6.11 |  | Green | GREEN |  |  |  |
| 2610 | 1.8.9.2.4 | Confirmation of Qualification Status for SIT MVC | milestone | 0d | 2025-09-15 | 2025-09-15 |  | 2025-09-15 | 2025-09-15 | 0d | 2d |  | start no earlier than 2025-09-15 | SIT MVC,Code Bodies | SI Transition,SIT MVC,Code Bodies | Transition | 229.33 | 6.11 | Matthew Breen | Green | GREEN |  |  |  |
| 2611 | 1.8.9.2.5 | Confirmation of Qualification Status for Non-SIT LDSOs | milestone | 0d | 2025-09-15 | 2025-09-15 |  | 2025-09-15 | 2025-09-15 | 0d | 2d |  | start no earlier than 2025-09-15 | PP,Code Bodies | SI Transition,PP,Code Bodies | Transition | 229.33 | 6.11 | Matthew Breen | Green | GREEN |  |  |  |
| 2612 | 1.8.9.2.6 | Confirmation of Qualification Status of at least one Supplier and their contracted Agents | milestone | 0d | 2025-09-15 | 2025-09-15 |  | 2025-09-15 | 2025-09-15 | 0d | 2d |  | start no earlier than 2025-09-15 | S&A Qualification | SI Transition,S&A Qualification | Transition | 229.33 | 6.11 | Matthew Breen | Green | GREEN |  |  |  |
| 2613 | 1.8.9.2.7 | Declaration from all Central Services and LDSOs that they are in a position to move forwards | milestone | 0d | 2025-09-15 | 2025-09-15 |  | 2025-09-15 | 2025-09-15 | 0d | 3d |  | start no earlier than 2025-09-15 | DIP Manager,Elexon,PP,Code Bodies | SI Transition,DIP Manager,Elexon,PP,Code Bodies | Transition | 229.33 | 6.11 | Matthew Breen | Green | GREEN |  |  |  |
| 2614 | 1.8.9.2.8 | Market-wide Participant MHHS Migration Supporting Functionality is Live | milestone | 0d | 2025-09-15 | 2025-09-15 |  | 2025-09-15 | 2025-09-15 | 0d | 3d |  | start no earlier than 2025-09-15 |  |  | Transition | 229.33 | 6.11 |  | Green | GREEN |  |  |  |
| 2615 | 1.8.9.2.9 | TORWG (Recommendation from TORWG that the Programme should enter M10) | milestone | 0d | 2025-09-17 | 2025-09-17 | 2607FS+1d, 2610FS+1d, 2612FS+1d, 2589FS+1d, 2590FS+1d, 2698FS+1d, 2608FS+1d, 2609FS+1d, 2611FS+1d, 2613, 2614 | 2025-09-17 | 2025-09-17 | 0d | 0d |  |  | SI Transition | SI Transition | Transition | 231.71 | 6.11 | Matthew Breen | Green | GREEN |  |  |  |
| 2616 | 1.8.4.1.4 | MCAG (Confirm that the Programme can Enter M10) | milestone | 0d | 2025-09-19 | 2025-09-19 | 2615FS+2d, 2704 | 2025-09-19 | 2025-09-19 | 0d | 0d |  |  | SI Migration | SI Transition,SI Migration | Transition | 233.71 | 6.11 | Matthew Breen | Green | GREEN | T3-MI-0035 | MCAG (Transition) | T3 |
| 2617 | 1.8.9.2.11 | Self-Declaration from all Central Services and LDSOs that Cutover activities have been successfully carried out | milestone | 0d | 2025-09-22 | 2025-09-22 | 2616FS+1d | 2025-09-22 | 2025-09-22 | 0d | 3d | 0d |  | PP,DCC,Code Bodies | SI Transition,PP,DCC,Code Bodies | Transition | 236.71 | 6.11 | Matthew Breen | Green | GREEN |  |  |  |
| 2618 | 1.8.9.2.12 | Confirmation that DIP and ECS have been deployed, Service management is active, ISD has been populated | milestone | 0d | 2025-09-22 | 2025-09-22 | 2616FS+1d | 2025-09-22 | 2025-09-22 | 0d | 3d | 0d |  | Elexon,DIP Manager | SI Transition,Elexon,DIP Manager | Transition | 236.71 | 6.11 | Matthew Breen | Green | GREEN |  |  |  |
| 2619 | 1.8.9.2.13 | Self-Declarations against all M10 Data Cleanse Activities | milestone | 0d | 2025-09-22 | 2025-09-22 | 2616FS+1d | 2025-09-22 | 2025-09-22 | 0d | 3d | 0d |  | PP | SI Transition,PP | Transition | 236.71 | 6.11 | Matthew Breen | Green | GREEN |  |  |  |
| 2620 | 1.8.9.2.14 | IF-047 has been sent | milestone | 0d | 2025-09-22 | 2025-09-22 | 2616FS+1d | 2025-09-22 | 2025-09-22 | 0d | 3d | 0d |  | ECS | SI Transition,ECS | Transition | 236.71 | 6.11 | Matthew Breen | Green | GREEN |  |  |  |
| 2621 | 1.8.9.2.15 | Recommendation from TORWG that PSG should approve M10 | milestone | 0d | 2025-09-23 | 2025-09-23 | 2617FS+1d, 2618FS+1d, 2619FS+1d, 2620FS+1d, 2702 | 2025-09-23 | 2025-09-23 | 0d | 3d | 0d |  | SI Transition | SI Transition | Transition | 237.71 | 6.11 | Matthew Breen | Green | GREEN |  |  |  |
| 2622 | 1.8.9.2.16 | PSG (OFGEM and PSG to Approve That Conditions of M10 and M13 Have Been Met) | milestone | 0d | 2025-09-24 | 2025-09-24 | 2621FS+1d | 2025-09-24 | 2025-09-24 | 0d | 3d | 0d |  | SI Transition,Ofgem | SI Transition,Ofgem | Transition | 238.71 | 6.11 | Matthew Breen | Green | GREEN |  |  |  |
| 2623 | 1.8.9.3 | **Cutover Governance M11** |  | 16d | 2025-09-26 | 2025-10-17 |  | 2025-09-26 | 2025-10-22 | 0d | 3d |  |  |  |  | Transition | -687.67 | 6.11 |  |  |  |  |  |  |
| 2624 | 1.8.9.3.1 | Confirmation of Qualified Parties from Code Bodies |  | 11d | 2025-09-26 | 2025-10-10 | 2622FS+1d | 2025-09-26 | 2025-10-10 | 11d | 3d | 0d |  | Code Bodies,SIT Participants | SI Transition,Code Bodies,SIT Participants | Transition | 240.33 | 6.11 | Matthew Breen | Green | GREEN |  |  |  |
| 2625 | 1.8.9.3.2 | Self-Declaration that MHHS Functionality will be deployed to Production by Qualified parties | milestone | 0d | 2025-10-10 | 2025-10-10 | 2622FS+12d | 2025-10-10 | 2025-10-10 | 0d | 3d | 0d |  | PP | SI Transition,PP | Transition | 254.71 | 6.11 | Matthew Breen | Green | GREEN |  |  |  |
| 2626 | 1.8.9.3.3 | Production Service Activation Activities have taken place | milestone | 0d | 2025-10-10 | 2025-10-10 | 2622FS+12d | 2025-10-10 | 2025-10-10 | 0d | 3d | 0d |  | PP | SI Transition,PP | Transition | 254.71 | 6.11 | Matthew Breen | Green | GREEN |  |  |  |
| 2627 | 1.8.9.3.4 | TORWG (Confirmation of Qualified Parties from TORWG) | milestone | 0d | 2025-10-13 | 2025-10-13 | 2624FS+1d, 2625FS+1d, 2626FS+1d, 2605, 2699, 2703 | 2025-10-13 | 2025-10-13 | 0d | 3d | 0d |  | SI Transition | SI Transition | Transition | 257.71 | 6.11 | Matthew Breen | Green | GREEN |  |  |  |
| 2628 | 1.8.9.3.5 | MCAG (Provide recommendation to PSG on M11 decision) | milestone | 0d | 2025-10-15 | 2025-10-15 | 2627FS+2d | 2025-10-15 | 2025-10-15 | 0d | 3d | 0d |  | SI Migration | SI Transition,SI Migration | Transition | 259.71 | 6.11 | Matthew Breen | Green | GREEN | T3-MI-0036 | MCAG (Transition) | T3 |
| 2629 | 1.8.9.3.6 | PSG (OFGEM and PSG Decision to Confirm M11 and M12) | milestone | 0d | 2025-10-17 | 2025-10-17 | 2628FS+2d | 2025-10-17 | 2025-10-17 | 0d | 3d |  |  | SI Transition | SI Transition | Transition | 261.71 | 6.11 | Matthew Breen | Green | GREEN |  |  |  |

Notes:
- 2616: Guidance: 25/7/24: New Milestone approved at MCAG on 25/7/24. It was initially approved at MCAG on 4/6 but didn't follow the usual process so addded to July MCAG for noting
- 2626: Guidance: 12/8/24: Think this is covered in Service activation prep section below
- 2628: Guidance: 25/7/24: New Milestone approved at MCAG on 25/7/24. It was initially approved at MCAG on 4/6 but didn't follow the usual process so addded to July MCAG for noting

| ID | WBS | Task | Type | Duration | Start | Finish | Predecessors | Complete | Remaining | Baseline start | Baseline finish | Baseline duration | Baseline 1 start | Baseline 1 finish | Total slack | Free slack | Constraint | Baseline cost | Responsible | Involved | Text9 | Task Status | Update Version | MHHS Resource Name | Sched Status | RAG | MHHS Programme Phase |
| --- | --- | --- | --- | --- | --- | --- | --- | --- | --- | --- | --- | --- | --- | --- | --- | --- | --- | --- | --- | --- | --- | --- | --- | --- | --- | --- | --- |
| 2630 | 1.8.10 | **UMS / Advanced Migration** |  | 402d | 2025-10-23 | 2027-05-07 |  |  |  | 2025-10-23 | 2027-05-07 | 391d |  |  | 0d |  |  | -0 | N/A | N/A | Transition | -555.67 | 6.17 | N/A |  |  |  |
| 2631 | 1.8.10.1 | SIT MVC UMS / Advanced Migration |  | 402d | 2025-10-23 | 2027-05-07 | 2704, 2660 |  |  | 2025-10-23 | 2027-05-07 | 391d |  |  | 0d |  |  |  |  |  | Transition | 267.33 | 6.17 |  | Green | GREEN |  |
| 2632 | 1.8.10.2 | SIT Non-MVC UMS / Advanced Migration |  | 355d | 2025-12-29 | 2027-05-07 | 2727 |  |  | 2025-12-29 | 2027-05-07 | 326d |  |  | 0d |  |  |  |  |  | Transition | 334.33 | 6.17 |  | Green | GREEN |  |
| 2633 | 1.8.10.3 | Wave 1 UMS / Advanced Migration |  | 256d | 2026-05-15 | 2027-05-07 | 2743 |  |  | 2026-05-15 | 2027-05-07 | 261d |  |  | 0d |  |  |  |  |  | Transition | 471.33 | 6.17 |  | Green | GREEN |  |
| 2634 | 1.8.10.4 | Wave 2 UMS / Advanced Migration |  | 223d | 2026-07-01 | 2027-05-07 | 2767FS-1d |  |  | 2026-07-01 | 2027-05-07 | 216d |  |  | 0d |  |  |  |  |  | Transition | 518.33 | 6.17 |  | Green | GREEN |  |
| 2635 | 1.8.10.5 | Wave 3 UMS / Advanced Migration |  | 191d | 2026-08-14 | 2027-05-07 | 2791 |  |  | 2026-08-14 | 2027-05-07 | 181d |  |  | 0d |  |  |  |  |  | Transition | 562.33 | 6.17 |  | Green | GREEN |  |
| 2636 | 1.8.10.6 | Wave 4 UMS / Advanced Migration |  | 141d | 2026-10-23 | 2027-05-07 | 2815FS-4d |  |  | 2026-10-23 | 2027-05-07 | 131d |  |  | 0d |  |  |  |  |  | Transition | 632.33 | 6.17 |  | Green | GREEN |  |
| 2637 | 1.8.11 | **Smart / Non-Smart Migration** |  | 402d | 2025-10-23 | 2027-05-07 |  |  |  | 2025-10-23 | 2027-05-07 | 391d |  |  | 0d |  |  | -0 | N/A | N/A | Transition | -555.67 | 6.17 | N/A |  |  |  |
| 2638 | 1.8.11.1 | SIT MVC Smart / Non-Smart Migration |  | 402d | 2025-10-23 | 2027-05-07 | 2704, 2660 |  |  | 2025-10-23 | 2027-05-07 | 391d |  |  | 0d |  |  |  |  |  | Transition | 267.33 | 6.17 |  | Green | GREEN |  |
| 2639 | 1.8.11.2 | SIT Non-MVC Smart / Non-Smart Migration |  | 355d | 2025-12-29 | 2027-05-07 | 2727 |  |  | 2025-12-29 | 2027-05-07 | 326d |  |  | 0d |  |  |  |  |  | Transition | 334.33 | 6.17 |  | Green | GREEN |  |
| 2640 | 1.8.11.3 | Wave 1 Smart / Non-Smart Migration |  | 256d | 2026-05-15 | 2027-05-07 | 2743 |  |  | 2026-05-15 | 2027-05-07 | 261d |  |  | 0d |  | start no earlier than 2025-10-03 |  |  |  | Transition | 471.33 | 6.17 |  | Green | GREEN |  |
| 2641 | 1.8.11.4 | Wave 2 Smart / Non-Smart Migration |  | 223d | 2026-07-01 | 2027-05-07 | 2767FS-1d |  |  | 2026-07-01 | 2027-05-07 | 216d |  |  | 0d |  |  |  |  |  | Transition | 518.33 | 6.17 |  | Green | GREEN |  |
| 2642 | 1.8.11.5 | Wave 3 Smart / Non-Smart Migration |  | 191d | 2026-08-14 | 2027-05-07 | 2791 |  |  | 2026-08-14 | 2027-05-07 | 181d |  |  | 0d |  |  |  |  |  | Transition | 562.33 | 6.17 |  | Green | GREEN |  |
| 2643 | 1.8.11.6 | Wave 4 Smart / Non-Smart Migration |  | 141d | 2026-10-23 | 2027-05-07 | 2815FS-4d |  |  | 2026-10-23 | 2027-05-07 | 131d |  |  | 0d |  |  |  |  |  | Transition | 632.33 | 6.17 |  | Green | GREEN |  |
| 2644 | 1.8.12 | **External Programme Dependency Management** |  | 740d | 2022-10-31 A | 2025-08-29 |  | 66% | 253.44d | 2022-10-31 | 2025-08-29 | 827d | 2022-10-31 | 2025-07-01 | 604d |  |  | -0 | N/A | N/A | Transition |  | 5.0 | N/A |  |  | Migration |
| 2645 | 1.8.12.1 | **BSC Mod P432 & REC CP R0015** |  | 392d | 2022-10-31 A | 2024-04-30 A |  | 100% |  | 2022-10-31 | 2024-04-30 | 827d | 2022-10-31 | 2025-07-01 |  |  |  | -0 | N/A | N/A | Transition |  | 5.0 | N/A |  |  | Migration |
| 2646 | 1.8.12.1.1 | MHHSP engagement with BSCCo until Ofgem decision |  | 316d | 2022-10-31 A | 2024-01-15 A |  | 100% |  | 2022-10-31 | 2024-01-15 | 400d | 2022-10-31 | 2022-12-30 |  |  |  |  | CPT,SRO Function | Code Bodies | Transition |  | 5.0 | MHHS Programme | Complete | COMPLETE | Migration |
| 2647 | 1.8.12.1.2 | Monitor progress and await implementation date |  | 76d | 2024-01-16 A | 2024-04-30 A | 2646 | 100% |  | 2024-01-16 | 2024-04-30 | 652d | 2023-01-02 | 2025-07-01 |  |  |  |  | CPT,SRO Function | Code Bodies | Transition |  | 5.0 | MHHS Programme | Complete | COMPLETE | Migration |
| 2648 | 1.8.12.2 | **BSC Mod P434** |  | 713d | 2022-10-31 A | 2025-07-23 |  | 57% | 310d | 2022-10-31 | 2025-07-23 | 713d | 2022-10-31 | 2025-07-01 | 631d |  |  |  | N/A | N/A | Transition |  | 5.0 | N/A |  |  | Migration |
| 2649 | 1.8.12.2.1 | MHHSP engagement with BSCCo until Ofgem decision |  | 61d | 2022-10-31 A | 2023-01-23 A |  | 100% |  | 2022-10-31 | 2023-01-23 | 61d | 2022-10-31 | 2022-12-30 |  |  |  |  | CPT,SRO Function | Code Bodies | Transition |  | 5.0 | MHHS Programme | Complete | COMPLETE | Migration |
| 2650 | 1.8.12.2.2 | Monitor progress and await implementation date |  | 652d | 2023-01-24 A | 2025-07-23 | 2649 | 52% | 310d | 2023-01-24 | 2025-07-23 | 652d | 2023-01-02 | 2025-07-01 | 631d |  |  |  | CPT,SRO Function | Code Bodies | Transition |  | 5.0 | MHHS Programme | Green | GREEN | Migration |
| 2651 | 1.8.12.3 | **Elexon System Capacity Upgrade** |  | 697d | 2022-10-31 A | 2025-07-01 |  | 58% | 294d | 2022-10-31 | 2025-07-01 | 697d | 2022-10-31 | 2025-07-01 | 647d |  |  |  | N/A | N/A | Transition |  | 5.0 | N/A |  |  | Migration |
| 2652 | 1.8.12.3.1 | Monitor progress to implementation |  | 697d | 2022-10-31 A | 2025-07-01 |  | 58% | 294d | 2022-10-31 | 2025-07-01 | 697d | 2022-10-31 | 2025-07-01 | 647d | 0d |  |  | SI Migration | PP | Transition |  | 5.0 | MHHS Programme | Green | GREEN | Migration |
| 2653 | 1.8.12.3.2 | Implementation date | milestone | 0d | 2025-07-01 | 2025-07-01 | 2652 |  |  | 2025-07-01 | 2025-07-01 | 0d | 2025-07-01 | 2025-07-01 | 647d |  |  |  | PP | SI Migration | Transition | 153.71 | 5.0 | MHHS Programme | Green | GREEN | Migration |

Notes:
- 2631: 29/01/25 - Migration end dates corrected to align with M15.
- 2632: 29/01/25 - Migration end dates corrected to align with M15.
- 2633: 29/01/25 - Migration end dates corrected to align with M15. / Guidance: 12/8/24: Made start no earlier, because shorter service actiobal was allowing this to start earlier than the date that had been set
- 2634: 29/01/25 - Migration end dates corrected to align with M15.
- 2635: 29/01/25 - Migration end dates corrected to align with M15.
- 2636: 29/01/25 - Migration end dates corrected to align with M15.
- 2637: 29/01/25 - Migration end dates corrected to align with M15.
- 2638: 29/01/25 - Migration end dates corrected to align with M15.
- 2639: 29/01/25 - Migration end dates corrected to align with M15.
- 2640: 29/01/25 - Migration end dates corrected to align with M15. / Guidance: 12/8/24: Made start no earlier, because shorter service actiobal was allowing this to start earlier than the date that had been set
- 2641: 29/01/25 - Migration end dates corrected to align with M15.
- 2642: 29/01/25 - Migration end dates corrected to align with M15.
- 2643: 29/01/25 - Migration end dates corrected to align with M15.

| ID | WBS | Task | Type | Duration | Start | Finish | Predecessors | Complete | Remaining | Baseline start | Baseline finish | Baseline duration | Baseline 1 start | Baseline 1 finish | Total slack | Free slack | Constraint | Baseline cost | Responsible | Involved | Text9 | Update Version | MHHS Resource Name | MHHS Programme Phase | Task Status | Sched Status | RAG | Milestone ID | Text29 | Tier | Future RAG |
| --- | --- | --- | --- | --- | --- | --- | --- | --- | --- | --- | --- | --- | --- | --- | --- | --- | --- | --- | --- | --- | --- | --- | --- | --- | --- | --- | --- | --- | --- | --- | --- |
| 2654 | 1.8.12.4 | **DCC System Capacity Upgrade** |  | 25d | 2025-07-28 | 2025-08-29 |  |  |  | 2025-07-28 | 2025-08-29 | 25d | 2025-01-13 | 2025-02-14 | 604d |  |  |  | N/A | N/A | Transition | 5.0 | N/A | Migration |  |  |  |  |  |  |  |
| 2655 | 1.8.12.4.1 | Assurance of DCC capacity upgrade to ensure suitability to support migration |  | 20d | 2025-07-28 | 2025-08-22 | 1756FF-23d |  |  | 2025-07-28 | 2025-08-22 | 20d | 2025-01-13 | 2025-02-07 | 604d | 0d |  |  | SI Migration | PP | Transition | 5.0 | MHHS Programme | Migration | 180.33 | Green | GREEN |  |  |  |  |
| 2656 | 1.8.12.4.2 | DCC Capacity Upgrade Operational | milestone | 0d | 2025-08-29 | 2025-08-29 | 2655FS+5d |  |  | 2025-08-29 | 2025-08-29 | 0d | 2025-02-14 | 2025-02-14 | 604d |  |  |  | PP | SI Migration,IPA | Transition | 5.0 | MHHS Programme | Migration | 212.71 | Green | GREEN | T2-MI-0350 | MCAG | T2 |  |
| 2657 | 1.8.13 | **Migration - Tier 1 Milestones** |  | 488d | 2025-09-24 | 2027-08-09 |  |  |  | 2025-09-24 | 2027-08-09 | 477d | 2025-03-07 | 2027-01-05 | 20d |  |  |  | N/A | N/A | Transition | 5.0 | N/A | Migration |  |  |  |  |  |  |  |
| 2658 | 1.8.13.1 | Load Shaping Service switched on (M13) | milestone | 0d | 2025-09-24 | 2025-09-24 | 1756 |  |  | 2025-09-24 | 2025-09-24 | 0d | 2025-03-07 | 2025-03-07 | 20d | 0d |  |  | CPT | CPT | Transition | 6.1 | CPT | Migration | 238.71 | Green | GREEN | T1-MI-2000 | PSG | T1 | Load Shaping Service switched on |
| 2659 | 1.8.13.2 | Load Shaping Service switched on (M13*) - Late Exit | milestone | 0d | 2025-12-24 | 2025-12-24 | 2658FS+65d |  |  | 2025-12-24 | 2025-12-24 | 0d | 2025-06-06 | 2025-06-06 | 521d |  |  |  | CPT | CPT | Transition | 6.1 | CPT | Migration | 329.71 | Green | GREEN | T2-MI-2500 | PSG | T1 | Load Shaping Service switched on |
| 2660 | 1.8.13.3 | Start of 18-month migration for UMS / Advanced (M11) | milestone | 0d | 2025-10-22 | 2025-10-22 | 2658, 2628, 2629, 2704, 1756FS+20d |  |  | 2025-10-22 | 2025-10-22 | 0d | 2025-04-04 | 2025-04-04 | 0d |  |  |  | CPT | CPT | Transition | 6.1 | CPT | Migration | 266.71 | Green | GREEN | T1-MI-3000 | PSG | T1 | Start of 1 year migration for UMS / Advanced |
| 2661 | 1.8.13.4 | Start of 18-month migration for UMS / Advanced (M11*) - Late Exit | milestone | 0d | 2026-01-21 | 2026-01-21 | 2660FS+65d |  |  | 2026-01-21 | 2026-01-21 | 0d | 2025-07-04 | 2025-07-04 | 501d |  |  |  | CPT | CPT | Transition | 6.1 | CPT | Migration | 357.71 | Green | GREEN | T2-MI-3500 | PSG | T1 | Start of 1 year migration for UMS / Advanced |
| 2662 | 1.8.13.5 | Start of 18-month migration for Smart / Non-smart (M12) | milestone | 0d | 2025-10-22 | 2025-10-22 | 2658, 1756FS+20d |  |  | 2025-10-22 | 2025-10-22 | 0d | 2025-04-04 | 2025-04-04 | 501d | 0d |  |  | CPT | CPT | Transition | 6.1 | CPT | Migration | 266.71 | Green | GREEN | T1-MI-4000 | PSG | T1 | Start of 1 year migration for Smart / Non-smart |
| 2663 | 1.8.13.6 | Start of 18-month migration for Smart / Non-smart (M12*) - Late Exit | milestone | 0d | 2026-01-21 | 2026-01-21 | 2662FS+65d |  |  | 2026-01-21 | 2026-01-21 | 0d | 2025-07-04 | 2025-07-04 | 501d |  |  |  | CPT | CPT | Transition | 6.1 | CPT | Migration | 357.71 | Green | GREEN | T2-MI-4500 | PSG | T1 | Start of 1 year migration for Smart / Non-smart |
| 2664 | 1.8.13.7 | Full transition complete (M15) | milestone | 0d | 2027-05-07 | 2027-05-07 | 2631, 2632, 2633, 2634, 2635, 2636, 2638, 2639, 2640, 2641, 2642, 2643 |  |  | 2027-05-07 | 2027-05-07 | 0d | 2026-10-05 | 2026-10-05 | 0d |  |  |  | CPT | CPT | Transition | 6.1 | CPT | Migration | 828.71 | Green | GREEN | T1-MI-6000 | PSG | T1 | Full transition complete |
| 2665 | 1.8.13.8 | Full transition complete (M15*) - Late Exit | milestone | 0d | 2027-08-09 | 2027-08-09 | 2664FS+66d |  |  | 2027-08-09 | 2027-08-09 | 0d | 2027-01-05 | 2027-01-05 | 98d |  |  |  | CPT | CPT | Transition | 6.1 | CPT | Migration | 922.71 | Green | GREEN | T2-MI-6500 | PSG | T1 | Full transition complete |
| 2666 | 1.9 | **BUSINESS & OPERATIONAL READINESS** |  | 1344d? | 2022-10-31 A | 2027-12-23 |  | 6% | 1268.57d? | 2022-10-31 | 2027-12-23 | 964d | 2023-03-01 | 2026-12-07 | 0d |  |  | -0 | N/A | N/A | Business & Operation Readiness |  | N/A | Business & Operational Readiness |  |  |  |  |  |  |  |
| 2667 | 1.9.1 | **Service Management** |  | 983d | 2023-09-19 A | 2027-06-24 |  | 26% | 728.35d | 2023-09-19 | 2027-06-24 | 840d | 2023-03-01 | 2026-12-07 | 130d |  |  | -0 | N/A | N/A | Business & Operation Readiness | 5.0 | N/A | Business & Operational Readiness |  |  |  |  |  |  |  |
| 2668 | 1.9.1.1 | **Service Management Strategy** |  | 116d | 2023-09-19 A | 2024-02-27 A |  | 100% |  | 2023-09-19 | 2024-02-27 | 116d | 2023-03-01 | 2023-05-31 |  |  |  | -0 | N/A | N/A | Business & Operation Readiness | 5.0 | N/A | Business & Operational Readiness |  |  |  |  |  |  |  |
| 2669 | 1.9.1.1.1 | Develop document with relevant participants (incl. review of the design baseline to ensure service management arrangements are in place across the solution architecture) |  | 84d | 2023-09-19 A | 2024-01-12 A |  | 100% |  | 2023-09-19 | 2024-01-12 | 84d | 2023-03-01 | 2023-04-28 |  |  | start no earlier than 2023-09-19 |  | SI Design |  | Business & Operation Readiness | 5.0 | Matthew Breen | Business & Operational Readiness |  | Complete | COMPLETE |  |  |  |  |
| 2670 | 1.9.1.1.2 | Artefact review (via relevant Advisory Group) and updates |  | 31d | 2024-01-15 A | 2024-02-26 A | 2669 | 100% |  | 2024-01-15 | 2024-02-26 | 31d | 2023-05-01 | 2023-05-24 |  |  |  |  | PP | SI Design,IPA | Business & Operation Readiness | 5.0 | Matthew Breen | Business & Operational Readiness |  | Complete | COMPLETE |  |  |  |  |
| 2671 | 1.9.1.1.3 | Service Management Strategy approved | milestone | 0d | 2024-02-27 A | 2024-02-27 A | 2670FS+1d | 100% |  | 2024-02-27 | 2024-02-27 | 0d | 2023-05-31 | 2023-05-31 |  |  |  |  | SI Design | PP | Business & Operation Readiness | 5.16 | Matthew Breen | Business & Operational Readiness |  | Complete | COMPLETE | T3-BC-0010 | MCAG | T3 |  |
| 2672 | 1.9.1.2 | **Early Life Support Model** |  | 110d | 2024-02-28 A | 2024-07-30 |  | 82% | 20.23d | 2024-02-28 | 2024-07-30 | 110d |  |  | 887d |  |  | -0 | N/A | N/A | Business & Operation Readiness | 5.16 | Matthew Breen | Business & Operational Readiness | -441.67 |  |  |  |  |  |  |
| 2673 | 1.9.1.2.1 | Draft Document |  | 74d | 2024-02-28 A | 2024-06-10 | 2671 | 96% | 3d | 2024-02-28 | 2024-06-10 | 74d |  |  | 887d | 0d |  |  | SI Transition | SI Transition,PP,SRO | Business & Operation Readiness | 5.24 | Matthew Breen | Business & Operational Readiness |  | Overdue | RED |  |  |  |  |
| 2674 | 1.9.1.2.2 | Share document with SRO |  | 1d | 2024-06-11 | 2024-06-11 | 2673 |  |  | 2024-06-11 | 2024-06-11 | 1d |  |  | 887d | 0d |  |  | SI Transition | SI Transition,PP,SRO | Business & Operation Readiness | 5.24 | Matthew Breen | Business & Operational Readiness | -231.67 | Overdue Start | RED |  |  |  |  |
| 2675 | 1.9.1.2.3 | Industry Consultation |  | 11d | 2024-06-18 | 2024-07-02 | 2674FS+4d |  |  | 2024-06-18 | 2024-07-02 | 11d |  |  | 887d | 0d |  |  | SI Transition | SI Transition,PP,SRO | Business & Operation Readiness | 5.24 | Matthew Breen | Business & Operational Readiness | -224.67 | Overdue Start | RED |  |  |  |  |
| 2676 | 1.9.1.2.4 | Assurance Meeting |  | 1d | 2024-07-16 | 2024-07-16 | 2675FS+9d |  |  | 2024-07-16 | 2024-07-16 | 1d |  |  | 887d | 0d |  |  | SI Transition | SI Transition,PP,SRO | Business & Operation Readiness | 5.24 | Matthew Breen | Business & Operational Readiness | -196.67 | Overdue Start | RED |  |  |  |  |
| 2677 | 1.9.1.2.5 | MCAG Approval of Early Life Support Model | milestone | 0d | 2024-07-30 | 2024-07-30 | 2676FS+10d |  |  | 2024-07-30 | 2024-07-30 | 0d |  |  | 887d |  |  |  | SI Transition | PP,SRO,SI Transition | Business & Operation Readiness | 5.24 | Matthew Breen | Business & Operational Readiness | -182.29 | Overdue Start | RED | T3-MI-0033 | MCAG (Transition) | T3 |  |

Notes:
- 2673: 28/01/25 - Consultation expected to take place ahead of Feb TORWG (12/02/25). Once scheduled, plan to be updated.
- 2674: 28/01/25 - Consultation expected to take place ahead of Feb TORWG (12/02/25). Once scheduled, plan to be updated.
- 2675: 28/01/25 - Consultation expected to take place ahead of Feb TORWG (12/02/25). Once scheduled, plan to be updated.
- 2676: 28/01/25 - Consultation expected to take place ahead of Feb TORWG (12/02/25). Once scheduled, plan to be updated.
- 2677: 28/01/25 - Consultation expected to take place ahead of Feb TORWG (12/02/25). Once scheduled, plan to be updated.

| ID | WBS | Task | Type | Duration | Start | Finish | Predecessors | Baseline start | Baseline finish | Baseline duration | Baseline 1 start | Baseline 1 finish | Total slack | Free slack | Constraint | Baseline cost | Responsible | Involved | Text9 | Update Version | MHHS Resource Name | MHHS Programme Phase | Task Status | Sched Status | RAG |
| --- | --- | --- | --- | --- | --- | --- | --- | --- | --- | --- | --- | --- | --- | --- | --- | --- | --- | --- | --- | --- | --- | --- | --- | --- | --- |
| 2678 | 1.9.1.3 | **Service Management Arrangements Implementation** |  | 456d | 2025-09-25 | 2027-06-24 |  | 2025-09-25 | 2027-06-24 | 453d | 2025-03-10 | 2026-12-07 | 130d |  |  | -0 | N/A | N/A | Business & Operation Readiness | 5.0 | N/A | Business & Operational Readiness |  |  |  |
| 2679 | 1.9.1.3.1 | Hypercare post M10 |  | 80d | 2025-09-25 | 2026-01-14 | 1756 | 2025-09-25 | 2026-01-14 | 80d | 2025-03-10 | 2025-06-27 | 506d |  |  |  | SI Design | PP | Business & Operation Readiness | 5.0 | Claire Silk | Business & Operational Readiness | 239.33 | Green | GREEN |
| 2680 | 1.9.1.3.2 | Monitor Elexon implementation of Service Management arrangements |  | 436d | 2025-10-23 | 2027-06-24 | 2631SS, 2638SS | 2025-10-23 | 2027-06-24 | 436d | 2025-04-07 | 2026-12-07 | 130d |  |  |  | PP | SI Design | Business & Operation Readiness | 5.0 | Claire Silk | Business & Operational Readiness | 267.33 | Green | GREEN |
| 2681 | 1.9.2 | **Service Activation** |  | 1043d? | 2022-10-31 | 2026-10-28 |  | 2022-10-31 | 2026-10-22 | 289d |  |  | 301d |  |  | -0 | N/A | N/A | Business & Operation Readiness | 5.24 | N/A |  | -555.67 |  |  |
| 2682 | 1.9.2.1 | **SIT MVC** |  | 770d? | 2022-10-31 | 2025-10-10 |  | 2025-02-03 | 2025-09-22 | 0d |  |  | 574d |  |  |  |  |  | Business & Operation Readiness | 5.31 |  |  | -650.67 | Overdue Start | RED |
| 2683 | 1.9.2.1.1 | **SIT MVC Service Activation Preparation Tasks** |  | 20d | 2025-02-03 | 2025-02-28 |  | 2025-02-03 | 2025-02-28 | 0d |  |  | 159d |  |  |  |  |  | Business & Operation Readiness | 5.31 |  |  |  |  |  |
| 2684 | 1.9.2.1.1.1 | Identify operational resources |  | 5d | 2025-02-03 | 2025-02-07 |  | 2025-02-03 | 2025-02-07 | 0d |  |  | 749d |  | finish no earlier than 2025-02-07 |  |  |  | Business & Operation Readiness | 5.31 |  |  | 5.33 | Green | GREEN |
| 2685 | 1.9.2.1.1.2 | Define and approve operational support model |  | 5d | 2025-02-10 | 2025-02-14 |  | 2025-02-10 | 2025-02-14 | 0d |  |  | 744d |  | finish no earlier than 2025-02-14 |  |  |  | Business & Operation Readiness | 5.31 |  |  | 12.33 | Green | GREEN |
| 2686 | 1.9.2.1.1.3 | Confirm SA Training completed |  | 10d | 2025-02-10 | 2025-02-21 |  | 2025-02-10 | 2025-02-21 | 0d |  |  | 739d |  | finish no earlier than 2025-02-21 |  |  |  | Business & Operation Readiness | 5.31 |  |  | 12.33 | Green | GREEN |
| 2687 | 1.9.2.1.1.4 | Participant Engagement / Communications |  | 15d | 2025-02-10 | 2025-02-28 |  | 2025-02-10 | 2025-02-28 | 0d |  |  | 734d |  | finish no earlier than 2025-02-28 |  |  |  | Business & Operation Readiness | 5.31 |  |  | 12.33 | Green | GREEN |
| 2688 | 1.9.2.1.1.5 | Internal Communications |  | 15d | 2025-02-10 | 2025-02-28 |  | 2025-02-10 | 2025-02-28 | 0d |  |  | 734d |  | finish no earlier than 2025-02-28 |  |  |  | Business & Operation Readiness | 5.31 |  |  | 12.33 | Green | GREEN |
| 2689 | 1.9.2.1.1.6 | Validate User Access |  | 5d | 2025-02-17 | 2025-02-21 |  | 2025-02-17 | 2025-02-21 | 0d |  |  | 739d |  | finish no earlier than 2025-02-21 |  |  |  | Business & Operation Readiness | 5.31 |  |  | 19.33 | Green | GREEN |
| 2690 | 1.9.2.1.1.7 | Target Systems and Environments Ready |  | 3d | 2025-02-20 | 2025-02-24 |  | 2025-02-20 | 2025-02-24 | 0d |  |  | 738d |  | finish no earlier than 2025-02-24 |  | HELIX |  | Business & Operation Readiness | 5.31 |  |  | 22.33 | Green | GREEN |
| 2691 | 1.9.2.1.1.8 | Provide opeartional resources with LWIs |  | 5d | 2025-02-17 | 2025-02-21 |  | 2025-02-17 | 2025-02-21 | 0d |  |  | 739d |  | finish no earlier than 2025-02-21 |  |  |  | Business & Operation Readiness | 5.31 |  |  | 19.33 | Green | GREEN |
| 2692 | 1.9.2.1.1.9 | Business Readiness Governance Approval |  | 3d | 2025-02-17 | 2025-02-19 |  | 2025-02-17 | 2025-02-19 | 0d |  |  | 741d |  | finish no earlier than 2025-02-19 |  |  |  | Business & Operation Readiness | 5.31 |  |  | 19.33 | Green | GREEN |
| 2693 | 1.9.2.1.1.10 | SIT MVC Service Activation Preparation Tasks Complete | milestone | 0d | 2025-02-28 | 2025-02-28 |  | 2025-02-28 | 2025-02-28 | 0d |  |  | 139d | 0d | finish no earlier than 2025-02-28 |  |  |  | Business & Operation Readiness | 5.31 |  |  | 30.71 | Green | GREEN |
| 2694 | 1.9.2.1.2 | MHHSP Confirms SIT MVC PPs MHHS Enabled |  | 1d | 2022-10-31 | 2022-10-31 |  | 2025-04-15 | 2025-04-15 | 0d |  |  | 748d |  |  |  |  |  | Business & Operation Readiness | 5.28 |  |  | -820.67 | Overdue Start | GREEN |
| 2695 | 1.9.2.1.3 | **SIT MVC Service Activation Implementation** |  | 7d? | 2025-09-12 | 2025-09-22 |  | 2025-09-12 | 2025-09-22 | 0d |  |  | 0d |  |  |  |  |  | Business & Operation Readiness | 6.13 |  |  |  |  |  |
| 2696 | 1.9.2.1.3.1 | Add EFD to DIP |  | 1d | 2025-09-12 | 2025-09-12 | 1956SS, 2694, 2693 | 2025-09-12 | 2025-09-12 | 0d |  |  | 0d |  |  |  |  |  | Business & Operation Readiness | 6.13 |  |  | 226.33 | Green | GREEN |
| 2697 | 1.9.2.1.3.2 | DIP Promoted to Production |  | 1d? | 2025-09-15 | 2025-09-15 | 2696 | 2025-09-15 | 2025-09-15 | 0d |  |  | 0d |  |  |  |  |  | Business & Operation Readiness | 6.13 |  |  | 229.33 | Green | GREEN |
| 2698 | 1.9.2.1.3.3 | SIT LDSOs Create Certificates and Test Connectivity |  | 1d? | 2025-09-16 | 2025-09-16 | 2697 | 2025-09-16 | 2025-09-16 | 0d |  |  | 0d |  |  |  |  |  | Business & Operation Readiness | 6.13 |  |  | 230.33 | Green | GREEN |
| 2699 | 1.9.2.1.3.4 | SIT MVC S&As Create Certificates and Test Connectivity |  | 1d? | 2025-09-16 | 2025-09-16 | 2697 | 2025-09-16 | 2025-09-16 | 0d |  |  | 22d | 19d |  |  |  |  | Business & Operation Readiness | 6.13 |  |  | 230.33 | Green | GREEN |
| 2700 | 1.9.2.1.3.5 | Create M16 in Customer Solution |  | 2d | 2025-09-16 | 2025-09-17 | 2697 | 2025-09-16 | 2025-09-17 | 0d |  |  | 0d |  | finish no earlier than 2025-03-07 |  |  |  | Business & Operation Readiness | 6.13 |  |  | 230.33 | Green | GREEN |
| 2701 | 1.9.2.1.3.6 | Publish ISD |  | 2d | 2025-09-18 | 2025-09-19 | 2700 | 2025-09-18 | 2025-09-19 | 0d |  |  | 0d |  | finish no earlier than 2025-03-07 |  |  |  | Business & Operation Readiness | 6.13 |  |  | 232.33 | Green | GREEN |
| 2702 | 1.9.2.1.3.7 | SIT LDSOs to update systems with ISD |  | 1d? | 2025-09-22 | 2025-09-22 | 2701 | 2025-09-22 | 2025-09-22 | 0d |  |  | 4d | 1d |  |  |  |  | Business & Operation Readiness | 6.13 |  |  | 236.33 | Green | GREEN |
| 2703 | 1.9.2.1.3.8 | SIT MVC S&As to update systems with ISD |  | 1d? | 2025-09-22 | 2025-09-22 | 2701 | 2025-09-22 | 2025-09-22 | 0d |  |  | 18d | 15d |  |  |  |  | Business & Operation Readiness | 6.13 |  |  | 236.33 | Green | GREEN |
| 2704 | 1.9.2.1.3.9 | SIT MVC Service Activation Implementation Complete | milestone | 0d | 2025-09-19 | 2025-09-19 | 2701 | 2025-09-19 | 2025-09-19 | 0d |  |  | 0d |  | finish no earlier than 2025-03-07 |  |  |  | Business & Operation Readiness | 6.13 |  |  | 233.71 | Green | GREEN |

Notes:
- 2681: 29/01/25 - Programme working with Helix to update the Service Activation plan section of the Programme Plan.

| ID | WBS | Task | Type | Duration | Start | Finish | Predecessors | Baseline start | Baseline finish | Baseline duration | Total slack | Free slack | Constraint | Text9 | Update Version | Task Status | Sched Status | RAG | Involved |
| --- | --- | --- | --- | --- | --- | --- | --- | --- | --- | --- | --- | --- | --- | --- | --- | --- | --- | --- | --- |
| 2705 | 1.9.2.1.4 | **SIT MVC Service Activation Implementation MDD** |  | 15d | 2025-09-22 | 2025-10-10 |  | 2025-03-06 | 2025-03-25 | 0d | 574d |  |  | Business & Operation Readiness | 6.13 |  |  |  |  |
| 2706 | 1.9.2.1.4.1 | MDD Manual Load |  | 7d | 2025-09-22 | 2025-09-30 | 2701 | 2025-03-06 | 2025-03-14 | 0d | 574d | 0d | finish no earlier than 2025-03-14 | Business & Operation Readiness | 6.13 | 236.33 | Red | RED |  |
| 2707 | 1.9.2.1.4.2 | MDD Update |  | 8d | 2025-10-01 | 2025-10-10 | 2706 | 2025-03-14 | 2025-03-25 | 0d | 574d | 0d | finish no earlier than 2025-03-25 | Business & Operation Readiness | 6.13 | 245.33 | Red | RED |  |
| 2708 | 1.9.2.1.4.3 | SIT MVC Service Activation Implementation MDD Complete | milestone | 0d | 2025-10-10 | 2025-10-10 | 2707 | 2025-03-25 | 2025-03-25 | 0d | 574d |  | finish no earlier than 2025-03-25 | Business & Operation Readiness | 6.13 | 254.71 | Red | RED |  |
| 2709 | 1.9.2.1.5 | **SIT MVC Service Activation Hypercare** |  | 21d | 2025-09-12 | 2025-10-10 |  | 2025-03-03 | 2025-03-26 | 0d | 574d |  |  | Business & Operation Readiness | 6.13 |  |  |  |  |
| 2710 | 1.9.2.1.5.1 | Service & Process Monitoring |  | 18d | 2025-09-12 | 2025-10-07 | 2696SS | 2025-03-03 | 2025-03-26 | 0d | 577d |  | finish no earlier than 2025-03-26 | Business & Operation Readiness | 6.13 | 226.33 | Red | RED |  |
| 2711 | 1.9.2.1.5.2 | Daily Reporting |  | 18d | 2025-09-12 | 2025-10-07 | 2696SS | 2025-03-03 | 2025-03-26 | 0d | 577d |  | finish no earlier than 2025-03-26 | Business & Operation Readiness | 6.13 | 226.33 | Red | RED |  |
| 2712 | 1.9.2.1.5.3 | Issue Management |  | 18d | 2025-09-12 | 2025-10-07 | 2696SS | 2025-03-03 | 2025-03-26 | 0d | 577d |  | finish no earlier than 2025-03-26 | Business & Operation Readiness | 6.13 | 226.33 | Red | RED |  |
| 2713 | 1.9.2.1.5.4 | SA Hypercare Close Down Activities |  | 18d | 2025-09-12 | 2025-10-07 | 2696SS | 2025-03-03 | 2025-03-26 | 0d | 574d | 0d | finish no earlier than 2025-03-26 | Business & Operation Readiness | 6.13 | 226.33 | Red | RED |  |
| 2714 | 1.9.2.1.5.5 | Handover to MHHSP |  | 3d | 2025-10-08 | 2025-10-10 | 2713 | 2025-03-21 | 2025-03-25 | 0d | 574d | 0d | finish no earlier than 2025-03-25 | Business & Operation Readiness | 6.13 | 252.33 | Red | RED | MHHSP |
| 2715 | 1.9.2.1.5.6 | SIT MVC Service Activation Hypercare Complete | milestone | 0d | 2025-10-10 | 2025-10-10 | 2714 | 2025-03-25 | 2025-03-25 | 0d | 574d |  | finish no earlier than 2025-03-25 | Business & Operation Readiness | 6.13 | 254.71 | Red | RED |  |
| 2716 | 1.9.2.2 | **SIT Non-MVC** |  | 841d? | 2022-10-31 | 2026-01-19 |  | 2022-10-31 | 2026-01-01 | 0d | 503d |  |  | Business & Operation Readiness | 6.13 | -650.67 | Overdue Start | RED |  |
| 2717 | 1.9.2.2.1 | **SIT Non-MVC Service Activation Preparation Tasks** |  | 610d | 2022-10-31 | 2025-02-28 |  | 2022-10-31 | 2022-10-31 | 0d | 734d |  |  | Business & Operation Readiness | 6.13 | -651.67 | Overdue Start | RED |  |
| 2718 | 1.9.2.2.1.1 | Helix Preparatory Activities Complete | milestone | 0d | 2025-02-28 | 2025-02-28 | 2693 | 2022-10-31 | 2022-10-31 | 0d | 734d |  |  | Business & Operation Readiness | 6.13 | 30.71 | Red | RED |  |
| 2719 | 1.9.2.2.1.2 | MHHSP Confirms SIT Non-MVC PPs MHHS Enabled |  | 1d | 2022-10-31 | 2022-10-31 |  | 2022-10-31 | 2022-10-31 | 0d | 818d | 739d |  | Business & Operation Readiness | 6.13 | -820.67 | Overdue Start | RED |  |
| 2720 | 1.9.2.2.2 | **SIT Non-MVC Service Activation Implementation** |  | 7d? | 2025-12-19 | 2025-12-29 |  | 2025-12-23 | 2026-01-01 | 0d | 0d |  |  | Business & Operation Readiness | 5.31 |  |  |  |  |
| 2721 | 1.9.2.2.2.1 | Add EDF to DIP |  | 1d | 2025-12-19 | 2025-12-19 | 1962SS, 2719 | 2025-12-23 | 2025-12-24 | 0d | 0d |  | finish no earlier than 2025-06-04 | Business & Operation Readiness | 5.31 | 324.33 | Green | GREEN |  |
| 2722 | 1.9.2.2.2.2 | DIP Promoted to Production |  | 1d | 2025-12-22 | 2025-12-22 | 2721 | 2025-12-25 | 2025-12-26 | 0d | 0d |  | finish no earlier than 2025-06-05 | Business & Operation Readiness | 6.13 | 327.33 | Green | GREEN |  |
| 2723 | 1.9.2.2.2.3 | SIT non-MVC S&As Create Certificates and Test Connectivity |  | 1d? | 2025-12-23 | 2025-12-23 | 2722 | 2025-12-23 | 2025-12-23 |  | 522d |  |  | SIT | 6.17 | 328.33 | Green | GREEN |  |
| 2724 | 1.9.2.2.2.4 | Create M16 in Customer Solution |  | 2d | 2025-12-23 | 2025-12-24 | 2722 | 2025-12-29 | 2025-12-30 | 0d | 0d |  | finish no earlier than 2025-06-06 | Business & Operation Readiness | 6.13 | 328.33 | Green | GREEN |  |
| 2725 | 1.9.2.2.2.5 | Publish ISD |  | 2d | 2025-12-25 | 2025-12-26 | 2724 | 2025-12-31 | 2026-01-01 | 0d | 0d |  | finish no earlier than 2025-06-06 | Business & Operation Readiness | 6.13 | 330.33 | Green | GREEN |  |
| 2726 | 1.9.2.2.2.6 | SIT non-MVC S&As to update systems with ISD |  | 1d? | 2025-12-29 | 2025-12-29 | 2725 | 2025-12-29 | 2025-12-29 |  | 518d |  |  | SIT | 6.17 | 334.33 | Green | GREEN |  |
| 2727 | 1.9.2.2.2.7 | SIT Non-MVC Service Activation Implementation Complete | milestone | 0d | 2025-12-26 | 2025-12-26 | 2725 | 2026-01-01 | 2026-01-01 | 0d | 0d |  | finish no earlier than 2025-06-06 | Business & Operation Readiness | 6.13 | 331.71 | Green | GREEN |  |
| 2728 | 1.9.2.2.3 | **SIT Non-MVC Service Activation Implementation MDD** |  | 15d | 2025-12-29 | 2026-01-16 |  | 2025-06-05 | 2025-06-24 | 0d | 504d |  |  | Business & Operation Readiness | 6.13 |  |  |  |  |
| 2729 | 1.9.2.2.3.1 | MDD Manual Load |  | 7d | 2025-12-29 | 2026-01-06 | 2725 | 2025-06-05 | 2025-06-13 | 0d | 504d | 0d | finish no earlier than 2025-06-13 | Business & Operation Readiness | 6.13 | 334.33 | Red | RED |  |
| 2730 | 1.9.2.2.3.2 | MDD Update |  | 8d | 2026-01-07 | 2026-01-16 | 2729 | 2025-06-13 | 2025-06-24 | 0d | 504d | 0d | finish no earlier than 2025-06-24 | Business & Operation Readiness | 6.13 | 343.33 | Red | RED |  |
| 2731 | 1.9.2.2.3.3 | SIT Non-MVC Service Activation Implementation MDD Complete | milestone | 0d | 2026-01-16 | 2026-01-16 | 2730 | 2025-06-24 | 2025-06-24 | 0d | 504d |  | finish no earlier than 2025-06-24 | Business & Operation Readiness | 6.13 | 352.71 | Red | RED |  |

Notes:
- 2714: Action: 12/8/24: Why is ths a dep into us?
- 2718: Action: 12/8/24: Emailed helix to clarify what needs to go in the prep section and if hypercare is required
- 2723: 29/01/25 - Added baseline date.
- 2726: 29/01/25 - Added baseline date.

| ID | WBS | Task | Type | Duration | Start | Finish | Predecessors | Baseline start | Baseline finish | Baseline duration | Total slack | Free slack | Constraint | Text9 | Update Version | Task Status | Sched Status | RAG | Involved |
| --- | --- | --- | --- | --- | --- | --- | --- | --- | --- | --- | --- | --- | --- | --- | --- | --- | --- | --- | --- |
| 2732 | 1.9.2.2.4 | **Non-SIT MVC Service Activation Hypercare** |  | 22d | 2025-12-19 | 2026-01-19 |  | 2025-06-02 | 2025-06-26 | 0d | 503d |  |  | Business & Operation Readiness | 6.13 |  |  |  |  |
| 2733 | 1.9.2.2.4.1 | Service& Process Monitoring |  | 18d | 2025-12-19 | 2026-01-13 | 2721SS | 2025-06-02 | 2025-06-25 | 0d | 507d |  | finish no earlier than 2025-06-25 | Business & Operation Readiness | 6.13 | 324.33 | Red | RED |  |
| 2734 | 1.9.2.2.4.2 | Daily Reporting |  | 18d | 2025-12-19 | 2026-01-13 | 2721SS | 2025-06-02 | 2025-06-25 | 0d | 507d |  | finish no earlier than 2025-06-25 | Business & Operation Readiness | 6.13 | 324.33 | Red | RED |  |
| 2735 | 1.9.2.2.4.3 | Issue Management |  | 18d | 2025-12-19 | 2026-01-13 | 2721SS | 2025-06-02 | 2025-06-25 | 0d | 507d |  | finish no earlier than 2025-06-25 | Business & Operation Readiness | 6.13 | 324.33 | Red | RED |  |
| 2736 | 1.9.2.2.4.4 | SA Hypercare Close Down Activities |  | 18d | 2025-12-19 | 2026-01-13 | 2721SS | 2025-06-02 | 2025-06-25 | 0d | 503d | 0d | finish no earlier than 2025-06-25 | Business & Operation Readiness | 6.13 | 324.33 | Red | RED |  |
| 2737 | 1.9.2.2.4.5 | Handover to MHHSP |  | 4d | 2026-01-14 | 2026-01-19 | 2736 | 2025-06-23 | 2025-06-26 | 0d | 503d | 0d | finish no earlier than 2025-06-26 | Business & Operation Readiness | 6.13 | 350.33 | Red | RED | MHHSP |
| 2738 | 1.9.2.2.4.6 | Non-SIT MVC Service Activation Hypercare Complete (M) | milestone | 0d | 2026-01-19 | 2026-01-19 | 2737 | 2025-06-25 | 2025-06-25 | 0d | 503d |  | finish no earlier than 2025-06-25 | Business & Operation Readiness | 6.13 | 355.71 | Red | RED |  |
| 2739 | 1.9.2.3 | **Wave 1** |  | 924d | 2022-10-31 | 2026-05-14 |  | 2022-10-31 | 2026-05-14 | 0d | 420d |  |  | Business & Operation Readiness | 5.31 | -650.67 | Overdue Start | RED |  |
| 2740 | 1.9.2.3.1 | **SIT Non-MVC Service Activation Preparation Tasks** |  | 924d | 2022-10-31 | 2026-05-14 |  | 2022-10-31 | 2026-05-14 | 0d | 420d |  |  | Business & Operation Readiness | 5.31 | -651.67 | Overdue Start | RED |  |
| 2741 | 1.9.2.3.1.1 | Helix Preparatory Activities Complete | milestone | 0d | 2022-10-31 | 2022-10-31 |  | 2022-10-31 | 2022-10-31 | 0d | 1344d |  |  | Business & Operation Readiness | 5.29 | -820.67 | Overdue Start | RED |  |
| 2742 | 1.9.2.3.1.2 | MHHSP Confirms Wave 1 PPs MHHS Enabled |  | 1d | 2022-10-31 | 2022-10-31 |  | 2022-10-31 | 2022-10-31 | 0d | 902d |  |  | Business & Operation Readiness | 5.28 | -820.67 | Overdue Start | RED |  |
| 2743 | 1.9.2.3.1.3 | Wave 1 Service Activation |  | 21d | 2026-04-16 | 2026-05-14 | 2185, 2742 | 2026-04-13 | 2026-05-14 | 25d | 0d |  |  | Business & Operation Readiness | 6.13 | 442.33 | Green | GREEN |  |
| 2744 | 1.9.2.3.2 | **Wave 1 - Service Activation Implementation** |  | 171d | 2025-09-01 | 2026-04-27 |  | 2025-09-01 | 2025-09-05 | 0d | 433d |  |  | Business & Operation Readiness | 5.31 |  |  |  |  |
| 2745 | 1.9.2.3.2.1 | MHHSP Enabled Confirmation |  | 2d | 2025-09-01 | 2025-09-02 | 2719 | 2025-09-01 | 2025-09-02 | 0d | 602d |  | finish no earlier than 2025-09-02 | Business & Operation Readiness | 5.31 | 215.33 | Green | GREEN |  |
| 2746 | 1.9.2.3.2.2 | PAB Approval |  | 2d | 2026-04-16 | 2026-04-17 | 2185 | 2025-09-01 | 2025-09-02 | 0d | 439d |  | finish no earlier than 2025-09-02 | Business & Operation Readiness | 5.31 | 442.33 | Red | RED |  |
| 2747 | 1.9.2.3.2.3 | Add EFD to DIP |  | 2d | 2026-04-16 | 2026-04-17 | 2185 | 2025-09-02 | 2025-09-03 | 0d | 422d | 0d | finish no earlier than 2025-09-03 | Business & Operation Readiness | 5.31 | 442.33 | Red | RED |  |
| 2748 | 1.9.2.3.2.4 | DIP Promoted to Production |  | 2d | 2026-04-20 | 2026-04-21 | 2747 | 2025-09-03 | 2025-09-04 | 0d | 422d | 0d | finish no earlier than 2025-09-04 | Business & Operation Readiness | 5.31 | 446.33 | Red | RED |  |
| 2749 | 1.9.2.3.2.5 | Create M16 in Customer Solution |  | 2d | 2026-04-22 | 2026-04-23 | 2748 | 2025-09-04 | 2025-09-05 | 0d | 422d | 0d | finish no earlier than 2025-09-05 | Business & Operation Readiness | 5.31 | 448.33 | Red | RED |  |
| 2750 | 1.9.2.3.2.6 | Publish ISD |  | 2d | 2026-04-24 | 2026-04-27 | 2749 | 2025-09-04 | 2025-09-05 | 0d | 422d | 0d | finish no earlier than 2025-09-05 | Business & Operation Readiness | 5.31 | 450.33 | Red | RED |  |
| 2751 | 1.9.2.3.2.7 | Wave 1 - Service Activation Implementation Complete (M) | milestone | 0d | 2026-04-27 | 2026-04-27 | 2750 | 2025-09-05 | 2025-09-05 | 0d | 433d |  | finish no earlier than 2025-09-05 | Business & Operation Readiness | 5.31 | 453.71 | Red | RED |  |
| 2752 | 1.9.2.3.3 | **Wave 1 - Service Activation Implementation MDD** |  | 11d | 2026-04-28 | 2026-05-12 |  | 2025-09-04 | 2025-09-17 | 0d | 422d |  |  | Business & Operation Readiness | 5.31 |  |  |  |  |
| 2753 | 1.9.2.3.3.1 | MDD Manual Load |  | 5d | 2026-04-28 | 2026-05-04 | 2750 | 2025-09-04 | 2025-09-10 | 0d | 422d | 0d | finish no earlier than 2025-09-10 | Business & Operation Readiness | 5.31 | 454.33 | Red | RED |  |
| 2754 | 1.9.2.3.3.2 | MDD Update |  | 6d | 2026-05-05 | 2026-05-12 | 2753 | 2025-09-10 | 2025-09-17 | 0d | 422d | 0d | finish no earlier than 2025-09-17 | Business & Operation Readiness | 5.31 | 461.33 | Red | RED |  |
| 2755 | 1.9.2.3.3.3 | Wave 1 - Service Activation Implementation MDD Complete (M) | milestone | 0d | 2026-05-12 | 2026-05-12 | 2754 | 2025-09-17 | 2025-09-17 | 0d | 422d |  | finish no earlier than 2025-09-17 | Business & Operation Readiness | 5.31 | 468.71 | Red | RED |  |

Notes:
- 2741: Action: 12/8/24: Emailed helix to clarify what needs to go in the prep section and if hypercare is required

| ID | WBS | Task | Type | Duration | Start | Finish | Predecessors | Baseline start | Baseline finish | Baseline duration | Total slack | Free slack | Constraint | Text9 | Update Version | Task Status | Sched Status | RAG | Future RAG |
| --- | --- | --- | --- | --- | --- | --- | --- | --- | --- | --- | --- | --- | --- | --- | --- | --- | --- | --- | --- |
| 2756 | 1.9.2.3.4 | **Wave 1 - Service Activation Hypercare** |  | 177d | 2025-09-01 | 2026-05-05 |  | 2022-10-31 | 2025-09-18 | 0d | 427d |  |  | Business & Operation Readiness | 5.31 |  |  |  |  |
| 2757 | 1.9.2.3.4.1 | Service& Process Monitoring |  | 14d | 2026-04-16 | 2026-05-05 | 2747SS | 2025-09-01 | 2025-09-18 | 0d | 427d |  | finish no earlier than 2025-09-18 | Business & Operation Readiness | 5.31 | 442.33 | Red | RED |  |
| 2758 | 1.9.2.3.4.2 | Daily Reporting |  | 14d | 2026-04-16 | 2026-05-05 | 2747SS | 2025-09-01 | 2025-09-18 | 0d | 427d |  | finish no earlier than 2025-09-18 | Business & Operation Readiness | 5.31 | 442.33 | Red | RED |  |
| 2759 | 1.9.2.3.4.3 | Issue Management |  | 14d | 2026-04-16 | 2026-05-05 | 2747SS | 2025-09-01 | 2025-09-18 | 0d | 427d |  | finish no earlier than 2025-09-18 | Business & Operation Readiness | 5.31 | 442.33 | Red | RED |  |
| 2760 | 1.9.2.3.4.4 | SA Hypercare Close Down Activities |  | 14d | 2025-09-01 | 2025-09-18 |  | 2025-09-01 | 2025-09-18 | 0d | 586d | 0d | finish no earlier than 2025-09-18 | Business & Operation Readiness | 5.31 | 215.33 | Green | GREEN |  |
| 2761 | 1.9.2.3.4.5 | Handover to MHHSP |  | 4d | 2025-09-19 | 2025-09-24 | 2760 | 2025-09-15 | 2025-09-18 | 0d | 586d | 0d | finish no earlier than 2025-09-18 | Business & Operation Readiness | 5.31 | 233.33 | yellow | RED |  |
| 2762 | 1.9.2.3.4.6 | Non-SIT LDSO Service Activation Hypercare Complete (M) | milestone | 0d | 2025-09-24 | 2025-09-24 | 2761 | 2022-10-31 | 2022-10-31 | 0d | 586d |  |  | Business & Operation Readiness | 5.31 | 238.71 | Red | RED | Dates to be confirmed |
| 2763 | 1.9.2.4 | **Wave 2** |  | 958d | 2022-10-31 | 2026-07-01 |  | 2022-10-31 | 2026-06-30 | 0d | 386d |  |  | Business & Operation Readiness | 5.31 | -650.67 | Overdue Start | RED |  |
| 2764 | 1.9.2.4.1 | **SIT Non-MVC Service Activation Preparation Tasks** |  | 958d | 2022-10-31 | 2026-07-01 |  | 2022-10-31 | 2026-06-30 | 0d | 386d |  |  | Business & Operation Readiness | 5.31 | -651.67 | Overdue Start | RED |  |
| 2765 | 1.9.2.4.1.1 | Helix Preparatory Activities Complete | milestone | 0d | 2022-10-31 | 2022-10-31 |  | 2022-10-31 | 2022-10-31 | 0d | 1344d |  |  | Business & Operation Readiness | 5.29 | -820.67 | Overdue Start | RED |  |
| 2766 | 1.9.2.4.1.2 | MHHSP Confirms Wave 2 PPs MHHS Enabled |  | 1d | 2022-10-31 | 2022-10-31 |  | 2022-10-31 | 2022-10-31 | 0d | 933d |  |  | Business & Operation Readiness | 5.28 | -820.67 | Overdue Start | RED |  |
| 2767 | 1.9.2.4.1.3 | Wave 2 Service Activation |  | 24d | 2026-05-29 | 2026-07-01 | 2215, 2766 | 2026-05-28 | 2026-06-30 | 25d | 0d |  |  | Business & Operation Readiness | 5.24 | 485.33 | yellow | RED |  |
| 2768 | 1.9.2.4.2 | **Wave 2 - Service Activation Implementation** |  | 157d | 2025-11-03 | 2026-06-09 |  | 2025-11-03 | 2025-11-07 | 0d | 402d |  |  | Business & Operation Readiness | 5.31 |  |  |  |  |
| 2769 | 1.9.2.4.2.1 | MHHSP Enabled Confirmation |  | 2d | 2025-11-03 | 2025-11-04 |  | 2025-11-03 | 2025-11-04 | 0d | 557d |  | finish no earlier than 2025-11-04 | Business & Operation Readiness | 5.31 | 278.33 | Green | GREEN |  |
| 2770 | 1.9.2.4.2.2 | PAB Approval |  | 2d | 2026-05-29 | 2026-06-01 | 2215 | 2025-11-03 | 2025-11-04 | 0d | 408d |  | finish no earlier than 2025-11-04 | Business & Operation Readiness | 5.31 | 485.33 | Red | RED |  |
| 2771 | 1.9.2.4.2.3 | Add EFD to DIP |  | 2d | 2026-05-29 | 2026-06-01 | 2215 | 2025-11-04 | 2025-11-05 | 0d | 402d | 0d | finish no earlier than 2025-11-05 | Business & Operation Readiness | 5.31 | 485.33 | Red | RED |  |
| 2772 | 1.9.2.4.2.4 | DIP Promoted to Production |  | 2d | 2026-06-02 | 2026-06-03 | 2771 | 2025-11-05 | 2025-11-06 | 0d | 402d | 0d | finish no earlier than 2025-11-06 | Business & Operation Readiness | 5.31 | 489.33 | Red | RED |  |
| 2773 | 1.9.2.4.2.5 | Create M16 in Customer Solution |  | 2d | 2026-06-04 | 2026-06-05 | 2772 | 2025-11-06 | 2025-11-07 | 0d | 402d | 0d | finish no earlier than 2025-11-07 | Business & Operation Readiness | 5.31 | 491.33 | Red | RED |  |
| 2774 | 1.9.2.4.2.6 | Publish ISD |  | 2d | 2026-06-08 | 2026-06-09 | 2773 | 2025-11-06 | 2025-11-07 | 0d | 402d | 0d | finish no earlier than 2025-11-07 | Business & Operation Readiness | 5.31 | 495.33 | Red | RED |  |
| 2775 | 1.9.2.4.2.7 | Wave 2 - Service Activation Implementation Complete (M) | milestone | 0d | 2026-06-09 | 2026-06-09 | 2774 | 2025-11-07 | 2025-11-07 | 0d | 402d |  | finish no earlier than 2025-11-07 | Business & Operation Readiness | 5.31 | 496.71 | Red | RED |  |
| 2776 | 1.9.2.4.3 | **Wave 2 - Service Activation Implementation MDD** |  | 10d | 2025-11-06 | 2025-11-19 |  | 2025-11-06 | 2025-11-19 | 0d | 546d |  |  | Business & Operation Readiness | 5.31 |  |  |  |  |
| 2777 | 1.9.2.4.3.1 | MDD Manual Load |  | 5d | 2025-11-06 | 2025-11-12 |  | 2025-11-06 | 2025-11-12 | 0d | 551d |  | finish no earlier than 2025-11-12 | Business & Operation Readiness | 5.31 | 281.33 | Green | GREEN |  |
| 2778 | 1.9.2.4.3.2 | MDD Update |  | 6d | 2025-11-12 | 2025-11-19 |  | 2025-11-12 | 2025-11-19 | 0d | 546d |  | finish no earlier than 2025-11-19 | Business & Operation Readiness | 5.31 | 287.33 | Green | GREEN |  |
| 2779 | 1.9.2.4.3.3 | Wave 2 - Service Activation Implementation MDD Complete (M) | milestone | 0d | 2025-11-19 | 2025-11-19 |  | 2025-11-19 | 2025-11-19 | 0d | 546d |  | finish no earlier than 2025-11-19 | Business & Operation Readiness | 5.31 | 294.71 | Green | GREEN |  |

Notes:
- 2765: Action: 12/8/24: Emailed helix to clarify what needs to go in the prep section and if hypercare is required

| ID | WBS | Task | Type | Duration | Start | Finish | Predecessors | Baseline start | Baseline finish | Baseline duration | Total slack | Free slack | Constraint | Text9 | Update Version | Task Status | Sched Status | RAG | Involved | Future RAG |
| --- | --- | --- | --- | --- | --- | --- | --- | --- | --- | --- | --- | --- | --- | --- | --- | --- | --- | --- | --- | --- |
| 2780 | 1.9.2.4.4 | **Wave 2 - Service Activation Hypercare** |  | 14d | 2025-11-03 | 2025-11-20 |  | 2025-11-03 | 2025-11-20 | 0d | 545d |  |  | Business & Operation Readiness | 5.31 |  |  |  |  |  |
| 2781 | 1.9.2.4.4.1 | Service& Process Monitoring |  | 14d | 2025-11-03 | 2025-11-20 |  | 2025-11-03 | 2025-11-20 | 0d | 545d |  | finish no earlier than 2025-11-20 | Business & Operation Readiness | 5.31 | 278.33 | Green | GREEN |  |  |
| 2782 | 1.9.2.4.4.2 | Daily Reporting |  | 14d | 2025-11-03 | 2025-11-20 |  | 2025-11-03 | 2025-11-20 | 0d | 545d |  | finish no earlier than 2025-11-20 | Business & Operation Readiness | 5.31 | 278.33 | Green | GREEN |  |  |
| 2783 | 1.9.2.4.4.3 | Issue Management |  | 14d | 2025-11-03 | 2025-11-20 |  | 2025-11-03 | 2025-11-20 | 0d | 545d |  | finish no earlier than 2025-11-20 | Business & Operation Readiness | 5.31 | 278.33 | Green | GREEN |  |  |
| 2784 | 1.9.2.4.4.4 | SA Hypercare Close Down Activities |  | 14d | 2025-11-03 | 2025-11-20 |  | 2025-11-03 | 2025-11-20 | 0d | 545d |  | finish no earlier than 2025-11-20 | Business & Operation Readiness | 5.31 | 278.33 | Green | GREEN |  |  |
| 2785 | 1.9.2.4.4.5 | Handover to MHHSP |  | 4d | 2025-11-17 | 2025-11-20 |  | 2025-11-17 | 2025-11-20 | 0d | 545d |  | finish no earlier than 2025-11-20 | Business & Operation Readiness | 5.31 | 292.33 | Green | GREEN | MHHSP |  |
| 2786 | 1.9.2.4.4.6 | Wave 2 - Service Activation Hypercare Complete (M) | milestone | 0d | 2025-11-19 | 2025-11-19 |  | 2025-11-19 | 2025-11-19 | 0d | 546d |  | finish no earlier than 2025-11-19 | Business & Operation Readiness | 5.31 | 294.71 | Green | GREEN |  |  |
| 2787 | 1.9.2.5 | **Wave 3** |  | 989d | 2022-10-31 | 2026-08-13 |  | 2022-10-31 | 2026-08-26 | 0d | 355d |  |  | Business & Operation Readiness | 5.31 | -650.67 | Overdue Start | RED |  |  |
| 2788 | 1.9.2.5.1 | **SIT Non-MVC Service Activation Preparation Tasks** |  | 989d | 2022-10-31 | 2026-08-13 |  | 2022-10-31 | 2026-08-26 | 0d | 355d |  |  | Business & Operation Readiness | 5.31 | -651.67 | Overdue Start | RED |  |  |
| 2789 | 1.9.2.5.1.1 | Helix Preparatory Activities Complete | milestone | 0d | 2022-10-31 | 2022-10-31 |  | 2022-10-31 | 2022-10-31 | 0d | 1344d |  |  | Business & Operation Readiness | 5.29 | -820.67 | Overdue Start | RED |  |  |
| 2790 | 1.9.2.5.1.2 | MHHSP Confirms Wave 3 PPs MHHS Enabled |  | 1d | 2022-10-31 | 2022-10-31 |  | 2022-10-31 | 2022-10-31 | 0d | 978d |  |  | Business & Operation Readiness | 5.28 | -820.67 | Overdue Start | RED |  |  |
| 2791 | 1.9.2.5.1.3 | Wave 3 Service Activation |  | 10d | 2026-07-31 | 2026-08-13 | 2245, 2790 | 2026-07-24 | 2026-08-26 | 25d | 0d |  |  | Business & Operation Readiness | 5.24 | 548.33 | Green | GREEN |  |  |
| 2792 | 1.9.2.5.2 | **Wave 3 - Service Activation Implementation** |  | 169d | 2025-12-22 | 2026-08-13 |  | 2025-12-22 | 2025-12-30 | 0d | 355d |  |  | Business & Operation Readiness | 5.31 |  |  |  |  |  |
| 2793 | 1.9.2.5.2.1 | MHHSP Enabled Confirmation |  | 2d | 2025-12-22 | 2025-12-23 |  | 2025-12-22 | 2025-12-23 | 0d | 522d |  | finish no earlier than 2025-12-23 | Business & Operation Readiness | 5.31 | 327.33 | Green | GREEN |  |  |
| 2794 | 1.9.2.5.2.2 | PAB Approval |  | 2d | 2026-07-31 | 2026-08-03 | 2245 | 2025-12-22 | 2025-12-23 | 0d | 355d | 0d | finish no earlier than 2025-12-23 | Business & Operation Readiness | 5.31 | 548.33 | Red | RED |  |  |
| 2795 | 1.9.2.5.2.3 | Add EFD to DIP |  | 2d | 2026-08-04 | 2026-08-05 | 2245, 2794 | 2025-12-23 | 2025-12-24 | 0d | 355d | 0d | finish no earlier than 2025-12-24 | Business & Operation Readiness | 5.31 | 552.33 | Red | RED |  |  |
| 2796 | 1.9.2.5.2.4 | DIP Promoted to Production |  | 2d | 2026-08-06 | 2026-08-07 | 2795 | 2025-12-29 | 2025-12-30 | 0d | 355d | 0d | finish no earlier than 2025-12-30 | Business & Operation Readiness | 5.31 | 554.33 | Red | RED |  |  |
| 2797 | 1.9.2.5.2.5 | Create M16 in Customer Solution |  | 2d | 2026-08-10 | 2026-08-11 | 2796 | 2025-12-29 | 2025-12-30 | 0d | 355d | 0d | finish no earlier than 2025-12-30 | Business & Operation Readiness | 5.31 | 558.33 | Red | RED |  |  |
| 2798 | 1.9.2.5.2.6 | Publish ISD |  | 2d | 2026-08-12 | 2026-08-13 | 2797 | 2025-12-29 | 2025-12-30 | 0d | 355d | 0d | finish no earlier than 2025-12-30 | Business & Operation Readiness | 5.31 | 560.33 | Red | RED |  |  |
| 2799 | 1.9.2.5.2.7 | Wave 3 - Service Activation Implementation Complete (M) | milestone | 0d | 2026-08-13 | 2026-08-13 | 2798 | 2025-12-30 | 2025-12-30 | 0d | 355d |  | finish no earlier than 2025-12-30 | Business & Operation Readiness | 5.31 | 561.71 | Red | RED |  |  |
| 2800 | 1.9.2.5.3 | **Wave 3 - Service Activation Implementation MDD** |  | 839d | 2022-10-31 | 2026-01-15 |  | 2022-10-31 | 2026-01-15 | 0d | 505d |  |  | Business & Operation Readiness | 5.31 |  |  |  |  |  |
| 2801 | 1.9.2.5.3.1 | MDD Manual Load |  | 7d | 2025-12-29 | 2026-01-06 |  | 2025-12-29 | 2026-01-06 | 0d | 512d |  | finish no earlier than 2026-01-06 | Business & Operation Readiness | 5.31 | 334.33 | Green | GREEN |  |  |
| 2802 | 1.9.2.5.3.2 | MDD Update |  | 269d | 2025-01-06 | 2026-01-15 |  | 2025-01-06 | 2026-01-15 | 0d | 505d |  | finish no earlier than 2026-01-15 | Business & Operation Readiness | 5.31 | -22.67 | Green | GREEN |  |  |
| 2803 | 1.9.2.5.3.3 | Wave 3 - Service Activation Implementation MDD Complete (M) | milestone | 0d | 2022-10-31 | 2022-10-31 |  | 2022-10-31 | 2022-10-31 | 0d | 1344d |  |  | Business & Operation Readiness | 5.31 | -820.67 | Overdue Start | RED |  | Dates to be confirmed |

Notes:
- 2789: Action: 12/8/24: Emailed helix to clarify what needs to go in the prep section and if hypercare is required

| ID | WBS | Task | Type | Duration | Start | Finish | Predecessors | Baseline start | Baseline finish | Baseline duration | Total slack | Free slack | Constraint | Text9 | Update Version | Task Status | Sched Status | RAG | Involved | Future RAG |
| --- | --- | --- | --- | --- | --- | --- | --- | --- | --- | --- | --- | --- | --- | --- | --- | --- | --- | --- | --- | --- |
| 2804 | 1.9.2.5.4 | **Wave 3 - Service Activation Hypercare** |  | 840d | 2022-10-31 | 2026-01-16 |  | 2022-10-31 | 2026-01-16 | 0d | 504d |  |  | Business & Operation Readiness | 5.31 |  |  |  |  |  |
| 2805 | 1.9.2.5.4.1 | Service& Process Monitoring |  | 20d | 2025-12-22 | 2026-01-16 |  | 2025-12-22 | 2026-01-16 | 0d | 504d |  | finish no earlier than 2026-01-16 | Business & Operation Readiness | 5.31 | 327.33 | Green | GREEN |  |  |
| 2806 | 1.9.2.5.4.2 | Daily Reporting |  | 20d | 2025-12-22 | 2026-01-16 |  | 2025-12-22 | 2026-01-16 | 0d | 504d |  | finish no earlier than 2026-01-16 | Business & Operation Readiness | 5.31 | 327.33 | Green | GREEN |  |  |
| 2807 | 1.9.2.5.4.3 | Issue Management |  | 20d | 2025-12-22 | 2026-01-16 |  | 2025-12-22 | 2026-01-16 | 0d | 504d |  | finish no earlier than 2026-01-16 | Business & Operation Readiness | 5.31 | 327.33 | Green | GREEN |  |  |
| 2808 | 1.9.2.5.4.4 | SA Hypercare Close Down Activities |  | 20d | 2025-12-22 | 2026-01-16 |  | 2025-12-22 | 2026-01-16 | 0d | 504d |  | finish no earlier than 2026-01-16 | Business & Operation Readiness | 5.31 | 327.33 | Green | GREEN |  |  |
| 2809 | 1.9.2.5.4.5 | Handover to MHHSP |  | 4d | 2026-01-12 | 2026-01-15 |  | 2026-01-12 | 2026-01-15 | 0d | 505d |  | finish no earlier than 2026-01-15 | Business & Operation Readiness | 5.31 | 348.33 | Green | GREEN | MHHSP |  |
| 2810 | 1.9.2.5.4.6 | Wave 3 Service Activation Hypercare Complete (M) | milestone | 0d | 2022-10-31 | 2022-10-31 |  | 2022-10-31 | 2022-10-31 | 0d | 1344d |  |  | Business & Operation Readiness | 5.31 | -820.67 | Overdue Start | RED |  | Date to be confirmed |
| 2811 | 1.9.2.6 | **Wave 4** |  | 1043d | 2022-10-31 | 2026-10-28 |  | 2022-10-31 | 2026-10-22 | 0d | 301d |  |  | Business & Operation Readiness | 5.31 | -650.67 | Overdue Start | RED |  |  |
| 2812 | 1.9.2.6.1 | **SIT Non-MVC Service Activation Preparation Tasks** |  | 1043d | 2022-10-31 | 2026-10-28 |  | 2022-10-31 | 2026-10-22 | 0d | 301d |  |  | Business & Operation Readiness | 5.31 | -651.67 | Overdue Start | RED |  |  |
| 2813 | 1.9.2.6.1.1 | Helix Preparatory Activities Complete | milestone | 0d | 2022-10-31 | 2022-10-31 |  | 2022-10-31 | 2022-10-31 | 0d | 1344d |  |  | Business & Operation Readiness | 5.29 | -820.67 | Overdue Start | RED |  |  |
| 2814 | 1.9.2.6.1.2 | MHHSP Confirms Wave 4 PPs MHHS Enabled |  | 1d | 2022-10-31 | 2022-10-31 |  | 2022-10-31 | 2022-10-31 | 0d | 1018d |  |  | Business & Operation Readiness | 5.28 | -820.67 | Overdue Start | RED |  |  |
| 2815 | 1.9.2.6.1.3 | Wave 4 Service Activation |  | 24d | 2026-09-25 | 2026-10-28 | 2275, 2814 | 2026-09-21 | 2026-10-22 | 25d | 0d |  |  | Business & Operation Readiness | 5.24 | 604.33 | yellow | RED |  |  |
| 2816 | 1.9.2.6.2 | **Wave 4 - Service Activation Implementation** |  | 158d | 2026-03-02 | 2026-10-07 |  | 2025-03-03 | 2026-03-06 | 0d | 316d |  |  | Business & Operation Readiness | 5.31 |  |  |  |  |  |
| 2817 | 1.9.2.6.2.1 | MHHSP Enabled Confirmation |  | 2d | 2026-03-02 | 2026-03-03 |  | 2026-03-02 | 2026-03-03 | 0d | 472d |  | finish no earlier than 2026-03-03 | Business & Operation Readiness | 5.31 | 397.33 | Green | GREEN |  |  |
| 2818 | 1.9.2.6.2.2 | PAB Approval |  | 1d | 2026-09-25 | 2026-09-25 | 2275 | 2025-03-03 | 2025-03-03 | 0d | 316d | 0d | finish no earlier than 2025-03-03 | Business & Operation Readiness | 5.31 | 604.33 | Red | RED |  |  |
| 2819 | 1.9.2.6.2.3 | Add EFD to DIP |  | 2d | 2026-09-28 | 2026-09-29 | 2818 | 2026-03-03 | 2026-03-04 | 0d | 316d | 0d | finish no earlier than 2026-03-04 | Business & Operation Readiness | 5.31 | 607.33 | Red | RED |  |  |
| 2820 | 1.9.2.6.2.4 | DIP Promoted to Production |  | 2d | 2026-09-30 | 2026-10-01 | 2819 | 2026-03-04 | 2026-03-05 | 0d | 316d | 0d | finish no earlier than 2026-03-05 | Business & Operation Readiness | 5.31 | 609.33 | Red | RED |  |  |
| 2821 | 1.9.2.6.2.5 | Create M16 in Customer Solution |  | 2d | 2026-10-02 | 2026-10-05 | 2820 | 2026-03-05 | 2026-03-06 | 0d | 316d | 0d | finish no earlier than 2026-03-06 | Business & Operation Readiness | 5.31 | 611.33 | Red | RED |  |  |
| 2822 | 1.9.2.6.2.6 | Publish ISD |  | 2d | 2026-10-06 | 2026-10-07 | 2821 | 2026-03-05 | 2026-03-06 | 0d | 316d | 0d | finish no earlier than 2026-03-06 | Business & Operation Readiness | 5.31 | 615.33 | Red | RED |  |  |
| 2823 | 1.9.2.6.2.7 | Wave 4 - Service Activation Implementation Complete (M) | milestone | 0d | 2026-10-07 | 2026-10-07 | 2822 | 2026-03-06 | 2026-03-06 | 0d | 316d |  | finish no earlier than 2026-03-06 | Business & Operation Readiness | 5.31 | 616.71 | Red | RED |  |  |
| 2824 | 1.9.2.6.3 | **Wave 4 - Service Activation Implementation MDD** |  | 15d | 2026-03-06 | 2026-03-26 |  | 2026-03-06 | 2026-03-26 | 0d | 455d |  |  | Business & Operation Readiness | 5.31 |  |  |  |  |  |
| 2825 | 1.9.2.6.3.1 | MDD Manual Load |  | 7d | 2026-03-06 | 2026-03-16 |  | 2026-03-06 | 2026-03-16 | 0d | 463d |  | finish no earlier than 2026-03-16 | Business & Operation Readiness | 5.31 | 401.33 | Green | GREEN |  |  |
| 2826 | 1.9.2.6.3.2 | MDD Update |  | 9d | 2026-03-16 | 2026-03-26 |  | 2026-03-16 | 2026-03-26 | 0d | 455d |  | finish no earlier than 2026-03-26 | Business & Operation Readiness | 5.31 | 411.33 | Green | GREEN |  |  |
| 2827 | 1.9.2.6.3.3 | Wave 4 - Service Activation Implementation MDD Complete | milestone | 0d | 2026-03-25 | 2026-03-25 |  | 2026-03-25 | 2026-03-25 | 0d | 456d |  | finish no earlier than 2026-03-25 | Business & Operation Readiness | 5.31 | 420.71 | Green | GREEN |  |  |

Notes:
- 2813: Action: 12/8/24: Emailed helix to clarify what needs to go in the prep section and if hypercare is required

| ID | WBS | Task | Type | Duration | Start | Finish | Predecessors | Baseline start | Baseline finish | Baseline duration | Total slack | Free slack | Constraint | Text9 | Update Version | Task Status | Sched Status | RAG | Involved | Responsible |
| --- | --- | --- | --- | --- | --- | --- | --- | --- | --- | --- | --- | --- | --- | --- | --- | --- | --- | --- | --- | --- |
| 2828 | 1.9.2.6.4 | **Wave 4 - Service Activation Hypercare** |  | 19d | 2026-03-02 | 2026-03-26 |  | 2026-03-02 | 2026-03-26 | 0d | 455d |  |  | Business & Operation Readiness | 5.31 |  |  |  |  |  |
| 2829 | 1.9.2.6.4.1 | Service& Process Monitoring |  | 19d | 2026-03-02 | 2026-03-26 |  | 2026-03-02 | 2026-03-26 | 0d | 455d |  | finish no earlier than 2026-03-26 | Business & Operation Readiness | 5.31 | 397.33 | Green | GREEN |  |  |
| 2830 | 1.9.2.6.4.2 | Daily Reporting |  | 19d | 2026-03-02 | 2026-03-26 |  | 2026-03-02 | 2026-03-26 | 0d | 455d |  | finish no earlier than 2026-03-26 | Business & Operation Readiness | 5.31 | 397.33 | Green | GREEN |  |  |
| 2831 | 1.9.2.6.4.3 | Issue Management |  | 19d | 2026-03-02 | 2026-03-26 |  | 2026-03-02 | 2026-03-26 | 0d | 455d |  | finish no earlier than 2026-03-26 | Business & Operation Readiness | 5.31 | 397.33 | Green | GREEN |  |  |
| 2832 | 1.9.2.6.4.4 | SA Hypercare Close Down Activities |  | 19d | 2026-03-02 | 2026-03-26 |  | 2026-03-02 | 2026-03-26 | 0d | 455d |  | finish no earlier than 2026-03-26 | Business & Operation Readiness | 5.31 | 397.33 | Green | GREEN |  |  |
| 2833 | 1.9.2.6.4.5 | Handover to MHHSP |  | 4d | 2026-03-02 | 2026-03-05 |  | 2026-03-02 | 2026-03-05 | 0d | 470d |  | finish no earlier than 2026-03-05 | Business & Operation Readiness | 5.31 | 397.33 | Green | GREEN | MHHSP |  |
| 2834 | 1.9.2.6.4.6 | Wave 4 - Service Activation Hypercare Complete (M) | milestone | 0d | 2026-03-25 | 2026-03-25 |  | 2026-03-25 | 2026-03-25 | 0d | 456d |  | finish no earlier than 2026-03-25 | Business & Operation Readiness | 5.31 | 420.71 | Green | GREEN |  |  |
| 2835 | 1.9.2.7 | **Non-SIT LDSO** |  | 754d | 2022-10-31 | 2025-09-18 |  | 2022-10-31 | 2025-09-01 | 0d | 590d |  |  | Business & Operation Readiness | 5.31 | -650.67 | Overdue Start | RED |  |  |
| 2836 | 1.9.2.7.1 | **Non-SIT LDSO Service Activation Data Loading** |  | 176d | 2024-06-07 | 2025-02-07 |  | 2024-06-07 | 2025-02-07 | 0d | 749d |  |  | Business & Operation Readiness | 5.31 |  |  |  |  |  |
| 2837 | 1.9.2.7.1.1 | Define pre Non-SIT LDSO upfront activities |  | 7d | 2024-06-07 | 2024-06-17 |  | 2024-06-07 | 2024-06-17 | 0d | 918d |  | finish no earlier than 2024-06-17 | Business & Operation Readiness | 5.31 | -235.67 | Overdue Start | RED |  |  |
| 2838 | 1.9.2.7.1.2 | **Execute Non-SIT LDSO Activities** |  | 5d | 2025-02-03 | 2025-02-07 |  | 2025-02-03 | 2025-02-07 | 0d | 749d |  |  | Business & Operation Readiness | 5.31 |  |  |  |  |  |
| 2839 | 1.9.2.7.1.2.1 | Create Entity Forms in Customer Solution |  | 3d | 2025-02-03 | 2025-02-05 |  | 2025-02-03 | 2025-02-05 | 0d | 751d |  | finish no earlier than 2025-02-05 | Business & Operation Readiness | 5.31 | 5.33 | Green | GREEN |  | PMP |
| 2840 | 1.9.2.7.1.2.2 | DIP - Promote to Production Environment |  | 3d | 2025-02-03 | 2025-02-05 |  | 2025-02-03 | 2025-02-05 | 0d | 751d |  | finish no earlier than 2025-02-05 | Business & Operation Readiness | 5.31 | 5.33 | Green | GREEN |  | DIP |
| 2841 | 1.9.2.7.1.2.3 | DIP - Enable Technology capabilities for participants |  | 3d | 2025-02-03 | 2025-02-05 |  | 2025-02-03 | 2025-02-05 | 0d | 751d |  | finish no earlier than 2025-02-05 | Business & Operation Readiness | 5.31 | 5.33 | Green | GREEN |  | DIP |
| 2842 | 1.9.2.7.1.2.4 | DIP - Add EFD to DIP |  | 3d | 2025-02-03 | 2025-02-05 |  | 2025-02-03 | 2025-02-05 | 0d | 751d |  | finish no earlier than 2025-02-05 | Business & Operation Readiness | 5.31 | 5.33 | Green | GREEN |  | DIP |
| 2843 | 1.9.2.7.1.2.5 | ISD - Replicate Entity Forms from CS |  | 2d | 2025-02-06 | 2025-02-07 |  | 2025-02-06 | 2025-02-07 | 0d | 749d |  | finish no earlier than 2025-02-07 | Business & Operation Readiness | 5.31 | 8.33 | Green | GREEN |  | HELIX |
| 2844 | 1.9.2.7.1.2.6 | MDD - Load MHHS roles |  | 3d | 2025-02-03 | 2025-02-05 |  | 2025-02-03 | 2025-02-05 | 0d | 751d |  | finish no earlier than 2025-02-05 | Business & Operation Readiness | 5.31 | 5.33 | Green | GREEN |  | PMP |
| 2845 | 1.9.2.7.1.3 | Non-SIT LDSO Service Activation Data Loading Completed (M) | milestone | 0d | 2025-02-07 | 2025-02-07 |  | 2025-02-07 | 2025-02-07 | 0d | 749d |  | finish no earlier than 2025-02-07 | Business & Operation Readiness | 5.31 | 9.71 | Green | GREEN |  |  |
| 2846 | 1.9.2.7.2 | **SIT Non-MVC Service Activation Preparation Tasks** |  | 754d | 2022-10-31 | 2025-09-18 |  | 2022-10-31 | 2025-09-01 | 0d | 590d |  |  | Business & Operation Readiness | 5.31 | -651.67 | Overdue Start | RED |  |  |
| 2847 | 1.9.2.7.2.1 | Helix Preparatory Activities Complete | milestone | 0d | 2022-10-31 | 2022-10-31 |  | 2022-10-31 | 2022-10-31 | 0d | 1344d |  |  | Business & Operation Readiness | 5.29 | -820.67 | Overdue Start | RED |  |  |
| 2848 | 1.9.2.7.2.2 | MHHSP Confirms Non-SIT LDSO PPs MHHS Enabled |  | 1d | 2022-10-31 | 2022-10-31 |  | 2022-10-31 | 2022-10-31 | 0d | 751d | 747d |  | Business & Operation Readiness | 5.28 | -820.67 | Overdue Start | RED |  |  |
| 2849 | 1.9.2.7.2.3 | Non-SIT LDSO Service Activation |  | 6d | 2025-09-11 | 2025-09-18 | 2848, 1974 | 2025-08-25 | 2025-09-01 | 9d | 4d |  |  | Business & Operation Readiness | 6.12 | 225.33 | Red | RED |  |  |
| 2850 | 1.9.2.7.3 | **Non-SIT LDSO Service Activation Implementation** |  | 4d | 2025-02-24 | 2025-02-27 |  | 2025-02-24 | 2025-02-27 | 0d | 735d |  |  | Business & Operation Readiness | 5.31 |  |  |  |  |  |
| 2851 | 1.9.2.7.3.1 | MHHSP Enabled Confirmation |  | 2d | 2025-02-24 | 2025-02-25 |  | 2025-02-24 | 2025-02-25 | 0d | 737d |  | finish no earlier than 2025-02-25 | Business & Operation Readiness | 5.31 | 26.33 | Green | GREEN |  | MHHSP |
| 2852 | 1.9.2.7.3.2 | PAB Approval |  | 2d | 2025-02-24 | 2025-02-25 |  | 2025-02-24 | 2025-02-25 | 0d | 737d |  | finish no earlier than 2025-02-25 | Business & Operation Readiness | 5.31 | 26.33 | Green | GREEN |  | QUALF |
| 2853 | 1.9.2.7.3.3 | Add EFD to DIP |  | 2d | 2025-02-25 | 2025-02-26 |  | 2025-02-25 | 2025-02-26 | 0d | 736d |  | finish no earlier than 2025-02-26 | Business & Operation Readiness | 5.31 | 27.33 | Green | GREEN |  | DIP |
| 2854 | 1.9.2.7.3.4 | DIP Promoted to Production |  | 2d | 2025-02-26 | 2025-02-27 |  | 2025-02-26 | 2025-02-27 | 0d | 735d |  | finish no earlier than 2025-02-27 | Business & Operation Readiness | 5.31 | 28.33 | Green | GREEN |  | DIP |
| 2855 | 1.9.2.7.3.5 | Create M16 in Customer Solution |  | 2d | 2025-02-26 | 2025-02-27 |  | 2025-02-26 | 2025-02-27 | 0d | 735d |  | finish no earlier than 2025-02-27 | Business & Operation Readiness | 5.31 | 28.33 | Green | GREEN |  | PMP |
| 2856 | 1.9.2.7.3.6 | Publish ISD |  | 2d | 2025-02-26 | 2025-02-27 |  | 2025-02-26 | 2025-02-27 | 0d | 735d |  | finish no earlier than 2025-02-27 | Business & Operation Readiness | 5.31 | 28.33 | Green | GREEN |  |  |
| 2857 | 1.9.2.7.3.7 | Non-SIT LDSO Service Activation Implementation Completed (M) | milestone | 0d | 2025-02-27 | 2025-02-27 |  | 2025-02-27 | 2025-02-27 | 0d | 735d |  | finish no earlier than 2025-02-27 | Business & Operation Readiness | 5.31 | 29.71 | Green | GREEN |  |  |

Notes:
- 2847: Action: 12/8/24: Emailed helix to clarify what needs to go in the prep section and if hypercare is required

| ID | WBS | Task | Type | Duration | Start | Finish | Predecessors | Baseline start | Baseline finish | Baseline duration | Baseline 1 start | Baseline 1 finish | Total slack | Free slack | Constraint | Baseline cost | Text9 | Update Version | Responsible | Task Status | Sched Status | RAG | Involved | MHHS Resource Name | MHHS Programme Phase | Artefact ID | Action |
| --- | --- | --- | --- | --- | --- | --- | --- | --- | --- | --- | --- | --- | --- | --- | --- | --- | --- | --- | --- | --- | --- | --- | --- | --- | --- | --- | --- |
| 2858 | 1.9.2.7.4 | **Non-SIT LDSO Service Activation Implementation MDD** |  | 14d | 2025-02-27 | 2025-03-18 |  | 2025-02-27 | 2025-03-18 | 0d |  |  | 722d |  |  |  | Business & Operation Readiness | 5.31 |  |  |  |  |  |  |  |  |  |
| 2859 | 1.9.2.7.4.1 | MDD Manual Load |  | 7d | 2025-02-27 | 2025-03-07 |  | 2025-02-27 | 2025-03-07 | 0d |  |  | 729d |  | finish no earlier than 2025-03-07 |  | Business & Operation Readiness | 5.31 | PMP | 29.33 | Green | GREEN |  |  |  |  |  |
| 2860 | 1.9.2.7.4.2 | MDD Update |  | 8d | 2025-03-07 | 2025-03-18 |  | 2025-03-07 | 2025-03-18 | 0d |  |  | 722d |  | finish no earlier than 2025-03-18 |  | Business & Operation Readiness | 5.31 | PMP | 37.33 | Green | GREEN |  |  |  |  |  |
| 2861 | 1.9.2.7.4.3 | Non-SIT LDSO Service Activation Implementation MDD Complete (M) | milestone | 0d | 2025-03-18 | 2025-03-18 |  | 2025-03-18 | 2025-03-18 | 0d |  |  | 722d |  | finish no earlier than 2025-03-18 |  | Business & Operation Readiness | 5.31 |  | 48.71 | Green | GREEN |  |  |  |  |  |
| 2862 | 1.9.2.7.5 | **Non-SIT LDSO Service Activation Hypercare** |  | 18d | 2025-02-24 | 2025-03-19 |  | 2025-02-24 | 2025-03-19 | 0d |  |  | 721d |  |  |  | Business & Operation Readiness | 5.31 |  |  |  |  |  |  |  |  |  |
| 2863 | 1.9.2.7.5.1 | **Non-SIT LDSO Service Activation Hypercare Support** |  | 18d | 2025-02-24 | 2025-03-19 |  | 2025-02-24 | 2025-03-19 | 0d |  |  | 721d |  |  |  | Business & Operation Readiness | 5.31 |  |  |  |  |  |  |  |  |  |
| 2864 | 1.9.2.7.5.1.1 | Service& Process Monitoring |  | 18d | 2025-02-24 | 2025-03-19 |  | 2025-02-24 | 2025-03-19 | 0d |  |  | 721d |  | finish no earlier than 2025-03-19 |  | Business & Operation Readiness | 5.31 |  | 26.33 | Green | GREEN |  |  |  |  |  |
| 2865 | 1.9.2.7.5.1.2 | Daily Reporting |  | 18d | 2025-02-24 | 2025-03-19 |  | 2025-02-24 | 2025-03-19 | 0d |  |  | 721d |  | finish no earlier than 2025-03-19 |  | Business & Operation Readiness | 5.31 |  | 26.33 | Green | GREEN |  |  |  |  |  |
| 2866 | 1.9.2.7.5.1.3 | Issue Management |  | 18d | 2025-02-24 | 2025-03-19 |  | 2025-02-24 | 2025-03-19 | 0d |  |  | 721d |  | finish no earlier than 2025-03-19 |  | Business & Operation Readiness | 5.31 |  | 26.33 | Green | GREEN |  |  |  |  |  |
| 2867 | 1.9.2.7.5.1.4 | SA Hypercare Close Down Activities |  | 18d | 2025-02-24 | 2025-03-19 |  | 2025-02-24 | 2025-03-19 | 0d |  |  | 721d |  | finish no earlier than 2025-03-19 |  | Business & Operation Readiness | 5.31 |  | 26.33 | Green | GREEN |  |  |  |  |  |
| 2868 | 1.9.2.7.5.1.5 | Handover to MHHSP |  | 3d | 2025-03-14 | 2025-03-18 |  | 2025-03-14 | 2025-03-18 | 0d |  |  | 722d |  | finish no earlier than 2025-03-18 |  | Business & Operation Readiness | 5.31 |  | 44.33 | Green | GREEN | MHHSP |  |  |  |  |
| 2869 | 1.9.2.7.5.1.6 | Non-SIT LDSO Service Activation Hypercare Complete (M) | milestone | 0d | 2025-03-18 | 2025-03-18 |  | 2025-03-18 | 2025-03-18 | 0d |  |  | 722d |  | finish no earlier than 2025-03-18 |  | Business & Operation Readiness | 5.31 |  | 48.71 | Green | GREEN |  |  |  |  |  |
| 2870 | 1.9.3 | **Implement Early Life Support Plan** |  | 55d | 2025-07-07 | 2025-09-19 |  | 2025-07-07 | 2025-09-19 | 45d | 2025-01-06 | 2025-02-28 | 589d |  |  | -0 | Business & Operation Readiness | 5.0 | N/A |  |  |  | N/A | N/A | Business & Operational Readiness |  |  |
| 2871 | 1.9.3.1 | Implement Early Life Support Plan |  | 55d | 2025-07-07 | 2025-09-19 |  | 2025-07-07 | 2025-09-19 | 45d | 2025-02-28 | 2025-02-28 | 589d |  | start no earlier than 2025-07-07 |  | Business & Operation Readiness | 5.23 | SI Transition | 159.33 | Green | GREEN | SI Transition,CPT | Matthew Breen | Business & Operational Readiness | MHHS-ART095 |  |
| 2872 | 1.9.4 | **Business Continuity and Disaster Recovery Plan** |  | 40d | 2025-07-31 | 2025-09-24 |  | 2025-07-31 | 2025-09-24 | 40d | 2025-01-13 | 2025-03-07 | 586d |  |  |  | Business & Operation Readiness | 5.0 | N/A |  |  |  | N/A | N/A | Business & Operational Readiness |  |  |
| 2873 | 1.9.4.1 | Central Parties BCDRs in Place |  | 20d | 2025-07-31 | 2025-08-27 | 2412FS-40d | 2025-07-31 | 2025-08-27 | 20d | 2025-01-13 | 2025-02-07 | 586d | 0d |  |  | Business & Operation Readiness | 5.0 | SI Design | 183.33 | Green | GREEN |  | MHHS Programme | Business & Operational Readiness |  |  |
| 2874 | 1.9.4.2 | Risk Based Assurance of Cental Party BCDRs |  | 20d | 2025-08-28 | 2025-09-24 | 2873 | 2025-08-28 | 2025-09-24 | 20d | 2025-02-10 | 2025-03-07 | 586d |  |  |  | Business & Operation Readiness | 5.0 | PP | 211.33 | Green | GREEN | SI Design | MHHS Programme | Business & Operational Readiness |  |  |
| 2875 | 1.9.5 | **Training and Support Materials** |  | 39d | 2025-08-21 | 2025-10-14 |  | 2025-08-21 | 2025-10-14 | 40d | 2025-02-03 | 2025-03-28 | 572d |  |  |  | Business & Operation Readiness | 5.0 | N/A |  |  |  | N/A | N/A | Business & Operational Readiness |  | 10/5: To be reworked with better clarity (LH) |
| 2876 | 1.9.5.1 | Develop document |  | 20d | 2025-08-21 | 2025-09-17 | 2662FS-45d | 2025-08-21 | 2025-09-17 | 20d | 2025-02-03 | 2025-02-28 | 572d | 0d |  |  | Business & Operation Readiness | 5.0 | SI Migration | 204.33 | Green | GREEN | CPT | PPC | Business & Operational Readiness |  |  |
| 2877 | 1.9.5.2 | Document review and update |  | 19d | 2025-09-18 | 2025-10-14 | 2876 | 2025-09-18 | 2025-10-14 | 20d | 2025-03-03 | 2025-03-28 | 572d | 0d |  |  | Business & Operation Readiness | 5.0 | SI Migration | 232.33 | Green | GREEN | PMO,CPT,IPA,PP | PPC | Business & Operational Readiness |  |  |
| 2878 | 1.9.5.3 | Training and Support Materials approved | milestone | 0d | 2025-10-14 | 2025-10-14 | 2877 | 2025-10-14 | 2025-10-14 | 0d | 2025-03-28 | 2025-03-28 | 572d |  |  |  | Business & Operation Readiness | 5.0 | SI Migration | 258.71 | Green | GREEN | PMO,CPT | PPC | Business & Operational Readiness | MHHS-ART118 |  |
| 2879 | 1.9.6 | **PP Business Change** |  | 129d | 2025-02-03 | 2025-07-31 |  | 2025-02-03 | 2025-07-31 | 129d | 2025-02-03 | 2025-07-31 | 625d |  |  |  | Business & Operation Readiness | 5.0 | N/A | M11 |  |  | N/A | N/A | Business & Operational Readiness |  | 10/5: Review with PPC (LH) |
| 2880 | 1.9.6.1 | Plan stakeholder management |  | 129d | 2025-02-03 | 2025-07-31 |  | 2025-02-03 | 2025-07-31 | 129d | 2025-02-03 | 2025-07-31 | 625d |  | start no earlier than 2025-02-03 |  | Business & Operation Readiness | 5.0 | PP | 5.33 | Green | GREEN | PPC | PPC | Business & Operational Readiness |  |  |
| 2881 | 1.9.6.2 | Manage stakeholders |  | 129d | 2025-02-03 | 2025-07-31 |  | 2025-02-03 | 2025-07-31 | 129d | 2025-02-03 | 2025-07-31 | 625d |  | start no earlier than 2025-02-03 |  | Business & Operation Readiness | 5.0 | PP | 5.33 | Green | GREEN | PPC | PPC | Business & Operational Readiness |  |  |
| 2882 | 1.9.6.3 | Develop & implement changes to KPIs, organisation & people management |  | 129d | 2025-02-03 | 2025-07-31 |  | 2025-02-03 | 2025-07-31 | 129d | 2025-02-03 | 2025-07-31 | 625d |  | start no earlier than 2025-02-03 |  | Business & Operation Readiness | 5.0 | PP | 5.33 | Green | GREEN | PPC | PPC | Business & Operational Readiness |  |  |
| 2883 | 1.9.6.4 | Develop & test changes to business processes |  | 129d | 2025-02-03 | 2025-07-31 |  | 2025-02-03 | 2025-07-31 | 129d | 2025-02-03 | 2025-07-31 | 625d |  | start no earlier than 2025-02-03 |  | Business & Operation Readiness | 5.0 | PP | 5.33 | Green | GREEN | PPC | PPC | Business & Operational Readiness |  |  |
| 2884 | 1.9.6.5 | Develop and deliver training |  | 129d | 2025-02-03 | 2025-07-31 |  | 2025-02-03 | 2025-07-31 | 129d | 2025-02-03 | 2025-07-31 | 625d |  | start no earlier than 2025-02-03 |  | Business & Operation Readiness | 5.0 | PP | 5.33 | Green | GREEN | PPC | PPC | Business & Operational Readiness |  |  |
| 2885 | 1.9.6.6 | Programme support for PP Business Change activities |  | 129d | 2025-02-03 | 2025-07-31 |  | 2025-02-03 | 2025-07-31 | 129d | 2025-02-03 | 2025-07-31 | 625d |  | start no earlier than 2025-02-03 |  | Business & Operation Readiness | 5.0 | PPC | 5.33 | Green | GREEN | PP | PPC | Business & Operational Readiness |  |  |

| ID | WBS | Task | Type | Duration | Start | Finish | Predecessors | Baseline start | Baseline finish | Baseline duration | Baseline 1 start | Baseline 1 finish | Total slack | Free slack | Baseline cost | Responsible | Involved | Text9 | Task Status | Update Version | MHHS Resource Name | MHHS Programme Phase | Sched Status | RAG | Milestone ID | Text29 | Tier | Future RAG | Artefact ID |
| --- | --- | --- | --- | --- | --- | --- | --- | --- | --- | --- | --- | --- | --- | --- | --- | --- | --- | --- | --- | --- | --- | --- | --- | --- | --- | --- | --- | --- | --- |
| 2886 | 1.9.7 | **Transition to New Settlement Timetable (M16)** |  | 566d | 2025-10-22 | 2027-12-23 |  | 2025-10-22 | 2027-12-23 | 560d |  |  | 0d |  | -0 | N/A | N/A | Business & Operation Readiness | -434.67 | 5.15 | N/A | Business & Operational Readiness |  |  |  |  |  |  |  |
| 2887 | 1.9.7.1 | Elexon to produce Settlement Calendar for Settlement Year 2025/2026 | milestone | 0d | 2025-10-22 | 2025-10-22 | 2660 | 2025-10-22 | 2025-10-22 | 0d |  |  | 5d | 0d |  | PP | PP, Code Bodies | Business & Operation Readiness | 266.71 | 5.15 | Matthew Breen | Business & Operational Readiness | Green | GREEN |  |  |  |  |  |
| 2888 | 1.9.7.2 | Elexon monitor settlement data of migrated MPANs |  | 436d | 2025-10-23 | 2027-06-24 | 2887 | 2025-10-23 | 2027-06-24 | 436d |  |  | 6d |  |  | PP | PP, Code Bodies | Business & Operation Readiness | 267.33 | 5.15 | Matthew Breen | Business & Operational Readiness | Green | GREEN |  |  |  |  |  |
| 2889 | 1.9.7.3 | M16 Checkpoint 1 | milestone | 0d | 2026-06-25 | 2026-06-25 | 2887FS+176d | 2026-06-25 | 2026-06-25 | 0d |  |  | 5d | 0d |  | PP | PP, Code Bodies | Business & Operation Readiness | 512.71 | 5.15 | Matthew Breen | Business & Operational Readiness | Green | GREEN |  |  |  |  |  |
| 2890 | 1.9.7.4 | Confirm if M16 date retained as 07/12/2026 | milestone | 0d | 2026-07-23 | 2026-07-23 | 2889FS+20d | 2026-07-23 | 2026-07-23 | 0d |  |  | 5d | 0d |  | CPT | PP | Business & Operation Readiness | 540.71 | 5.15 | Matthew Breen | Business & Operational Readiness | Green | GREEN |  |  |  |  |  |
| 2891 | 1.9.7.5 | Readiness assessment of participants' readiness to transition to new Settlement Timetable | milestone | 0d | 2026-08-20 | 2026-08-20 | 2890FS+20d | 2026-08-20 | 2026-08-20 | 0d |  |  | 5d | 0d |  | CPT | PP | Business & Operation Readiness | 568.71 | 5.15 | Matthew Breen | Business & Operational Readiness | Green | GREEN |  |  |  |  |  |
| 2892 | 1.9.7.6 | Elexon to produce Settlement Calendar for Settlement Year 2026 up until day before M16 cutover | milestone | 0d | 2026-10-19 | 2026-10-19 | 2891FS+42d | 2026-10-19 | 2026-10-19 | 0d |  |  | 5d | 0d |  | PP | PP, Code Bodies | Business & Operation Readiness | 628.71 | 5.15 | Matthew Breen | Business & Operational Readiness | Green | GREEN |  |  |  |  |  |
| 2893 | 1.9.7.7 | M16 Checkpoint 2 | milestone | 0d | 2027-04-02 | 2027-04-02 | 2892FS+119d | 2027-04-02 | 2027-04-02 | 0d |  |  | 5d | 0d |  | PP | PP, Code Bodies | Business & Operation Readiness | 793.71 | 5.15 | Matthew Breen | Business & Operational Readiness | Green | GREEN |  |  |  |  |  |
| 2894 | 1.9.7.8 | Readiness assessment of participants' readiness to transition to new Settlement Timetable | milestone | 0d | 2027-04-19 | 2027-04-19 | 2893FS+11d | 2027-04-19 | 2027-04-19 | 0d |  |  | 5d | 0d |  | CPT | PP | Business & Operation Readiness | 810.71 | 5.15 | Matthew Breen | Business & Operational Readiness | Green | GREEN |  |  |  |  |  |
| 2895 | 1.9.7.9 | Confirm M16 Date | milestone | 0d | 2027-04-30 | 2027-04-30 | 2894FS+9d | 2027-04-30 | 2027-04-30 | 1d |  |  | 5d | 0d |  | CPT | Code Bodies,CPT,PP,SRO | Business & Operation Readiness | 821.71 | 5.3 | Matthew Breen | Business & Operational Readiness | Green | GREEN | T2-EL-0100 | PSG/BSC PAB | T2 |  |  |
| 2896 | 1.9.7.10 | Raise fast track change to ISD (November publish) | milestone | 0d | 2027-04-30 | 2027-04-30 | 2895 | 2027-04-30 | 2027-04-30 | 0d |  |  | 45d |  |  | PP | PP,CPT,Code Bodies | Business & Operation Readiness | 821.71 | 5.15 | Matthew Breen | Business & Operational Readiness | Green | GREEN |  |  |  |  |  |
| 2897 | 1.9.7.11 | **M16 Approval Window** |  | 129d | 2027-06-25 | 2027-12-23 |  | 2027-06-25 | 2027-12-23 | 124d | 2026-12-07 | 2027-05-24 | 0d |  |  | N/A | N/A | Business & Operation Readiness | 966.71 | 5.0 | N/A | Business & Operational Readiness | Green | GREEN |  |  |  |  |  |
| 2898 | 1.9.7.11.1 | Panel approval that M16 criteria met | milestone | 0d | 2027-06-25 | 2027-06-25 | 2895FS+40d | 2027-06-25 | 2027-06-25 | 0d | 2026-12-07 | 2026-12-07 | 5d |  |  | Panel | Code Bodies,CPT,PP,SRO | Business & Operation Readiness | 877.71 | 5.0 | Matthew Breen | Business & Operational Readiness | Green | GREEN |  |  |  |  |  |
| 2899 | 1.9.7.11.2 | Cut over to new settlement timetable (M16) | milestone | 0d | 2027-07-02 | 2027-07-02 | 2898, 2664FS+40d, 2888, 2896, 2574 | 2027-07-02 | 2027-07-02 | 0d | 2026-12-07 | 2026-12-07 | 0d |  |  | CPT | PP | Business & Operation Readiness | 884.71 | 5.0 | Matthew Breen | Business & Operational Readiness | Green | GREEN | T1-EL-1000 | PSG | T1 |  |  |
| 2900 | 1.9.7.11.3 | Maximum 6-month window for approval of M16 |  | 124d | 2027-07-05 | 2027-12-23 | 2899 | 2027-07-05 | 2027-12-23 | 124d | 2026-12-08 | 2027-05-24 | 0d |  |  | CPT |  | Business & Operation Readiness | 887.33 | 5.0 | Matthew Breen | Business & Operational Readiness | Green | GREEN |  |  |  |  |  |
| 2901 | 1.9.7.11.4 | Cut over to new settlement timetable (M16*) - Late Exit | milestone | 0d | 2027-12-23 | 2027-12-23 | 2900 | 2027-12-23 | 2027-12-23 | 0d | 2027-05-24 | 2027-05-24 | 0d |  |  | CPT | PP | Business & Operation Readiness | 1058.71 | 5.0 | Matthew Breen | Business & Operational Readiness | Green | GREEN | T1-EL-2000 | PSG | T1 |  |  |
| 2902 | 1.10 | **EARLY LIVE RUNNING** |  | 45d | 2027-05-10 | 2027-07-09 |  | 2027-05-10 | 2027-07-09 | 889d | 2024-01-02 | 2027-05-28 | 119d |  |  | N/A | N/A | Business & Operation Readiness |  |  | N/A | Early Live Running |  |  |  |  |  | 1 Nov 2025 - 30 Apr 2026 |  |
| 2903 | 1.10.1 | **Early Live Running Stabilisation Period** |  | 45d | 2027-05-10 | 2027-07-09 |  | 2027-05-10 | 2027-07-09 | 45d | 2026-10-06 | 2026-12-07 | 119d |  |  | N/A | N/A | Business & Operation Readiness |  | 5.0 | N/A | Early Live Running |  |  |  |  |  |  |  |
| 2904 | 1.10.1.1 | Manage Early Live Running stabilisation period |  | 45d | 2027-05-10 | 2027-07-09 | 2664 | 2027-05-10 | 2027-07-09 | 45d | 2026-10-06 | 2026-12-07 | 119d | 0d |  | Code Bodies | PP | Business & Operation Readiness | 831.33 | 5.0 | Matthew Breen | Early Live Running | Green | GREEN |  |  |  |  |  |
| 2905 | 1.10.1.2 | Monitor Early Live Running stabilisation period |  | 45d | 2027-05-10 | 2027-07-09 | 2904SS | 2027-05-10 | 2027-07-09 | 45d | 2026-10-06 | 2026-12-07 | 119d |  |  | SI Migration | Code Bodies,PP | Business & Operation Readiness | 831.33 | 5.0 | Matthew Breen | Early Live Running | Green | GREEN |  |  |  |  |  |
| 2906 | 1.11 | **PROGRAMME CLOSURE** |  | 80d | 2027-03-08 | 2027-06-25 |  | 2027-03-08 | 2027-06-25 | 85d | 2026-08-04 | 2026-11-30 | 129d |  |  | N/A | N/A | Programme Closure |  |  | N/A | Programme Closure |  |  |  |  |  |  |  |
| 2907 | 1.11.1 | **Handover Pack** |  | 80d | 2027-03-08 | 2027-06-25 |  | 2027-03-08 | 2027-06-25 | 85d | 2026-08-04 | 2026-11-30 | 129d |  |  | N/A | N/A | Programme Closure |  | 5.0 | N/A | Programme Closure |  |  |  |  |  |  |  |
| 2908 | 1.11.1.1 | **Draft Handover Pack (for M15)** |  | 40d | 2027-03-08 | 2027-04-30 |  | 2027-03-08 | 2027-04-30 | 40d | 2026-08-04 | 2026-09-28 | 169d |  |  | N/A | N/A | Programme Closure |  | 5.0 | N/A | Programme Closure |  |  |  |  |  |  |  |
| 2909 | 1.11.1.1.1 | Develop document |  | 20d | 2027-03-08 | 2027-04-02 | 2664FS-45d | 2027-03-08 | 2027-04-02 | 20d | 2026-08-04 | 2026-08-31 | 169d | 0d |  | PMO | CPT | Programme Closure | 768.33 | 5.0 |  | Programme Closure | Green | GREEN |  |  |  |  |  |
| 2910 | 1.11.1.1.2 | Document review and update |  | 20d | 2027-04-05 | 2027-04-30 | 2909 | 2027-04-05 | 2027-04-30 | 20d | 2026-09-01 | 2026-09-28 | 169d | 0d |  | SRO | PMO,CPT,IPA,PP | Programme Closure | 796.33 | 5.0 |  | Programme Closure | Green | GREEN |  |  |  |  |  |
| 2911 | 1.11.1.1.3 | Draft Handover Pack approved | milestone | 0d | 2027-04-30 | 2027-04-30 | 2910 | 2027-04-30 | 2027-04-30 | 0d | 2026-09-28 | 2026-09-28 | 169d |  |  | SRO | PMO,CPT | Programme Closure | 821.71 | 5.0 |  | Programme Closure | Green | GREEN |  |  |  |  | MHHS-ART126 |

| ID | WBS | Task | Type | Duration | Start | Finish | Predecessors | Baseline start | Baseline finish | Baseline duration | Baseline 1 start | Baseline 1 finish | Total slack | Free slack | Responsible | Involved | Text9 | Update Version | MHHS Resource Name | MHHS Programme Phase | Task Status | Sched Status | RAG | Artefact ID | Milestone ID | Text29 | Tier |
| --- | --- | --- | --- | --- | --- | --- | --- | --- | --- | --- | --- | --- | --- | --- | --- | --- | --- | --- | --- | --- | --- | --- | --- | --- | --- | --- | --- |
| 2912 | 1.11.1.2 | **Master Handover Pack (for M16)** |  | 40d | 2027-05-03 | 2027-06-25 |  | 2027-05-03 | 2027-06-25 | 40d | 2026-10-06 | 2026-11-30 | 129d |  | N/A | N/A | Programme Closure | 5.0 | N/A | Programme Closure |  |  |  |  |  |  |  |
| 2913 | 1.11.1.2.1 | Update document |  | 20d | 2027-05-03 | 2027-05-28 | 2899FS-45d | 2027-05-03 | 2027-05-28 | 20d | 2026-10-06 | 2026-11-02 | 129d | 0d | PMO | CPT | Programme Closure | 5.0 |  | Programme Closure | 824.33 | Green | GREEN |  |  |  |  |
| 2914 | 1.11.1.2.2 | Document review and update |  | 20d | 2027-05-31 | 2027-06-25 | 2913 | 2027-05-31 | 2027-06-25 | 20d | 2026-11-03 | 2026-11-30 | 129d | 0d | SRO | PMO,CPT,IPA,PP | Programme Closure | 5.0 |  | Programme Closure | 852.33 | Green | GREEN |  |  |  |  |
| 2915 | 1.11.1.2.3 | Master Handover Pack approved | milestone | 0d | 2027-06-25 | 2027-06-25 | 2914 | 2027-06-25 | 2027-06-25 | 0d | 2026-11-30 | 2026-11-30 | 129d |  | SRO | PMO,CPT | Programme Closure | 5.0 |  | Programme Closure | 877.71 | Green | GREEN | MHHS-ART126 |  |  |  |
| 2916 | 1.11.2 | **Programme Lessons Learned** |  | 40d | 2027-03-08 | 2027-04-30 |  | 2027-03-08 | 2027-04-30 | 40d | 2026-08-04 | 2026-09-28 | 169d |  | N/A | N/A | Programme Closure | 5.0 | N/A | Programme Closure |  |  |  |  |  |  |  |
| 2917 | 1.11.2.1 | Develop document |  | 20d | 2027-03-08 | 2027-04-02 | 2664FS-45d | 2027-03-08 | 2027-04-02 | 20d | 2026-08-04 | 2026-08-31 | 169d | 0d | PMO | CPT | Programme Closure | 5.0 |  | Programme Closure | 768.33 | Green | GREEN |  |  |  |  |
| 2918 | 1.11.2.2 | Document review and update |  | 20d | 2027-04-05 | 2027-04-30 | 2917 | 2027-04-05 | 2027-04-30 | 20d | 2026-09-01 | 2026-09-28 | 169d | 0d | SRO | PMO,CPT,IPA | Programme Closure | 5.0 |  | Programme Closure | 796.33 | Green | GREEN |  |  |  |  |
| 2919 | 1.11.2.3 | Programme Lessons Learned document approved | milestone | 0d | 2027-04-30 | 2027-04-30 | 2918 | 2027-04-30 | 2027-04-30 | 0d | 2026-09-28 | 2026-09-28 | 169d |  | SRO | PMO,CPT | Programme Closure | 5.0 |  | Programme Closure | 821.71 | Green | GREEN | MHHS-ART131 |  |  |  |
| 2920 | 1.11.3 | **Programme Closure Report** |  | 40d | 2027-03-08 | 2027-04-30 |  | 2027-03-08 | 2027-04-30 | 40d | 2026-08-04 | 2026-09-28 | 169d |  | N/A | N/A | Programme Closure | 5.0 | N/A | Programme Closure |  |  |  |  |  |  |  |
| 2921 | 1.11.3.1 | Develop document |  | 20d | 2027-03-08 | 2027-04-02 | 2664FS-45d | 2027-03-08 | 2027-04-02 | 20d | 2026-08-04 | 2026-08-31 | 169d | 0d | PMO | CPT | Programme Closure | 5.0 |  | Programme Closure | 768.33 | Green | GREEN |  |  |  |  |
| 2922 | 1.11.3.2 | Document review and update |  | 20d | 2027-04-05 | 2027-04-30 | 2921 | 2027-04-05 | 2027-04-30 | 20d | 2026-09-01 | 2026-09-28 | 169d | 0d | Ofgem | PMO,CPT,IPA,SRO | Programme Closure | 5.0 |  | Programme Closure | 796.33 | Green | GREEN |  |  |  |  |
| 2923 | 1.11.3.3 | Programme Closure Report approved | milestone | 0d | 2027-04-30 | 2027-04-30 | 2922 | 2027-04-30 | 2027-04-30 | 0d | 2026-09-28 | 2026-09-28 | 169d |  | Ofgem | PMO,CPT,IPA,SRO | Programme Closure | 5.0 |  | Programme Closure | 821.71 | Green | GREEN | MHHS-ART130 |  |  |  |
| 2924 | 1.11.4 | **Benefit Realisation Report** |  | 45d | 2027-03-08 | 2027-05-07 |  | 2027-03-08 | 2027-05-07 | 45d | 2026-08-04 | 2026-10-05 | 164d |  | N/A | N/A | Programme Closure | 5.0 | N/A | Programme Closure |  |  |  |  |  |  |  |
| 2925 | 1.11.4.1 | Develop document |  | 20d | 2027-03-08 | 2027-04-02 | 2664FS-45d | 2027-03-08 | 2027-04-02 | 20d | 2026-08-04 | 2026-08-31 | 164d | 0d | PMO | CPT | Programme Closure | 5.0 |  | Programme Closure | 768.33 | Green | GREEN |  |  |  |  |
| 2926 | 1.11.4.2 | Document review and update |  | 20d | 2027-04-05 | 2027-04-30 | 2925 | 2027-04-05 | 2027-04-30 | 20d | 2026-09-01 | 2026-09-28 | 164d | 0d | PP | PMO,CPT,IPA,SRO | Programme Closure | 5.0 |  | Programme Closure | 796.33 | Green | GREEN |  |  |  |  |
| 2927 | 1.11.4.3 | Benefit Realisation Report approved | milestone | 0d | 2027-05-07 | 2027-05-07 | 2926FS+5d | 2027-05-07 | 2027-05-07 | 0d | 2026-10-05 | 2026-10-05 | 164d |  | PMO | CPT,PP,IPA,SRO | Programme Closure | 5.0 |  | Programme Closure | 828.71 | Green | GREEN | MHHS-ART124 | T3-PC-0010 | PSG | T3 |
| 2928 | 1.11.5 | **Operating Model Gap Review with recommendations** |  | 45d | 2027-03-08 | 2027-05-07 |  | 2027-03-08 | 2027-05-07 | 45d | 2026-08-04 | 2026-10-05 | 164d |  | N/A | N/A | Programme Closure | 5.0 | N/A | Programme Closure |  |  |  |  |  |  |  |
| 2929 | 1.11.5.1 | Develop document |  | 20d | 2027-03-08 | 2027-04-02 | 2664FS-45d | 2027-03-08 | 2027-04-02 | 20d | 2026-08-04 | 2026-08-31 | 164d | 0d | PMO | CPT | Programme Closure | 5.0 |  | Programme Closure | 768.33 | Green | GREEN |  |  |  |  |
| 2930 | 1.11.5.2 | Document review and update |  | 20d | 2027-04-05 | 2027-04-30 | 2929 | 2027-04-05 | 2027-04-30 | 20d | 2026-09-01 | 2026-09-28 | 164d | 0d | PP | PMO,CPT,IPA,SRO | Programme Closure | 5.0 |  | Programme Closure | 796.33 | Green | GREEN |  |  |  |  |
| 2931 | 1.11.5.3 | Operating Model Gap Review with recommendations approved | milestone | 0d | 2027-05-07 | 2027-05-07 | 2930FS+5d | 2027-05-07 | 2027-05-07 | 0d | 2026-10-05 | 2026-10-05 | 164d |  | Paul Pettitt | CPT,PP,IPA,SRO | Programme Closure | 5.0 | Paul Pettitt | Programme Closure | 828.71 | Green | GREEN | MHHS-ART128 | T3-PC-0020 | DAG | T3 |
| 2932 | 1.11.6 | **Post-Implementation Review** |  | 45d | 2027-03-08 | 2027-05-07 |  | 2027-03-08 | 2027-05-07 | 45d | 2026-08-04 | 2026-10-05 | 164d |  | N/A | N/A | Programme Closure | 5.0 | N/A | Programme Closure |  |  |  |  |  |  |  |
| 2933 | 1.11.6.1 | Develop document |  | 20d | 2027-03-08 | 2027-04-02 | 2664FS-45d | 2027-03-08 | 2027-04-02 | 20d | 2026-08-04 | 2026-08-31 | 164d | 0d | PMO | CPT | Programme Closure | 5.0 |  | Programme Closure | 768.33 | Green | GREEN |  |  |  |  |
| 2934 | 1.11.6.2 | Document review and update |  | 20d | 2027-04-05 | 2027-04-30 | 2933 | 2027-04-05 | 2027-04-30 | 20d | 2026-09-01 | 2026-09-28 | 164d | 0d | PP | PMO,CPT,IPA,SRO | Programme Closure | 5.0 |  | Programme Closure | 796.33 | Green | GREEN |  |  |  |  |
| 2935 | 1.11.6.3 | Post-Implementation Review approved | milestone | 0d | 2027-05-07 | 2027-05-07 | 2934FS+5d | 2027-05-07 | 2027-05-07 | 0d | 2026-10-05 | 2026-10-05 | 164d |  | PMO | CPT,PP,IPA,SRO | Programme Closure | 5.0 |  | Programme Closure | 828.71 | Green | GREEN | MHHS-ART129 | T3-PC-0030 | PSG | T3 |

Notes:
- 2931: Action: 5/2 - PP said ask MB if belonged to him. MB says doesn't sit with him

| ID | WBS | Task | Type | Duration | Start | Finish | Predecessors | Complete | Remaining | Baseline start | Baseline finish | Baseline duration | Baseline 1 start | Baseline 1 finish | Total slack | Free slack | Constraint | Responsible | Involved | Text9 | Update Version | MHHS Resource Name | MHHS Programme Phase | Task Status | Sched Status | RAG | Artefact ID | Milestone ID | Text29 | Tier | Future RAG |
| --- | --- | --- | --- | --- | --- | --- | --- | --- | --- | --- | --- | --- | --- | --- | --- | --- | --- | --- | --- | --- | --- | --- | --- | --- | --- | --- | --- | --- | --- | --- | --- |
| 2936 | 1.11.7 | **Reinforcement Guide** |  | 45d | 2027-03-08 | 2027-05-07 |  |  |  | 2027-03-08 | 2027-05-07 | 45d | 2026-08-04 | 2026-10-05 | 164d |  |  | N/A | N/A | Programme Closure | 5.0 | N/A | Programme Closure |  |  |  |  |  |  |  |  |
| 2937 | 1.11.7.1 | Develop document |  | 20d | 2027-03-08 | 2027-04-02 | 2664FS-45d |  |  | 2027-03-08 | 2027-04-02 | 20d | 2026-08-04 | 2026-08-31 | 164d | 0d |  | PMO | CPT | Programme Closure | 5.0 |  | Programme Closure | 768.33 | Green | GREEN |  |  |  |  |  |
| 2938 | 1.11.7.2 | Document review and update |  | 20d | 2027-04-05 | 2027-04-30 | 2937 |  |  | 2027-04-05 | 2027-04-30 | 20d | 2026-09-01 | 2026-09-28 | 164d | 0d |  | PP | PMO,CPT,IPA,SRO | Programme Closure | 5.0 |  | Programme Closure | 796.33 | Green | GREEN |  |  |  |  |  |
| 2939 | 1.11.7.3 | Reinforcement Guide approved | milestone | 0d | 2027-05-07 | 2027-05-07 | 2938FS+5d |  |  | 2027-05-07 | 2027-05-07 | 0d | 2026-10-05 | 2026-10-05 | 164d |  |  | PMO | CPT,PP,IPA,SRO | Programme Closure | 5.0 |  | Programme Closure | 828.71 | Green | GREEN | MHHS-ART133 | T3-PC-0040 | PSG | T3 |  |
| 2940 | 1.11.8 | **Material and Licenses Transfer** |  | 60d | 2027-04-05 | 2027-06-25 |  |  |  | 2027-04-05 | 2027-06-25 | 60d | 2026-09-08 | 2026-11-30 | 129d |  |  | N/A | N/A | Programme Closure | 5.0 | N/A | Programme Closure |  |  |  |  |  |  |  |  |
| 2941 | 1.11.8.1 | Transfer of Programme material to Elexon and perpetual licenses as appropriate |  | 60d | 2027-04-05 | 2027-06-25 | 2899FF-5d |  |  | 2027-04-05 | 2027-06-25 | 60d | 2026-09-08 | 2026-11-30 | 129d |  |  | PMO | CPT,PP | Programme Closure | 5.0 |  | Programme Closure | 796.33 | Green | GREEN | MHHS-ART139 |  |  |  |  |
| 2942 | 1.12 | **READINESS ASSESSMENTS** |  | 988d | 2023-09-05 A | 2027-06-17 |  | 23% | 764.9d | 2023-09-05 | 2027-06-17 | 849d | 2023-09-11 | 2026-12-04 | 135d |  |  | N/A | N/A | Readiness Assessment |  | N/A | Readiness Assessments |  |  |  |  |  |  |  |  |
| 2943 | 1.12.1 | **Readiness Assessment 3 - Design and Build Progress Check and CP2 Check** |  | 60d | 2023-09-05 A | 2023-11-27 A |  | 100% |  | 2023-09-05 | 2023-11-27 | 50d | 2023-09-11 | 2023-11-17 |  |  |  | N/A | N/A | Readiness Assessment | 5.5 | N/A | Readiness Assessments | M5,M6 |  |  |  |  |  |  |  |
| 2944 | 1.12.1.1 | Launch Readiness Assessment survey | milestone | 0d | 2023-09-05 A | 2023-09-05 A | 1483FS-40d | 100% |  | 2023-09-05 | 2023-09-05 | 0d | 2023-09-11 | 2023-09-11 |  |  |  | PPC |  | Readiness Assessment | 5.5 | PPC | Readiness Assessments |  | Complete | COMPLETE |  |  |  |  |  |
| 2945 | 1.12.1.2 | PPs submit survey responses |  | 15d | 2023-09-05 A | 2023-09-25 A | 2944 | 100% |  | 2023-09-05 | 2023-09-25 | 15d | 2023-09-11 | 2023-09-29 |  |  |  | PP | PPC | Readiness Assessment | 5.5 | PPC | Readiness Assessments |  | Complete | COMPLETE |  |  |  |  |  |
| 2946 | 1.12.1.3 | Analyse survey responses |  | 15d | 2023-09-26 A | 2023-10-16 A | 2945 | 100% |  | 2023-09-26 | 2023-10-16 | 15d | 2023-10-02 | 2023-10-20 |  |  |  | PPC | CPT | Readiness Assessment | 5.5 | PPC | Readiness Assessments |  | Complete | COMPLETE |  |  |  |  |  |
| 2947 | 1.12.1.4 | Conduct deep-dive interviews (sample of PPs) |  | 15d | 2023-09-26 A | 2023-10-16 A | 2945 | 100% |  | 2023-09-26 | 2023-10-16 | 15d | 2023-10-02 | 2023-10-20 |  |  |  | PPC | CPT | Readiness Assessment | 5.5 | PPC | Readiness Assessments |  | Complete | COMPLETE |  |  |  |  |  |
| 2948 | 1.12.1.5 | Produce Readiness Assessment Reports (Overall Report & Individual Participant Reports) |  | 25d | 2023-10-17 A | 2023-11-20 A | 2946, 2947 | 100% |  | 2023-10-17 | 2023-11-20 | 15d | 2023-10-23 | 2023-11-10 |  |  |  | PPC |  | Readiness Assessment | 5.5 | PPC | Readiness Assessments |  | Complete | COMPLETE |  |  |  |  |  |
| 2949 | 1.12.1.6 | Readiness Assessment 3 - Design & Build Checkpoint 1 - Completed (incl. Readiness Assessment Report approval) | milestone | 0d | 2023-11-27 A | 2023-11-27 A | 2948FS+5d | 100% |  | 2023-11-27 | 2023-11-27 | 0d | 2023-11-17 | 2023-11-17 |  |  |  | CPT | PPC | Readiness Assessment | 5.13 | PPC | Readiness Assessments |  | Complete | COMPLETE |  | T2-RA-0200 | PSG | T2 |  |
| 2950 | 1.12.2 | **Readiness Assessment 5 / 6 - Start of Qualification and Participant Readiness for M10 and M11 and CP3/CP4 check** |  | 47d | 2025-04-21 | 2025-06-24 |  |  |  | 2025-04-21 | 2025-06-24 | 49d | 2024-11-12 | 2025-01-17 | 652d |  |  | N/A | N/A | Readiness Assessment | 5.0 | N/A | Readiness Assessments | M11 |  |  |  |  |  |  | D25 - RA6 Readiness Report |
| 2951 | 1.12.2.1 | Launch Readiness Assessment survey | milestone | 0d | 2025-04-21 | 2025-04-21 |  |  |  | 2025-04-21 | 2025-04-21 | 0d | 2024-11-12 | 2024-11-12 | 652d | 0d | start no earlier than 2025-04-21 | PPC |  | Readiness Assessment | 5.0 | PPC | Readiness Assessments | 82.33 | Green | GREEN |  |  |  |  |  |
| 2952 | 1.12.2.2 | PPs submit survey responses |  | 15d | 2025-04-21 | 2025-05-09 | 2951 |  |  | 2025-04-21 | 2025-05-09 | 15d | 2024-11-12 | 2024-12-02 | 652d | 0d |  | PP | PPC | Readiness Assessment | 5.0 | PPC | Readiness Assessments | 82.33 | Green | GREEN |  |  |  |  |  |
| 2953 | 1.12.2.3 | Analyse survey responses |  | 15d | 2025-05-12 | 2025-05-30 | 2952 |  |  | 2025-05-12 | 2025-05-30 | 15d | 2024-12-03 | 2024-12-23 | 652d | 0d |  | PPC | CPT | Readiness Assessment | 5.0 | PPC | Readiness Assessments | 103.33 | Green | GREEN |  |  |  |  |  |
| 2954 | 1.12.2.4 | Conduct deep-dive interviews (sample of PPs) |  | 15d | 2025-05-12 | 2025-05-30 | 2952 |  |  | 2025-05-12 | 2025-05-30 | 15d | 2024-12-03 | 2024-12-23 | 652d | 0d |  | PPC | CPT | Readiness Assessment | 5.0 | PPC | Readiness Assessments | 103.33 | Green | GREEN |  |  |  |  |  |
| 2955 | 1.12.2.5 | Produce Readiness Assessment Reports (Overall Report & Individual Participant Reports) |  | 15d | 2025-06-02 | 2025-06-20 | 2953, 2954 |  |  | 2025-06-02 | 2025-06-20 | 15d | 2024-12-24 | 2025-01-13 | 652d | 0d |  | PPC |  | Readiness Assessment | 5.0 | PPC | Readiness Assessments | 124.33 | Green | GREEN |  |  |  |  |  |
| 2956 | 1.12.2.6 | Readiness Assessment 5 / 6 - Start of Qualification and Participant Readiness for M10 and M11 and CP3/CP4 check (incl. Readiness Assessment Report approval) Completed | milestone | 0d | 2025-06-24 | 2025-06-24 | 2955FS+2d |  |  | 2025-06-24 | 2025-06-24 | 0d | 2025-01-17 | 2025-01-17 | 652d | 0d |  | CPT | PPC | Readiness Assessment | 5.18 | PPC | Readiness Assessments | 146.71 | Green | GREEN |  | T2-RA-0400 | PSG | T2 |  |
| 2957 | 1.12.3 | **Readiness Assessment 7 - Migration Checkpoint** |  | 49d | 2026-01-12 | 2026-03-19 |  |  |  | 2026-01-12 | 2026-03-19 | 49d | 2025-08-04 | 2025-10-09 | 460d |  |  | N/A | N/A | Readiness Assessment | 5.0 | N/A | Readiness Assessments | M14 |  |  |  |  |  |  | D29 - RA8 Readiness Report |
| 2958 | 1.12.3.1 | Launch Readiness Assessment survey | milestone | 0d | 2026-01-12 | 2026-01-12 |  |  |  | 2026-01-12 | 2026-01-12 | 0d | 2025-08-04 | 2025-08-04 | 460d | 0d | start no earlier than 2026-01-12 | PPC |  | Readiness Assessment | 5.0 | PPC | Readiness Assessments | 348.33 | Green | GREEN |  |  |  |  |  |
| 2959 | 1.12.3.2 | PPs submit survey responses |  | 15d | 2026-01-12 | 2026-01-30 | 2958 |  |  | 2026-01-12 | 2026-01-30 | 15d | 2025-08-04 | 2025-08-22 | 460d | 0d |  | PP | PPC | Readiness Assessment | 5.0 | PPC | Readiness Assessments | 348.33 | Green | GREEN |  |  |  |  |  |
| 2960 | 1.12.3.3 | Analyse survey responses |  | 15d | 2026-02-02 | 2026-02-20 | 2959 |  |  | 2026-02-02 | 2026-02-20 | 15d | 2025-08-25 | 2025-09-12 | 460d | 0d |  | PPC | CPT | Readiness Assessment | 5.0 | PPC | Readiness Assessments | 369.33 | Green | GREEN |  |  |  |  |  |
| 2961 | 1.12.3.4 | Conduct deep-dive interviews (sample of PPs) |  | 15d | 2026-02-02 | 2026-02-20 | 2959 |  |  | 2026-02-02 | 2026-02-20 | 15d | 2025-08-25 | 2025-09-12 | 460d | 0d |  | PPC | CPT | Readiness Assessment | 5.0 | PPC | Readiness Assessments | 369.33 | Green | GREEN |  |  |  |  |  |
| 2962 | 1.12.3.5 | Produce Readiness Assessment Reports (Overall Report & Individual Participant Reports) |  | 15d | 2026-02-23 | 2026-03-13 | 2960, 2961 |  |  | 2026-02-23 | 2026-03-13 | 15d | 2025-09-15 | 2025-10-03 | 460d | 0d |  | PPC |  | Readiness Assessment | 5.0 | PPC | Readiness Assessments | 390.33 | Green | GREEN |  |  |  |  |  |
| 2963 | 1.12.3.6 | Readiness Assessment 7 - Migration Checkpoint - Completed (incl. Readiness Assessment Report approval) | milestone | 0d | 2026-03-19 | 2026-03-19 | 2962FS+4d |  |  | 2026-03-19 | 2026-03-19 | 0d | 2025-10-09 | 2025-10-09 | 460d | 0d |  | CPT | PPC | Readiness Assessment | 5.0 | PPC | Readiness Assessments | 414.71 | Green | GREEN |  | T2-RA-0600 | PSG | T2 |  |

| ID | WBS | Task | Type | Duration | Start | Finish | Predecessors | Complete | Remaining | Baseline start | Baseline finish | Baseline duration | Baseline 1 start | Baseline 1 finish | Total slack | Free slack | Constraint | Responsible | Involved | Future RAG | Text9 | Task Status | Update Version | MHHS Resource Name | MHHS Programme Phase | Sched Status | RAG | Milestone ID | Text29 | Tier |
| --- | --- | --- | --- | --- | --- | --- | --- | --- | --- | --- | --- | --- | --- | --- | --- | --- | --- | --- | --- | --- | --- | --- | --- | --- | --- | --- | --- | --- | --- | --- |
| 2964 | 1.12.4 | **Readiness Assessment 8 - Ready to Accept New MPANs** |  | 49d | 2026-08-06 | 2026-10-13 |  |  |  | 2026-08-06 | 2026-10-13 | 49d | 2026-01-06 | 2026-03-13 | 312d |  |  | N/A | N/A | D29 - RA8 Readiness Report | Readiness Assessment | M14 | 5.0 | N/A | Readiness Assessments |  |  |  |  |  |
| 2965 | 1.12.4.1 | Launch Readiness Assessment survey | milestone | 0d | 2026-08-06 | 2026-08-06 | 2277FS-60d |  |  | 2026-08-06 | 2026-08-06 | 0d | 2026-01-06 | 2026-01-06 | 312d | 0d |  | PPC |  |  | Readiness Assessment | 554.33 | 5.0 | PPC | Readiness Assessments | Green | GREEN |  |  |  |
| 2966 | 1.12.4.2 | PPs submit survey responses |  | 15d | 2026-08-06 | 2026-08-26 | 2965 |  |  | 2026-08-06 | 2026-08-26 | 15d | 2026-01-06 | 2026-01-26 | 312d | 0d |  | PP | PPC |  | Readiness Assessment | 554.33 | 5.0 | PPC | Readiness Assessments | Green | GREEN |  |  |  |
| 2967 | 1.12.4.3 | Analyse survey responses |  | 15d | 2026-08-27 | 2026-09-16 | 2966 |  |  | 2026-08-27 | 2026-09-16 | 15d | 2026-01-27 | 2026-02-16 | 312d | 0d |  | PPC | CPT |  | Readiness Assessment | 575.33 | 5.0 | PPC | Readiness Assessments | Green | GREEN |  |  |  |
| 2968 | 1.12.4.4 | Conduct deep-dive interviews (sample of PPs) |  | 15d | 2026-08-27 | 2026-09-16 | 2966 |  |  | 2026-08-27 | 2026-09-16 | 15d | 2026-01-27 | 2026-02-16 | 312d | 0d |  | PPC | CPT |  | Readiness Assessment | 575.33 | 5.0 | PPC | Readiness Assessments | Green | GREEN |  |  |  |
| 2969 | 1.12.4.5 | Produce Readiness Assessment Reports (Overall Report & Individual Participant Reports) |  | 15d | 2026-09-17 | 2026-10-07 | 2967, 2968 |  |  | 2026-09-17 | 2026-10-07 | 15d | 2026-02-17 | 2026-03-09 | 312d | 0d |  | PPC |  |  | Readiness Assessment | 596.33 | 5.0 | PPC | Readiness Assessments | Green | GREEN |  |  |  |
| 2970 | 1.12.4.6 | Readiness Assessment 8 - Ready to Accept New MPANs - Completed (incl. Readiness Assessment Report approval) | milestone | 0d | 2026-10-13 | 2026-10-13 | 2969FS+4d |  |  | 2026-10-13 | 2026-10-13 | 0d | 2026-03-13 | 2026-03-13 | 312d | 0d |  | CPT | PPC |  | Readiness Assessment | 622.71 | 5.0 | PPC | Readiness Assessments | Green | GREEN | T2-RA-0700 | PSG | T2 |
| 2971 | 1.12.5 | **Readiness Assessment 9 - Ready for New Settlement Timetable and CP5 Check** |  | 49d | 2027-04-12 | 2027-06-17 |  |  |  | 2027-04-12 | 2027-06-17 | 49d | 2026-09-29 | 2026-12-04 | 135d |  |  | N/A | N/A | D32 - RA10 Readiness Report | Readiness Assessment | M16 | 5.0 | N/A | Readiness Assessments |  |  |  |  |  |
| 2972 | 1.12.5.1 | Launch Readiness Assessment survey | milestone | 0d | 2027-04-12 | 2027-04-12 | 2899FS-60d |  |  | 2027-04-12 | 2027-04-12 | 0d | 2026-09-29 | 2026-09-29 | 135d | 0d |  | PPC |  |  | Readiness Assessment | 803.33 | 5.0 | PPC | Readiness Assessments | Green | GREEN |  |  |  |
| 2973 | 1.12.5.2 | PPs submit survey responses |  | 15d | 2027-04-12 | 2027-04-30 | 2972 |  |  | 2027-04-12 | 2027-04-30 | 15d | 2026-09-29 | 2026-10-19 | 135d | 0d |  | PP | PPC |  | Readiness Assessment | 803.33 | 5.0 | PPC | Readiness Assessments | Green | GREEN |  |  |  |
| 2974 | 1.12.5.3 | Analyse survey responses |  | 15d | 2027-05-03 | 2027-05-21 | 2973 |  |  | 2027-05-03 | 2027-05-21 | 15d | 2026-10-20 | 2026-11-09 | 135d | 0d |  | PPC | CPT |  | Readiness Assessment | 824.33 | 5.0 | PPC | Readiness Assessments | Green | GREEN |  |  |  |
| 2975 | 1.12.5.4 | Conduct deep-dive interviews (sample of PPs) |  | 15d | 2027-05-03 | 2027-05-21 | 2973 |  |  | 2027-05-03 | 2027-05-21 | 15d | 2026-10-20 | 2026-11-09 | 135d | 0d |  | PPC | CPT |  | Readiness Assessment | 824.33 | 5.0 | PPC | Readiness Assessments | Green | GREEN |  |  |  |
| 2976 | 1.12.5.5 | Produce Readiness Assessment Reports (Overall Report & Individual Participant Reports) |  | 15d | 2027-05-24 | 2027-06-11 | 2974, 2975 |  |  | 2027-05-24 | 2027-06-11 | 15d | 2026-11-10 | 2026-11-30 | 135d | 0d |  | PPC |  |  | Readiness Assessment | 845.33 | 5.0 | PPC | Readiness Assessments | Green | GREEN |  |  |  |
| 2977 | 1.12.5.6 | Readiness Assessment 9 - Readiness for New Settlement Timetable - Completed (incl. Readiness Assessment Report approval) | milestone | 0d | 2027-06-17 | 2027-06-17 | 2976FS+4d |  |  | 2027-06-17 | 2027-06-17 | 0d | 2026-12-04 | 2026-12-04 | 135d | 0d |  | CPT | PPC |  | Readiness Assessment | 869.71 | 5.0 | PPC | Readiness Assessments | Green | GREEN | T2-RA-0800 | PSG | T2 |
| 2978 | 1.12.6 | **Readiness Assessments - Tier 1 Milestones** |  | 517d | 2025-06-24 | 2027-06-17 |  |  |  | 2025-06-24 | 2027-06-17 | 799d | 2023-11-17 | 2026-12-04 | 135d |  |  | N/A | N/A |  | Readiness Assessment |  | 5.0 | N/A | Readiness Assessments |  |  |  |  |  |
| 2979 | 1.12.6.1 | Readiness Assessment 6 - Start of Migration - Completed (incl. Readiness Assessment Report approval) | milestone | 0d | 2025-06-24 | 2025-06-24 | 2956 |  |  | 2025-06-24 | 2025-06-24 | 0d | 2025-04-04 | 2025-04-04 | 652d |  | finish no earlier than 2025-04-04 | CPT | PPC |  | Readiness Assessment | 146.71 | 5.0 | PPC | Readiness Assessments | Green | GREEN | T2-RA-0500 | PSG | T2 |
| 2980 | 1.12.6.2 | Readiness Assessment 7 - Migration Checkpoint - Completed (incl. Readiness Assessment Report approval) | milestone | 0d | 2026-03-19 | 2026-03-19 | 2963 |  |  | 2026-03-19 | 2026-03-19 | 0d | 2025-10-09 | 2025-10-09 | 460d |  |  | CPT | PPC |  | Readiness Assessment | 414.71 | 5.0 | PPC | Readiness Assessments | Green | GREEN | T2-RA-0600 | PSG | T2 |
| 2981 | 1.12.6.3 | Readiness Assessment 8 - Ready to Accept New MPANs - Completed (incl. Readiness Assessment Report approval) | milestone | 0d | 2026-10-13 | 2026-10-13 | 2970 |  |  | 2026-10-13 | 2026-10-13 | 0d | 2026-03-13 | 2026-03-13 | 312d |  |  | CPT | PPC |  | Readiness Assessment | 622.71 | 5.0 | PPC | Readiness Assessments | Green | GREEN | T2-RA-0700 | PSG | T2 |
| 2982 | 1.12.6.4 | Readiness Assessment 9 - Readiness for New Settlement Timetable - Completed (incl. Readiness Assessment Report approval) | milestone | 0d | 2027-06-17 | 2027-06-17 | 2977 |  |  | 2027-06-17 | 2027-06-17 | 0d | 2026-12-04 | 2026-12-04 | 135d |  |  | CPT | PPC |  | Readiness Assessment | 869.71 | 5.0 | PPC | Readiness Assessments | Green | GREEN | T2-RA-0800 | PSG | T2 |
| 2983 | 1.13 | **CONTROL POINTS** |  | 1204d | 2022-11-10 A | 2027-06-23 |  | 51% | 591.8d | 2022-11-10 | 2027-06-23 | 1063d | 2022-11-10 | 2026-12-07 | 132d |  |  | N/A | N/A |  | Control Points |  |  | N/A | Control Points |  |  |  |  |  |
| 2984 | 1.13.1 | **Control Point 1 - Start of System Design, Build & Test** |  | 20d | 2022-11-10 A | 2022-12-07 A |  | 100% |  | 2022-11-10 | 2022-12-07 | 20d | 2022-11-10 | 2022-12-07 |  |  |  | N/A | N/A |  | Control Points |  | 5.0 | N/A | Control Points |  |  |  |  |  |
| 2985 | 1.13.1.1 | Control Point 1 Preparation (incl. Control Point Report development and review) |  | 15d | 2022-11-10 A | 2022-11-30 A | 2986SS-20d | 100% |  | 2022-11-10 | 2022-11-30 | 15d | 2022-11-10 | 2022-11-30 |  |  |  | CPT | PMO |  | Control Points |  | 5.0 | PMO | Control Points | Complete | COMPLETE |  |  |  |
| 2986 | 1.13.1.2 | Control Point 1 - Start of System Design, Build & Test (incl. Control Point Report approval) | milestone | 0d | 2022-12-07 A | 2022-12-07 A |  | 100% |  | 2022-12-07 | 2022-12-07 | 0d | 2022-12-07 | 2022-12-07 |  |  | must finish on 2022-12-07 | CPT | PMO | D24 - CP2 Approval | Control Points |  | 5.0 | PMO | Control Points | Complete | COMPLETE | T1-CP-1000 | PSG | T1 |
| 2987 | 1.13.2 | **Control Point 2 - Start of Integration & Test** |  | 20d | 2023-10-02 A | 2023-10-30 A |  | 100% |  | 2023-10-02 | 2023-10-30 | 20d | 2023-10-02 | 2023-10-30 |  |  |  | N/A | N/A |  | Control Points |  | 5.0 | N/A | Control Points |  |  |  |  |  |
| 2988 | 1.13.2.1 | Control Point 2 Preparation (incl. Control Point Report development and review) |  | 15d | 2023-10-02 A | 2023-10-20 A | 2989SS-20d | 100% |  | 2023-10-02 | 2023-10-20 | 15d | 2023-10-02 | 2023-10-20 |  |  |  | CPT | PMO |  | Control Points |  | 5.0 | PMO | Control Points | Complete | COMPLETE |  |  |  |
| 2989 | 1.13.2.2 | Control Point 2 - Start of Integration & Test (incl. Control Point Report approval) | milestone | 0d | 2023-10-30 A | 2023-10-30 A | 1483 | 100% |  | 2023-10-30 | 2023-10-30 | 0d | 2023-10-30 | 2023-10-30 |  |  |  | CPT | PMO | D24 - CP2 Approval | Control Points |  | 5.11 | PMO | Control Points | Complete | COMPLETE | T1-CP-2000 | PSG | T1 |

| ID | WBS | Task | Type | Duration | Start | Finish | Predecessors | Complete | Remaining | Baseline start | Baseline finish | Baseline duration | Baseline 1 start | Baseline 1 finish | Total slack | Free slack | Responsible | Involved | Future RAG | Text9 | Update Version | MHHS Resource Name | MHHS Programme Phase | Task Status | Sched Status | RAG | Milestone ID | Text29 | Tier |
| --- | --- | --- | --- | --- | --- | --- | --- | --- | --- | --- | --- | --- | --- | --- | --- | --- | --- | --- | --- | --- | --- | --- | --- | --- | --- | --- | --- | --- | --- |
| 2990 | 1.13.3 | **Control Point 3/4 - Readiness for Migration** |  | 20d | 2025-08-21 | 2025-09-18 |  |  |  | 2025-08-21 | 2025-09-18 | 20d | 2025-03-03 | 2025-03-28 | 591d |  | N/A | N/A | D26 - CP3 Approval | Control Points | 5.0 | N/A | Control Points |  |  |  |  |  |  |
| 2991 | 1.13.3.1 | Control Point 3/4 Preparation (incl. Control Point Report development and review) |  | 14d | 2025-08-21 | 2025-09-09 | 2992SS-20d |  |  | 2025-08-21 | 2025-09-09 | 14d | 2025-03-03 | 2025-03-21 | 597d |  | CPT | PMO |  | Control Points | 5.0 | PMO | Control Points | 204.33 | Green | GREEN |  |  |  |
| 2992 | 1.13.3.2 | Control Point 3/4 - Readiness for Migration (incl. Control Point Report approval) | milestone | 0d | 2025-09-18 | 2025-09-18 | 1756FS-5d |  |  | 2025-09-18 | 2025-09-18 | 0d | 2025-03-28 | 2025-03-28 | 591d | 0d | CPT | PMO |  | Control Points | 5.0 | PMO | Control Points | 232.33 | Green | GREEN | T1-CP-3000 | PSG | T1 |
| 2993 | 1.13.4 | **Control Point 5 - Cut Over to New Settlement Timetable** |  | 20d | 2027-05-26 | 2027-06-23 |  |  |  | 2027-05-26 | 2027-06-23 | 20d | 2026-11-10 | 2026-12-07 | 132d |  | N/A | N/A | D33 - Control Point 6 Approval | Control Points | 5.0 | N/A | Control Points | M16 |  |  |  |  |  |
| 2994 | 1.13.4.1 | Control Point 5 Preparation (incl. Control Point Report development and review) |  | 15d | 2027-05-26 | 2027-06-15 | 2995SS-20d |  |  | 2027-05-26 | 2027-06-15 | 15d | 2026-11-10 | 2026-11-30 | 137d |  | CPT | PP |  | Control Points | 5.0 | PMO | Control Points | 847.33 | Green | GREEN |  |  |  |
| 2995 | 1.13.4.2 | Control Point 5 - Cut Over to New Settlement Timetable (incl. Control Point Report approval) | milestone | 0d | 2027-06-23 | 2027-06-23 | 2899FS-8d |  |  | 2027-06-23 | 2027-06-23 | 0d | 2026-12-07 | 2026-12-07 | 132d | 0d | CPT | CPT | D33 - Control Point 6 Approval | Control Points | 5.0 | PMO | Control Points | 875.33 | Green | GREEN | T1-CP-4000 | PSG | T1 |
| 2996 | 1.13.5 | **Control Points - Tier 1 Milestones** |  | 1184d | 2022-12-07 A | 2027-06-23 |  |  | 1184d | 2022-12-07 | 2027-06-23 | 1043d | 2022-12-07 | 2026-12-07 | 132d |  | N/A | N/A |  | Control Points | 5.0 | N/A | Control Points |  |  |  |  |  |  |
| 2997 | 1.13.5.1 | Control Point 1 - Start of System Design, Build & Test (incl. Control Point Report approval) | milestone | 0d | 2022-12-07 A | 2022-12-07 A | 2986SS | 100% |  | 2022-12-07 | 2022-12-07 | 0d | 2022-12-07 | 2022-12-07 |  |  | CPT | PMO |  | Control Points | 5.0 | PMO | Control Points |  | Complete | COMPLETE | T1-CP-1000 | PSG | T1 |
| 2998 | 1.13.5.2 | Control Point 2 - Start of Integration & Test (incl. Control Point Report approval) | milestone | 0d | 2023-10-30 A | 2023-10-30 A | 2989SS | 100% |  | 2023-10-30 | 2023-10-30 | 0d | 2023-10-30 | 2023-10-30 |  |  | CPT | PMO | D24 - CP2 Approval | Control Points | 5.11 | PMO | Control Points |  | Complete | COMPLETE | T1-CP-2000 | PSG | T1 |
| 2999 | 1.13.5.3 | Control Point 3/4 - Readiness for Migration (incl. Control Point Report approval) | milestone | 0d | 2025-09-18 | 2025-09-18 | 2992SS |  |  | 2025-09-18 | 2025-09-18 | 0d | 2025-03-28 | 2025-03-28 | 591d |  | CPT | PMO |  | Control Points | 5.0 | PMO | Control Points | 232.33 | Green | GREEN | T1-CP-3000 | PSG | T1 |
| 3000 | 1.13.5.4 | Control Point 5 - Cut Over to New Settlement Timetable (incl. Control Point Report approval) | milestone | 0d | 2027-06-23 | 2027-06-23 | 2995SS |  |  | 2027-06-23 | 2027-06-23 | 0d | 2026-12-07 | 2026-12-07 | 132d |  | CPT | CPT | D33 - Control Point 6 Approval | Control Points | 5.0 | PMO | Control Points | 875.33 | Green | GREEN | T1-CP-4000 | PSG | T1 |
| 3001 | 1.14 | **MILESTONE RANGE CHECKPOINTS** |  | 1160d? | 2022-10-31 | 2027-04-12 |  |  |  | 2022-10-31 | 2027-04-12 | 436d | 2025-01-13 | 2026-09-15 | 184d |  | N/A | N/A |  | Milestone Range Checkpoints |  | N/A | Milestone Range Checkpoints |  |  |  |  |  |  |
| 3002 | 1.14.1 | **M10, M11, M12 and M13 milestone checkpoint** |  | 0d | 2025-07-31 | 2025-07-31 |  |  |  | 2025-07-31 | 2025-07-31 | 0d | 2025-01-13 | 2025-01-13 | 626d |  | N/A | N/A |  | Milestone Range Checkpoints | 5.0 | N/A | Milestone Range Checkpoints |  |  |  |  |  |  |
| 3003 | 1.14.1.1 | M10, M11, M12, and M13 milestone checkpoint - date approval | milestone | 0d | 2025-07-31 | 2025-07-31 | 2660FS-3mo, 2662FS-3mo, 2658FS-3mo, 1756FS-3mo |  |  | 2025-07-31 | 2025-07-31 | 0d | 2025-01-13 | 2025-01-13 | 626d |  | CPT | CPT |  | Milestone Range Checkpoints | 5.0 | PMO | Milestone Range Checkpoints | 183.33 | Green | GREEN | T2-MR-0100 | PSG | T2 |
| 3004 | 1.14.2 | **M14 milestone checkpoint** |  | 0d | 2026-08-06 | 2026-08-06 |  |  |  | 2026-08-06 | 2026-08-06 | 0d | 2025-12-23 | 2025-12-23 | 361d |  | N/A | N/A |  | Milestone Range Checkpoints | 5.0 | N/A | Milestone Range Checkpoints |  |  |  |  |  |  |
| 3005 | 1.14.2.1 | M14 milestone checkpoint - date approval | milestone | 0d | 2026-08-06 | 2026-08-06 | 2277FS-3mo |  |  | 2026-08-06 | 2026-08-06 | 0d | 2025-12-23 | 2025-12-23 | 361d |  | CPT | CPT |  | Milestone Range Checkpoints | 5.0 | PMO | Milestone Range Checkpoints | 554.33 | Green | GREEN | T2-MR-0200 | PSG | T2 |
| 3006 | 1.14.3 | **M15 milestone checkpoint** |  | 0d | 2027-02-15 | 2027-02-15 |  |  |  | 2027-02-15 | 2027-02-15 | 0d | 2026-07-14 | 2026-07-14 | 224d |  | N/A | N/A |  | Milestone Range Checkpoints | 5.0 | N/A | Milestone Range Checkpoints |  |  |  |  |  |  |
| 3007 | 1.14.3.1 | M15 milestone checkpoint - date approval | milestone | 0d | 2027-02-15 | 2027-02-15 | 2664FS-3mo |  |  | 2027-02-15 | 2027-02-15 | 0d | 2026-07-14 | 2026-07-14 | 224d |  | CPT | CPT |  | Milestone Range Checkpoints | 5.0 | PMO | Milestone Range Checkpoints | 747.33 | Green | GREEN | T2-MR-0300 | PSG | T2 |
| 3008 | 1.14.4 | **M16 milestone checkpoint** |  | 1160d? | 2022-10-31 | 2027-04-12 |  |  |  | 2022-10-31 | 2027-04-12 | 0d | 2026-09-15 | 2026-09-15 | 184d |  | N/A | N/A |  | Milestone Range Checkpoints | 5.0 | N/A | Milestone Range Checkpoints |  |  |  |  |  |  |
| 3009 | 1.14.4.1 | M16 milestone checkpoint - date approval | milestone | 0d | 2027-04-12 | 2027-04-12 | 2899FS-3mo |  |  | 2027-04-12 | 2027-04-12 | 0d | 2026-09-15 | 2026-09-15 | 184d |  | CPT | CPT |  | Milestone Range Checkpoints | 5.0 | PMO | Milestone Range Checkpoints | 803.33 | Green | GREEN | T2-MR-0400 | PSG | T2 |
